# Work_plan_3gpp_190315_Rel15_onwrds

Schedule from MS Project, 1999-01-01 to 2125-12-12, A marks actual dates.

| ID | WBS | Task | Duration | Start | Finish | Complete | Baseline start | Baseline finish | Baseline duration | Constraint | Resources | Work | Actual work | Acronym | PCG approved | WI rapporteur name | WI rapporteur e-mail | Release | TSG approved | Status Report | Acronym_3GU_Export |
| --- | --- | --- | --- | --- | --- | --- | --- | --- | --- | --- | --- | --- | --- | --- | --- | --- | --- | --- | --- | --- | --- |
| 4886 | 1814.54 | **LTE Advanced dual uplink inter-band Carrier Aggregation Class A2 in REL-13** | 379d? | 2014-12-15 A | 2015-12-15 A | 100% |  |  |  |  | R4 | 6288h | 6288h | LTE_CA_2UL_R13-A2 | 34 | Qualcomm | Qualcomm | Rel-13 | 66 |  |  |
| 4887 | 1814.54.1 | Core part:LTE Advanced dual uplink inter-band Carrier Aggregation Class A2 in REL-13 | 262d? | 2014-12-15 A | 2015-12-15 A | 100% |  |  |  | finish no earlier than 2015-12-15 | R4 | 2096h | 2096h | LTE_CA_2UL_R13-A2-Core | 34 | Qualcomm | Qualcomm | Rel-13 | 66 | RP-151131 |  |
| 4888 | 1814.54.2 | Perf. part:LTE Advanced dual uplink inter-band Carrier Aggregation Class A2 in REL-13 | 262d? | 2014-12-15 A | 2015-12-15 A | 100% |  |  |  | finish no earlier than 2015-12-15 | R4 | 2096h | 2096h | LTE_CA_2UL_R13-A2-Perf | 34 | Qualcomm | Qualcomm | Rel-13 | 66 | RP-151131 |  |
| 4889 | 1814.55 | **LTE Advanced dual uplink inter-band Carrier Aggregation Class A3 in REL-13** | 379d? | 2014-12-15 A | 2015-12-15 A | 100% |  |  |  |  | R4 | 6288h | 6288h | LTE_CA_2UL_R13-A3 | 34 | Ericsson | Ericsson | Rel-13 | 66 |  |  |
| 4890 | 1814.55.1 | Core part:LTE Advanced dual uplink inter-band Carrier Aggregation Class A3 in REL-13 | 262d? | 2014-12-15 A | 2015-12-15 A | 100% |  |  |  | finish no earlier than 2015-12-15 | R4 | 2096h | 2096h | LTE_CA_2UL_R13-A3-Core | 34 | Ericsson | Ericsson | Rel-13 | 66 | RP-151131 |  |
| 4891 | 1814.55.2 | Perf. part:LTE Advanced dual uplink inter-band Carrier Aggregation Class A3 in REL-13 | 262d? | 2014-12-15 A | 2015-12-15 A | 100% |  |  |  | finish no earlier than 2015-12-15 | R4 | 2096h | 2096h | LTE_CA_2UL_R13-A3-Perf | 34 | Ericsson | Ericsson | Rel-13 | 66 | RP-151131 |  |
| 4892 | 1814.56 | **LTE Advanced intra-band non-contiguous Carrier Aggregation in Band 41 for 4 DL** | 379d? | 2014-12-15 A | 2015-12-15 A | 100% |  |  |  |  | R4 | 6288h | 6288h | LTE_CA_NC_B41_4DL | 34 | Alcatel-Lucent | Alcatel-Lucent | Rel-13 | 66 |  |  |
| 4893 | 1814.56.1 | Core part:LTE Advanced intra-band non-contiguous Carrier Aggregation in Band 41 for 4 DL | 262d? | 2014-12-15 A | 2015-12-15 A | 100% |  |  |  | finish no earlier than 2015-12-15 | R4 | 2096h | 2096h | LTE_CA_NC_B41_4DL-Core | 34 | Alcatel-Lucent | Alcatel-Lucent | Rel-13 | 66 | RP-151131 |  |
| 4894 | 1814.56.2 | Perf. part:LTE Advanced intra-band non-contiguous Carrier Aggregation in Band 41 for 4 DL | 262d? | 2014-12-15 A | 2015-12-15 A | 100% | 2013-09-18 | 2015-12-24 | 593d? | finish no earlier than 2015-12-15 | R4 | 2096h | 2096h | LTE_CA_NC_B41_4DL-Perf | 31 | Alcatel-Lucent | Alcatel-Lucent | Rel-13 | 66 | RP-151131 | TEI13 |
| 4895 | 1814.57 | **LTE Advanced 3 Band Carrier Aggregation (3DL/1UL) of Band 1, Band 3 and Band 42** | 95.25d? | 2015-03-16 A | 2015-06-15 A | 100% |  |  |  |  | R4 | 1584h | 1584h | LTE_CA_B1_B3_B42 | 34 | NTT DOCOMO, INC. |  | Rel-13 | 67 |  |  |
| 4896 | 1814.57.1 | Core part:LTE Advanced 3 Band Carrier Aggregation (3DL/1UL) of Band 1, Band 3 and Band 42 | 66d? | 2015-03-16 A | 2015-06-15 A | 100% |  |  |  | finish no earlier than 2015-09-15 | R4 | 528h | 528h | LTE_CA_B1_B3_B42-Core | 34 | NTT DOCOMO, INC. |  | Rel-13 | 67 | RP-150536 |  |
| 4897 | 1814.57.2 | Perf. part:LTE Advanced 3 Band Carrier Aggregation (3DL/1UL) of Band 1, Band 3 and Band 42 | 66d? | 2015-03-16 A | 2015-06-15 A | 100% |  |  |  | finish no earlier than 2015-09-15 | R4 | 528h | 528h | LTE_CA_B1_B3_B42-Perf | 34 | NTT DOCOMO, INC. |  | Rel-13 | 67 | RP-150536 |  |
| 4898 | 1814.58 | **LTE Advanced 3 Band Carrier Aggregation (3DL/1UL) of Band 1, Band 19 and Band 42** | 95.25d? | 2015-03-16 A | 2015-06-15 A | 100% |  |  |  |  | R4 | 1584h | 1584h | LTE_CA_B1_B19_B42 | 34 | NTT DOCOMO, INC. |  | Rel-13 | 67 |  |  |
| 4899 | 1814.58.1 | Core part:LTE Advanced 3 Band Carrier Aggregation (3DL/1UL) of Band 1, Band 19 and Band 42 | 66d? | 2015-03-16 A | 2015-06-15 A | 100% |  |  |  | finish no earlier than 2015-09-15 | R4 | 528h | 528h | LTE_CA_B1_B19_B42-Core | 34 | NTT DOCOMO, INC. |  | Rel-13 | 67 | RP-150536 |  |
| 4900 | 1814.58.2 | Perf. part:LTE Advanced 3 Band Carrier Aggregation (3DL/1UL) of Band 1, Band 19 and Band 42 | 66d? | 2015-03-16 A | 2015-06-15 A | 100% |  |  |  | finish no earlier than 2015-09-15 | R4 | 528h | 528h | LTE_CA_B1_B19_B42-Perf | 34 | NTT DOCOMO, INC. |  | Rel-13 | 67 | RP-150536 |  |
| 4901 | 1814.59 | **LTE Advanced 3 Band Carrier Aggregation (3DL/1UL) of Band 1, Band 21 and Band 42** | 95.25d? | 2015-03-16 A | 2015-06-15 A | 100% |  |  |  |  | R4 | 1584h | 1584h | LTE_CA_B1_B21_B42 | 34 | NTT DOCOMO, INC. |  | Rel-13 | 67 |  |  |
| 4902 | 1814.59.1 | Core part:LTE Advanced 3 Band Carrier Aggregation (3DL/1UL) of Band 1, Band 21 and Band 42 | 66d? | 2015-03-16 A | 2015-06-15 A | 100% |  |  |  | finish no earlier than 2015-09-15 | R4 | 528h | 528h | LTE_CA_B1_B21_B42-Core | 34 | NTT DOCOMO, INC. |  | Rel-13 | 67 | RP-150536 |  |
| 4903 | 1814.59.2 | Perf. part:LTE Advanced 3 Band Carrier Aggregation (3DL/1UL) of Band 1, Band 21 and Band 42 | 66d? | 2015-03-16 A | 2015-06-15 A | 100% |  |  |  | finish no earlier than 2015-09-15 | R4 | 528h | 528h | LTE_CA_B1_B21_B42-Perf | 34 | NTT DOCOMO, INC. |  | Rel-13 | 67 | RP-150536 |  |
| 4904 | 1814.60 | **LTE Advanced 3 Band Carrier Aggregation (3DL/1UL) of Band 3, Band 19 and Band 42** | 95.25d? | 2015-03-16 A | 2015-06-15 A | 100% |  |  |  |  | R4 | 1584h | 1584h | LTE_CA_B3_B19_B42 | 34 | NTT DOCOMO, INC. |  | Rel-13 | 67 |  |  |
| 4905 | 1814.60.1 | Core part:LTE Advanced 3 Band Carrier Aggregation (3DL/1UL) of Band 3, Band 19 and Band 42 | 66d? | 2015-03-16 A | 2015-06-15 A | 100% |  |  |  | finish no earlier than 2015-09-15 | R4 | 528h | 528h | LTE_CA_B3_B19_B42-Core | 34 | NTT DOCOMO, INC. |  | Rel-13 | 67 | RP-150536 |  |
| 4906 | 1814.60.2 | Perf. part:LTE Advanced 3 Band Carrier Aggregation (3DL/1UL) of Band 3, Band 19 and Band 42 | 66d? | 2015-03-16 A | 2015-06-15 A | 100% |  |  |  | finish no earlier than 2015-09-15 | R4 | 528h | 528h | LTE_CA_B3_B19_B42-Perf | 34 | NTT DOCOMO, INC. |  | Rel-13 | 67 | RP-150536 |  |
| 4907 | 1814.61 | **LTE Advanced 3 Band Carrier Aggregation (3DL/1UL) of Band 19, Band 21 and Band 42** | 95.25d? | 2015-03-16 A | 2015-06-15 A | 100% |  |  |  |  | R4 | 1584h | 1584h | LTE_CA_B19_B21_B42 | 34 | NTT DOCOMO, INC. |  | Rel-13 | 67 |  |  |
| 4908 | 1814.61.1 | Core part:LTE Advanced 3 Band Carrier Aggregation (3DL/1UL) of Band 19, Band 21 and Band 42 | 66d? | 2015-03-16 A | 2015-06-15 A | 100% |  |  |  | finish no earlier than 2015-09-15 | R4 | 528h | 528h | LTE_CA_B19_B21_B42-Core | 34 | NTT DOCOMO, INC. |  | Rel-13 | 67 | RP-150536 |  |
| 4909 | 1814.61.2 | Perf. part:LTE Advanced 3 Band Carrier Aggregation (3DL/1UL) of Band 19, Band 21 and Band 42 | 66d? | 2015-03-16 A | 2015-06-15 A | 100% |  |  |  | finish no earlier than 2015-09-15 | R4 | 528h | 528h | LTE_CA_B19_B21_B42-Perf | 34 | NTT DOCOMO, INC. |  | Rel-13 | 67 | RP-150536 |  |

Notes:
- 4887: 1st Apr 15: Compl:0%->50% 1st Apr 15: WID: RP-141975->RP-150408 1st Apr 15: Stat Rep: ->RP-150013 03/07/15: Stat Rep: RP-150013->RP-150536 29/09/15: Stat Rep: RP-150536->RP-151131
- 4888: 1st Apr 15: Compl:0%->50% 1st Apr 15: WID: RP-141975->RP-150408 1st Apr 15: Stat Rep: ->RP-150013 03/07/15: Stat Rep: RP-150013->RP-150536 29/09/15: Stat Rep: RP-150536->RP-151131
- 4890: 1st Apr 15: Compl:0%->25% 1st Apr 15: WID: RP-142010->RP-150409 1st Apr 15: Stat Rep: ->RP-150013 03/07/15: Compl:25%->50% 03/07/15: Stat Rep: RP-150013->RP-150536 29/09/15: Compl:50%->75% 29/09/15: Stat Rep: RP-150536->RP-151131¦
- 4891: 1st Apr 15: Compl:0%->25% 1st Apr 15: WID: RP-142010->RP-150409 1st Apr 15: Stat Rep: ->RP-150013 03/07/15: Compl:25%->50% 03/07/15: Stat Rep: RP-150013->RP-150536 29/09/15: Compl:50%->75% 29/09/15: Stat Rep: RP-150536->RP-151131¦
- 4893: 1st Apr 15: Compl:0%->10% 1st Apr 15: CD:Tue 15/03/16->Tue 15/12/15 1st Apr 15: Stat Rep: ->RP-150013 03/07/15: Compl:10%->50% 03/07/15: Stat Rep: RP-150013->RP-150536 29/09/15: Compl:50%->80% 29/09/15: Stat Rep: RP-150536->RP-151131
- 4894: 1st Apr 15: Compl:0%->10% 1st Apr 15: CD:Tue 18/12/18->Tue 15/12/15 1st Apr 15: Stat Rep: -->RP-150013 03/07/15: Compl:10%->25% 03/07/15: Stat Rep: RP-150013->RP-150536 29/09/15: Compl:25%->50% 29/09/15: Stat Rep: RP-150536->RP-151131 ¦
- 4896: 03/07/15: Compl:0%->100% 03/07/15: CD:Tue 15/09/15->Mon 15/06/15 03/07/15: WID: RP-150121->RP-150641 03/07/15: Stat Rep: ->RP-150536
- 4897: 03/07/15: Compl:0%->100% 03/07/15: CD:Tue 15/09/15->Mon 15/06/15 03/07/15: WID: RP-150121->RP-150641 03/07/15: Stat Rep: ->RP-150536
- 4899: 03/07/15: Compl:0%->100% 03/07/15: CD:Tue 15/09/15->Mon 15/06/15 03/07/15: WID: RP-150122->RP-150642 03/07/15: Stat Rep: ->RP-150536
- 4900: 03/07/15: Compl:0%->100% 03/07/15: CD:Tue 15/09/15->Mon 15/06/15 03/07/15: WID: RP-150122->RP-150642 03/07/15: Stat Rep: ->RP-150536
- 4902: 03/07/15: Compl:0%->100% 03/07/15: CD:Tue 15/09/15->Mon 15/06/15 03/07/15: WID: RP-150123->RP-150643 03/07/15: Stat Rep: ->RP-150536
- 4903: 03/07/15: Compl:0%->100% 03/07/15: CD:Tue 15/09/15->Mon 15/06/15 03/07/15: WID: RP-150123->RP-150643 03/07/15: Stat Rep: ->RP-150536
- 4905: 03/07/15: Compl:0%->100% 03/07/15: CD:Tue 15/09/15->Mon 15/06/15 03/07/15: WID: RP-150124->RP-150644 03/07/15: Stat Rep: ->RP-150536
- 4906: 03/07/15: Compl:0%->100% 03/07/15: CD:Tue 15/09/15->Mon 15/06/15 03/07/15: WID: RP-150124->RP-150644 03/07/15: Stat Rep: ->RP-150536
- 4908: 03/07/15: Compl:0%->100% 03/07/15: CD:Tue 15/09/15->Mon 15/06/15 03/07/15: WID: RP-150125->RP-150645 03/07/15: Stat Rep: ->RP-150536
- 4909: 03/07/15: Compl:0%->100% 03/07/15: CD:Tue 15/09/15->Mon 15/06/15 03/07/15: WID: RP-150125->RP-150645 03/07/15: Stat Rep: ->RP-150536

| ID | WBS | Task | Duration | Start | Finish | Complete | Constraint | Resources | Work | Actual work | Acronym | PCG approved | WI rapporteur name | Release | TSG approved | Status Report |
| --- | --- | --- | --- | --- | --- | --- | --- | --- | --- | --- | --- | --- | --- | --- | --- | --- |
| 4910 | 1814.62 | **Additional bandwidth combination set for LTE Advanced 3 Band Carrier Aggregation (3DL/1UL) of Band 4, Band 4 and Band 7** | 284.75d? | 2015-03-16 A | 2015-12-15 A | 100% |  | R4 | 4728h | 4728h | LTE_CA_B4_B4_B7_BWset | 34 | Rogers Communications | Rel-13 | 67 |  |
| 4911 | 1814.62.1 | Core part: Additional bandwidth combination set for LTE Advanced 3 Band Carrier Aggregation (3DL/1UL) of Band 4, Band 4 and Band 7 | 197d? | 2015-03-16 A | 2015-12-15 A | 100% | finish no earlier than 2015-12-15 | R4 | 1576h | 1576h | LTE_CA_B4_B4_B7_BWset-Core | 34 | Rogers Communications | Rel-13 | 67 | RP-151131 |
| 4912 | 1814.62.2 | Perf. part: Additional bandwidth combination set for LTE Advanced 3 Band Carrier Aggregation (3DL/1UL) of Band 4, Band 4 and Band 7 | 197d? | 2015-03-16 A | 2015-12-15 A | 100% | finish no earlier than 2015-12-15 | R4 | 1576h | 1576h | LTE_CA_B4_B4_B7_BWset-Perf | 34 | Rogers Communications | Rel-13 | 67 | RP-151131 |
| 4913 | 1814.63 | **Additional bandwidth combination set for LTE Advanced 3 Band Carrier Aggregation (3DL/1UL) of Band 4, Band 7 and Band 12** | 284.75d? | 2015-03-16 A | 2015-12-15 A | 100% |  | R4 | 4728h | 4728h | LTE_CA_B4_B7_B12_BWset | 34 | Rogers Communications | Rel-13 | 67 |  |
| 4914 | 1814.63.1 | Core part: Additional bandwidth combination set for LTE Advanced 3 Band Carrier Aggregation (3DL/1UL) of Band 4, Band 7 and Band 12 | 197d? | 2015-03-16 A | 2015-12-15 A | 100% | finish no earlier than 2015-12-15 | R4 | 1576h | 1576h | LTE_CA_B4_B7_B12_BWset-Core | 34 | Rogers Communications | Rel-13 | 67 | RP-151131 |
| 4915 | 1814.63.2 | Perf. part: Additional bandwidth combination set for LTE Advanced 3 Band Carrier Aggregation (3DL/1UL) of Band 4, Band 7 and Band 12 | 197d? | 2015-03-16 A | 2015-12-15 A | 100% | finish no earlier than 2015-12-15 | R4 | 1576h | 1576h | LTE_CA_B4_B7_B12_BWset-Perf | 34 | Rogers Communications | Rel-13 | 67 | RP-151131 |
| 4916 | 1814.64 | **LTE Advanced 3 Band Carrier Aggregation (3DL/1UL) of Band 2, Band 7 and Band 12** | 379d? | 2015-03-16 A | 2016-03-15 A | 100% |  | R4 | 6288h | 6288h | LTE_CA_B2_B7_B12 | 34 | Rogers Communications | Rel-13 | 67 |  |
| 4917 | 1814.64.1 | Core part:LTE Advanced 3 Band Carrier Aggregation (3DL/1UL) of Band 2, Band 7 and Band 12 | 262d? | 2015-03-16 A | 2016-03-15 A | 100% | finish no earlier than 2016-03-15 | R4 | 2096h | 2096h | LTE_CA_B2_B7_B12-Core | 34 | Rogers Communications | Rel-13 | 67 | RP-151131 |
| 4918 | 1814.64.2 | Perf. part:LTE Advanced 3 Band Carrier Aggregation (3DL/1UL) of Band 2, Band 7 and Band 12 | 262d? | 2015-03-16 A | 2016-03-15 A | 100% | finish no earlier than 2016-03-15 | R4 | 2096h | 2096h | LTE_CA_B2_B7_B12-Perf | 34 | Rogers Communications | Rel-13 | 67 | RP-151131 |
| 4919 | 1814.65 | **LTE Advanced 3 Band Carrier Aggregation (3DL/1UL) of Band 2, Band 4 and Band 7** | 379d? | 2015-03-16 A | 2016-03-15 A | 100% |  | R4 | 6288h | 6288h | LTE_CA_B2_B4_B7 | 34 | Rogers Communications | Rel-13 | 67 |  |
| 4920 | 1814.65.1 | Core part:LTE Advanced 3 Band Carrier Aggregation (3DL/1UL) of Band 2, Band 4 and Band 7 | 262d? | 2015-03-16 A | 2016-03-15 A | 100% | finish no earlier than 2016-03-15 | R4 | 2096h | 2096h | LTE_CA_B2_B4_B7-Core | 34 | Rogers Communications | Rel-13 | 67 | RP-151131 |
| 4921 | 1814.65.2 | Perf. part:LTE Advanced 3 Band Carrier Aggregation (3DL/1UL) of Band 2, Band 4 and Band 7 | 262d? | 2015-03-16 A | 2016-03-15 A | 100% | finish no earlier than 2016-03-15 | R4 | 2096h | 2096h | LTE_CA_B2_B4_B7-Perf | 34 | Rogers Communications | Rel-13 | 67 | RP-151131 |
| 4922 | 1814.66 | **LTE Advanced 3 Band Carrier Aggregation (3DL/1UL) of Band 7, Band 20 and Band 38** | 284.75d? | 2015-03-16 A | 2015-12-15 A | 100% |  | R4 | 4728h | 4728h | LTE_CA_B7_B20_B38 | 34 | Nokia Networks | Rel-13 | 67 |  |
| 4923 | 1814.66.1 | Core part:LTE Advanced 3 Band Carrier Aggregation (3DL/1UL) of Band 7, Band 20 and Band 38 | 197d? | 2015-03-16 A | 2015-12-15 A | 100% | finish no earlier than 2015-12-15 | R4 | 1576h | 1576h | LTE_CA_B7_B20_B38-Core | 34 | Nokia Networks | Rel-13 | 67 | RP-151131 |
| 4924 | 1814.66.2 | Perf. part:LTE Advanced 3 Band Carrier Aggregation (3DL/1UL) of Band 7, Band 20 and Band 38 | 197d? | 2015-03-16 A | 2015-12-15 A | 100% | finish no earlier than 2015-12-15 | R4 | 1576h | 1576h | LTE_CA_B7_B20_B38-Perf | 34 | Nokia Networks | Rel-13 | 67 | RP-151131 |
| 4925 | 1814.67 | **LTE Advanced 4 Band Carrier Aggregation (4DL/1UL) of Band 2, Band 4, Band 4 and Band 12** | 284.75d? | 2015-03-16 A | 2015-12-15 A | 100% |  | R4 | 4728h | 4728h | LTE_CA_B2_B4_B4_B12 | 34 | Nokia Networks | Rel-13 | 67 |  |
| 4926 | 1814.67.1 | Core part:LTE Advanced 4 Band Carrier Aggregation (4DL/1UL) of Band 2, Band 4, Band 4 and Band 12 | 197d? | 2015-03-16 A | 2015-12-15 A | 100% | finish no earlier than 2015-12-15 | R4 | 1576h | 1576h | LTE_CA_B2_B4_B4_B12-Core | 34 | Nokia Networks | Rel-13 | 67 | RP-151131 |
| 4927 | 1814.67.2 | Perf. part:LTE Advanced 4 Band Carrier Aggregation (4DL/1UL) of Band 2, Band 4, Band 4 and Band 12 | 197d? | 2015-03-16 A | 2015-12-15 A | 100% | finish no earlier than 2015-12-15 | R4 | 1576h | 1576h | LTE_CA_B2_B4_B4_B12-Perf | 34 | Nokia Networks | Rel-13 | 67 | RP-151131 |
| 4928 | 1814.68 | **LTE Advanced 4 Band Carrier Aggregation (4DL/1UL) of Band 2, Band 2, Band 4 and Band 12** | 284.75d? | 2015-03-16 A | 2015-12-15 A | 100% |  | R4 | 4728h | 4728h | LTE_CA_B2_B2_B4_B12 | 34 | Nokia Networks | Rel-13 | 67 |  |
| 4929 | 1814.68.1 | Core part:LTE Advanced 4 Band Carrier Aggregation (4DL/1UL) of Band 2, Band 2, Band 4 and Band 12 | 197d? | 2015-03-16 A | 2015-12-15 A | 100% | finish no earlier than 2015-12-15 | R4 | 1576h | 1576h | LTE_CA_B2_B2_B4_B12-Core | 34 | Nokia Networks | Rel-13 | 67 | RP-151131 |
| 4930 | 1814.68.2 | Perf. part:LTE Advanced 4 Band Carrier Aggregation (4DL/1UL) of Band 2, Band 2, Band 4 and Band 12 | 197d? | 2015-03-16 A | 2015-12-15 A | 100% | finish no earlier than 2015-12-15 | R4 | 1576h | 1576h | LTE_CA_B2_B2_B4_B12-Perf | 34 | Nokia Networks | Rel-13 | 67 | RP-151131 |
| 4931 | 1814.69 | **LTE Advanced 4 Band Carrier Aggregation (4DL/1UL) of Band 2, Band 2, Band 4 and Band 4** | 284.75d? | 2015-03-16 A | 2015-12-15 A | 100% |  | R4 | 4728h | 4728h | LTE_CA_B2_B2_B4_B4 | 34 | Nokia Networks | Rel-13 | 67 |  |
| 4932 | 1814.69.1 | Core part:LTE Advanced 4 Band Carrier Aggregation (4DL/1UL) of Band 2, Band 2, Band 4 and Band 4 | 197d? | 2015-03-16 A | 2015-12-15 A | 100% | finish no earlier than 2015-12-15 | R4 | 1576h | 1576h | LTE_CA_B2_B2_B4_B4-Core | 34 | Nokia Networks | Rel-13 | 67 | RP-151131 |
| 4933 | 1814.69.2 | Perf. part:LTE Advanced 4 Band Carrier Aggregation (4DL/1UL) of Band 2, Band 2, Band 4 and Band 4 | 197d? | 2015-03-16 A | 2015-12-15 A | 100% | finish no earlier than 2015-12-15 | R4 | 1576h | 1576h | LTE_CA_B2_B2_B4_B4-Perf | 34 | Nokia Networks | Rel-13 | 67 | RP-151131 |

Notes:
- 4911: 03/07/15: CD:Tue 15/09/15->Tue 15/12/15 03/07/15: Stat Rep: ->RP-150536 29/09/15: Stat Rep: RP-150536->RP-151131
- 4912: 03/07/15: CD:Tue 15/09/15->Tue 15/12/15 03/07/15: Stat Rep: ->RP-150536 29/09/15: Stat Rep: RP-150536->RP-151131
- 4914: 03/07/15: CD:Tue 15/09/15->Tue 15/12/15 03/07/15: Stat Rep: ->RP-150536 29/09/15: Stat Rep: RP-150536->RP-151131
- 4915: 03/07/15: CD:Tue 15/09/15->Tue 15/12/15 03/07/15: Stat Rep: ->RP-150536 29/09/15: Stat Rep: RP-150536->RP-151131
- 4917: 03/07/15: Stat Rep: ->RP-150536 29/09/15: Stat Rep: RP-150536->RP-151131 ¦1/122/3/16: Compl:0%->100%
- 4918: 03/07/15: Stat Rep: ->RP-150536 29/09/15: Stat Rep: RP-150536->RP-151131 122/3/16: Compl:0%->100%
- 4920: 03/07/15: Stat Rep: ->RP-150536 29/09/15: Stat Rep: RP-150536->RP-1511311/1/16:22/3/16: Compl:0%->100%
- 4921: 03/07/15: Stat Rep: ->RP-150536 29/09/15: Stat Rep: RP-150536->RP-151131 1/1/1¦22/3/16: Compl:0%->100%
- 4923: 03/07/15: Compl:0%->30% 03/07/15: Stat Rep: ->RP-150536 29/09/15: Compl:30%->60% 29/09/15: Stat Rep: RP-150536->RP-151131
- 4924: 03/07/15: Compl:0%->30% 03/07/15: Stat Rep: ->RP-150536 29/09/15: Compl:30%->60% 29/09/15: Stat Rep: RP-150536->RP-151131
- 4926: 03/07/15: Compl:0%->95% 03/07/15: WID: RP-150073->RP-150660 03/07/15: Stat Rep: ->RP-150536 29/09/15: Stat Rep: RP-150536->RP-151131
- 4927: 03/07/15: Compl:0%->95% 03/07/15: WID: RP-150073->RP-150660 03/07/15: Stat Rep: ->RP-150536 29/09/15: Stat Rep: RP-150536->RP-151131
- 4929: 03/07/15: Compl:0%->95% 03/07/15: WID: RP-150074->RP-150659 03/07/15: Stat Rep: ->RP-150536 29/09/15: Stat Rep: RP-150536->RP-151131
- 4930: 03/07/15: Compl:0%->95% 03/07/15: WID: RP-150074->RP-150659 03/07/15: Stat Rep: ->RP-150536 29/09/15: Stat Rep: RP-150536->RP-151131
- 4932: 03/07/15: Compl:0%->95% 03/07/15: WID: RP-150075->RP-150658 03/07/15: Stat Rep: ->RP-150536 29/09/15: Stat Rep: RP-150536->RP-151131
- 4933: 03/07/15: Compl:0%->95% 03/07/15: WID: RP-150075->RP-150658 03/07/15: Stat Rep: ->RP-150536 29/09/15: Stat Rep: RP-150536->RP-151131

| ID | WBS | Task | Duration | Start | Finish | Complete | Constraint | Resources | Work | Actual work | Acronym | PCG approved | WI rapporteur name | Release | TSG approved | Status Report |
| --- | --- | --- | --- | --- | --- | --- | --- | --- | --- | --- | --- | --- | --- | --- | --- | --- |
| 4934 | 1814.70 | **LTE Advanced 4 Band Carrier Aggregation (4DL/1UL) of Band 1, Band 3, Band 5 and Band 40** | 284.75d? | 2015-03-16 A | 2015-12-15 A | 100% |  | R4 | 4728h | 4728h | LTE_CA_B1_B3_B5_B40 | 34 | SK Telecom | Rel-13 | 67 |  |
| 4935 | 1814.70.1 | Core part:LTE Advanced 4 Band Carrier Aggregation (4DL/1UL) of Band 1, Band 3, Band 5 and Band 40 | 197d? | 2015-03-16 A | 2015-12-15 A | 100% | finish no earlier than 2015-12-15 | R4 | 1576h | 1576h | LTE_CA_B1_B3_B5_B40-Core | 34 | SK Telecom | Rel-13 | 67 | RP-151131 |
| 4936 | 1814.70.2 | Perf. part:LTE Advanced 4 Band Carrier Aggregation (4DL/1UL) of Band 1, Band 3, Band 5 and Band 40 | 197d? | 2015-03-16 A | 2015-12-15 A | 100% | finish no earlier than 2015-12-15 | R4 | 1576h | 1576h | LTE_CA_B1_B3_B5_B40-Perf | 34 | SK Telecom | Rel-13 | 67 | RP-151131 |
| 4937 | 1814.71 | **LTE Advanced 4 Band Carrier Aggregation (4DL/1UL) of Band 1, Band 3, Band 7 and Band 8** | 284.75d? | 2015-03-16 A | 2015-12-15 A | 100% |  | R4 | 4728h | 4728h | LTE_CA_B1_B3_B7_B8 | 34 | Nokia Networks | Rel-13 | 67 |  |
| 4938 | 1814.71.1 | Core part:LTE Advanced 4 Band Carrier Aggregation (4DL/1UL) of Band 1, Band 3, Band 7 and Band 8 | 197d? | 2015-03-16 A | 2015-12-15 A | 100% | finish no earlier than 2015-12-15 | R4 | 1576h | 1576h | LTE_CA_B1_B3_B7_B8-Core | 34 | Nokia Networks | Rel-13 | 67 | RP-151131 |
| 4939 | 1814.71.2 | Perf. part:LTE Advanced 4 Band Carrier Aggregation (4DL/1UL) of Band 1, Band 3, Band 7 and Band 8 | 197d? | 2015-03-16 A | 2015-12-15 A | 100% | finish no earlier than 2015-12-15 | R4 | 1576h | 1576h | LTE_CA_B1_B3_B7_B8-Perf | 34 | Nokia Networks | Rel-13 | 67 | RP-151131 |
| 4940 | 1814.72 | **LTE Advanced 4 Band Carrier Aggregation (4DL/1UL) of Band 2, Band 4, Band 5 and Band 29** | 284.75d? | 2015-03-16 A | 2015-12-15 A | 100% |  | R4 | 4728h | 4728h | LTE_CA_B2_B4_B5_B29 | 34 | Huawei | Rel-13 | 67 |  |
| 4941 | 1814.72.1 | Core part:LTE Advanced 4 Band Carrier Aggregation (4DL/1UL) of Band 2, Band 4, Band 5 and Band 29 | 197d? | 2015-03-16 A | 2015-12-15 A | 100% | finish no earlier than 2015-12-15 | R4 | 1576h | 1576h | LTE_CA_B2_B4_B5_B29-Core | 34 | Huawei | Rel-13 | 67 | RP-151131 |
| 4942 | 1814.72.2 | Perf. part:LTE Advanced 4 Band Carrier Aggregation (4DL/1UL) of Band 2, Band 4, Band 5 and Band 29 | 197d? | 2015-03-16 A | 2015-12-15 A | 100% | finish no earlier than 2015-12-15 | R4 | 1576h | 1576h | LTE_CA_B2_B4_B5_B29-Perf | 34 | Huawei | Rel-13 | 67 | RP-151131 |
| 4943 | 1814.73 | **LTE Advanced dual uplink inter-band Carrier Aggregation FDD-TDD** | 284.75d? | 2015-03-16 A | 2015-12-15 A | 100% |  | R4 | 4728h | 4728h | LTE_CA_2UL_FDD_TDD | 34 | KDDI | Rel-13 | 67 |  |
| 4944 | 1814.73.1 | Core part:LTE Advanced dual uplink inter-band Carrier Aggregation FDD-TDD | 197d? | 2015-03-16 A | 2015-12-15 A | 100% | finish no earlier than 2015-12-15 | R4 | 1576h | 1576h | LTE_CA_2UL_FDD_TDD-Core | 34 | KDDI | Rel-13 | 67 | RP-151131 |
| 4945 | 1814.73.2 | Perf. part:LTE Advanced dual uplink inter-band Carrier Aggregation FDD-TDD | 197d? | 2015-03-16 A | 2015-12-15 A | 100% | finish no earlier than 2015-12-15 | R4 | 1576h | 1576h | LTE_CA_2UL_FDD_TDD-Perf | 34 | KDDI | Rel-13 | 67 | RP-151131 |
| 4946 | 1814.74 | **LTE Advanced dual uplink inter-band Carrier Aggregation Class A4** | 284.75d? | 2015-03-16 A | 2015-12-15 A | 100% |  | R4 | 4728h | 4728h | LTE_CA_2UL_R13-A4 | 34 | Nokia Networks | Rel-13 | 67 |  |
| 4947 | 1814.74.1 | Core part:LTE Advanced dual uplink inter-band Carrier Aggregation Class A4 in REL-13 | 197d? | 2015-03-16 A | 2015-12-15 A | 100% | finish no earlier than 2015-12-15 | R4 | 1576h | 1576h | LTE_CA_2UL_R13-A4-Core | 34 | Nokia Networks | Rel-13 | 67 | RP-151131 |
| 4948 | 1814.74.2 | Perf. Part:LTE Advanced dual uplink inter-band Carrier Aggregation Class A4 in REL-13 | 197d? | 2015-03-16 A | 2015-12-15 A | 100% | finish no earlier than 2015-12-15 | R4 | 1576h | 1576h | LTE_CA_2UL_R13-A4-Perf | 34 | Nokia Networks | Rel-13 | 67 | RP-151131 |
| 4949 | 1814.75 | **LTE Advanced 3DL/2UL inter-band Carrier Aggregation** | 284.75d? | 2015-03-16 A | 2015-12-15 A | 100% |  | R4 | 4728h | 4728h | LTE_CA_3DL_2UL | 34 | Nokia Corporation | Rel-13 | 67 |  |
| 4950 | 1814.75.1 | Core part:LTE Advanced 3DL/2UL inter-band Carrier Aggregation | 197d? | 2015-03-16 A | 2015-12-15 A | 100% | finish no earlier than 2015-12-15 | R4 | 1576h | 1576h | LTE_CA_3DL_2UL-Core | 34 | Nokia Corporation | Rel-13 | 67 | RP-151131 |
| 4951 | 1814.75.2 | Perf. part:LTE Advanced 3DL/2UL inter-band Carrier Aggregation | 197d? | 2015-03-16 A | 2015-12-15 A | 100% | finish no earlier than 2015-12-15 | R4 | 1576h | 1576h | LTE_CA_3DL_2UL-Perf | 34 | Nokia Corporation | Rel-13 | 67 | RP-151131 |
| 4952 | 1814.76 | **LTE Advanced intra-band non-contiguous Carrier Aggregation in Band 42 for 3DL** | 95.25d? | 2015-03-16 A | 2015-06-15 A | 100% |  | R4 | 1584h | 1584h | LTE_CA_NC_B42_3DL | 34 | Huawei | Rel-13 | 67 |  |
| 4953 | 1814.76.1 | Core part:LTE Advanced intra-band non-contiguous Carrier Aggregation in Band 42 for 3DL | 66d? | 2015-03-16 A | 2015-06-15 A | 100% | finish no earlier than 2015-09-15 | R4 | 528h | 528h | LTE_CA_NC_B42_3DL-Core | 34 | Huawei | Rel-13 | 67 | RP-150536 |
| 4954 | 1814.76.2 | Perf. part:LTE Advanced intra-band non-contiguous Carrier Aggregation in Band 42 for 3DL | 66d? | 2015-03-16 A | 2015-06-15 A | 100% | finish no earlier than 2015-09-15 | R4 | 528h | 528h | LTE_CA_NC_B42_3DL-Perf | 34 | Huawei | Rel-13 | 67 | RP-150536 |
| 4955 | 1814.77 | **LTE Advanced intra-band contiguous Carrier Aggregation in Band 8** | 284.75d? | 2015-03-16 A | 2015-12-15 A | 100% |  | R4 | 4728h | 4728h | LTE_CA_C_B8 | 34 | CMCC | Rel-13 | 67 |  |
| 4956 | 1814.77.1 | Core part: LTE Advanced intra-band contiguous Carrier Aggregation in Band 8 | 197d? | 2015-03-16 A | 2015-12-15 A | 100% | finish no earlier than 2015-12-15 | R4 | 1576h | 1576h | LTE_CA_C_B8-Core | 34 | CMCC | Rel-13 | 67 | RP-151131 |
| 4957 | 1814.77.2 | Perf. part: LTE Advanced intra-band contiguous Carrier Aggregation in Band 8 | 197d? | 2015-03-16 A | 2015-12-15 A | 100% | finish no earlier than 2015-12-15 | R4 | 1576h | 1576h | LTE_CA_C_B8-Perf | 34 | CMCC | Rel-13 | 67 | RP-151131 |

Notes:
- 4935: 03/07/15: Compl:0%->30% 03/07/15: WID: RP-150434->RP-150617 03/07/15: Stat Rep: ->RP-150536 29/09/15: Compl:30%->60% 29/09/15: CD:Tue 15/09/15->Tue 15/12/15 29/09/15: WID: RP-150617->RP-151216 29/09/15: Stat Rep: RP-150536->RP-151131
- 4936: 03/07/15: WID: RP-150434->RP-150617 03/07/15: Stat Rep: ->RP-150536 29/09/15: CD:Tue 15/09/15->Tue 15/12/15 29/09/15: WID: RP-150617->RP-151216 29/09/15: Stat Rep: RP-150536->RP-151131
- 4938: 03/07/15: Compl:0%->40% 03/07/15: Stat Rep: ->RP-150536 29/09/15: Compl:40%->45% 29/09/15: Stat Rep: RP-150536->RP-151131
- 4939: 03/07/15: Stat Rep: ->RP-150536 29/09/15: Stat Rep: RP-150536->RP-151131
- 4941: 03/07/15: Compl:0%->50% 03/07/15: Stat Rep: ->RP-150536 29/09/15: Compl:50%->95% 29/09/15: Stat Rep: RP-150536->RP-151131
- 4942: 03/07/15: Stat Rep: ->RP-150536 29/09/15: Compl:0%->95% 29/09/15: Stat Rep: RP-150536->RP-151131
- 4944: 03/07/15: Compl:0%->70% 03/07/15: Stat Rep: ->RP-150536 29/09/15: Compl:70%->90% 29/09/15: Stat Rep: RP-150536->RP-151131
- 4945: 03/07/15: CD:Tue 15/09/15->Tue 15/12/15 03/07/15: Stat Rep: ->RP-150536 29/09/15: Compl:0%->90% 29/09/15: Stat Rep: RP-150536->RP-151131
- 4947: 03/07/15: Compl:0%->25% 03/07/15: WID: RP-150410->RP-150616 03/07/15: Stat Rep: ->RP-150536 29/09/15: Compl:25%->75% 29/09/15: Stat Rep: RP-150536->RP-151131
- 4948: 03/07/15: Compl:0%->25% 03/07/15: WID: RP-150410->RP-150616 03/07/15: Stat Rep: ->RP-150536 29/09/15: Compl:25%->75% 29/09/15: Stat Rep: RP-150536->RP-151131
- 4950: 03/07/15: Compl:0%->25% 03/07/15: CD:Tue 15/03/16->Tue 15/12/15 03/07/15: Stat Rep: ->RP-150536 29/09/15: Compl:25%->75% 29/09/15: WID: RP-150479->RP-151230 29/09/15: Stat Rep: RP-150536->RP-151131
- 4951: 03/07/15: Compl:0%->25% 03/07/15: Stat Rep: ->RP-150536 29/09/15: Compl:25%->75% 29/09/15: CD:Tue 15/03/16->Tue 15/12/15 29/09/15: WID: RP-150479->RP-151230 29/09/15: Stat Rep: RP-150536->RP-151131
- 4953: 03/07/15: Compl:0%->100% 03/07/15: CD:Tue 15/09/15->Mon 15/06/15 03/07/15: Stat Rep: ->RP-150536
- 4954: 03/07/15: Compl:0%->100% 03/07/15: CD:Tue 15/09/15->Mon 15/06/15 03/07/15: Stat Rep: ->RP-150536
- 4956: 03/07/15: Compl:0%->60% 03/07/15: WID: RP-150437->RP-150809 03/07/15: Stat Rep: ->RP-150536 29/09/15: Compl:60%->90% 29/09/15: CD:Tue 15/09/15->Tue 15/12/15 29/09/15: WID: RP-150809->RP-151177 29/09/15: Stat Rep: RP-150536->RP-151131
- 4957: 03/07/15: WID: RP-150437->RP-150809 03/07/15: Stat Rep: ->RP-150536 29/09/15: Compl:0%->50% 29/09/15: CD:Tue 15/09/15->Tue 15/12/15 29/09/15: WID: RP-150809->RP-151177 29/09/15: Stat Rep: RP-150536->RP-151131¦

| ID | WBS | Task | Duration | Start | Finish | Complete | Remaining | Total slack | Constraint | Resources | Work | Actual work | Acronym | PCG approved | WI rapporteur name | Release | TSG approved | Status Report |
| --- | --- | --- | --- | --- | --- | --- | --- | --- | --- | --- | --- | --- | --- | --- | --- | --- | --- | --- |
| 4958 | 1814.78 | **LTE Advanced intra-band contiguous Carrier Aggregation in Band 42 for 4DL** | 284.75d? | 2015-03-16 A | 2015-12-15 A | 100% |  |  |  | R4 | 4728h | 4728h | LTE_CA_C_B42_4DL | 34 | CATT | Rel-13 | 67 |  |
| 4959 | 1814.78.1 | Core part: LTE Advanced intra-band contiguous Carrier Aggregation in Band 42 for 4DL | 197d? | 2015-03-16 A | 2015-12-15 A | 100% |  |  | finish no earlier than 2015-12-15 | R4 | 1576h | 1576h | LTE_CA_C_B42_4DL-Core | 34 | CATT | Rel-13 | 67 | RP-151131 |
| 4960 | 1814.78.2 | Perf. part: LTE Advanced intra-band contiguous Carrier Aggregation in Band 42 for 4DL | 197d? | 2015-03-16 A | 2015-12-15 A | 100% |  |  | finish no earlier than 2015-12-15 | R4 | 1576h | 1576h | LTE_CA_C_B42_4DL-Perf | 34 | CATT | Rel-13 | 67 | RP-151131 |
| 4961 | 1814.79 | **LTE Advanced 3 Band Carrier Aggregation (3DL/1UL) of Band 1, Band 8 and Band 11** | 96.25d? | 2015-06-15 A | 2015-09-15 A | 100% |  |  |  | R4 | 1608h | 1608h | LTE_CA_B1_B8_B11 | 35 | Softbank Mobile | Rel-13 | 68 |  |
| 4962 | 1814.79.1 | Core part:LTE Advanced 3 Band Carrier Aggregation (3DL/1UL) of Band 1, Band 8 and Band 11 | 67d? | 2015-06-15 A | 2015-09-15 A | 100% |  |  | finish no earlier than 2015-09-15 | R4 | 536h | 536h | LTE_CA_B1_B8_B11-Core | 35 | Softbank Mobile | Rel-13 | 68 | RP-151131 |
| 4963 | 1814.79.2 | Perf. part:LTE Advanced 3 Band Carrier Aggregation (3DL/1UL) of Band 1, Band 8 and Band 11 | 67d? | 2015-06-15 A | 2015-09-15 A | 100% |  |  | finish no earlier than 2015-09-15 | R4 | 536h | 536h | LTE_CA_B1_B8_B11-Perf | 35 | Softbank Mobile | Rel-13 | 68 | RP-151131 |
| 4964 | 1814.80 | **LTE Advanced 3 Band Carrier Aggregation (3DL/1UL) of Band 3, Band 20 and Band 32** | 197d? | 2015-06-15 A | 2015-12-22 | 90% | 19.69d? | 41601.2d |  | R4 | 4728h | 3364.8h | LTE_CA_B3_B20_B32 | 35 | Ericsson | Rel-13 | 68 |  |
| 4965 | 1814.80.1 | Core part:LTE Advanced 3 Band Carrier Aggregation (3DL/1UL) of Band 3, Band 20 and Band 32 | 197d? | 2015-06-15 A | 2015-12-22 | 90% | 19.7d? | 41601.2d | finish no earlier than 2016-03-15 | R4 | 1576h | 1418.4h | LTE_CA_B3_B20_B32-Core | 35 | Ericsson | Rel-14 | 68 | RP-151131 |
| 4966 | 1814.80.2 | Perf. part:LTE Advanced 3 Band Carrier Aggregation (3DL/1UL) of Band 3, Band 20 and Band 32 | 197d? | 2015-06-15 A | 2015-12-22 | 90% | 19.7d? | 41601.2d | finish no earlier than 2016-03-15 | R4 | 1576h | 1418.4h | LTE_CA_B3_B20_B32-Perf | 35 | Ericsson | Rel-14 | 68 | RP-151131 |
| 4967 | 1814.81 | **LTE Advanced 3 Band Carrier Aggregation (3DL/1UL) for Band 7, Band 42 and Band 42** | 190.5d? | 2015-06-15 A | 2015-12-15 A | 100% |  |  |  | R4 | 3168h | 3168h | LTE_CA_B7_B42_B42 | 35 | Huawei | Rel-13 | 68 |  |
| 4968 | 1814.81.1 | Core part:LTE Advanced 3 Band Carrier Aggregation (3DL/1UL) for Band 7, Band 42 and Band 42 | 132d? | 2015-06-15 A | 2015-12-15 A | 100% |  |  | finish no earlier than 2015-12-15 | R4 | 1056h | 1056h | LTE_CA_B7_B42_B42-Core | 35 | Huawei | Rel-13 | 68 | RP-151131 |
| 4969 | 1814.81.2 | Perf. part:LTE Advanced 3 Band Carrier Aggregation (3DL/1UL) for Band 7, Band 42 and Band 42 | 132d? | 2015-06-15 A | 2015-12-15 A | 100% |  |  | finish no earlier than 2015-12-15 | R4 | 1056h | 1056h | LTE_CA_B7_B42_B42-Perf | 35 | Huawei | Rel-13 | 68 | RP-151131 |
| 4970 | 1814.82 | **LTE Advanced 3 Band Carrier Aggregation (3DL/1UL) for Band 20, Band 42 and Band 42** | 96.25d? | 2015-06-15 A | 2015-09-15 A | 100% |  |  |  | R4 | 1608h | 1608h | LTE_CA_B20_B42_B42 | 35 | Huawei | Rel-13 | 68 |  |
| 4971 | 1814.82.1 | Core part:LTE Advanced 3 Band Carrier Aggregation (3DL/1UL) for Band 20, Band 42 and Band 42 | 67d? | 2015-06-15 A | 2015-09-15 A | 100% |  |  | finish no earlier than 2015-12-15 | R4 | 536h | 536h | LTE_CA_B20_B42_B42-Core | 35 | Huawei | Rel-13 | 68 | RP-151131 |
| 4972 | 1814.82.2 | Perf. part:LTE Advanced 3 Band Carrier Aggregation (3DL/1UL) for Band 20, Band 42 and Band 42 | 67d? | 2015-06-15 A | 2015-09-15 A | 100% |  |  | finish no earlier than 2015-12-15 | R4 | 536h | 536h | LTE_CA_B20_B42_B42-Perf | 35 | Huawei | Rel-13 | 68 | RP-151131 |
| 4973 | 1814.83 | **LTE Advanced 3 Band Carrier Aggregation (3DL/1UL) for Band 3, Band 7 and Band 38** | 190.5d? | 2015-06-15 A | 2015-12-15 A | 100% |  |  |  | R4 | 3168h | 3168h | LTE_CA_B3_B7_B38 | 35 | Nokia Networks | Rel-13 | 68 |  |
| 4974 | 1814.83.1 | Core part:LTE Advanced 3 Band Carrier Aggregation (3DL/1UL) for Band 3, Band 7 and Band 38 | 132d? | 2015-06-15 A | 2015-12-15 A | 100% |  |  | finish no earlier than 2015-12-15 | R4 | 1056h | 1056h | LTE_CA_B3_B7_B38-Core | 35 | Nokia Networks | Rel-13 | 68 | RP-151131 |
| 4975 | 1814.83.2 | Perf. part:LTE Advanced 3 Band Carrier Aggregation (3DL/1UL) for Band 3, Band 7 and Band 38 | 132d? | 2015-06-15 A | 2015-12-15 A | 100% |  |  | finish no earlier than 2015-12-15 | R4 | 1056h | 1056h | LTE_CA_B3_B7_B38-Perf | 35 | Nokia Networks | Rel-13 | 68 | RP-151131 |
| 4976 | 1814.84 | **LTE Advanced 3 Band Carrier Aggregation (3DL/1UL) of Band 28, Band 41 and Band 41** | 190.5d? | 2015-06-15 A | 2015-12-15 A | 100% |  |  |  | R4 | 3168h | 3168h | LTE_CA_B28_B41_B41 | 35 | KDDI | Rel-13 | 68 |  |
| 4977 | 1814.84.1 | Core part:LTE Advanced 3 Band Carrier Aggregation (3DL/1UL) of Band 28, Band 41 and Band 41 | 132d? | 2015-06-15 A | 2015-12-15 A | 100% |  |  | finish no earlier than 2015-12-15 | R4 | 1056h | 1056h | LTE_CA_B28_B41_B41-Core | 35 | KDDI | Rel-13 | 68 | RP-151131 |
| 4978 | 1814.84.2 | Perf. part:LTE Advanced 3 Band Carrier Aggregation (3DL/1UL) of Band 28, Band 41 and Band 41 | 132d? | 2015-06-15 A | 2015-12-15 A | 100% |  |  | finish no earlier than 2015-12-15 | R4 | 1056h | 1056h | LTE_CA_B28_B41_B41-Perf | 35 | KDDI | Rel-13 | 68 | RP-151131 |
| 4979 | 1814.85 | **LTE Advanced 3 Band Carrier Aggregation (3DL/1UL) of Band 28, Band 42 and Band 42** | 190.5d? | 2015-06-15 A | 2015-12-15 A | 100% |  |  |  | R4 | 3168h | 3168h | LTE_CA_B28_B42_B42 | 35 | KDDI | Rel-13 | 68 |  |
| 4980 | 1814.85.1 | Core part:LTE Advanced 3 Band Carrier Aggregation (3DL/1UL) of Band 28, Band 42 and Band 42 | 132d? | 2015-06-15 A | 2015-12-15 A | 100% |  |  | finish no earlier than 2015-12-15 | R4 | 1056h | 1056h | LTE_CA_B28_B42_B42-Core | 35 | KDDI | Rel-13 | 68 | RP-151131 |
| 4981 | 1814.85.2 | Perf. part:LTE Advanced 3 Band Carrier Aggregation (3DL/1UL) of Band 28, Band 42 and Band 42 | 132d? | 2015-06-15 A | 2015-12-15 A | 100% |  |  | finish no earlier than 2015-12-15 | R4 | 1056h | 1056h | LTE_CA_B28_B42_B42-Perf | 35 | KDDI | Rel-13 | 68 | RP-151131 |

Notes:
- 4959: 03/07/15: Compl:0%->50% 03/07/15: Stat Rep: ->RP-150536 29/09/15: Compl:50%->80% 29/09/15: Stat Rep: RP-150536->RP-151131
- 4960: 03/07/15: Compl:0%->50% 03/07/15: Stat Rep: ->RP-150536 29/09/15: Compl:50%->80% 29/09/15: Stat Rep: RP-150536->RP-151131
- 4962: 29/09/15: Compl:0%->100% 29/09/15: Stat Rep: -->RP-151131
- 4963: 29/09/15: Compl:0%->100% 29/09/15: Stat Rep: -->RP-151131
- 4965: 29/09/15: Compl:0%->50% 29/09/15: Stat Rep: -->RP-1511311/22/3/16: Compl:50%->90%
- 4966: 29/09/15: Compl:0%->50% 29/09/15: Stat Rep: -->RP-151131 ¦22/3/16: Compl:50%->90%
- 4968: 29/09/15: Compl:0%->70% 29/09/15: Stat Rep: -->RP-151131
- 4969: 29/09/15: Compl:0%->70% 29/09/15: Stat Rep: -->RP-151131
- 4971: 29/09/15: Compl:0%->100% 29/09/15: CD:Tue 15/12/15->Tue 15/09/15 29/09/15: Stat Rep: -->RP-151131
- 4972: 29/09/15: Compl:0%->100% 29/09/15: CD:Tue 15/12/15->Tue 15/09/15 29/09/15: Stat Rep: -->RP-151131
- 4974: 29/09/15: Compl:0%->60% 29/09/15: Stat Rep: -->RP-1511311/1/16: Compl:
- 4975: 29/09/15: Compl:0%->60% 29/09/15: Stat Rep: -->RP-151131¦1/1/16: Comp
- 4977: 29/09/15: Compl:0%->50% 29/09/15: Stat Rep: -->RP-151131
- 4978: 29/09/15: Stat Rep: -->RP-151131
- 4980: 29/09/15: Compl:0%->40% 29/09/15: WID: RP-151112->RP-151158 29/09/15: Stat Rep: -->RP-151131
- 4981: 29/09/15: WID: RP-151112->RP-151158 29/09/15: Stat Rep: -->RP-151131¦

| ID | WBS | Task | Duration | Start | Finish | Complete | Constraint | Resources | Work | Actual work | Acronym | PCG approved | WI rapporteur name | Release | TSG approved | Status Report |
| --- | --- | --- | --- | --- | --- | --- | --- | --- | --- | --- | --- | --- | --- | --- | --- | --- |
| 4982 | 1814.86 | **LTE Advanced 4 Band Carrier Aggregation (4DL/1UL) of Band 2, Band 4, Band 7 and Band 12** | 284.75d? | 2015-06-15 A | 2016-03-15 A | 100% |  | R4 | 4728h | 4728h | LTE_CA_B2_B4_B7_B12 | 35 | Rogers Communications | Rel-13 | 68 |  |
| 4983 | 1814.86.1 | Core part:LTE Advanced 4 Band Carrier Aggregation (4DL/1UL) of Band 2, Band 4, Band 7 and Band 12 | 197d? | 2015-06-15 A | 2016-03-15 A | 100% | finish no earlier than 2016-03-15 | R4 | 1576h | 1576h | LTE_CA_B2_B4_B7_B12-Core | 35 | Rogers Communications | Rel-13 | 68 | RP-151131 |
| 4984 | 1814.86.2 | Perf. part:LTE Advanced 4 Band Carrier Aggregation (4DL/1UL) of Band 2, Band 4, Band 7 and Band 12 | 197d? | 2015-06-15 A | 2016-03-15 A | 100% | finish no earlier than 2016-03-15 | R4 | 1576h | 1576h | LTE_CA_B2_B4_B7_B12-Perf | 35 | Rogers Communications | Rel-13 | 68 | RP-151131 |
| 4985 | 1814.87 | **LTE Advanced 4 Band Carrier Aggregation (4DL/1UL) of Band 1, Band 3, Band 19 and Band 42** | 190.5d? | 2015-06-15 A | 2015-12-15 A | 100% |  | R4 | 3168h | 3168h | LTE_CA_B1_B3_B19_B42 | 35 | NTT DOCOMO, INC. | Rel-13 | 68 |  |
| 4986 | 1814.87.1 | Core part:LTE Advanced 4 Band Carrier Aggregation (4DL/1UL) of Band 1, Band 3, Band 19 and Band 42 | 132d? | 2015-06-15 A | 2015-12-15 A | 100% | finish no earlier than 2015-12-15 | R4 | 1056h | 1056h | LTE_CA_B1_B3_B19_B42-Core | 35 | NTT DOCOMO, INC. | Rel-13 | 68 | RP-151131 |
| 4987 | 1814.87.2 | Perf. part:LTE Advanced 4 Band Carrier Aggregation (4DL/1UL) of Band 1, Band 3, Band 19 and Band 42 | 132d? | 2015-06-15 A | 2015-12-15 A | 100% | finish no earlier than 2015-12-15 | R4 | 1056h | 1056h | LTE_CA_B1_B3_B19_B42-Perf | 35 | NTT DOCOMO, INC. | Rel-13 | 68 | RP-151131 |
| 4988 | 1814.88 | **LTE Advanced 4 Band Carrier Aggregation (4DL/1UL) of Band 1, Band 3, Band 42 and Band 42** | 190.5d? | 2015-06-15 A | 2015-12-15 A | 100% |  | R4 | 3168h | 3168h | LTE_CA_B1_B3_B42_B42 | 35 | NTT DOCOMO, INC. | Rel-13 | 68 |  |
| 4989 | 1814.88.1 | Core part:LTE Advanced 4 Band Carrier Aggregation (4DL/1UL) of Band 1, Band 3, Band 42 and Band 42 | 132d? | 2015-06-15 A | 2015-12-15 A | 100% | finish no earlier than 2015-12-15 | R4 | 1056h | 1056h | LTE_CA_B1_B3_B42_B42-Core | 35 | NTT DOCOMO, INC. | Rel-13 | 68 | RP-151131 |
| 4990 | 1814.88.2 | Perf. part:LTE Advanced 4 Band Carrier Aggregation (4DL/1UL) of Band 1, Band 3, Band 42 and Band 42 | 132d? | 2015-06-15 A | 2015-12-15 A | 100% | finish no earlier than 2015-12-15 | R4 | 1056h | 1056h | LTE_CA_B1_B3_B42_B42-Perf | 35 | NTT DOCOMO, INC. | Rel-13 | 68 | RP-151131 |
| 4991 | 1814.89 | **LTE Advanced 4 Band Carrier Aggregation (4DL/1UL) of Band 1, Band 19, Band 42 and Band 42** | 190.5d? | 2015-06-15 A | 2015-12-15 A | 100% |  | R4 | 3168h | 3168h | LTE_CA_B1_B19_B42_B42 | 35 | NTT DOCOMO, INC. | Rel-13 | 68 |  |
| 4992 | 1814.89.1 | Core part:LTE Advanced 4 Band Carrier Aggregation (4DL/1UL) of Band 1, Band 19, Band 42 and Band 42 | 132d? | 2015-06-15 A | 2015-12-15 A | 100% | finish no earlier than 2015-12-15 | R4 | 1056h | 1056h | LTE_CA_B1_B19_B42_B42-Core | 35 | NTT DOCOMO, INC. | Rel-13 | 68 | RP-151131 |
| 4993 | 1814.89.2 | Perf. part:LTE Advanced 4 Band Carrier Aggregation (4DL/1UL) of Band 1, Band 19, Band 42 and Band 42 | 132d? | 2015-06-15 A | 2015-12-15 A | 100% | finish no earlier than 2015-12-15 | R4 | 1056h | 1056h | LTE_CA_B1_B19_B42_B42-Perf | 35 | NTT DOCOMO, INC. | Rel-13 | 68 | RP-151131 |
| 4994 | 1814.90 | **LTE Advanced 4 Band Carrier Aggregation (4DL/1UL) of Band 3, Band 19, Band 42 and Band 42** | 190.5d? | 2015-06-15 A | 2015-12-15 A | 100% |  | R4 | 3168h | 3168h | LTE_CA_B3_B19_B42_B42 | 35 | NTT DOCOMO, INC. | Rel-13 | 68 |  |
| 4995 | 1814.90.1 | Core part:LTE Advanced 4 Band Carrier Aggregation (4DL/1UL) of Band 3, Band 19, Band 42 and Band 42 | 132d? | 2015-06-15 A | 2015-12-15 A | 100% | finish no earlier than 2015-12-15 | R4 | 1056h | 1056h | LTE_CA_B3_B19_B42_B42-Core | 35 | NTT DOCOMO, INC. | Rel-13 | 68 | RP-151131 |
| 4996 | 1814.90.2 | Perf. part:LTE Advanced 4 Band Carrier Aggregation (4DL/1UL) of Band 3, Band 19, Band 42 and Band 42 | 132d? | 2015-06-15 A | 2015-12-15 A | 100% | finish no earlier than 2015-12-15 | R4 | 1056h | 1056h | LTE_CA_B3_B19_B42_B42-Perf | 35 | NTT DOCOMO, INC. | Rel-13 | 68 | RP-151131 |
| 4997 | 1814.91 | **LTE Advanced 4 Band Carrier Aggregation (4DL/1UL) of Band 1, Band 19, Band 21 and Band 42** | 190.5d? | 2015-06-15 A | 2015-12-15 A | 100% |  | R4 | 3168h | 3168h | LTE_CA_B1_B19_B21_B42 | 35 | NTT DOCOMO, INC. | Rel-13 | 68 |  |
| 4998 | 1814.91.1 | Core part:LTE Advanced 4 Band Carrier Aggregation (4DL/1UL) of Band 1, Band 19, Band 21 and Band 42 | 132d? | 2015-06-15 A | 2015-12-15 A | 100% | finish no earlier than 2015-12-15 | R4 | 1056h | 1056h | LTE_CA_B1_B19_B21_B42-Core | 35 | NTT DOCOMO, INC. | Rel-13 | 68 | RP-151131 |
| 4999 | 1814.91.2 | Perf. part:LTE Advanced 4 Band Carrier Aggregation (4DL/1UL) of Band 1, Band 19, Band 21 and Band 42 | 132d? | 2015-06-15 A | 2015-12-15 A | 100% | finish no earlier than 2015-12-15 | R4 | 1056h | 1056h | LTE_CA_B1_B19_B21_B42-Perf | 35 | NTT DOCOMO, INC. | Rel-13 | 68 | RP-151131 |
| 5000 | 1814.92 | **LTE Advanced 4 Band Carrier Aggregation (4DL/1UL) of Band 1, Band 21, Band 42 and Band 42** | 190.5d? | 2015-06-15 A | 2015-12-15 A | 100% |  | R4 | 3168h | 3168h | LTE_CA_B1_B21_B42_B42 | 35 | NTT DOCOMO, INC. | Rel-13 | 68 |  |
| 5001 | 1814.92.1 | Core part:LTE Advanced 4 Band Carrier Aggregation (4DL/1UL) of Band 1, Band 21, Band 42 and Band 42 | 132d? | 2015-06-15 A | 2015-12-15 A | 100% | finish no earlier than 2015-12-15 | R4 | 1056h | 1056h | LTE_CA_B1_B21_B42_B42-Core | 35 | NTT DOCOMO, INC. | Rel-13 | 68 | RP-151131 |
| 5002 | 1814.92.2 | Perf. part:LTE Advanced 4 Band Carrier Aggregation (4DL/1UL) of Band 1, Band 21, Band 42 and Band 42 | 132d? | 2015-06-15 A | 2015-12-15 A | 100% | finish no earlier than 2015-12-15 | R4 | 1056h | 1056h | LTE_CA_B1_B21_B42_B42-Perf | 35 | NTT DOCOMO, INC. | Rel-13 | 68 | RP-151131 |
| 5003 | 1814.93 | **LTE Advanced 4 Band Carrier Aggregation (4DL/1UL) of Band 19, Band 21, Band 42 and Band 42** | 190.5d? | 2015-06-15 A | 2015-12-15 A | 100% |  | R4 | 3168h | 3168h | LTE_CA_B19_B21_B42_B42 | 35 | NTT DOCOMO, INC. | Rel-13 | 68 |  |
| 5004 | 1814.93.1 | Core part:LTE Advanced 4 Band Carrier Aggregation (4DL/1UL) of Band 19, Band 21, Band 42 and Band 42 | 132d? | 2015-06-15 A | 2015-12-15 A | 100% | finish no earlier than 2015-12-15 | R4 | 1056h | 1056h | LTE_CA_B19_B21_B42_B42-Core | 35 | NTT DOCOMO, INC. | Rel-13 | 68 | RP-151131 |
| 5005 | 1814.93.2 | Perf. part:LTE Advanced 4 Band Carrier Aggregation (4DL/1UL) of Band 19, Band 21, Band 42 and Band 42 | 132d? | 2015-06-15 A | 2015-12-15 A | 100% | finish no earlier than 2015-12-15 | R4 | 1056h | 1056h | LTE_CA_B19_B21_B42_B42-Perf | 35 | NTT DOCOMO, INC. | Rel-13 | 68 | RP-151131 |

Notes:
- 4983: 29/09/15: Stat Rep: -->RP-151131 22/3/16: Compl:0%->100%
- 4984: 29/09/15: Stat Rep: -->RP-151131 ¦22/3/16: Compl:0%->100%
- 4986: 29/09/15: Compl:0%->95% 29/09/15: CD:Tue 15/09/15->Tue 15/12/15 29/09/15: Stat Rep: -->RP-151131
- 4987: 29/09/15: Compl:0%->95% 29/09/15: CD:Tue 15/09/15->Tue 15/12/15 29/09/15: Stat Rep: -->RP-151131
- 4989: 29/09/15: Compl:0%->95% 29/09/15: CD:Tue 15/09/15->Tue 15/12/15 29/09/15: Stat Rep: -->RP-151131
- 4990: 29/09/15: Compl:0%->95% 29/09/15: CD:Tue 15/09/15->Tue 15/12/15 29/09/15: Stat Rep: -->RP-151131
- 4992: 29/09/15: Compl:0%->95% 29/09/15: CD:Tue 15/09/15->Tue 15/12/15 29/09/15: Stat Rep: -->RP-151131
- 4993: 29/09/15: Compl:0%->95% 29/09/15: CD:Tue 15/09/15->Tue 15/12/15 29/09/15: Stat Rep: -->RP-151131
- 4995: 29/09/15: Compl:0%->95% 29/09/15: CD:Tue 15/09/15->Tue 15/12/15 29/09/15: Stat Rep: -->RP-151131
- 4996: 29/09/15: Compl:0%->95% 29/09/15: CD:Tue 15/09/15->Tue 15/12/15 29/09/15: Stat Rep: -->RP-151131
- 4998: 29/09/15: Compl:0%->95% 29/09/15: CD:Tue 15/09/15->Tue 15/12/15 29/09/15: Stat Rep: -->RP-151131
- 4999: 29/09/15: Compl:0%->95% 29/09/15: CD:Tue 15/09/15->Tue 15/12/15 29/09/15: Stat Rep: -->RP-151131
- 5001: 29/09/15: Compl:0%->95% 29/09/15: CD:Tue 15/09/15->Tue 15/12/15 29/09/15: Stat Rep: -->RP-151131
- 5002: 29/09/15: Compl:0%->95% 29/09/15: CD:Tue 15/09/15->Tue 15/12/15 29/09/15: Stat Rep: -->RP-151131
- 5004: 29/09/15: Compl:0%->95% 29/09/15: CD:Tue 15/09/15->Tue 15/12/15 29/09/15: Stat Rep: -->RP-151131
- 5005: 29/09/15: Compl:0%->95% 29/09/15: CD:Tue 15/09/15->Tue 15/12/15 29/09/15: Stat Rep: -->RP-151131

| ID | WBS | Task | Duration | Start | Finish | Complete | Constraint | Resources | Work | Actual work | Acronym | PCG approved | WI rapporteur name | Release | TSG approved | Status Report |
| --- | --- | --- | --- | --- | --- | --- | --- | --- | --- | --- | --- | --- | --- | --- | --- | --- |
| 5006 | 1814.94 | **LTE Advanced 4 Band Carrier Aggregation (4DL/1UL) of Band 2, Band 4, Band 5 and Band 12** | 190.5d? | 2015-06-15 A | 2015-12-15 A | 100% |  | R4 | 3168h | 3168h | LTE_CA_B2_B4_B5_B12 | 35 | U.S. Cellular | Rel-13 | 68 |  |
| 5007 | 1814.94.1 | Core part:LTE Advanced 4 Band Carrier Aggregation (4DL/1UL) of Band 2, Band 4, Band 5 and Band 12 | 132d? | 2015-06-15 A | 2015-12-15 A | 100% | finish no earlier than 2015-12-15 | R4 | 1056h | 1056h | LTE_CA_B2_B4_B5_B12-Core | 35 | U.S. Cellular | Rel-13 | 68 | RP-151131 |
| 5008 | 1814.94.2 | Perf. part:LTE Advanced 4 Band Carrier Aggregation (4DL/1UL) of Band 2, Band 4, Band 5 and Band 12 | 132d? | 2015-06-15 A | 2015-12-15 A | 100% | finish no earlier than 2015-12-15 | R4 | 1056h | 1056h | LTE_CA_B2_B4_B5_B12-Perf | 35 | U.S. Cellular | Rel-13 | 68 | RP-151131 |
| 5009 | 1814.95 | **LTE Advanced 4 Band Carrier Aggregation (4DL/1UL) of Band 2, Band 2, Band 4 and Band 5** | 190.5d? | 2015-06-15 A | 2015-12-15 A | 100% |  | R4 | 3168h | 3168h | LTE_CA_B2_B2_B4_B5 | 35 | U.S. Cellular | Rel-13 | 68 |  |
| 5010 | 1814.95.1 | Core part:LTE Advanced 4 Band Carrier Aggregation (4DL/1UL) of Band 2, Band 2, Band 4 and Band 5 | 132d? | 2015-06-15 A | 2015-12-15 A | 100% | finish no earlier than 2015-12-15 | R4 | 1056h | 1056h | LTE_CA_B2_B2_B4_B5-Core | 35 | U.S. Cellular | Rel-13 | 68 | RP-151131 |
| 5011 | 1814.95.2 | Perf. part:LTE Advanced 4 Band Carrier Aggregation (4DL/1UL) of Band 2, Band 2, Band 4 and Band 5 | 132d? | 2015-06-15 A | 2015-12-15 A | 100% | finish no earlier than 2015-12-15 | R4 | 1056h | 1056h | LTE_CA_B2_B2_B4_B5-Perf | 35 | U.S. Cellular | Rel-13 | 68 | RP-151131 |
| 5012 | 1814.96 | **LTE Advanced 4-Band Carrier Aggregation (4DL/1UL) of Band 2, Band 2, Band 12 and Band 12** | 190.5d? | 2015-06-15 A | 2015-12-15 A | 100% |  | R4 | 3168h | 3168h | LTE_CA_B2_B2_B12_B12 | 35 | U.S. Cellular | Rel-13 | 68 |  |
| 5013 | 1814.96.1 | Core part:LTE Advanced 4-Band Carrier Aggregation (4DL/1UL) of Band 2, Band 2, Band 12 and Band 12 | 132d? | 2015-06-15 A | 2015-12-15 A | 100% | finish no earlier than 2015-12-15 | R4 | 1056h | 1056h | LTE_CA_B2_B2_B12_B12-Core | 35 | U.S. Cellular | Rel-13 | 68 | RP-151131 |
| 5014 | 1814.96.2 | Perf. part:LTE Advanced 4-Band Carrier Aggregation (4DL/1UL) of Band 2, Band 2, Band 12 and Band 12 | 132d? | 2015-06-15 A | 2015-12-15 A | 100% | finish no earlier than 2015-12-15 | R4 | 1056h | 1056h | LTE_CA_B2_B2_B12_B12-Perf | 35 | U.S. Cellular | Rel-13 | 68 | RP-151131 |
| 5015 | 1814.97 | **LTE Advanced 4 Band Carrier Aggregation (4DL/1UL) of Band 4, Band 4, Band 5 and Band 30** | 284.75d? | 2015-06-15 A | 2016-03-15 A | 100% |  | R4 | 4728h | 4728h | LTE_CA_B4_B4_B5_B30 | 35 | AT&T | Rel-13 | 68 |  |
| 5016 | 1814.97.1 | Core part:LTE Advanced 4 Band Carrier Aggregation (4DL/1UL) of Band 4, Band 4, Band 5 and Band 30 | 197d? | 2015-06-15 A | 2016-03-15 A | 100% | finish no earlier than 2016-03-15 | R4 | 1576h | 1576h | LTE_CA_B4_B4_B5_B30-Core | 35 | AT&T | Rel-13 | 68 | RP-151131 |
| 5017 | 1814.97.2 | Perf. part:LTE Advanced 4 Band Carrier Aggregation (4DL/1UL) of Band 4, Band 4, Band 5 and Band 30 | 197d? | 2015-06-15 A | 2016-03-15 A | 100% | finish no earlier than 2016-03-15 | R4 | 1576h | 1576h | LTE_CA_B4_B4_B5_B30-Perf | 35 | AT&T | Rel-13 | 68 | RP-151131 |
| 5018 | 1814.98 | **LTE Advanced 4 Band Carrier Aggregation (4DL/1UL) of Band 4, Band 4, Band 12 and Band 30** | 284.75d? | 2015-06-15 A | 2016-03-15 A | 100% |  | R4 | 4728h | 4728h | LTE_CA_B4_B4_B12_B30 | 35 | AT&T | Rel-13 | 68 |  |
| 5019 | 1814.98.1 | Core part:LTE Advanced 4 Band Carrier Aggregation (4DL/1UL) of Band 4, Band 4, Band 12 and Band 30 | 197d? | 2015-06-15 A | 2016-03-15 A | 100% | finish no earlier than 2016-03-15 | R4 | 1576h | 1576h | LTE_CA_B4_B4_B12_B30-Core | 35 | AT&T | Rel-13 | 68 | RP-151131 |
| 5020 | 1814.98.2 | Perf. part:LTE Advanced 4 Band Carrier Aggregation (4DL/1UL) of Band 4, Band 4, Band 12 and Band 30 | 197d? | 2015-06-15 A | 2016-03-15 A | 100% | finish no earlier than 2016-03-15 | R4 | 1576h | 1576h | LTE_CA_B4_B4_B12_B30-Perf | 35 | AT&T | Rel-13 | 68 | RP-151131 |
| 5021 | 1814.99 | **LTE Advanced 4 Band Carrier Aggregation (4DL/1UL) of Band 4, Band 4, Band 29 and Band 30** | 284.75d? | 2015-06-15 A | 2016-03-15 A | 100% |  | R4 | 4728h | 4728h | LTE_CA_B4_B4_B29_B30 | 35 | AT&T | Rel-13 | 68 |  |
| 5022 | 1814.99.1 | Core part:LTE Advanced 4 Band Carrier Aggregation (4DL/1UL) of Band 4, Band 4, Band 29 and Band 30 | 197d? | 2015-06-15 A | 2016-03-15 A | 100% | finish no earlier than 2016-03-15 | R4 | 1576h | 1576h | LTE_CA_B4_B4_B29_B30-Core | 35 | AT&T | Rel-13 | 68 | RP-151131 |
| 5023 | 1814.99.2 | Perf. part:LTE Advanced 4 Band Carrier Aggregation (4DL/1UL) of Band 4, Band 4, Band 29 and Band 30 | 197d? | 2015-06-15 A | 2016-03-15 A | 100% | finish no earlier than 2016-03-15 | R4 | 1576h | 1576h | LTE_CA_B4_B4_B29_B30-Perf | 35 | AT&T | Rel-13 | 68 | RP-151131 |
| 5024 | 1814.100 | **LTE Advanced 4 Band Carrier Aggregation (4DL/1UL) of Band 2, Band 2, Band 5 and Band 12** | 190.5d? | 2015-06-15 A | 2015-12-15 A | 100% |  | R4 | 3168h | 3168h | LTE_CA_B2_B2_B5_B12 | 35 | U.S. Cellular | Rel-13 | 68 |  |
| 5025 | 1814.100.1 | Core part:LTE Advanced 4 Band Carrier Aggregation (4DL/1UL) of Band 2, Band 2, Band 5 and Band 12 | 132d? | 2015-06-15 A | 2015-12-15 A | 100% | finish no earlier than 2015-12-15 | R4 | 1056h | 1056h | LTE_CA_B2_B2_B5_B12-Core | 35 | U.S. Cellular | Rel-13 | 68 | RP-151131 |
| 5026 | 1814.100.2 | Perf. part:LTE Advanced 4 Band Carrier Aggregation (4DL/1UL) of Band 2, Band 2, Band 5 and Band 12 | 132d? | 2015-06-15 A | 2015-12-15 A | 100% | finish no earlier than 2015-12-15 | R4 | 1056h | 1056h | LTE_CA_B2_B2_B5_B12-Perf | 35 | U.S. Cellular | Rel-13 | 68 | RP-151131 |
| 5027 | 1814.101 | **LTE Advanced 4 Band Carrier Aggregation (4DL/1UL) of Band 2, Band 5, Band 12 and Band 12** | 190.5d? | 2015-06-15 A | 2015-12-15 A | 100% |  | R4 | 3168h | 3168h | LTE_CA_B2_B5_B12_B12 | 35 | U.S. Cellular | Rel-13 | 68 |  |
| 5028 | 1814.101.1 | Core part:LTE Advanced 4 Band Carrier Aggregation (4DL/1UL) of Band 2, Band 5, Band 12 and Band 12 | 132d? | 2015-06-15 A | 2015-12-15 A | 100% | finish no earlier than 2015-12-15 | R4 | 1056h | 1056h | LTE_CA_B2_B5_B12_B12-Core | 35 | U.S. Cellular | Rel-13 | 68 | RP-151131 |
| 5029 | 1814.101.2 | Perf. part:LTE Advanced 4 Band Carrier Aggregation (4DL/1UL) of Band 2, Band 5, Band 12 and Band 12 | 132d? | 2015-06-15 A | 2015-12-15 A | 100% | finish no earlier than 2015-12-15 | R4 | 1056h | 1056h | LTE_CA_B2_B5_B12_B12-Perf | 35 | U.S. Cellular | Rel-13 | 68 | RP-151131 |

Notes:
- 5007: 29/09/15: Compl:0%->40% 29/09/15: Stat Rep: -->RP-151131
- 5008: 29/09/15: Compl:0%->40% 29/09/15: Stat Rep: -->RP-151131
- 5010: 29/09/15: Compl:0%->40% 29/09/15: Stat Rep: -->RP-151131
- 5011: 29/09/15: Compl:0%->40% 29/09/15: Stat Rep: -->RP-151131
- 5013: 29/09/15: Compl:0%->40% 29/09/15: Stat Rep: -->RP-151131
- 5014: 29/09/15: Compl:0%->40% 29/09/15: Stat Rep: -->RP-151131
- 5016: 29/09/15: Stat Rep: -->RP-151131 22/3/16: Compl:50%->100%
- 5017: 29/09/15: Stat Rep: -->RP-151131 ¦22/3/16: Compl:50%->100%
- 5019: 29/09/15: Stat Rep: -->RP-151131 22/3/16: Compl:50%->100%
- 5020: 29/09/15: Stat Rep: -->RP-151131 22/3/16: Compl:50%->100%
- 5022: 29/09/15: Stat Rep: -->RP-151131 ¦22/3/16: Compl:50%->100%
- 5023: 29/09/15: Stat Rep: -->RP-151131 22/3/16: Compl:50%->100%
- 5025: 29/09/15: Compl:0%->40% 29/09/15: Stat Rep: -->RP-151131
- 5026: 29/09/15: Compl:0%->40% 29/09/15: Stat Rep: -->RP-151131
- 5028: 29/09/15: Compl:0%->40% 29/09/15: Stat Rep: -->RP-151131
- 5029: 29/09/15: Compl:0%->40% 29/09/15: Stat Rep: -->RP-151131

| ID | WBS | Task | Duration | Start | Finish | Complete | Constraint | Resources | Work | Actual work | Acronym | PCG approved | WI rapporteur name | Release | TSG approved | Status Report | Impacted TSs and TRs |
| --- | --- | --- | --- | --- | --- | --- | --- | --- | --- | --- | --- | --- | --- | --- | --- | --- | --- |
| 5030 | 1814.102 | **LTE Advanced 3DL/2UL mixed intra- and inter-band Carrier Aggregation** | 190.5d? | 2015-06-15 A | 2015-12-15 A | 100% |  | R4 | 3168h | 3168h | LTE_CA_3DL_2UL_inter_intra | 35 | Nokia Networks | Rel-14 | 68 |  |  |
| 5031 | 1814.102.1 | Core part:LTE Advanced 3DL/2UL mixed intra- and inter-band Carrier Aggregation | 132d? | 2015-06-15 A | 2015-12-15 A | 100% | finish no earlier than 2015-12-15 | R4 | 1056h | 1056h | LTE_CA_3DL_2UL_inter_intra-Core | 35 | Nokia Networks | Rel-13 | 68 | RP-151131 |  |
| 5032 | 1814.102.2 | Perf. part:LTE Advanced 3DL/2UL mixed intra- and inter-band Carrier Aggregation | 132d? | 2015-06-15 A | 2015-12-15 A | 100% | finish no earlier than 2015-12-15 | R4 | 1056h | 1056h | LTE_CA_3DL_2UL_inter_intra-Perf | 35 | Nokia Networks | Rel-13 | 68 | RP-151131 |  |
| 5033 | 1814.103 | **LTE Advanced intra-band contiguous Carrier Aggregation in Band 5** | 190.5d? | 2015-06-15 A | 2015-12-15 A | 100% |  | R4 | 3168h | 3168h | LTE_CA_C_B5 | 35 | Intel | Rel-13 | 68 |  |  |
| 5034 | 1814.103.1 | Core part: LTE Advanced intra-band contiguous Carrier Aggregation in Band 5 | 132d? | 2015-06-15 A | 2015-12-15 A | 100% | finish no earlier than 2015-12-15 | R4 | 1056h | 1056h | LTE_CA_C_B5-Core | 35 | Intel | Rel-13 | 68 | RP-151131 |  |
| 5035 | 1814.103.2 | Perf. part: LTE Advanced intra-band contiguous Carrier Aggregation in Band 5 | 132d? | 2015-06-15 A | 2015-12-15 A | 100% | finish no earlier than 2015-12-15 | R4 | 1056h | 1056h | LTE_CA_C_B5-Perf | 35 | Intel | Rel-13 | 68 | RP-151131 |  |
| 5036 | 1814.104 | **Additional bandwidth combination set for LTE Advanced intra-band non-contiguous Carrier Aggregation in Band 4** | 96.25d? | 2015-06-15 A | 2015-09-15 A | 100% |  | R4 | 1608h | 1608h | LTE_CA_NC_B4_BWset | 35 | Nokia Networks | Rel-13 | 68 |  |  |
| 5037 | 1814.104.1 | Core part: Additional bandwidth combination set for LTE Advanced intra-band non-contiguous Carrier Aggregation in Band 4 | 67d? | 2015-06-15 A | 2015-09-15 A | 100% | finish no earlier than 2015-09-15 | R4 | 536h | 536h | LTE_CA_NC_B4_BWset-Core | 35 | Nokia Networks | Rel-13 | 68 | RP-151131 |  |
| 5038 | 1814.104.2 | Perf. part: Additional bandwidth combination set for LTE Advanced intra-band non-contiguous Carrier Aggregation in Band 4 | 67d? | 2015-06-15 A | 2015-09-15 A | 100% | finish no earlier than 2015-09-15 | R4 | 536h | 536h | LTE_CA_NC_B4_BWset-Perf | 35 | Nokia Networks | Rel-13 | 68 | RP-151131 |  |
| 5039 | 1814.105 | **LTE Advanced intra-band non-contiguous Carrier Aggregation in Band 5** | 190.5d? | 2015-06-15 A | 2015-12-15 A | 100% |  | R4 | 3168h | 3168h | LTE_CA_NC_B5 | 35 | Intel | Rel-13 | 68 |  |  |
| 5040 | 1814.105.1 | Core part:LTE Advanced intra-band non-contiguous Carrier Aggregation in Band 5 | 132d? | 2015-06-15 A | 2015-12-15 A | 100% | finish no earlier than 2015-12-15 | R4 | 1056h | 1056h | LTE_CA_NC_B5-Core | 35 | Intel | Rel-13 | 68 | RP-151131 |  |
| 5041 | 1814.105.2 | Perf. part:LTE Advanced intra-band non-contiguous Carrier Aggregation in Band 5 | 132d? | 2015-06-15 A | 2015-12-15 A | 100% | finish no earlier than 2015-12-15 | R4 | 1056h | 1056h | LTE_CA_NC_B5-Perf | 35 | Intel | Rel-13 | 68 | RP-151131 |  |
| 5042 | 1814.106 | **LTE Advanced intra-band non-contiguous Carrier Aggregation in Band 42 for 4DL** | 190.5d? | 2015-06-15 A | 2015-12-15 A | 100% |  | R4 | 3168h | 3168h | LTE_CA_NC_B42_4DL | 35 | Huawei | Rel-13 | 68 |  |  |
| 5043 | 1814.106.1 | Core part:LTE Advanced intra-band non-contiguous Carrier Aggregation in Band 42 for 4DL | 132d? | 2015-06-15 A | 2015-12-15 A | 100% | finish no earlier than 2015-12-15 | R4 | 1056h | 1056h | LTE_CA_NC_B42_4DL-Core | 35 | Huawei | Rel-13 | 68 | RP-151131 |  |
| 5044 | 1814.106.2 | Perf. part:LTE Advanced intra-band non-contiguous Carrier Aggregation in Band 42 for 4DL | 132d? | 2015-06-15 A | 2015-12-15 A | 100% | finish no earlier than 2015-12-15 | R4 | 1056h | 1056h | LTE_CA_NC_B42_4DL-Perf | 35 | Huawei | Rel-13 | 68 | RP-151131 |  |
| 5045 | 1814.107 | **Additional bandwidth combination set for LTE Advanced inter-band Carrier Aggregation of Band 2 and Band 12** | 96.25d? | 2015-06-15 A | 2015-09-15 A | 100% |  | R4 | 1608h | 1608h | LTE_CA_B2_B12_BWset | 35 | Nokia Networks | Rel-13 | 68 |  |  |
| 5046 | 1814.107.1 | Core part: Additional bandwidth combination set for LTE Advanced inter-band Carrier Aggregation of Band 2 and Band 12 | 67d? | 2015-06-15 A | 2015-09-15 A | 100% | finish no earlier than 2015-09-15 | R4 | 536h | 536h | LTE_CA_B2_B12_BWset-Core | 35 | Nokia Networks | Rel-13 | 68 | RP-151131 |  |
| 5047 | 1814.107.2 | Perf. part: Additional bandwidth combination set for LTE Advanced inter-band Carrier Aggregation of Band 2 and Band 12 | 67d? | 2015-06-15 A | 2015-09-15 A | 100% | finish no earlier than 2015-09-15 | R4 | 536h | 536h | LTE_CA_B2_B12_BWset-Perf | 35 | Nokia Networks | Rel-13 | 68 | RP-151131 |  |
| 5048 | 1814.108 | **Additional bandwidth combination set 2 for LTE Advanced inter-band Carrier Aggregation of Band 4 and Band 12** | 96.25d? | 2015-06-15 A | 2015-09-15 A | 100% |  | R4 | 1608h | 1608h | LTE_CA_B4_B12_BWset2 | 35 | Nokia Networks | Rel-13 | 68 |  |  |
| 5049 | 1814.108.1 | Core part: Additional bandwidth combination set 2 for LTE Advanced inter-band Carrier Aggregation of Band 4 and Band 12 | 67d? | 2015-06-15 A | 2015-09-15 A | 100% | finish no earlier than 2015-09-15 | R4 | 536h | 536h | LTE_CA_B4_B12_BWset2-Core | 35 | Nokia Networks | Rel-13 | 68 | RP-151131 |  |
| 5050 | 1814.108.2 | Perf. part: Additional bandwidth combination set 2 for LTE Advanced inter-band Carrier Aggregation of Band 4 and Band 12 | 67d? | 2015-06-15 A | 2015-09-15 A | 100% | finish no earlier than 2015-09-15 | R4 | 536h | 536h | LTE_CA_B4_B12_BWset2-Perf | 35 | Nokia Networks | Rel-13 | 68 | RP-151131 |  |
| 5051 | 1814.109 | **Introduction of 1447-1467MHz Band for TD-LTE in China** | 475.12d? | 2015-06-15 A | 2016-09-15 A | 100% |  | R4 | 5824h | 5824h | LTE_TDD_1447MHz_China | 35 | Huawei | Rel-13 | 68 |  |  |
| 5052 | 1814.109.1 | Core part: Introduction of 1447-1467MHz Band for TD-LTE in China | 132d? | 2015-06-15 A | 2015-12-15 A | 100% | finish no earlier than 2015-12-15 | R4 | 1056h | 1056h | LTE_TDD_1447MHz_China-Core | 35 | Huawei | Rel-13 | 68 | RP-151242 | 36.892 |
| 5053 | 1814.109.2 | Perf. part: Introduction of 1447-1467MHz Band for TD-LTE in China | 132d? | 2015-06-15 A | 2015-12-15 A | 100% | finish no earlier than 2016-03-15 | R4 | 1056h | 1056h | LTE_TDD_1447MHz_China-Perf | 35 | Huawei | Rel-13 | 68 | RP-151242 |  |
| 5054 | 1814.109.3 | UE Conformance Test Aspects - Introduction of 1447-1467MHz Band for TD-LTE in China | 134d? | 2016-03-15 A | 2016-09-15 A | 100% | finish no earlier than 2016-09-15 | R5 | 1072h | 1072h | LTE_TDD_1447MHz_China-UEConTest | 36 | Huawei | Rel-13 | 71 |  |  |

Notes:
- 5030: covers combinations of contiguous intra-band CA and inter-band CA or combinations of non-contiguous intra-band CA and inter-band CA for LTE¦pure intra-band CA combinations are also covered by this WI¦note: There is already a REL-13 WI LTE_CA_3DL_2UL whi
- 5031: covers combinations of contiguous intra-band CA and inter-band CA or combinations of non-contiguous intra-band CA and inter-band CA for LTE¦pure intra-band CA combinations are also covered by this WI¦note: There is already a REL-13 WI LTE_CA_3DL_2UL
- 5032: covers combinations of contiguous intra-band CA and inter-band CA or combinations of non-contiguous intra-band CA and inter-band CA for LTE¦pure intra-band CA combinations are also covered by this WI¦note: There is already a REL-13 WI LTE_CA_3DL_2UL
- 5034: 29/09/15: Compl:0%->20% 29/09/15: Stat Rep: -->RP-151131
- 5035: 29/09/15: Compl:0%->20% 29/09/15: Stat Rep: -->RP-151131
- 5036: LTE_CA_NC_B4 was completed in REL-12
- 5037: LTE_CA_NC_B4 was completed in REL-12 29/09/15: Compl:0%->100% 29/09/15: Stat Rep: -->RP-151131
- 5038: LTE_CA_NC_B4 was completed in REL-12 29/09/15: Compl:0%->100% 29/09/15: Stat Rep: -->RP-151131
- 5040: 29/09/15: Compl:0%->20% 29/09/15: Stat Rep: -->RP-151131
- 5041: 29/09/15: Compl:0%->20% 29/09/15: Stat Rep: -->RP-151131
- 5043: 29/09/15: Compl:0%->50% 29/09/15: Stat Rep: -->RP-151131
- 5044: 29/09/15: Stat Rep: -->RP-151131
- 5045: LTE_CA_B2_B12 was completed as REL-12 WI
- 5046: LTE_CA_B2_B12 was completed as REL-12 WI 29/09/15: Compl:0%->100% 29/09/15: Stat Rep: -->RP-151131
- 5047: LTE_CA_B2_B12 was completed as REL-12 WI 29/09/15: Compl:0%->100% 29/09/15: Stat Rep: -->RP-151131
- 5048: LTE_CA_B4_B12 was completed in REL-11 and LTE_CA_B4_B12_BWset was completed in REL-12
- 5049: LTE_CA_B4_B12 was completed in REL-11 and LTE_CA_B4_B12_BWset was completed in REL-12 29/09/15: Compl:0%->100% 29/09/15: Stat Rep: -->RP-151131
- 5050: LTE_CA_B4_B12 was completed in REL-11 and LTE_CA_B4_B12_BWset was completed in REL-12 29/09/15: Compl:0%->100% 29/09/15: Stat Rep: -->RP-151131
- 5051: Aug 15: TR numb added
- 5052: Aug 15: TR numb added 29/09/15: Compl:0%->20% 29/09/15: Stat Rep: -->RP-151242
- 5053: 29/09/15: Stat Rep: -->RP-151242
- 5054: testing REL-13 LTE_TDD_1447MHz_China-Core¦1/7/16: C¦

| ID | WBS | Task | Duration | Start | Finish | Complete | Constraint | Resources | Work | Actual work | Acronym | PCG approved | WI rapporteur name | Release | TSG approved | Status Report |
| --- | --- | --- | --- | --- | --- | --- | --- | --- | --- | --- | --- | --- | --- | --- | --- | --- |
| 5055 | 1814.110 | **LTE Advanced 4 Band Carrier Aggregation (4DL/1UL) of Band 41, Band 41, Band 42 and Band 42** | 190.5d? | 2015-06-15 A | 2015-12-15 A | 100% |  | R4 | 3168h | 3168h | LTE_CA_B41_B41_B42_B42 | 35 | ZTE | Rel-13 | 68 |  |
| 5056 | 1814.110.1 | Core part:LTE Advanced 4 Band Carrier Aggregation (4DL/1UL) of Band 41, Band 41, Band 42 and Band 42 | 132d? | 2015-06-15 A | 2015-12-15 A | 100% | finish no earlier than 2015-12-15 | R4 | 1056h | 1056h | LTE_CA_B41_B41_B42_B42-Core | 35 | ZTE | Rel-13 | 68 | RP-151131 |
| 5057 | 1814.110.2 | Perf. part:LTE Advanced 4 Band Carrier Aggregation (4DL/1UL) of Band 41, Band 41, Band 42 and Band 42 | 132d? | 2015-06-15 A | 2015-12-15 A | 100% | finish no earlier than 2015-12-15 | R4 | 1056h | 1056h | LTE_CA_B41_B41_B42_B42-Perf | 35 | ZTE | Rel-13 | 68 | RP-151131 |
| 5058 | 1814.111 | **LTE Advanced inter-band Carrier Aggregation for Band 5 and Band 38** | 95.25d? | 2015-09-15 A | 2015-12-15 A | 100% |  | R4 | 1584h | 1584h | LTE_CA_B5_B38 | 35 | Huawei | Rel-13 | 69 |  |
| 5059 | 1814.111.1 | Core part:LTE Advanced inter-band Carrier Aggregation for Band 5 and Band 38 | 66d? | 2015-09-15 A | 2015-12-15 A | 100% | finish no earlier than 2015-12-15 | R4 | 528h | 528h | LTE_CA_B5_B38-Core | 35 | Huawei | Rel-13 | 69 |  |
| 5060 | 1814.111.2 | Perf. part:LTE Advanced inter-band Carrier Aggregation for Band 5 and Band 38 | 66d? | 2015-09-15 A | 2015-12-15 A | 100% | finish no earlier than 2015-12-15 | R4 | 528h | 528h | LTE_CA_B5_B38-Perf | 35 | Huawei | Rel-13 | 69 |  |
| 5061 | 1814.112 | **LTE Advanced 3 Band Carrier Aggregation (3DL/1UL) of Band 1, Band 11 and Band 18** | 95.25d? | 2015-09-15 A | 2015-12-15 A | 100% |  | R4 | 1584h | 1584h | LTE_CA_B1_B11_B18 | 35 | KDDI | Rel-13 | 69 |  |
| 5062 | 1814.112.1 | Core part:LTE Advanced 3 Band Carrier Aggregation (3DL/1UL) of Band 1, Band 11 and Band 18 | 66d? | 2015-09-15 A | 2015-12-15 A | 100% | finish no earlier than 2015-12-15 | R4 | 528h | 528h | LTE_CA_B1_B11_B18-Core | 35 | KDDI | Rel-13 | 69 |  |
| 5063 | 1814.112.2 | Perf. part:LTE Advanced 3 Band Carrier Aggregation (3DL/1UL) of Band 1, Band 11 and Band 18 | 66d? | 2015-09-15 A | 2015-12-15 A | 100% | finish no earlier than 2015-12-15 | R4 | 528h | 528h | LTE_CA_B1_B11_B18-Perf | 35 | KDDI | Rel-13 | 69 |  |
| 5064 | 1814.113 | **LTE Advanced 3 Band Carrier Aggregation (3DL/1UL) of Band 5, Band 40, and Band 40** | 95.25d? | 2015-09-15 A | 2015-12-15 A | 100% |  | R4 | 1584h | 1584h | LTE_CA_B5_B40_B40 | 35 | ZTE | Rel-13 | 69 |  |
| 5065 | 1814.113.1 | Core part:LTE Advanced 3 Band Carrier Aggregation (3DL/1UL) of Band 5, Band 40, and Band 40 | 66d? | 2015-09-15 A | 2015-12-15 A | 100% | finish no earlier than 2015-12-15 | R4 | 528h | 528h | LTE_CA_B5_B40_B40-Core | 35 | ZTE | Rel-13 | 69 |  |
| 5066 | 1814.113.2 | Perf. part:LTE Advanced 3 Band Carrier Aggregation (3DL/1UL) of Band 5, Band 40, and Band 40 | 66d? | 2015-09-15 A | 2015-12-15 A | 100% | finish no earlier than 2015-12-15 | R4 | 528h | 528h | LTE_CA_B5_B40_B40-Perf | 35 | ZTE | Rel-13 | 69 |  |
| 5067 | 1814.114 | **LTE Advanced 3 Band Carrier Aggregation (3DL/1UL) for Band 3, Band 41 and Band 42** | 95.25d? | 2015-09-15 A | 2015-12-15 A | 100% |  | R4 | 1584h | 1584h | LTE_CA_B3_B41_B42 | 35 | Huawei | Rel-13 | 69 |  |
| 5068 | 1814.114.1 | Core part:LTE Advanced 3 Band Carrier Aggregation (3DL/1UL) for Band 3, Band 41 and Band 42 | 66d? | 2015-09-15 A | 2015-12-15 A | 100% | finish no earlier than 2015-12-15 | R4 | 528h | 528h | LTE_CA_B3_B41_B42-Core | 35 | Huawei | Rel-13 | 69 |  |
| 5069 | 1814.114.2 | Perf. part:LTE Advanced 3 Band Carrier Aggregation (3DL/1UL) for Band 3, Band 41 and Band 42 | 66d? | 2015-09-15 A | 2015-12-15 A | 100% | finish no earlier than 2015-12-15 | R4 | 528h | 528h | LTE_CA_B3_B41_B42-Perf | 35 | Huawei | Rel-13 | 69 |  |
| 5070 | 1814.115 | **LTE Advanced 3 Band Carrier Aggregation (3DL/1UL) of Band 3, Band 41, and Band 41** | 95.25d? | 2015-09-15 A | 2015-12-15 A | 100% |  | R4 | 1584h | 1584h | LTE_CA_B3_B41_B41 | 35 | ZTE | Rel-13 | 69 |  |
| 5071 | 1814.115.1 | Core part:LTE Advanced 3 Band Carrier Aggregation (3DL/1UL) of Band 3, Band 41, and Band 41 | 66d? | 2015-09-15 A | 2015-12-15 A | 100% | finish no earlier than 2015-12-15 | R4 | 528h | 528h | LTE_CA_B3_B41_B41-Core | 35 | ZTE | Rel-13 | 69 |  |
| 5072 | 1814.115.2 | Perf. part:LTE Advanced 3 Band Carrier Aggregation (3DL/1UL) of Band 3, Band 41, and Band 41 | 66d? | 2015-09-15 A | 2015-12-15 A | 100% | finish no earlier than 2015-12-15 | R4 | 528h | 528h | LTE_CA_B3_B41_B41-Perf | 35 | ZTE | Rel-13 | 69 |  |
| 5073 | 1814.116 | **LTE Advanced 4 Band Carrier Aggregation (4DL1UL) of Band 39, Band 41, Band 41 and Band 41** | 95.25d? | 2015-09-15 A | 2015-12-15 A | 100% |  | R4 | 1584h | 1584h | LTE_CA_B39_B41_B41_B41 | 35 | CMCC | Rel-13 | 69 |  |
| 5074 | 1814.116.1 | Core part:LTE Advanced 4 Band Carrier Aggregation (4DL1UL) of Band 39, Band 41, Band 41 and Band 41 | 66d? | 2015-09-15 A | 2015-12-15 A | 100% | finish no earlier than 2015-12-15 | R4 | 528h | 528h | LTE_CA_B39_B41_B41_B41-Core | 35 | CMCC | Rel-13 | 69 |  |
| 5075 | 1814.116.2 | Perf. part:LTE Advanced 4 Band Carrier Aggregation (4DL1UL) of Band 39, Band 41, Band 41 and Band 41 | 66d? | 2015-09-15 A | 2015-12-15 A | 100% | finish no earlier than 2015-12-15 | R4 | 528h | 528h | LTE_CA_B39_B41_B41_B41-Perf | 35 | CMCC | Rel-13 | 69 |  |
| 5076 | 1814.117 | **LTE Advanced 4 Band Carrier Aggregation (4DL1UL) of Band 39, Band 39, Band 41 and Band 41** | 95.25d? | 2015-09-15 A | 2015-12-15 A | 100% |  | R4 | 1584h | 1584h | LTE_CA_B39_B39_B41_B41 | 35 | CMCC | Rel-13 | 69 |  |
| 5077 | 1814.117.1 | Core part:LTE Advanced 4 Band Carrier Aggregation (4DL1UL) of Band 39, Band 39, Band 41 and Band 41 | 66d? | 2015-09-15 A | 2015-12-15 A | 100% | finish no earlier than 2015-12-15 | R4 | 528h | 528h | LTE_CA_B39_B39_B41_B41-Core | 35 | CMCC | Rel-13 | 69 |  |
| 5078 | 1814.117.2 | Perf. part:LTE Advanced 4 Band Carrier Aggregation (4DL1UL) of Band 39, Band 39, Band 41 and Band 41 | 66d? | 2015-09-15 A | 2015-12-15 A | 100% | finish no earlier than 2015-12-15 | R4 | 528h | 528h | LTE_CA_B39_B39_B41_B41-Perf | 35 | CMCC | Rel-13 | 69 |  |

Notes:
- 5056: 29/09/15: Compl:0%->40% 29/09/15: WID: RP-150627->RP-151562 29/09/15: Stat Rep: ->RP-151131
- 5057: 29/09/15: Compl:0%->40% 29/09/15: WID: RP-150627->RP-151562 29/09/15: Stat Rep: ->RP-151131
- 5059: 1/1/16: Compl:0%->100%
- 5060: ¦1/1/16: Compl:0%->100%
- 5062: ¦1/1/16: Compl:0%->100%
- 5063: 1/1/16: Compl:0%->100%
- 5065: 1/1/16: Compl:0%->100%
- 5066: 1/1/16: Compl:0%->100%
- 5068: 1/1/16: Compl:0%->100%
- 5069: ¦1/1/16: Compl:0%->100%
- 5071: ¦1/1/16: Compl:0%->100%
- 5072: 1/1/16: Compl:0%->100%

| ID | WBS | Task | Duration | Start | Finish | Complete | Constraint | Resources | Work | Actual work | Acronym | PCG approved | WI rapporteur name | Release | TSG approved | Impacted TSs and TRs |
| --- | --- | --- | --- | --- | --- | --- | --- | --- | --- | --- | --- | --- | --- | --- | --- | --- |
| 5079 | 1814.118 | **LTE Advanced 4 Band Carrier Aggregation (4DL/1UL) of Band 1, Band 3, Band 8 and Band 40** | 95.25d? | 2015-09-15 A | 2015-12-15 A | 100% |  | R4 | 1584h | 1584h | LTE_CA_B1_B3_B8_B40 | 35 | KT | Rel-13 | 69 |  |
| 5080 | 1814.118.1 | Core part:LTE Advanced 4 Band Carrier Aggregation (4DL/1UL) of Band 1, Band 3, Band 8 and Band 40 | 66d? | 2015-09-15 A | 2015-12-15 A | 100% | finish no earlier than 2015-12-15 | R4 | 528h | 528h | LTE_CA_B1_B3_B8_B40-Core | 35 | KT | Rel-13 | 69 |  |
| 5081 | 1814.118.2 | Perf. part:LTE Advanced 4 Band Carrier Aggregation (4DL/1UL) of Band 1, Band 3, Band 8 and Band 40 | 66d? | 2015-09-15 A | 2015-12-15 A | 100% | finish no earlier than 2015-12-15 | R4 | 528h | 528h | LTE_CA_B1_B3_B8_B40-Perf | 35 | KT | Rel-13 | 69 |  |
| 5082 | 1814.119 | **LTE Advanced 4 Band Carrier Aggregation (4DL/1UL) for Band 3, Band 28, Band 40 and Band 40** | 95.25d? | 2015-09-15 A | 2015-12-15 A | 100% |  | R4 | 1584h | 1584h | LTE_CA_B3_B28_B40_B40 | 35 | Huawei | Rel-13 | 69 |  |
| 5083 | 1814.119.1 | Core part:LTE Advanced 4 Band Carrier Aggregation (4DL/1UL) for Band 3, Band 28, Band 40 and Band 40 | 66d? | 2015-09-15 A | 2015-12-15 A | 100% | finish no earlier than 2015-12-15 | R4 | 528h | 528h | LTE_CA_B3_B28_B40_B40-Core | 35 | Huawei | Rel-13 | 69 |  |
| 5084 | 1814.119.2 | Perf. part:LTE Advanced 4 Band Carrier Aggregation (4DL/1UL) for Band 3, Band 28, Band 40 and Band 40 | 66d? | 2015-09-15 A | 2015-12-15 A | 100% | finish no earlier than 2015-12-15 | R4 | 528h | 528h | LTE_CA_B3_B28_B40_B40-Perf | 35 | Huawei | Rel-13 | 69 |  |
| 5085 | 1814.120 | **LTE Advanced 4 Band Carrier Aggregation (4DL/1UL) for Band 28, Band 40, Band 40 and Band 40** | 95.25d? | 2015-09-15 A | 2015-12-15 A | 100% |  | R4 | 1584h | 1584h | LTE_CA_B28_B40_B40_B40 | 35 | Huawei | Rel-13 | 69 |  |
| 5086 | 1814.120.1 | Core part:LTE Advanced 4 Band Carrier Aggregation (4DL/1UL) for Band 28, Band 40, Band 40 and Band 40 | 66d? | 2015-09-15 A | 2015-12-15 A | 100% | finish no earlier than 2015-12-15 | R4 | 528h | 528h | LTE_CA_B28_B40_B40_B40-Core | 35 | Huawei | Rel-13 | 69 |  |
| 5087 | 1814.120.2 | Perf. part:LTE Advanced 4 Band Carrier Aggregation (4DL/1UL) for Band 28, Band 40, Band 40 and Band 40 | 66d? | 2015-09-15 A | 2015-12-15 A | 100% | finish no earlier than 2015-12-15 | R4 | 528h | 528h | LTE_CA_B28_B40_B40_B40-Perf | 35 | Huawei | Rel-13 | 69 |  |
| 5088 | 1814.121 | **LTE Advanced 4 Band Carrier Aggregation (4DL/1UL) of Band 3, Band 7, Band 7 and Band 28** | 95.25d? | 2015-09-15 A | 2015-12-15 A | 100% |  | R4 | 1584h | 1584h | LTE_CA_B3_B7_B7_B28 | 35 | Telstra | Rel-13 | 69 |  |
| 5089 | 1814.121.1 | Core part:LTE Advanced 4 Band Carrier Aggregation (4DL/1UL) of Band 3, Band 7, Band 7 and Band 28 | 66d? | 2015-09-15 A | 2015-12-15 A | 100% | finish no earlier than 2015-12-15 | R4 | 528h | 528h | LTE_CA_B3_B7_B7_B28-Core | 35 | Telstra | Rel-13 | 69 |  |
| 5090 | 1814.121.2 | Perf. part:LTE Advanced 4 Band Carrier Aggregation (4DL/1UL) of Band 3, Band 7, Band 7 and Band 28 | 66d? | 2015-09-15 A | 2015-12-15 A | 100% | finish no earlier than 2015-12-15 | R4 | 528h | 528h | LTE_CA_B3_B7_B7_B28-Perf | 35 | Telstra | Rel-13 | 69 |  |
| 5091 | 1814.122 | **LTE Advanced 5 Band Carrier Aggregation (5DL/1UL) of Band 1, Band 3, Band 19, Band 42 and Band 42** | 95.25d? | 2015-09-15 A | 2015-12-15 A | 100% |  | R4 | 1584h | 1584h | LTE_CA_B1_B3_B19_B42_B42 | 35 | NTT DOCOMO | Rel-13 | 69 | 36.857-13 |
| 5092 | 1814.122.1 | Core part:LTE Advanced 5 Band Carrier Aggregation (5DL/1UL) of Band 1, Band 3, Band 19, Band 42 and Band 42 | 66d? | 2015-09-15 A | 2015-12-15 A | 100% | finish no earlier than 2015-12-15 | R4 | 528h | 528h | LTE_CA_B1_B3_B19_B42_B42-Core | 35 | NTT DOCOMO | Rel-13 | 69 | 36.857-13 |
| 5093 | 1814.122.2 | Perf. part:LTE Advanced 5 Band Carrier Aggregation (5DL/1UL) of Band 1, Band 3, Band 19, Band 42 and Band 42 | 66d? | 2015-09-15 A | 2015-12-15 A | 100% | finish no earlier than 2015-12-15 | R4 | 528h | 528h | LTE_CA_B1_B3_B19_B42_B42-Perf | 35 | NTT DOCOMO | Rel-13 | 69 | 36.857-13 |
| 5094 | 1814.123 | **LTE Advanced 5 Band Carrier Aggregation (5DL/1UL) of Band 1, Band 19, Band 21, Band 42 and Band 42** | 95.25d? | 2015-09-15 A | 2015-12-15 A | 100% |  | R4 | 1584h | 1584h | LTE_CA_B1_B19_B21_B42_B42 | 35 | NTT DOCOMO | Rel-13 | 69 |  |
| 5095 | 1814.123.1 | Core part:LTE Advanced 5 Band Carrier Aggregation (5DL/1UL) of Band 1, Band 19, Band 21, Band 42 and Band 42 | 66d? | 2015-09-15 A | 2015-12-15 A | 100% | finish no earlier than 2015-12-15 | R4 | 528h | 528h | LTE_CA_B1_B19_B21_B42_B42-Core | 35 | NTT DOCOMO | Rel-13 | 69 |  |
| 5096 | 1814.123.2 | Perf. part:LTE Advanced 5 Band Carrier Aggregation (5DL/1UL) of Band 1, Band 19, Band 21, Band 42 and Band 42 | 66d? | 2015-09-15 A | 2015-12-15 A | 100% | finish no earlier than 2015-12-15 | R4 | 528h | 528h | LTE_CA_B1_B19_B21_B42_B42-Perf | 35 | NTT DOCOMO | Rel-13 | 69 |  |
| 5097 | 1814.124 | **LTE Advanced 5 Band Carrier Aggregation (5DL/1UL) of Band 1, Band 3, Band 7, Band 7 and Band 28** | 189.5d? | 2015-09-15 A | 2016-03-15 A | 100% |  | R4 | 3144h | 3144h | LTE_CA_B1_B3_B7_B7_B28 | 35 | Telstra | Rel-13 | 69 |  |
| 5098 | 1814.124.1 | Core part:LTE Advanced 5 Band Carrier Aggregation (5DL/1UL) of Band 1, Band 3, Band 7, Band 7 and Band 28 | 131d? | 2015-09-15 A | 2016-03-15 A | 100% | finish no earlier than 2016-03-15 | R4 | 1048h | 1048h | LTE_CA_B1_B3_B7_B7_B28-Core | 35 | Telstra | Rel-13 | 69 |  |
| 5099 | 1814.124.2 | Perf. part:LTE Advanced 5 Band Carrier Aggregation (5DL/1UL) of Band 1, Band 3, Band 7, Band 7 and Band 28 | 131d? | 2015-09-15 A | 2016-03-15 A | 100% | finish no earlier than 2016-03-15 | R4 | 1048h | 1048h | LTE_CA_B1_B3_B7_B7_B28-Perf | 35 | Telstra | Rel-13 | 69 |  |
| 5100 | 1814.125 | **LTE Advanced 5 Band Carrier Aggregation (5DL/1UL) of Band 3, Band 3, Band 7, Band 7 and Band 28** | 189.5d? | 2015-09-15 A | 2016-03-15 A | 100% |  | R4 | 3144h | 3144h | LTE_CA_B3_B3_B7_B7_B28 | 35 | Telstra | Rel-13 | 69 |  |
| 5101 | 1814.125.1 | Core part:LTE Advanced 5 Band Carrier Aggregation (5DL/1UL) of Band 3, Band 3, Band 7, Band 7 and Band 28 | 131d? | 2015-09-15 A | 2016-03-15 A | 100% | finish no earlier than 2016-03-15 | R4 | 1048h | 1048h | LTE_CA_B3_B3_B7_B7_B28-Core | 35 | Telstra | Rel-13 | 69 |  |
| 5102 | 1814.125.2 | Perf. part:LTE Advanced 5 Band Carrier Aggregation (5DL/1UL) of Band 3, Band 3, Band 7, Band 7 and Band 28 | 131d? | 2015-09-15 A | 2016-03-15 A | 100% | finish no earlier than 2016-03-15 | R4 | 1048h | 1048h | LTE_CA_B3_B3_B7_B7_B28-Perf | 35 | Telstra | Rel-13 | 69 |  |

Notes:
- 5080: ¦1/1
- 5081: 1
- 5098: ¦22/3/16: Compl:95%->100%;
- 5099: 22/3/16: Compl:95%->100%;
- 5101: 22/3/16: Compl:95%->100%
- 5102: ¦22/3/16: Compl:95%->100%

| ID | WBS | Task | Duration | Start | Finish | Complete | Baseline start | Baseline finish | Baseline duration | Constraint | Resources | Work | Actual work | Acronym | PCG approved | WI rapporteur name | Release | TSG approved | Impacted TSs and TRs | Status Report | WI rapporteur e-mail | Acronym_3GU_Export | Special Focus Doc | MCC resp |
| --- | --- | --- | --- | --- | --- | --- | --- | --- | --- | --- | --- | --- | --- | --- | --- | --- | --- | --- | --- | --- | --- | --- | --- | --- |
| 5103 | 1814.126 | **LTE Advanced 3 Band Carrier Aggregation (3DL/3UL) of Band 39, Band 41 and Band 41** | 95.25d? | 2015-09-15 A | 2015-12-15 A | 100% |  |  |  |  | R4 | 1584h | 1584h | LTE_CA_3DL3UL_B39_B41_B41 | 35 | CATT | Rel-13 | 69 |  |  |  |  |  |  |
| 5104 | 1814.126.1 | Core part:LTE Advanced 3 Band Carrier Aggregation (3DL/3UL) of Band 39, Band 41 and Band 41 | 66d? | 2015-09-15 A | 2015-12-15 A | 100% |  |  |  | finish no earlier than 2015-12-15 | R4 | 528h | 528h | LTE_CA_3DL3UL_B39_B41_B41-Core | 35 | CATT | Rel-13 | 69 |  |  |  |  |  |  |
| 5105 | 1814.126.2 | Perf. part:LTE Advanced 3 Band Carrier Aggregation (3DL/3UL) of Band 39, Band 41 and Band 41 | 66d? | 2015-09-15 A | 2015-12-15 A | 100% |  |  |  | finish no earlier than 2015-12-15 | R4 | 528h | 528h | LTE_CA_3DL3UL_B39_B41_B41-Perf | 35 | CATT | Rel-13 | 69 |  |  |  |  |  |  |
| 5106 | 1814.127 | **LTE Advanced 3 Band Carrier Aggregation (3DL/3UL) of Band 39, Band 39 and Band 41** | 95.25d? | 2015-09-15 A | 2015-12-15 A | 100% |  |  |  |  | R4 | 1584h | 1584h | LTE_CA_3DL3UL_B39_B39_B41 | 35 | CATT | Rel-13 | 69 | 36.899-13 |  |  |  |  |  |
| 5107 | 1814.127.1 | Core part:LTE Advanced 3 Band Carrier Aggregation (3DL/3UL) of Band 39, Band 39 and Band 41 | 66d? | 2015-09-15 A | 2015-12-15 A | 100% |  |  |  | finish no earlier than 2015-12-15 | R4 | 528h | 528h | LTE_CA_3DL3UL_B39_B39_B41-Core | 35 | CATT | Rel-13 | 69 |  |  |  |  |  |  |
| 5108 | 1814.127.2 | Perf. part:LTE Advanced 3 Band Carrier Aggregation (3DL/3UL) of Band 39, Band 39 and Band 41 | 66d? | 2015-09-15 A | 2015-12-15 A | 100% |  |  |  | finish no earlier than 2015-12-15 | R4 | 528h | 528h | LTE_CA_3DL3UL_B39_B39_B41-Perf | 35 | CATT | Rel-13 | 69 |  |  |  |  |  |  |
| 5109 | 1814.128 | **Additional bandwidth combination set for LTE Advanced intra-band non-contiguous Carrier Aggregation in Band 7** | 95.25d? | 2015-09-15 A | 2015-12-15 A | 100% |  |  |  |  | R4 | 1584h | 1584h | LTE_CA_NC_B7_BWset | 35 | Huawei | Rel-13 | 69 |  |  |  |  |  |  |
| 5110 | 1814.128.1 | Core part: Additional bandwidth combination set for LTE Advanced intra-band non-contiguous Carrier Aggregation in Band 7 | 66d? | 2015-09-15 A | 2015-12-15 A | 100% |  |  |  | finish no earlier than 2015-12-15 | R4 | 528h | 528h | LTE_CA_NC_B7_BWset-Core | 35 | Huawei | Rel-13 | 69 |  |  |  |  |  |  |
| 5111 | 1814.128.2 | Perf. part: Additional bandwidth combination set for LTE Advanced intra-band non-contiguous Carrier Aggregation in Band 7 | 66d? | 2015-09-15 A | 2015-12-15 A | 100% |  |  |  | finish no earlier than 2015-12-15 | R4 | 528h | 528h | LTE_CA_NC_B7_BWset-Perf | 35 | Huawei | Rel-13 | 69 |  |  |  |  |  |  |
| 5112 | 1814.129 | UE Conformance Test Aspects - Rel-13 LTE CA configurations | 785d? | 2015-12-15 A | 2018-12-14 A | 100% |  |  |  | finish no earlier than 2018-12-15 | R5 | 6280h | 6280h | LTE_CA_Rel13-UEConTest | 36 | Ericsson | Rel-13 | 70 |  |  |  |  |  |  |
| 5113 | 1815 | (Small) Technical Enhancements and Improvements for Rel-13 | 593d? | 2013-09-18 A | 2015-12-21 A | 100% |  |  |  | finish no earlier than 2015-12-21 | SP; CP; RP; GP | 18976h | 18976h | TEI13 | 31 |  | Rel-13 | 61 |  | PCG-31 |  |  |  |  |
| 5114 | 1816 | (Small) Test Technical Enhancements and Improvements for Rel-13 | 593d? | 2013-09-18 A | 2015-12-21 A | 100% |  |  |  | finish no earlier than 2015-12-21 | SP; CP; RP; GP | 18976h | 18976h | TEI13_Test | 31 |  | Rel-13 | 61 |  | PCG-31 |  |  |  |  |
| 5115 | 1817 | Awaiting formal work item | 593d? | 2013-09-18 A | 2015-12-21 A | 100% |  |  |  | start no earlier than 2013-09-18 | SP; CP; RP; GP | 18976h | 18976h | DUMMY | 35 |  | Rel-13 | 69 |  |  |  |  |  |  |
| 5116 | 1818 | (Small) Security Enhancements and Improvements for Rel-13 | 2372d? | 2006-12-12 A | 2015-12-21 A | 100% |  |  |  | finish no earlier than 2015-12-21 | S3 | 18976h | 18976h | SEC13 | 31 |  | Rel-13 | 61 |  | PCG-31 |  |  |  |  |
| 5117 | 1819 | Release 13 IoT related Studies | 602d? | 2013-09-12 A | 2015-12-25 A | 100% | 2014-07-31 | 2015-12-25 | 366.5d? | start no earlier than 2013-09-12 | SP; R2 | 9632h | 9632h |  |  |  | Rel-13 |  |  |  |  |  |  |  |
| 5118 | 1820 | Study on Power saving for Machine-Type Communications (MTC) devices | 266.6d? | 2014-08-12 A | 2015-08-14 A | 100% | 2014-06-18 | 2015-02-20 | 160.5d? | finish no earlier than 2015-08-14 | G2; G1 | 4000.8h | 4000.8h | FS_uPoD | 32 | China Mobile | Rel-13 | 60 | 43.869 |  | Jing Han (hanjing@chinamobile.com) | FS_uPoD |  |  |
| 5119 | 1821 | Study on Cellular system support for ultra Low Complexity and low throughput Internet of Things | 329d? | 2014-05-30 A | 2015-08-28 A | 100% | 2015-01-14 | 2015-08-28 | 163d? | finish no earlier than 2015-08-28 | G1; G2 | 5264h | 5264h | FS_IoT_LC | 33 | Vodafone | Rel-13 | 66 | 45.8xy |  | chris.pudney@vodafone.com | FS_IoT_LC | MTC, M2M |  |
| 5120 | 1822 | Study on architecture enhancements of cellular systems for ultra low complexity and low throughput Internet of Things | 196d? | 2015-03-13 A | 2015-12-11 A | 100% |  |  |  | finish no earlier than 2015-12-11 | S2 | 1568h | 1568h | FS_AE_CIoT | 34 | puneet.jain@intel.com | Rel-13 | 67 | New 23.8xx |  | puneet.jain@intel.com |  |  |  |
| 5121 | 1823 | Study on Battery Efficient Security for very low Throughput Machine Type Communication Devices | 196d? | 2015-03-13 A | 2015-12-11 A | 100% |  |  |  | finish no earlier than 2015-12-11 | S3 | 1568h | 1568h | FS_BEST_MTC_Sec | 34 | Barry, Aguibou, VODAFONE Group Plc | Rel-13 | 67 | 32.863; 33.163 |  | Barry, Aguibou, VODAFONE Group Plc |  |  |  |
| 5122 | 1824 | Study on Small data transmission enhancements for UMTS | 197d? | 2014-09-16 A | 2015-06-15 A | 100% |  |  |  | finish no earlier than 2015-06-15 | R1; R3 | 3152h | 3152h | FS_UTRA_SDATA | 33 | Ericsson | Rel-13 | 65 | 25.705 | RP-150843 | gerardo.agni.medina.acosta@ericsson.com | FS_UTRA_SDATA |  |  |
| 5123 | 1825 | Study on Application specific Congestion control for Data Communication | 531.29d? | 2012-09-17 A | 2014-09-17 A | 100% | 2012-09-13 | 2014-09-17 | 532d? | finish no earlier than 2014-09-17 | S1 | 4250.28h | 4250.28h | FS_ACDC | 29 | NTT DOCOMO | Rel-13 | 57 | 22.806 | S1-143305 | Atsushi Minokuchi (minokuchi@nttdocomo.co.jp) | FS_ACDC |  | Alain |
| 5124 | 1826 | Study on enhancements for Infrastructure based data Communication Between Devices | 266d? | 2013-09-14 A | 2014-09-17 A | 100% | 2013-09-12 | 2014-09-17 | 266d? | finish no earlier than 2014-09-17 | S1 | 2128h | 2128h | FS_eICBD | 31 | KPN | Rel-13 | 61 | 22.807 | S1-143309 | toon.norp@tno.nl | FS_eICBD | MTC, M2M | Alain |
| 5125 | 1827 | Release 13 other Studies | 602d? | 2013-09-12 A | 2015-12-25 A | 100% | 2014-07-31 | 2015-12-25 | 366.5d? | start no earlier than 2013-09-12 | SP; R2 | 9632h | 9632h |  |  |  | Rel-13 |  |  |  |  |  |  |  |
| 5126 | 1828 | Study on Isolated E-UTRAN Operation for Public Safety | 261d? | 2013-06-25 A | 2014-06-18 A | 100% | 2013-06-21 | 2014-06-18 | 262d? | finish no earlier than 2014-06-18 | S1 | 2088h | 2088h | FS_IOPS | 31 | General Dynamics | Rel-13 | 60 | 22.897 |  | paul.piggin@gd-broadband.com | FS_IOPS | Public Safety (A-A) | Alain |
| 5127 | 1829 | Study on architecture enhancements for Public Safety | 131d? | 2014-12-12 A | 2015-06-12 A | 100% |  |  |  | finish no earlier than 2015-06-12 | S2 | 1048h | 1048h | FS_IOPS_St2 | 34 |  | Rel-13 | 66 |  |  | phil.young@gd-broadband.com |  |  |  |
| 5128 | 1830 | Study on Security Aspects of Isolated E-UTRAN Operation for Public Safety | 137d? | 2015-03-12 A | 2015-09-18 A | 100% |  |  |  | finish no earlier than 2015-09-18 | S3 | 1096h | 1096h | FS_IOPS_Sec | 34 | Paul Piggin, General Dynamics UK | Rel-13 | 67 | New 33.897 |  | paul.piggin@gd-broadband.com |  |  |  |
| 5129 | 1831 | (SA66: on hold) Study on Co-ordinated packet data network gateway (P-GW) change for SIPTO | 201d? | 2013-09-13 A | 2014-06-18 A | 100% | 2013-09-12 | 2014-06-18 | 202d? | finish no earlier than 2014-06-18 | S1 | 1608h | 1608h | FS_CSIPTO | 31 | Intel | Rel-13 | 61 | 22.828 |  | Eric.siow@intel.com | FS_CSIPTO |  | Alain |
| 5130 | 1832 | Study on Flexible Mobile Service Steering | 201d? | 2013-12-13 A | 2014-09-17 A | 100% | 2013-12-11 | 2014-09-17 | 202d? | finish no earlier than 2014-09-17 | S1 | 1608h | 1608h | FS_FMSS | 32 | China Mobile | Rel-13 | 62 | 22.808 | S1-143310 | Lu Lu (lulu@chinamobile.com) | FS_FMSS |  | Alain |
| 5131 | 1833 | Study on Enhanced Calling Information Presentation | 201d? | 2013-12-13 A | 2014-09-17 A | 100% | 2013-12-11 | 2014-09-17 | 201d? | finish no earlier than 2014-09-17 | S1 | 1608h | 1608h | FS_ECIP | 32 | China Mobile | Rel-13 | 62 | 22.810 | S1-143311 | LI Xiaofan (lixiaofan@chinamobile.com | FS_ECIP |  | Alain |
| 5132 | 1834 | Study on RAN Sharing Enhancements on GERAN and UTRAN | 140d? | 2014-03-07 A | 2014-09-17 A | 100% | 2014-03-07 | 2014-09-17 | 139d? | finish no earlier than 2014-09-17 | S1 | 1120h | 1120h | FS_GUSH | 32 | Telefónica | Rel-13 | 63 | 22.852 updates |  | chris.friel@telefonica.com | FS_GUSH |  | Alain |

Notes:
- 5103: TDD case
- 5104: TDD case
- 5105: TDD case
- 5106: TDD case¦5/10/15: 36.899-13 added;
- 5107: TDD case
- 5108: TDD case
- 5109: LTE_CA_NC_B7 was completed in REL-12
- 5110: LTE_CA_NC_B7 was completed in REL-12 ¦
- 5111: LTE_CA_NC_B7 was completed in REL-12 ¦
- 5112: ¦22/3/16: Compl:0%->5%;1/7/16: Compl:5%->22%26/9/16: Compl:22%->¦2 21/3/17: Compl:39% ;; 14/1/20: 62%->100
- 5113: -
- 5114: Created upon demand of RAN5
- 5116: -
- 5117: -
- 5118: GP#65 completion 02/15=>05/15. GP#60 approved WID. Linked to Rel-12 Feature MTCe, Stage 2 BB3: UE Power Consumptions Optimizations (UEPCOP). Dec.14: 30->40%¦June2015: Compl:40%->75¦07/09/15: 75%->100
- 5119: GP#62 approved WID. Dec.14: 15->40%¦June2015: Compl:40%->75¦07/09/15: 75%->100¦14/09/15: WID:GP-140421->GP-150354
- 5120: 07/09/15: 0%->20¦07/09/15: 20%->65¦7/12/15: 65%->95¦7/3/16: 95%->100
- 5121: TR number added¦June2015: Compl:0%->10¦7/12/15: 10%->50¦11/12/15: 50%->75¦7/3/16: 75%->95¦19/9/16: 95%->100¦6/10/16: 33.163 added;
- 5122: 3/3/15: WID: RP-141861¦Stat Rep: -->RP-141859. Impacted TR number added. 1st Apr 15: Compl:30%->55% 1st Apr 15: Stat Rep: RP-141859->RP-150196 03/07/15: Compl:55%->100% 03/07/15: Stat Rep: RP-150196->RP-150843
- 5123: SP#65 completed. SP#64 TR 22.806v200 for Approval. ACDC is applicable to UTRAN and E-UTRAN. Possible overlap with RAN2 TR 36.848 Study on smart congestion mitigation in E-UTRAN (prioritising MMTEL voice over other traffic during congestion)
- 5124: SP#65 completed. TR 22.807v200 for Approval
- 5125: -
- 5126: SP#64 completed. TR 22.897v200 for Approval. Linked to Rel-12 TR 22.803 (FS_ProSe) and FeaturES in CP-150ProSe, GCSE_LTE
- 5127: June2015: Compl:0%->100
- 5128: TR added¦June2015: Compl:0%->30¦7/12/15: 30%->100
- 5129: SP#64 completed. TR 22.828v200 for Approval. Linked to FeaturES in CP-150Rel-10 LIPA_SIPTO & Rel-12 LIMONET
- 5130: SP#65 completed. TR 22.808v200 for Approval. Study supporting traffic classification and service chain selection capabilities per operators policy in order to realize efficient and flexible mobile service steering in the Gi-LAN network
- 5131: SP#65 completed. TR 22.810v200 for Approval. Linked to Multimedia Telephony Service for IMS (UID_7038), Customized Alerting Tone (CAT) UID_370028, Customized Ringing Signal (CRS) UID_380067
- 5132: SP#65 completed. Update on GERAN and UTRAN of Rel-12 TR 22.852 Study on RAN Sharing Enhancements (FS_RSE)

| ID | WBS | Task | Duration | Start | Finish | Complete | Baseline start | Baseline finish | Baseline duration | Total slack | Constraint | Resources | Work | Actual work | Acronym | PCG approved | WI rapporteur name | Release | TSG approved | MCC resp | Acronym_3GU_Export | PCG stopped | TSG stopped | Special Focus Doc | Status Report |
| --- | --- | --- | --- | --- | --- | --- | --- | --- | --- | --- | --- | --- | --- | --- | --- | --- | --- | --- | --- | --- | --- | --- | --- | --- | --- |
| 5133 | 1835 | **Study on Usage Monitoring Enhancements for Service, Application and Subscriber Group** | 1327.75d? | 2011-06-08 A | 2014-12-12 A | 100% | 2011-06-08 | 2014-12-10 | 929d? |  |  | S2 | 13978.1h | 13978.1h | FS_UMONC_sas | 27 | China Telecom | Rel-13 | 52 | Maurice | FS_UMONC_sas |  |  |  |  |
| 5134 | 1835.1 | Deleted - SA1 part of Study on Usage Monitoring Control PCC Enhancement | 392d? | 2011-06-08 A | 2012-06-20 A | 100% | 2011-06-08 | 2012-06-20 | 275d? |  | finish no earlier than 2012-06-20 | S1 | 2200h | 2200h |  | 27 | ZTE |  | 52 | Maurice | FS_UMONC | PCG-31 | SP-58 |  |  |
| 5135 | 1835.2 | SA2 part of Study on Usage Monitoring Control PCC Enhancement | 397.26d? | 2013-06-14 A | 2014-12-12 A | 100% | 2013-06-02 | 2014-12-10 | 403d? |  | finish no earlier than 2014-12-12 | S2 | 3178.08h | 3178.08h | FS_UMONC_sas | 27 | China Telecom | Rel-13 | 52 | Maurice |  |  |  |  |  |
| 5136 | 1835.3 | Deleted - SA5 part of Study on Usage Monitoring Control enhancement | 201.75d? | 2012-03-02 A | 2012-09-12 A | 100% | 2012-03-02 | 2012-09-12 | 141d? |  | finish no earlier than 2012-09-12 | S5 | 1128h | 1128h |  | 27 | Huawei |  | 52 | Mirko |  | PCG-29 | SP-57 |  |  |
| 5137 | 1836 | Study on Security aspects of Integration of Single Sign-On (SSO) frameworks with 3GPP networks | 1180d? | 2010-12-28 A | 2015-06-12 A | 100% | 2010-12-16 | 2014-09-17 | 988d? |  | finish no earlier than 2015-06-12 | S3 | 9440h | 9440h | FS_SSO_Int_Sec | 26 | Ericsson | Rel-13 | 50 | Mirko | FS_SSO_Int_Sec |  |  |  |  |
| 5138 | 1837 | Study on Subscriber Privacy Impact in 3GPP | 591d? | 2013-09-17 A | 2015-12-16 A | 100% | 2013-09-12 | 2014-09-17 | 266d? |  | finish no earlier than 2015-12-16 | S3 | 4728h | 4728h | FS_SPI | 31 | China Unicom | Rel-13 | 61 | Mirko | FS_SPI |  |  |  |  |
| 5139 | 1838 | Study on Enhancements of OAM aspects of Distributed Mobility Load Balancing (MLB) SON function | 458d? | 2014-09-15 A | 2016-06-13 A | 100% | 2013-09-12 | 2014-12-10 | 326d? |  | finish no earlier than 2016-06-13 | S5 | 3664h | 3664h | FS_D_MLB_SON_OAM | 31 | Cisco | Rel-13 | 61 | Mirko | FS_D_MLB_SON_OAM |  |  | SON |  |
| 5140 | 1839 | Study on Application and Partitioning of Itf-N | 458d? | 2013-12-17 A | 2015-09-11 A | 100% | 2013-12-11 | 2014-12-10 | 261d? |  | finish no earlier than 2015-09-11 | S5 | 3664h | 3664h | FS_OAM_AP_Itf-N | 32 | China Mobile | Rel-13 | 62 | Mirko | FS_OAM_AP_Itf-N |  |  |  |  |
| 5141 | 1840 | Study on Charging aspects on Roaming End-to-end scenarios with VoLTE IMS and interconnecting networks | 393d? | 2013-12-17 A | 2015-06-12 A | 100% | 2013-12-11 | 2014-12-10 | 261d? |  | finish no earlier than 2015-06-12 | S5 | 3144h | 3144h | FS_REVOLTE_IMS_CH | 32 | Deutsche Telekom | Rel-13 | 62 | Mirko | FS_REVOLTE_IMS_CH |  |  |  |  |
| 5142 | 1841 | Study on Network Management of Virtualized Networks | 269d? | 2014-06-11 A | 2015-06-17 A | 100% | 2014-06-06 | 2015-06-17 | 269d? |  | finish no earlier than 2015-06-17 | S5 | 2152h | 2152h | FS_OAM_VIRNET | 33 | China Mobile, Huawei | Rel-13 | 64 |  | FS_OAM_VIRNET |  |  |  |  |
| 5143 | 1842 | Study on Review of dedicated 3GPP UICC features | 729d? | 2013-03-13 A | 2015-12-16 A | 100% | 2013-03-04 | 2014-09-12 | 401d? |  | finish no earlier than 2015-12-16 | C6 | 5832h | 5832h | FS_Red_UCe | 30 | BlackBerry | Rel-13 | 59 | Xavier | FS_Red_UCe |  |  |  |  |
| 5144 | 1843 | Study on Solutions for GSM/EDGE BTS Energy Saving | 458.8d? | 2011-08-30 A | 2015-11-20 A | 100% | 2009-03-10 | 2014-08-29 | 557d? |  | finish no earlier than 2015-11-20 | G1; G2 | 3670.4h | 3670.4h | FS_Energy_BTS | 25 | Nokia Networks | Rel-13 | 47 | Paolo | FS_Energy_BTS |  |  |  |  |
| 5145 | 1844 | Study on Downlink MIMO | 459d? | 2014-08-14 A | 2016-05-12 A | 100% | 2013-08-20 | 2015-02-20 | 396d? |  | finish no earlier than 2016-05-12 | G1; G2 | 4004.8h | 4004.8h | FS_DOMIMO | 30 | Nokia Networks | Rel-13 | 57 | Paolo | FS_DOMIMO |  |  |  |  |
| 5146 | 1845 | Study on MIMO OTA antenna test function for LTE | 462d? | 2013-03-18 A | 2014-12-15 A | 100% | 2013-03-15 | 2014-12-05 | 456d? |  | finish no earlier than 2014-12-15 | R4 | 3696h | 3696h | FS_LTE_MIMO_OTA_ATF | 33 | Keysight | Rel-13 | 64 |  | FS_LTE_MIMO_OTA_ATF |  |  |  | RP-142045 |
| 5147 | 1846 | Stopped at 20% - Study on UpLink MultiUser Multiple-Input Multiple-Output (UL MU-MIMO) | 481.6d? | 2014-04-17 A | 2016-02-19 A | 100% | 2014-04-17 | 2015-02-20 | 195.5d? |  | finish no earlier than 2016-02-19 | G1; G2 | 5688h | 5688h | FS_UL_MU_MIMO | 32 | Huawei | Rel-13 | 60 |  | FS_UL_MU_MIMO |  | SP#71 |  |  |
| 5148 | 1847 | Study on LTE FDD in the bands 1980-2010 MHz and 2170-2200 MHz | 854d? | 2012-09-11 A | 2015-12-15 A | 100% | 2012-09-11 | 2014-09-12 | 527d? |  | finish no earlier than 2015-12-15 | R4 | 6832h | 6832h | FS_LTE_1980_2170_Korea | 29 | KT | Rel-13 | 57 | Issam | FS_LTE_1980_2170_Korea |  |  |  | RP-151274 |
| 5149 | 1848 | Study on Positioning enhancements for E-UTRA | 524d? | 2012-05-01 A | 2014-12-15 A | 100% | 2013-04-25 | 2014-12-05 | 256d? |  | finish no earlier than 2014-12-15 | R4 | 4192h | 4192h | FS_LCSenh_LTE | 31 | Huawei | Rel-13 | 60 | Issam | FS_LCSenh_LTE |  |  |  | RP-142224 |
| 5150 | 1849 | Study on Multi-RAT joint coordination | 397d? | 2013-12-06 A | 2015-06-15 A | 100% | 2013-12-06 | 2014-12-05 | 261d? |  | finish no earlier than 2015-06-15 | R4 | 3176h | 3176h | FS_MultiRAT_JC | 32 | China Mobile | Rel-13 | 62 | Juha | FS_MultiRAT_JC |  |  | WLAN | RP-150807 |
| 5151 | 1850 | Study on Advanced Wireless Services (AWS) - Extension band for LTE | 265d? | 2013-12-16 A | 2014-12-15 A | 100% | 2013-12-09 | 2014-12-05 | 261d? |  | finish no earlier than 2014-12-15 | R4 | 2120h | 2120h | FS_LTE_AWS_EXT | 33 | Qualcomm | Rel-13 | 64 |  | FS_LTE_AWS_EXT |  |  |  | RP-141968 |
| 5152 | 1851 | Study on Indoor Positioning Enhancements for UTRA and LTE | 328d? | 2014-06-18 A | 2015-09-15 A | 100% | 2014-06-13 | 2015-09-17 | 330d? |  | finish no earlier than 2015-09-15 | R1; R4 | 5248h | 5248h | FS_UTRA_LTE_iPos_enh | 33 | NextNav | Rel-13 | 64 |  | FS_UTRA_LTE_iPos_enh |  |  |  | RP-151178 |
| 5153 | 1852 | Study on Downlink enhancements for UMTS | 199d? | 2014-09-12 A | 2015-06-15 A | 100% |  |  |  |  | finish no earlier than 2015-06-15 | R2; R1 | 3184h | 3184h | FS_UTRA_EDL | 33 | Huawei | Rel-13 | 65 |  | FS_UTRA_EDL |  |  |  | RP-150681 |
| 5154 | 1853 | Study on Elevation Beamforming/Full-Dimension (FD) MIMO for LTE | 199d? | 2014-09-12 A | 2015-06-15 A | 100% |  |  |  |  | finish no earlier than 2015-06-15 | R1 | 1592h | 1592h | FS_LTE_EBF_FDMIMO | 33 | Nokia Networks (DL), Samsung (UL) | Rel-13 | 65 |  | FS_LTE_EBF_FDMIMO |  |  |  | RP-150734 |
| 5155 | 1854 | Study on Licensed-Assisted Access using LTE | 197d? | 2014-09-16 A | 2015-06-15 A | 100% |  |  |  |  | finish no earlier than 2015-06-15 | R1; R2; R4 | 4728h | 4728h | FS_LTE_LAA | 33 | Ericsson, Huawei | Rel-13 | 65 |  | FS_LTE_LAA |  |  |  | RP-150624 |
| 5156 | 1855 | Study on EPC Signalling Improvement for Race Scenarios | 203d? | 2014-12-03 A | 2015-09-11 A | 100% |  |  |  |  | finish no earlier than 2015-09-11 | C4 | 1624h | 1624h | FS_EPC_SIG_RACE | 34 | Huawei | Rel-13 | 66 |  |  |  |  |  |  |
| 5157 | 1856 | Study on Video Enhancements in 3GPP Multimedia Services | 261d? | 2014-12-12 A | 2015-12-11 A | 100% |  |  |  |  | finish no earlier than 2015-12-11 | S4 | 2088h | 2088h | FS_VE_3MS | 34 | Ye-Kui Wang, Qualcomm Incorporated | Rel-13 | 66 |  |  |  |  |  |  |
| 5158 | 1857 | Study on possible additional configuration for LTE TDD | 197d? | 2014-12-15 A | 2015-09-15 A | 100% |  |  |  |  | finish no earlier than 2015-09-15 | R4 | 1576h | 1576h | FS_LTE_TDD_add_config | 34 | NTT DOCOMO, Hideaki Takahashi | Rel-13 | 66 |  |  |  |  |  | RP-151283 |
| 5159 | 1858 | Study on Network-Assisted Interference Cancellation and Suppression for UMTS | 197d? | 2014-12-15 A | 2015-09-15 A | 100% |  |  |  |  | finish no earlier than 2015-09-15 | R1 | 1576h | 1576h | FS_UTRA_NAICS | 34 | Huawei | Rel-13 | 66 |  |  |  |  |  | RP-151235 |
| 5160 | 1859 | Study on Enhanced Multiuser Transmissions and Network Assisted Interference Cancellation for LTE | 65d? | 2015-01-12 | 2015-03-15 |  |  |  |  | 41892.5d | finish no earlier than 2015-03-15 | R1 | 520h |  | FS_LTE_MUTX_NAIC | 34 | MediaTek | Rel-13 | 66 |  |  |  |  |  | RP-150213 |
| 5161 | 1860 | Study on Support of single-cell point-to-multipoint transmission in LTE | 131d? | 2014-12-15 A | 2015-06-15 A | 100% |  |  |  |  | finish no earlier than 2015-06-15 | R4 | 1048h | 1048h | FS_LTE_SC_PTM | 34 | Jeff GAO | Rel-13 | 66 |  |  |  |  |  | RP-150695 |
| 5162 | 1861 | Study on Extension of Dual Connectivity in E-UTRAN | 131d? | 2014-12-15 A | 2015-06-15 A | 100% |  |  |  |  | finish no earlier than 2015-06-15 | R3 | 1048h | 1048h | FS_LTE_dualC_ext | 34 | Samsung | Rel-13 | 66 |  |  |  |  |  | RP-150849 |
| 5163 | 1862 | Study on further enhancements of small cell higher layer aspects for LTE | 197d? | 2014-12-15 A | 2015-09-15 A | 100% |  |  |  |  | finish no earlier than 2015-09-15 | R3 | 1576h | 1576h | FS_LTE_SC_enh2_hilayer | 34 | Huawei | Rel-13 | 66 |  |  |  |  |  | RP-151243 |
| 5164 | 1863 | Study on RAN sharing enhancements for UMTS | 131d? | 2014-12-15 A | 2015-06-15 A | 100% |  |  |  |  | finish no earlier than 2015-06-15 | R3 | 1048h | 1048h | FS_RSE_UTRA_GUSH | 34 | Huawei | Rel-13 | 66 |  |  |  |  |  | RP-150684 |
| 5165 | 1864 | Study on LTE DL 4 Rx antenna ports | 65d? | 2014-12-15 A | 2015-03-13 A | 100% |  |  |  |  | finish no earlier than 2015-03-15 | R4 | 520h | 520h | FS_LTE_4Rx_AP_DL | 34 | Ericsson | Rel-13 | 66 |  |  |  |  |  | RP-150138 |
| 5166 | 1865 | Study on performance enhancements for high speed scenario in LTE | 262d? | 2014-12-15 A | 2015-12-15 A | 100% |  |  |  |  | finish no earlier than 2015-12-15 | R4 | 2096h | 2096h | FS_LTE_high_speed | 34 | NTTDoCoMo | Rel-13 | 66 |  |  |  |  |  | RP-151313 |
| 5167 | 1866 | Study on Enhanced Multiuser Transmissions and Network | 261d? | 2015-04-04 | 2015-12-11 |  |  |  |  | 41612d | finish no earlier than 2015-12-11 | R1 | 2088h |  | FS_MUIC_LTE | 34 | Pei-Kai Liao | Rel-13 | 67 |  |  |  |  |  |  |
| 5168 | 1867 | Study on regulatory aspects for flexible duplex for E-UTRAN | 133d? | 2016-06-15 A | 2016-12-15 A | 100% |  |  |  |  |  | RP | 1064h | 1064h | FS_LTE_flex_duplex_reg | 34 | LG Electronics Inc. | Rel-13 | 67 |  |  |  |  |  | RP-151307 |
| 5169 | 1868 | Study on Downlink Multiuser Superposition Transmission for LTE | 197d? | 2015-03-16 A | 2015-12-15 A | 100% |  |  |  |  | finish no earlier than 2015-12-15 | R1 | 1576h | 1576h | FS_LTE_MUST | 34 | Mediatek | Rel-13 | 67 |  |  |  |  |  | RP-151345 |
| 5170 | 1869 | Study on Measurement gap enhancement for LTE | 197d? | 2015-03-16 A | 2015-12-15 A | 100% |  |  |  |  | finish no earlier than 2015-12-15 | R4 | 1576h | 1576h | FS_LTE_meas_gap | 34 |  | Rel-13 | 67 |  |  |  |  |  | RP-151317 |
| 5171 | 1870 | Study on Phase 1 of the Support of Emergency services over WLAN | 71d? | 2015-03-12 A | 2015-06-18 A | 100% |  |  |  |  | finish no earlier than 2015-06-18 | S2 | 568h | 568h | FS_SEW | 34 | Laurent Thiebaut, Alcatel Lucent | Rel-13 | 67 |  |  |  |  |  |  |
| 5172 | 1871 | Study on EGPRS Access Security Enhancements with relation to cellular IoT | 197d? | 2015-03-12 A | 2015-12-11 A | 100% |  |  |  |  | finish no earlier than 2015-12-11 | S3 | 1576h | 1576h | FS_EASE_IoT | 34 | Vesa Torvinen, Ericsson | Rel-13 | 67 |  |  |  |  |  |  |
| 5173 | 1872 | Study on SCC AS Restoration | 1d? | 2015-06-15 A | 2015-06-15 A | 100% |  |  |  |  | start no earlier than 2015-06-15 | C4 | 8h | 8h | FS_SCCAS_RES | 35 | Hao Zhang,, China Mobile | Rel-13 | 68 |  |  |  |  |  |  |
| 5174 | 1873 | Study on S6a/S6d Shared Data Update | 130d? | 2015-06-15 A | 2015-12-11 A | 100% |  |  |  |  | finish no earlier than 2015-12-11 | C4 | 1040h | 1040h | FS_eSDU | 35 | Ulrich Wiehe, Nokia Networks | Rel-13 | 68 |  |  |  |  |  |  |
| 5175 | 1874 | Study on Network Assistance for Network Synchronization in LTE | 395d? | 2015-06-15 A | 2016-12-15 A | 100% |  |  |  |  | finish no earlier than 2016-12-15 | R3 | 3160h | 3160h | FS_LTE_NW_SYNC | 35 | Huawei | Rel-14 | 68 |  |  |  |  |  |  |
| 5176 | 1875 | Study onLTE Advanced inter-band Carrier Aggregation of Band 20 and Band 28 | 132d? | 2015-06-15 A | 2015-12-15 A | 100% |  |  |  |  | finish no earlier than 2015-12-15 | R4 | 1056h | 1056h | FS_LTE_CA_B20_B28 | 35 | TeliaSonera | Rel-13 | 68 |  |  |  |  |  | RP-151231 |
| 5177 | 1876 | Study on Impacts of the Diameter Base Protocol Specification Update | 75d? | 2015-09-07 A | 2015-12-18 A | 100% |  |  |  |  | finish no earlier than 2015-12-18 | C4 | 600h | 600h | FS_DBPU | 35 | Huawei, Peter Schmitt | Rel-13 | 69 |  |  |  |  |  |  |
| 5178 | 1877 | Study on new AWS-3/4 Band for LTE | 66d? | 2015-09-15 A | 2015-12-15 A | 100% |  |  |  |  | finish no earlier than 2015-12-15 | R4 | 528h | 528h | FS_LTE_AWS_3_4 | 35 | Dish Network | Rel-13 | 69 |  |  |  |  |  |  |
| 5179 | 1878 | Study on multi-node testing for LAA | 263d? | 2016-06-15 A | 2017-06-15 A | 100% |  |  |  |  | finish no earlier than 2017-06-15 | R4 | 2104h | 2104h | FS_LTE_LAA_multinode_test | 37 | Huawei | Rel-13 | 72 |  |  |  |  |  |  |
| 5180 | 1879 | Stopped - Study on Compliance of 3GPP SA5 specifications to the NGMN NGCOR | 1442d? | 2012-06-26 A | 2017-12-15 A | 100% | 2012-06-20 | 2015-09-16 | 854d? |  | finish no earlier than 2017-12-15 | S5 | 11536h | 11536h | FS_OAM_NGMN_NGCOR | 29 | Huawei | Rel-13 | 56 | Mirko | FS_OAM_NGMN_NGCOR |  | 80 |  |  |
| 5181 | 1880 | --- RELEASE 12 --- | 306d? | 2013-10-14 A | 2014-12-12 A | 100% | 2013-10-14 | 2014-12-10 | 304d? |  | finish no earlier than 2014-12-12 | SP; CP; RP; GP | 9792h | 9792h |  |  |  | Rel-12 |  |  |  |  |  |  |  |
| 5182 | 1881 | Stage 1 - ONLY Features | 647d? | 2011-09-27 A | 2014-03-05 A | 100% | 2011-09-27 | 2014-03-05 | 647d? |  | start no earlier than 2011-09-27 | SP; CP | 10352h | 10352h |  | 30 |  | Rel-12 | 58 |  |  |  |  |  |  |

Notes:
- 5133: SP#64 revived. Added to the Title "for Service, Application and Subscriber Group", Changed Acronym: FS_UMONC=>FS_UMONC_sas / Impacted TSs and TRs: 23.858 / WI rapporteur e-mail: Jinyan Li (lijy@ctbri.com.cn)
- 5134: SP#56 completed / Impacted TSs and TRs: 23.858 / WI rapporteur e-mail: Li.Mian@zte.com.cn
- 5135: SP#64 revived. Updated WID SP-120554=>SP-140403. Changed Justification/objectives/Rapporteut ZTE=>China Unciom. SP#58 SA2 stopped (at 70% completion). Dec.14: 80->100%. Mar 15: WID SP-140403->SP-150029 / Impacted TSs and TRs: 23.858 / WI rapporteur e-mail: Jinyan Li (lijy@ctbri.com.cn)
- 5136: SP#57 stopped / Impacted TSs and TRs: 32.858 / WI rapporteur e-mail: Hui Cai (Sarah.Cai@huawei.com)
- 5137: SP#65 moved to Rel-13. Updated WID SP-100734=>SP-140576. Completion 09/14=>06/15. Dec.14: 60->65%¦June2015: Compl:65%->100¦June2015: WID:SP-140576->SP-150368 / Impacted TSs and TRs: 33.895 / WI rapporteur e-mail: vesa.lehtovirta@ericsson.com
- 5138: SP#65 moved to Rel-13. Completion 09/14=>12/15. Related to SA1 TR 22.949 Rel-6 Study on Privacy Capability (PrivCap) UID_31030 studied generalized privacy capability (protection of personal data and non-disclosure of identity). Dec.14: 80->85¦June2015 / Impacted TSs and TRs: 33.849 / WI rapporteur e-mail: Feng Gao (gaofeng149@chinaunicom.cn)
- 5139: SP#64 completion 06/14=>12/14. Dec.14: 20->25%, CD: 12/14->06/15¦June2015: Compl:25%->30¦7/12/15: 30%->45¦7/3/16: 45%->50¦13/6/16: 50%->100 / Impacted TSs and TRs: 32.860 / WI rapporteur e-mail: Vladimir Yanover (vyanover@cisco.com)
- 5140: -Dec.14: 15->30%, CD: 12/14->09/15¦June2015: Compl:30%->60¦07/09/15: 60%->100 / Impacted TSs and TRs: 32.861 / WI rapporteur e-mail: Li Jian (lijian@chinamobile.com), Hu Yaxi (huyaxi@cmdi.chinamobile.com)
- 5141: SP#64 moved to Rel-13. Completion 06/14=>12/14. Dec.14: 35->55, CD: 12/14->06/15. Mar 15: 55->75%¦June2015: Compl:75%->100 / Impacted TSs and TRs: 32.849 / WI rapporteur e-mail: Roland Jesske (r.jesske@telekom.de)
- 5142: Dec.14: 10->25%. Mar 15: 25->60%¦June2015: Compl:60%->85¦07/09/15: 85%->100 / Impacted TSs and TRs: 32.842 / WI rapporteur e-mail: Liu Jinglei (liujinglei@chinamobile.com), zoulan@huawei.com
- 5143: CP#65 TR 31.901v100 for Information. Moved to Rel-13. Completion 09/14=>12/15. Waiting for feedback from external organizations (PTCRB/PVG). Dec.14: 65->100% / Impacted TSs and TRs: 31.901 / WI rapporteur e-mail: Adrian Buckley (abuckley@blackberry.com)
- 5144: GP#63 moved to Rel-13. Completion 08/14=>11/14. GP#55 TR 45.926v100 for Information. GP#47 approved WID. Dec.14: 90->95%. 3/3/15: start date corrected (was 03/09). 7/9/15: FCD: 8/15->11/15¦7/12/15: 95%->100 / Impacted TSs and TRs: 45.926 / WI rapporteur e-mail: juergen.hofmann@nokia.com
- 5145: GP#62 completion 08/14=>02/15. Moved to Rel-13. GP#57 approved WID. Dec.14: 50->65%, CD: 02/15->05/15. 7/9/15: FCD: 11/15->02/16¦2/3/16: 65%->75, FCD: 02/16->05/16¦11/9/17: 75%->100 / Impacted TSs and TRs: 45.8xy / WI rapporteur e-mail: juergen.hofmann@nokia.com
- 5146: CD:Thu 11/12/14->Mon 15/12/14¦Compl:60%->100%¦Stat Rep: RP-141124->RP-142045 / Impacted TSs and TRs: 36.509; new 37.978 / WI rapporteur e-mail: Moray_Rumney@keysight.com
- 5147: GP#62 completion 11/14=>02/15. GP#60 approved WID. Dec.14: 02/15->05/15. 02/03/16: stopped at 20% / Impacted TSs and TRs: 45.876 / WI rapporteur e-mail: Chao Luo (chluo@huawei.com)
- 5148: CD:Thu 11/12/14->Sun 15/03/15¦Compl:85%->90%¦Stat Rep: RP-141153->RP-141851 1st Apr 15: CD:Sun 15/03/15->Mon 15/06/15 1st Apr 15: WID: RP-141154->RP-150119 1st Apr 15: Stat Rep: RP-141851->RP-150120 03/07/15: CD:Mon 15/06/15->Tue 15/09/15 03/07/15: S / Impacted TSs and TRs: LTE 36.861 / WI rapporteur e-mail: Chungwoo HWANG (cwhwang@kt.com)
- 5149: WID: RP-140667->RP-130680¦Stat Rep: RP-140639->RP-142224. 3/3/15: R1 removed as 2nd responsible WG / Impacted TSs and TRs: LTE 36.855 / WI rapporteur e-mail: Jie Cui (cuijie@huawei.com)
- 5150: ¦WID: RP-142043->RP-132086¦Stat Rep: RP-141301->RP-141838 1st Apr 15: Compl:55%->85% 1st Apr 15: WID: RP-132086->RP-150417 1st Apr 15: Stat Rep: RP-141838->RP-150187 03/07/15: Compl:85%->100% 03/07/15: Stat Rep: RP-150187->RP-150807 / Impacted TSs and TRs: UTRA; LTE 37.870 / WI rapporteur e-mail: Kimba Dit Adamou, Boubacar (jinba@chinamobile.com)
- 5151: CD:Thu 11/12/14->Mon 15/12/14¦Compl:10%->100%¦Stat Rep: RP-141429->RP-141968. 5/5/15: 2nd TR number added (to be clarified why two TR for a same topic) / Impacted TSs and TRs: 36.849; 36.869 / WI rapporteur e-mail: Gene Fong (gfong@qti.qualcomm.com)
- 5152: CD:Thu 17/09/15->Tue 15/09/15¦Compl:0%->8%¦Stat Rep: RP-141101->RP-141818 1st Apr 15: Compl:8%->30% 1st Apr 15: Stat Rep: RP-141818->RP-150080 03/07/15: Compl:30%->75% 03/07/15: Stat Rep: RP-150080->RP-150595 29/09/15: Compl:75%->100% 29/09/15: Stat / Impacted TSs and TRs: UTRA; LTE 37.857 / WI rapporteur e-mail: Vogedes Jerome (jvogedes@NextNav.com)
- 5153: WID: RP-141901¦Stat Rep: -->RP-142233 1st Apr 15: Compl:40%->80% 1st Apr 15: WID: RP-141901->RP-150224 1st Apr 15: Stat Rep: RP-142233->RP-150223. 5/5/15: R4 replaced by R1 (correction mistake) 03/07/15: Compl:80%->100% 03/07/15: Stat Rep: RP-150223-> / Impacted TSs and TRs: UTRA 25.706 / WI rapporteur e-mail: jun.chen@huawei.com
- 5154: 3/3/15: WID: RP-141831¦Stat Rep: -->RP-141822, impacted TR number added. 1st Apr 15: Compl:30%->45% 1st Apr 15: Stat Rep: RP-141822->RP-150346. 5/5/15: "R4" replaced by "R1" (correction mistake) 03/07/15: Compl:45%->100% 03/07/15: WID: RP-141831->RP-1 / Impacted TSs and TRs: 36.897 / WI rapporteur e-mail: bishwarup.mondal@nsn.com, hyoungju.ji@samsung.com
- 5155: 3/3/15: WID: RP-141817¦Stat Rep: -->RP-141816. Impacted TR number added. 1st Apr 15: Compl:30%->40% 1st Apr 15: Stat Rep: RP-141816->RP-150414 03/07/15: Compl:40%->100% 03/07/15: Stat Rep: RP-150414->RP-150624 / Impacted TSs and TRs: 36.889 / WI rapporteur e-mail: havish.koorapaty@ericsson.com, david.mazzarese@huawei.com
- 5156: Mar15: 0->20%¦June2015: Compl:20%->80¦07/09/15: 80%->95¦7/12/15: 95%->100 / Impacted TSs and TRs: New 29.811
- 5157: Mar. 15: 0->20%¦June2015: Compl:20%->40¦07/09/15: 40%->80¦7/12/15: 80%->100 / WI rapporteur e-mail: yekuiw@qti.qualcomm.com
- 5158: TR 36.825 rapporteur: CATT. TR number added. 1st Apr 15: Compl:0%->5% 1st Apr 15: Stat Rep: ->RP-150151 03/07/15: Compl:5%->35% 03/07/15: WID: RP-142248->RP-150652 03/07/15: Stat Rep: RP-150151->RP-150805 29/09/15: Compl:35%->100% 29/09/15: Stat Rep: R / Impacted TSs and TRs: 36.825 / WI rapporteur e-mail: NTT DOCOMO
- 5159: TS number added 1st Apr 15: Compl:0%->20% 1st Apr 15: WID: RP-142250->RP-150174 1st Apr 15: Stat Rep: ->RP-150175. 5/5/15: "R4" replaced by "R1" (correction mistake) 03/07/15: Compl:20%->65% 03/07/15: Stat Rep: RP-150175->RP-150679 29/09/15: Compl:65%- / Impacted TSs and TRs: 25.766 / WI rapporteur e-mail: Huawei
- 5160: 1st Apr 15: CD:Tue 15/12/15->Sun 15/03/15 1st Apr 15: Stat Rep: ->RP-150213. 5/5/15: "R4" replaced by "R1" (correction mistake) / WI rapporteur e-mail: MediaTek
- 5161: deleted 660062 (duplicated). 29/1: TR number added 1st Apr 15: Compl:0%->25% 1st Apr 15: WID: RP-142205->RP-150177 1st Apr 15: Stat Rep: ->RP-150176 03/07/15: Compl:25%->100% 03/07/15: Stat Rep: RP-150176->RP-150695 / Impacted TSs and TRs: 36.890 / WI rapporteur e-mail: gaoyongqiang@huawei.com
- 5162: 1st Apr 15: WID: RP-142257->RP-150170 1st Apr 15: Stat Rep: ->RP-150163 03/07/15: Compl:85%->100% 03/07/15: Stat Rep: RP-150163->RP-150849. 7/10/15: responsible group corrected (R4->R3) / Impacted TSs and TRs: 36.875 / WI rapporteur e-mail: Samsung
- 5163: 03/07/15: Compl:10%->30% 03/07/15: Stat Rep: RP-150226->RP-150683 29/09/15: Compl:30%->100% 29/09/15: Stat Rep: RP-150683->RP-151243. 7/10/15: responsible group corrected (R4->R3) and TS (37.876->36.876) / Impacted TSs and TRs: 36.876 / WI rapporteur e-mail: Huawei
- 5164: 03/07/15: Compl:10%->100% 03/07/15: WID: RP-142284->RP-150686 03/07/15: Stat Rep: RP-150227->RP-150684. 7/10/15: responsible group corrected (R4->R3) / Impacted TSs and TRs: 25.756 / WI rapporteur e-mail: Huawei
- 5165: 1st Apr 15: Compl:0%->100% 1st Apr 15: WID: RP-142299->RP-150457 1st Apr 15: Stat Rep: ->RP-150138 / WI rapporteur e-mail: Ericsson
- 5166: TR Rapporteur is Huawei 1st Apr 15: Compl:0%->5% 1st Apr 15: WID: RP-142307->RP-150159 1st Apr 15: Stat Rep: ->RP-150517 03/07/15: Compl:5%->40% 03/07/15: Stat Rep: RP-150517->RP-150793 29/09/15: Compl:40%->80% 29/09/15: CD:Tue 15/09/15->Tue 15/12/15 2 / WI rapporteur e-mail: NTTDoCoMo
- 5167: TR added / Impacted TSs and TRs: 36.891 / WI rapporteur e-mail: pk.liao@mediatek.com
- 5168: TR added 03/07/15: Compl:0%->5% 03/07/15: Stat Rep: -->RP-150770 29/09/15: Compl:5%->100% 29/09/15: Stat Rep: RP-150770->RP-151307 / Impacted TSs and TRs: 36.882
- 5169: TR added 03/07/15: Compl:0%->30% 03/07/15: WID: RP-150496->RP-151100 03/07/15: Stat Rep: -->RP-150857 29/09/15: Compl:30%->50% 29/09/15: Stat Rep: RP-150857->RP-151345 / Impacted TSs and TRs: 36.859
- 5170: 03/07/15: Compl:0%->15% 03/07/15: CD:Thu 10/12/15->Tue 15/12/15 03/07/15: Stat Rep: ->RP-150754 03/07/15: Release: REL-13->Rel-13. Aug 15: TR numb added 29/09/15: Compl:15%->65% 29/09/15: Stat Rep: RP-150754->RP-151317 / Impacted TSs and TRs: 36.894
- 5171: June2015: Compl:0%->100, SP-150151->SP-150251 / Impacted TSs and TRs: new 23.771 / WI rapporteur e-mail: Laurent.thiebaut@alcatel-lucent.com
- 5172: TR added¦June2015: Compl:0%->25¦7/12/15: 25%->70¦28/1/16: 33.420 added¦7/3/16: 70%->100 / Impacted TSs and TRs: New 33.860; 33.420
- 5173: 07/09/15: 5%->20¦7/12/15: 20%->100 / Impacted TSs and TRs: New 29.812 / WI rapporteur e-mail: zhanghao@chinamobile.com
- 5174: 07/09/15: 0%->20¦7/12/15: 20%->100 / Impacted TSs and TRs: New 29.813 / WI rapporteur e-mail: ulrich.wiehe@nokia.com
- 5175: Aug 15: TR numb added 29/09/15: Compl:0%->15% 29/09/15: WID: RP-151084->RP-151252 29/09/15: Stat Rep: -->RP-151240 22/3/16: Compl:60%->80%¦22/3/16: CD:Tue 15/03/16->Wed 15/06/16¦ ¦ / Impacted TSs and TRs: New 36.898
- 5176: 29/09/15: Compl:0%->20% 29/09/15: WID: RP-151101->RP-151515 29/09/15: Stat Rep: -->RP-151231
- 5177: 7/3/16: 0%->79¦13/6/16: 79%->99¦2/12/16: 99%->100 / Impacted TSs and TRs: 29.274; 29.060; 23.003; 29.272; 29.002; 29.305; 23.008; 29.230; 29.303; 23.007; 24.301; 24.008
- 5178: Impacted TSs and TRs: 36.870
- 5179: coexistence testing for REL-13 WI LTE_LAA26/9/16: Compl:0%->10%26/9/16: WID: RP-161197->RP-161672¦20/12/16: Compl:10%->30%¦20/12/16: CD:Thu 15/12/16->Wed 15/03/17¦20/12/16: WID: RP-161672->RP-162144¦21/3/17: CD:Wed 15/03/17->Thu 15/06/17;
- 5180: SP#65 updated WID SP-140349=>SP-140539. Dec.14: 35->45, 12/14: 28.821 added. Mar 15: 45->50%¦June2015: Compl:50%->60. 07/09/15: FCD: 09/15->12/15¦7/12/15: FCD:12/15->03/16¦21/3/17:marked as stopped, was 60% / Impacted TSs and TRs: 32.837; 28.821 / WI rapporteur e-mail: zoulan@huawei.com
- 5181: -
- 5182: -

| ID | WBS | Task | Duration | Start | Finish | Complete | Baseline start | Baseline finish | Baseline duration | Constraint | Resources | Work | Actual work | Acronym | PCG approved | Impacted TSs and TRs | WI rapporteur name | WI rapporteur e-mail | Release | TSG approved | MCC resp | Special Focus Doc | Acronym_3GU_Export | PCG stopped | TSG stopped |
| --- | --- | --- | --- | --- | --- | --- | --- | --- | --- | --- | --- | --- | --- | --- | --- | --- | --- | --- | --- | --- | --- | --- | --- | --- | --- |
| 5183 | 1882 | **SIPTO Service Continuity of IP Data Session** | 376.75d? | 2010-09-23 A | 2011-09-21 A | 100% | 2010-09-23 | 2011-09-21 | 262d? |  | S1 | 4176h | 4176h | SIPTO_SC | 25 | Stage 1 | Vodafone | mona.mustapha@vodafone.com | Rel-12 | 49 | Alain | HNB | SIPTO_SC |  |  |
| 5184 | 1882.1 | Stage 1 for SIPTO Service Continuity of IP Data Session | 262d? | 2010-09-23 A | 2011-09-21 A | 100% | 2010-09-23 | 2011-09-21 | 262d? | finish no earlier than 2011-09-21 | S1 | 2080h | 2080h | SIPTO_SC-SA1 | 25 | 22.101; 22.220 | Vodafone | mona.mustapha@vodafone.com | Rel-12 | 49 | Alain | HNB |  |  |  |
| 5185 | 1883 | **Interworking between Mobile Operators using the Evolved Packet System and Data Application Providers** | 1129.5d? | 2010-12-16 A | 2013-12-11 A | 100% | 2010-12-16 | 2013-12-11 | 792d? |  | S1; S2 | 22794.7h | 22794.7h | MOSAP | 26 | Stage 1 | Cisco | Vojislav Vucetic (vvucetic@cisco.com) | Rel-12 | 50 | Alain |  | MOSAP |  |  |
| 5186 | 1883.1 | Stage 1 for MOSAP | 202d? | 2010-12-16 A | 2011-09-21 A | 100% | 2010-12-16 | 2011-09-21 | 202d? | finish no earlier than 2011-09-21 | S1 | 1600h | 1600h | MOSAP-SA1 | 26 | 22.278 | Cisco | Vojislav Vucetic (vvucetic@cisco.com) | Rel-12 | 50 | Alain |  |  |  |  |
| 5187 | 1883.2 | TR on Stage 2 for MOSAP | 669d? | 2011-06-06 A | 2013-12-11 A | 100% | 2011-06-06 | 2013-12-11 | 669d? | finish no earlier than 2012-12-12 | S2 | 5338.74h | 5338.74h | MOSAP-SA2TR | 27 | new 23.862 | Intel | chang.hong.shan@intel.com | Rel-12 | 52 | Maurice |  |  |  |  |
| 5188 | 1883.3 | Deleted - Stage 2 for MOSAP | 399d? | 2011-06-14 A | 2012-12-12 A | 100% | 2011-06-14 | 2012-12-12 | 399d? | finish no earlier than 2012-12-12 | S2 | 3184h | 3184h | MOSAP-SA2Del | 27 | TBD | Intel | chang.hong.shan@intel.com | Rel-12 | 52 | Maurice |  |  | PCG-30 | SP-58 |
| 5189 | 1884 | **IMS Network-Independent Public User Identities** | 392d? | 2011-06-08 A | 2012-06-20 A | 100% | 2011-06-08 | 2012-06-20 | 275d? |  | S1 | 4390.4h | 4390.4h | INIPUI | 27 | Stage 1 | Vodafone | mona.mustapha@vodafone.com | Rel-12 | 52 | Alain |  | INIPUI |  |  |
| 5190 | 1884.1 | Stage 1 for IMS Network-Independent Public User Identities | 275d? | 2011-06-08 A | 2012-06-20 A | 100% | 2011-06-08 | 2012-06-20 | 275d? | finish no earlier than 2012-06-20 | S1 | 2190.4h | 2190.4h | INIPUI-SA1 | 27 | 22.115; 22.228 | Vodafone | mona.mustapha@vodafone.com | Rel-12 | 52 | Alain |  |  |  |  |
| 5191 | 1885 | **Service and Media Reachability for Users over Restrictive Firewalls** | 283.5d? | 2011-09-21 A | 2012-06-20 A | 100% | 2011-09-21 | 2012-06-20 | 198d? |  | S1 | 3161.66h | 3161.66h | SMURFs | 27 | Stage 1 | Vodafone | mona.mustapha@vodafone.com | Rel-12 | 53 | Alain |  | SMURFs |  |  |
| 5192 | 1885.1 | Stage 1 for Service and Media Reachability for Users over Restrictive Firewalls | 198d? | 2011-09-21 A | 2012-06-20 A | 100% | 2011-09-21 | 2012-06-20 | 198d? | finish no earlier than 2012-06-08 | S1 | 1577.66h | 1577.66h | SMURFs-SA1 | 27 | 22.278 | Vodafone | mona.mustapha@vodafone.com | Rel-12 | 53 | Alain |  |  |  |  |
| 5193 | 1886 | **Advanced IP Interconnection of Services (IPXS) for national interconnect** | 197.5d? | 2012-03-06 A | 2012-09-12 A | 100% | 2012-03-06 | 2012-09-12 | 139d? |  | S1 | 2208h | 2208h | IPXSNAT | 28 | Stage 1 | KPN | toon.norp@tno.nl | Rel-12 | 55 | Alain |  | IPXSNAT |  |  |
| 5194 | 1886.1 | Stage 1 for Advanced IP Interconnection of Services (IPXS) for national interconnect | 139d? | 2012-03-06 A | 2012-09-12 A | 100% | 2012-03-06 | 2012-09-12 | 139d? | finish no earlier than 2012-09-12 | S1 | 1096h | 1096h | IPXSNAT-SA1 | 28 | 22.228 CR#0161 | KPN | toon.norp@tno.nl | Rel-12 | 55 | Alain |  |  |  |  |
| 5195 | 1887 | **Integration of Single Sign-On (SSO) frameworks with 3GPP networks** | 195.5d? | 2012-03-08 A | 2012-09-12 A | 100% | 2012-03-08 | 2012-09-12 | 137d? |  | S1 | 2184h | 2184h | SSO_Int | 28 | Stage 1 | InterDigital | christopher.wallace@interdigital.com | Rel-12 | 55 | Alain |  | SSO_Int |  |  |
| 5196 | 1887.1 | Stage 1 for Integration of Single Sign-On (SSO) frameworks with 3GPP networks | 137d? | 2012-03-08 A | 2012-09-12 A | 100% | 2012-03-08 | 2012-09-12 | 137d? | finish no earlier than 2012-09-12 | S1 | 1088h | 1088h | SSO_Int-SA1 | 28 | 22.101 | InterDigital | christopher.wallace@interdigital.com | Rel-12 | 55 | Alain |  |  |  |  |
| 5197 | 1888 | **Explicit Communication Transfer Blind (ECT Blind) service interactions** | 3d? | 2012-06-18 A | 2012-06-20 A | 100% | 2012-06-18 | 2012-06-20 | 3d? |  | S1 | 48h | 48h | ECTB | 29 | Stage 1 | Orange | philippe.lottin@orange.com | Rel-12 | 56 | Alain |  | ECTB |  |  |
| 5198 | 1888.1 | Stage 1 for Explicit Communication Transfer Blind (ECT Blind) service interactions | 3d? | 2012-06-18 A | 2012-06-20 A | 100% | 2012-06-18 | 2012-06-20 | 3d? | finish no earlier than 2012-06-20 | S1 | 24h | 24h | ECTB-SA1 | 29 | 22.173 | Orange | philippe.lottin@orange.com | Rel-12 | 56 | Alain |  |  |  |  |
| 5199 | 1889 | **IMS access via Digital Video Broadcast - Return Channel via Satellite (DVB-RCS2)** | 231.75d? | 2012-02-02 A | 2012-09-12 A | 100% | 2012-02-02 | 2012-09-12 | 162d? |  | S1 | 2584h | 2584h | IMSSat | 29 | Stage 1 | KPN | toon.norp@tno.nl | Rel-12 | 57 | Alain |  | IMSSat |  |  |
| 5200 | 1889.1 | Stage 1 for IMS access via DVB-RCS2 | 162d? | 2012-02-02 A | 2012-09-12 A | 100% | 2012-02-02 | 2012-09-12 | 162d? | finish no earlier than 2012-09-12 | S1 | 1288h | 1288h | IMSSat-SA1 | 29 | 22.228 | KPN | toon.norp@tno.nl | Rel-12 | 57 | Alain |  |  |  |  |
| 5201 | 1890 | **Sequential Flexible Alerting** | 3d? | 2012-12-10 A | 2012-12-12 A | 100% | 2012-12-10 | 2012-12-12 | 3d? |  | S1 | 48h | 48h | SEQ_FA | 30 | Stage 1 | Orange | bruno.tossou@orange-ftgroup.com | Rel-12 | 58 | Alain |  | IMSSat |  |  |
| 5202 | 1890.1 | Stage 1 for Sequential Flexible Alerting | 3d? | 2012-12-10 A | 2012-12-12 A | 100% | 2012-12-10 | 2012-12-12 | 3d? | finish no earlier than 2012-12-12 | S1 | 24h | 24h | SEQ_FA | 30 | 22.173 | Orange | bruno.tossou@orange-ftgroup.com | Rel-12 | 58 | Alain |  |  |  |  |
| 5203 | 1891 | **Language and Modality Information for communications** | 88.88d? | 2012-12-11 A | 2013-03-06 A | 100% | 2012-12-11 | 2013-03-06 | 63d? |  | S1 | 1008h | 1008h | LangInfo | 30 | Stage 1 | Orange | philippe.lottin@orange.com | Rel-12 | 58 | Alain |  | LangInfo |  |  |
| 5204 | 1891.1 | Stage 1 for Language and Modality Information for communications | 63d? | 2012-12-11 A | 2013-03-06 A | 100% | 2012-12-11 | 2013-03-06 | 63d? | finish no earlier than 2013-03-06 | S1 | 504h | 504h | LangInfo-SA1 | 30 | 22.228 | Orange | philippe.lottin@orange.com | Rel-12 | 58 | Alain |  |  |  |  |
| 5205 | 1892 | **Emergency Session Identification** | 3d? | 2013-03-04 A | 2013-03-06 A | 100% | 2013-03-04 | 2013-03-06 | 3d? |  | S1 | 48h | 48h | ESID | 30 | Stage 1 | Telecom Italia | carmen.catalano@telecomitalia.it | Rel-12 | 59 | Alain |  | ESID |  |  |
| 5206 | 1892.1 | Stage 1 for Emergency Session Identification | 3d? | 2013-03-04 A | 2013-03-06 A | 100% | 2013-03-04 | 2013-03-06 | 3d? | finish no earlier than 2013-03-06 | S1 | 24h | 24h | ESID-SA1 | 30 | 22.101 | Telecom Italia | carmen.catalano@telecomitalia.it | Rel-12 | 59 | Alain |  |  |  |  |

Notes:
- 5183: SP#57 moved to Rel-12 (Reason: Stage 2 for requirements in TS 22.101 clause 4.3.5 have not been implemented in Rel-11). Linked to Rel-10 Local IP Access and Selected Internet IP Traffic Offload (LIPA_SIPTO)
- 5184: SP#57 moved to Rel-12. SP#53 completed
- 5185: SP#58 Stage 2 stopped (TR only, no normative work done)
- 5186: SP#53 completed
- 5187: SP#62 completed. TR 23.862v200 for Approval. SP#58 frozen as v100.
- 5188: SP#58 stopped (no normative work done)
- 5189: Triggered by Rel-11 TR 22.894 (FS_INIPUI)
- 5190: SP#56 re-completed. Updated WID SP-110381=>SP-120425 (Re-opened & moved to Rel-12 by adding new reqs & removing reqs from Rel-11). SP#53 Rel-11 Stage 1 completed
- 5191: SP#56 Stage 1 completed
- 5192: SP#56 completed
- 5193: SP#57 Stage 1 completed. Linked to Rel-11 Feature Advanced IP Interconnection of Services (IPXS) UID_470051.
- 5194: SP#57 completed
- 5195: SP#57 Stage 1 completed. Triggered by Rel-12 TR 22.895. Linked to SA3 33.8xy (Study on Security aspects of SSO_Int), 33.914 (SSO application security for common IMS based on SIP Digest), 33.924 (i/w GBA and OpenID), 33.980 (i/w GBA and Liberty Alliance)
- 5196: SP#57 completed
- 5197: SP#56 WID approved & Stage 1 completed
- 5198: SP#56 new WID approved & work completed. Clarify the service interactions between ECT Blind and other MMTEL Supplementary Services
- 5199: SP#57 Stage 1 completed. Integrate Satcom access with IMS. Specify DVB-RCS2 as an IP Connectivity Access Network for IMS
- 5200: SP#57 completed. Definition of DVB-RCS2 as a non-3GPP IP Connectivity Access Network for IMS
- 5201: SP#58 approved WID & Stage 1 completed. Currently Flexible Alerting (FA) group members are simultaneously alerted by the incoming call. Add the possibility to alert FA group members sequentially. 22/01: acronym modified
- 5202: SP#58 approved WID & Stage 1 completed
- 5203: SP#59 Stage 1 completed. Triggered by Rel-11 Study on Non Voice Emergency Services (FS_NOVES) TR 22.871 use case 10
- 5204: SP#59 completed. Updated WID SP-120937=>SP-130108
- 5205: SP#59 Stage 1 completed.
- 5206: SP#59 completed (22.101 CR#0445)

| ID | WBS | Task | Duration | Start | Finish | Complete | Baseline start | Baseline finish | Baseline duration | Constraint | Resources | Work | Actual work | Acronym | PCG approved | WI rapporteur name | WI rapporteur e-mail | Release | TSG approved | MCC resp | PCG stopped | TSG stopped | Acronym_3GU_Export | Special Focus Doc | Status Report |
| --- | --- | --- | --- | --- | --- | --- | --- | --- | --- | --- | --- | --- | --- | --- | --- | --- | --- | --- | --- | --- | --- | --- | --- | --- | --- |
| 5207 | 1893 | **Deleted - Application and Service Access Control** | 109.62d? | 2013-03-06 A | 2013-06-19 A | 100% | 2013-03-06 | 2013-06-19 | 77d? |  | S1 | 1224h | 1224h | ASAC | 30 | NTT DOCOMO | Atsushi Minokuchi (minokuchi@nttdocomo.co.jp) | Rel-12 | 59 | Alain | PCG-31 | SP-60 | ASAC |  |  |
| 5208 | 1893.1 | Deleted - Stage 1 for Application and Service Access Control | 77d? | 2013-03-06 A | 2013-06-19 A | 100% | 2013-03-06 | 2013-06-19 | 77d? | finish no earlier than 2013-06-19 | S1 | 608h | 608h | ASAC-SA1del | 30 | NTT DOCOMO | Atsushi Minokuchi (minokuchi@nttdocomo.co.jp) | Rel-12 | 59 | Alain | PCG-31 | SP-60 |  |  |  |
| 5209 | 1894 | **Prevention of Mobile-Originating signalling and/or data traffic of UE in Connected mode** | 3d? | 2013-03-04 A | 2013-03-06 A | 100% | 2013-03-04 | 2013-03-06 | 3d? |  | S1 | 48h | 48h | PMOC | 30 | NTT DOCOMO | Atsushi Minokuchi (minokuchi@nttdocomo.co.jp) | Rel-12 | 59 | Alain |  |  | PMOC |  |  |
| 5210 | 1894.1 | Stage 1 for Prevention of Mobile-Originating signalling and/or data traffic of UE in Connected mode | 3d? | 2013-03-04 A | 2013-03-06 A | 100% | 2013-03-04 | 2013-03-06 | 3d? | finish no earlier than 2013-03-06 | S1 | 24h | 24h | PMOC-SA1 | 30 | NTT DOCOMO | Atsushi Minokuchi (minokuchi@nttdocomo.co.jp) | Rel-12 | 59 | Alain |  |  |  |  |  |
| 5211 | 1895 | SA1/SA2 Features | 216d? | 2013-05-17 A | 2014-03-07 A | 100% | 2013-05-17 | 2014-03-07 | 216d? | finish no earlier than 2014-03-07 | SP; CP; RP | 5184h | 5184h |  | 30 |  |  | Rel-12 | 58 |  |  |  |  |  |  |
| 5212 | 1896 | **LIPA Mobility and SIPTO at the Local Network** | 1281.62d? | 2010-10-15 A | 2014-03-06 A | 100% | 2010-10-15 | 2014-03-06 | 898d? |  | S2; C4; C1; R3 | 87994h | 87994h | LIMONET | 26 | Huawei | zhufenqin@huawei.com | Rel-12 | 50 | Maurice |  |  | LIMONET | HNB |  |
| 5213 | 1896.1 | TR on Stage 2 for LIPA Mobility and SIPTO at the Local Network | 580.85d? | 2010-10-15 A | 2013-03-06 A | 100% | 2010-10-15 | 2013-03-06 | 580.85d? | finish no earlier than 2013-03-06 | S2 | 4646.8h | 4646.8h | LIMONET-SA3 | 26 | Huawei | zhufenqin@huawei.com | Rel-12 | 50 | Maurice |  |  |  | HNB |  |
| 5214 | 1896.2 | **BB1: SIPTO at the Local Network** | 1273.38d? | 2010-10-22 A | 2014-03-05 A | 100% | 2010-10-22 | 2014-03-05 | 892d? |  | S2 | 31685.6h | 31685.6h | LIMONET-SIPTO | 26 | Huawei | zhufenqin@huawei.com | Rel-12 | 50 | Maurice |  |  | LIMONET-SIPTO | HNB |  |
| 5215 | 1896.2.1 | Stage 2 for SIPTO at the Local Network | 655.85d? | 2010-10-22 A | 2013-06-19 A | 100% | 2010-10-22 | 2013-06-19 | 655.85d? | finish no earlier than 2013-06-19 | S2 | 5246.8h | 5246.8h | LIMONET-SIPTO-SA2 | 26 | Huawei | zhufenqin@huawei.com | Rel-12 | 50 | Maurice |  |  |  | HNB |  |
| 5216 | 1896.2.2 | **Stage 3 CN aspects of SIPTO at the Local Network** | 924.62d? | 2011-09-24 A | 2014-03-05 A | 100% | 2011-09-24 | 2014-03-05 | 649d? |  | C4; C1 | 19680h | 19680h | LIMONET-SIPTO | 27 | Huawei | peter.schmitt@huawei.com | Rel-12 | 53 | Kimmo |  |  |  | HNB |  |
| 5217 | 1896.2.2.1 | CT4 part of Stage 3 CN aspects of SIPTO at the Local Network | 518d? | 2011-09-24 A | 2013-09-06 A | 100% | 2011-09-24 | 2013-09-06 | 518d? | finish no earlier than 2013-09-06 | C4 | 4136h | 4136h | LIMONET-SIPTO-CT4 | 27 | Huawei | peter.schmitt@huawei.com | Rel-12 | 53 | Kimmo |  |  |  | HNB |  |
| 5218 | 1896.2.2.2 | CT1 part of Stage 3 CN aspects of SIPTO at the Local Network | 646d? | 2011-09-24 A | 2014-03-05 A | 100% | 2011-09-24 | 2014-03-05 | 646d? | finish no earlier than 2014-01-29 | C1 | 5160h | 5160h | LIMONET-SIPTO-CT1 | 27 | Huawei | peter.schmitt@huawei.com | Rel-12 | 53 | Frederic |  |  |  | HNB |  |
| 5219 | 1896.3 | **RAN aspects for SIPTO at the Local Network** | 380.38d? | 2013-03-04 A | 2014-03-06 A | 100% | 2013-03-04 | 2014-03-06 | 269d? |  | R3 | 4272h | 4272h | LIMONET-RAN | 30 | Huawei | zheng.zhou@huawei.com | Rel-12 | 59 | Juha |  |  | LIMONET-RAN | HNB |  |
| 5220 | 1896.3.1 | Core part: RAN aspects for SIPTO at the Local Network | 266d? | 2013-03-04 A | 2014-03-06 A | 100% | 2013-03-04 | 2014-03-06 | 266d? | finish no earlier than 2014-03-06 | R3 | 2120h | 2120h | LIMONET-RAN-Core | 30 | Huawei | zheng.zhou@huawei.com | Rel-12 | 59 | Juha |  |  | LIMONET-RAN-Core | HNB | RP-131512 |
| 5221 | 1896.4 | **Deleted - BB2: Stand-alone L-GW and associated Mobility for LIPA and SIPTO at the Local Network** | 810.12d? | 2010-10-22 A | 2012-12-12 A | 100% | 2010-10-22 | 2012-12-12 | 566d? |  | S2 | 18653.6h | 18653.6h | LIMONET-LIPA | 26 | Huawei | zhufenqin@huawei.com | Rel-12 | 50 | Maurice | PCG-30 | SP-58 | LIMONET-LIPA | HNB |  |
| 5222 | 1896.4.1 | Deleted - Stage 2 for stand-alone L-GW and associated Mobility for LIPA and SIPTO at the Local Network | 519.85d? | 2010-10-22 A | 2012-12-12 A | 100% | 2010-10-22 | 2012-12-12 | 519.85d? | finish no earlier than 2012-12-12 | S2 | 4158.8h | 4158.8h | LIMONET-LIPA-del1 | 26 | Huawei | zhufenqin@huawei.com | Rel-12 | 50 | Maurice | PCG-30 | SP-58 |  | HNB |  |
| 5223 | 1896.4.2 | **Deleted - Stage 3 CN aspects of LIPA Mobility** | 461.38d? | 2011-09-24 A | 2012-12-12 A | 100% | 2011-09-24 | 2012-12-12 | 323d? |  | C1; C4 | 10336h | 10336h | LIMONET-LIPA-del2 | 27 | Huawei | christian.herrero@huawei.com | Rel-12 | 53 | Frederic | PCG-30 | SP-58 |  | HNB |  |
| 5224 | 1896.4.2.1 | Deleted - CT1 part of CN aspects of LIPA Mobility | 323d? | 2011-09-24 A | 2012-12-12 A | 100% | 2011-09-24 | 2012-12-12 | 323d? | finish no earlier than 2012-12-12 | C1 | 2584h | 2584h | LIMONET-LIPA-del3 | 27 | Huawei | christian.herrero@huawei.com | Rel-12 | 53 | Frederic | PCG-30 | SP-58 |  | HNB |  |
| 5225 | 1896.4.2.2 | Deleted - CT4 part of CN aspects of LIPA Mobility | 323d? | 2011-09-24 A | 2012-12-12 A | 100% | 2011-09-24 | 2012-12-12 | 323d? | finish no earlier than 2012-12-12 | C4 | 2584h | 2584h | LIMONET-LIPA-del4 | 27 | Huawei | christian.herrero@huawei.com | Rel-12 | 53 | Kimmo | PCG-30 | SP-58 |  | HNB |  |
| 5226 | 1897 | **Operator Policies for IP Interface Selection** | 1023.75d? | 2011-03-23 A | 2013-12-06 A | 100% | 2011-03-23 | 2013-12-06 | 720d? |  | S2; C1 | 20256h | 20256h | OPIIS | 26 | LG Electronics | taehyeon.kim@lge.com | Rel-12 | 51 | Maurice |  |  | OPIIS |  |  |
| 5227 | 1897.1 | TR on Stage 2 for Operator Policies for IP Interface Selection | 457d? | 2011-03-23 A | 2012-12-12 A | 100% | 2011-03-23 | 2012-12-12 | 457d? | finish no earlier than 2012-12-12 | S2 | 3640h | 3640h | OPIIS | 26 | LG Electronics | taehyeon.kim@lge.com | Rel-12 | 51 | Maurice |  |  |  |  |  |
| 5228 | 1897.2 | Stage 2 for Operator Policies for IP Interface Selection | 511d? | 2011-04-04 A | 2013-03-06 A | 100% | 2011-04-04 | 2013-03-06 | 511d? | finish no earlier than 2013-03-06 | S2 | 4088h | 4088h | OPIIS | 26 | LG Electronics | taehyeon.kim@lge.com | Rel-12 | 51 | Maurice |  |  |  |  |  |
| 5229 | 1897.3 | Stage 3 for Operator Policies for IP Interface Selection | 126d? | 2013-06-14 A | 2013-12-06 A | 100% | 2013-06-14 | 2013-12-06 | 126d? | finish no earlier than 2013-12-06 | C1 | 1008h | 1008h | OPIIS-CT | 31 | LG Electronics | Jaehyun Kim (jaehyun7.kim@lge.com) | Rel-12 | 60 | Frederic |  |  | OPIIS-CT |  |  |
| 5230 | 1898 | **Short Message Service (SMS) submit and delivery without MSISDN in IMS** | 944d? | 2011-06-08 A | 2013-12-06 A | 100% | 2011-06-08 | 2013-12-06 | 665d? |  | S2; C1; C4 | 28336.3h | 28336.3h | SMSMI | 27 | Nokia Siemens Networks | curt.wong@nsn.com | Rel-12 | 52 | Maurice |  |  | SMSMI |  |  |
| 5231 | 1898.1 | TR on Stage 2 for SMS submit and delivery without MSISDN in IMS | 402d? | 2011-06-08 A | 2012-12-12 A | 100% | 2011-06-08 | 2012-12-12 | 402d? | finish no earlier than 2012-12-12 | S2 | 3192.32h | 3192.32h | SMSMI-SA2TR | 27 | Nokia Siemens Networks | curt.wong@nsn.com | Rel-12 | 52 | Maurice |  |  |  |  |  |
| 5232 | 1898.2 | Stage 2 for SMS submit and delivery without MSISDN in IMS | 400d? | 2011-06-13 A | 2012-12-12 A | 100% | 2011-06-13 | 2012-12-12 | 400d? | finish no earlier than 2012-12-12 | S2 | 3192h | 3192h | SMSMI-SA2 | 27 | Nokia Siemens Networks | curt.wong@nsn.com | Rel-12 | 52 | Maurice |  |  |  |  |  |

Notes:
- 5207: SP#60 stopped and Rel-13 FS_ACDC continues. Triggered by TR 22.806 Study on Application specific Congestion control for Data Communication (FS_ACDC) UID_570034 / Impacted TSs and TRs: Stage 1
- 5208: SP#60 stopped and Rel-13 FS_ACDC contd. Allow/prohibit for E-UTRAN idle mode UE initiation of particular applications defined by operator and subject to regional regulations. Prevent/mitigate overload of AN/CN defined by operator (congestion or disaster) / Impacted TSs and TRs: 22.011
- 5209: SP#59 Stage 1 completed / Impacted TSs and TRs: Stage 1
- 5210: SP#59 completed / Impacted TSs and TRs: 22.011
- 5211: -
- 5212: CP#63 completed. SP#58 updated WID SP-120256=>SP-120926 (stopped BB2 LIMONET-LIPA on Mobility). Linked to UID_450035 Local IP Access and Selected IP Traffic Offload (LIPA_SIPTO) / Impacted TSs and TRs: Stage 2/3
- 5213: SP#59 completed. TR 23.859 v100 for Information and Approval / Impacted TSs and TRs: new 23.859
- 5214: SP#60 completed / Impacted TSs and TRs: 23.060; 23.401
- 5215: SP#60 completed / Impacted TSs and TRs: 23.060; 23.401
- 5216: CP#63 completed / Impacted TSs and TRs: Stage 3
- 5217: CP#61 completed / Impacted TSs and TRs: 23.003; 23.008; 29.002; 29.060; 29.230; 29.272; 29.274; 29.303
- 5218: CP#63 completed / Impacted TSs and TRs: 24.008; 24.301
- 5219: - / Impacted TSs and TRs: UTRA; LTE
- 5220: RP#62 completed / Impacted TSs and TRs: 25.401; 25.413; 25.423; 25.467; 25.469; 36.300; 36.413; 36.423
- 5221: SP#58 updated WID SP-120256=>SP-120926 (stopped BB2 LIMONET-LIPA on Mobility) / Impacted TSs and TRs: 23.060; 23.401
- 5222: SP#58 updated WID SP-120256=>SP-120926 (stopped BB2 LIMONET-LIPA on Mobility) / Impacted TSs and TRs: 23.060; 23.401
- 5223: SP#58 CT Stage 3 part stopped because of SA stopping Stage 2 for BB2 LIMONET-LIPA on Mobility) / Impacted TSs and TRs: Stage 3
- 5224: SP#58 CT Stage 3 part stopped because of SA stopping Stage 2 for BB2 LIMONET-LIPA on Mobility) / Impacted TSs and TRs: 24.008; 24.301
- 5225: SP#58 CT Stage 3 part stopped because of SA stopping Stage 2 for BB2 LIMONET-LIPA on Mobility) / Impacted TSs and TRs: 29.060; 29.274; 29.281; 29.303; 29.002; 29.272; 29.275; 29.282; 29.305
- 5226: Linked to Rel-10 IFOM IP Flow Mobility and seamless WLAN offload (non-seamless WLAN offload aspects) & Rel-11 LIMONET (support traffic offload at local network) / Impacted TSs and TRs: Stage 2/3
- 5227: SP#58 completed / Impacted TSs and TRs: new 23.853
- 5228: SP#59 completed (23.402 CR#152: Introduction of Inter-APN Routing Policies) / Impacted TSs and TRs: 23.402
- 5229: CP#62 completed. Specify Inter-APN Routing Policies for selecting an IP interface to route IP flows among a choice of available interfacES in CP-150both 3GPP and non-3GPP accesses / Impacted TSs and TRs: 24.302; 24.312
- 5230: Linked to Rel-7 SMSIP (Support of SMS over generic 3GPP IP access), Rel-11 SIMTC, Rel-12 TR 22.988 SA1 Study on alternatives to E.164 for MTC / Impacted TSs and TRs: Stage 2/3
- 5231: SP#58 completed / Impacted TSs and TRs: new 23.863
- 5232: SP#58 completed / Impacted TSs and TRs: 23.204; 23.682

| ID | WBS | Task | Duration | Start | Finish | Complete | Baseline start | Baseline finish | Baseline duration | Constraint | Resources | Work | Actual work | Acronym | PCG approved | Impacted TSs and TRs | WI rapporteur name | WI rapporteur e-mail | Release | TSG approved | MCC resp | Acronym_3GU_Export | Status Report | Special Focus Doc |
| --- | --- | --- | --- | --- | --- | --- | --- | --- | --- | --- | --- | --- | --- | --- | --- | --- | --- | --- | --- | --- | --- | --- | --- | --- |
| 5233 | 1898.3 | **Stage 3 for SMS submit and delivery without MSISDN in IMS** | 290.5d? | 2013-03-01 A | 2013-12-06 A | 100% | 2013-03-01 | 2013-12-06 | 205d? |  | C1; C4 | 5992h | 5992h | SMSMI-CT | 30 | Stage 3 | NSN | peter.leis@nsn.com | Rel-12 | 59 | Frederic | SMSMI-CT |  |  |
| 5234 | 1898.3.1 | CT1 part of Stage 3 for SMS submit and delivery without MSISDN in IMS | 205d? | 2013-03-01 A | 2013-12-06 A | 100% | 2013-03-01 | 2013-12-06 | 205d? | finish no earlier than 2013-12-06 | C1 | 1608h | 1608h | SMSMI-CT | 30 | 23.040; 24.341 | NSN | peter.leis@nsn.com | Rel-12 | 59 | Frederic |  |  |  |
| 5235 | 1898.3.2 | CT4 part of Stage 3 for SMS submit and delivery without MSISDN in IMS | 139d? | 2013-03-01 A | 2013-09-06 A | 100% | 2013-03-01 | 2013-09-06 | 139d? | finish no earlier than 2013-09-06 | C4 | 1104h | 1104h | SMSMI-CT | 30 | 23.008; 29.002; 29.305; 29.328; 29.338 | NSN | peter.leis@nsn.com | Rel-12 | 59 | Kimmo |  |  |  |
| 5236 | 1899 | **IMS-based Telepresence** | 1783d? | 2010-03-22 A | 2014-12-09 A | 100% | 2010-03-19 | 2014-12-05 | 1243.5d? |  | S1; C1; C3; C4; IETF | 122882h | 122882h | IMS_TELEP | 27 | Stage 1/2/3 | Orange | bruno.tossou@orange-ftgroup.com | Rel-12 | 53 | Alain | IMS_TELEP |  |  |
| 5237 | 1899.1 | Stage 1 for IMS-based Telepresence | 197d? | 2011-09-22 A | 2012-06-20 A | 100% | 2011-09-22 | 2012-06-20 | 197d? | finish no earlier than 2012-06-08 | S1 | 1569.86h | 1569.86h | IMS_TELEP | 27 | 22.228 | Orange | bruno.tossou@orange-ftgroup.com | Rel-12 | 53 | Alain |  |  |  |
| 5238 | 1899.2 | **CT part for IMS Telepresence (Stage 2/3)** | 1783d? | 2010-03-22 A | 2014-12-09 A | 100% | 2010-03-19 | 2014-12-05 | 1243.5d? |  | C1; C3; C4; IETF | 87712h | 87712h | IMS_TELEP | 30 | Stage 2/3 | Huawei | Weiwei(Tommy) Yang (tommy@huawei.com) | Rel-12 | 58 | Frederic |  |  |  |
| 5239 | 1899.2.1 | TR on CT part of IMS Telepresence (Stage 2/3) | 399d? | 2012-12-07 A | 2014-06-13 A | 100% | 2012-12-07 | 2014-06-13 | 399d? | finish no earlier than 2014-06-13 | C1 | 3184h | 3184h | IMS_TELEP | 30 | New 24.803 | Huawei | Weiwei(Tommy) Yang (tommy@huawei.com) | Rel-12 | 58 | Frederic |  |  |  |
| 5240 | 1899.2.2 | CT1 part of IMS Telepresence (Stage 3) | 526d? | 2012-12-07 A | 2014-12-09 A | 100% | 2012-12-07 | 2014-09-12 | 464d? | finish no earlier than 2014-12-09 | C1 | 4208h | 4208h | IMS_TELEP | 30 | 24.147; 24.166; 24.229; New 24.103 | Huawei | Weiwei(Tommy) Yang (tommy@huawei.com) | Rel-12 | 58 | Frederic |  | CP-140616 |  |
| 5241 | 1899.2.3 | (IETF) Session Description Protocol (SDP) Offer/Answer Procedures For Stream Control Transmission Protocol (SCTP) over Datagram Transport Layer Security (DTLS) | 851d? | 2010-03-22 A | 2014-12-05 A | 100% | 2010-03-19 | 2014-12-05 | 849d? | finish no earlier than 2014-12-09 | C1-IETF | 6808h | 6808h | IMS_TELEP | 33 | draft-ietf-mmusic-sctp-sdp; RFC 8842 | christer.holmberg@ericsson.com | christer.holmberg@ericsson.com | Rel-12 | 64 |  |  |  |  |
| 5242 | 1899.2.4 | (IETF) Framework for Telepresence Multi-Streams (draft-ietf-clue-framework) | 851d? | 2010-03-22 A | 2014-12-05 A | 100% | 2010-03-19 | 2014-12-05 | 849d? | finish no earlier than 2014-12-09 | C1-IETF | 6808h | 6808h | IMS_TELEP | 33 | draft-ietf-clue-framework; RFC 8845 | christer.holmberg@ericsson.com | christer.holmberg@ericsson.com | Rel-12 | 64 |  |  |  |  |
| 5243 | 1899.2.5 | (IETF) CLUE Protocol data channel (draft-ietf-clue-datachannel) | 851d? | 2010-03-22 A | 2014-12-05 A | 100% | 2010-03-19 | 2014-12-05 | 849d? | finish no earlier than 2014-12-09 | C1-IETF | 6808h | 6808h | IMS_TELEP | 33 | draft-ietf-clue-datachannel; RFC 8850 | christer.holmberg@ericsson.com | christer.holmberg@ericsson.com | Rel-12 | 64 |  |  |  |  |
| 5244 | 1899.2.6 | (IETF) Session Signaling for Controlling Multiple Streams for Telepresence (CLUE) (draft-ietf-clue-signaling) | 851d? | 2010-03-22 A | 2014-12-05 A | 100% | 2010-03-19 | 2014-12-05 | 849d? | finish no earlier than 2014-12-09 | C1-IETF | 6808h | 6808h | IMS_TELEP | 33 | draft-ietf-clue-signaling; RFC 8848 | christer.holmberg@ericsson.com | christer.holmberg@ericsson.com | Rel-12 | 64 |  |  |  |  |
| 5245 | 1899.2.7 | (IETF) An XML Schema for the CLUE data model (draft-ietf-clue-data-model-schema) | 851d? | 2010-03-22 A | 2014-12-05 A | 100% | 2010-03-19 | 2014-12-05 | 849d? | finish no earlier than 2014-12-09 | C1-IETF | 6808h | 6808h | IMS_TELEP | 33 | draft-ietf-clue-data-model-schema; RFC 8846 | christer.holmberg@ericsson.com | christer.holmberg@ericsson.com | Rel-12 | 64 |  |  |  |  |
| 5246 | 1899.2.8 | CT3 part of IMS Telepresence (Stage 3) | 467d? | 2012-12-07 A | 2014-09-11 A | 100% | 2012-12-07 | 2014-09-12 | 467d? | finish no earlier than 2014-09-12 | C3 | 3736h | 3736h | IMS_TELEP | 30 | 29.165 | Huawei | Weiwei(Tommy) Yang (tommy@huawei.com) | Rel-12 | 58 | Adrian |  |  |  |
| 5247 | 1899.2.9 | CT4 part of IMS Telepresence (Stage 2/3) | 328d? | 2013-09-13 A | 2014-12-09 A | 100% | 2013-09-10 | 2014-09-12 | 266d? | finish no earlier than 2014-12-09 | C4 | 2624h | 2624h | IMS_TELEP | 31 | 23.333; 29.333 | Huawei | Weiwei(Tommy) Yang (tommy@huawei.com) | Rel-12 | 61 | Kimmo |  | CP-140477 |  |
| 5248 | 1900 | **Group Communication System Enablers for LTE** | 1033d? | 2012-06-18 A | 2015-03-13 A | 100% | 2012-06-18 | 2014-09-17 | 597d? |  | S1; S2; S3; C3; C4; R3; C1 | 58696h | 58696h | GCSE_LTE | 29 | Stage 1/2/3 | Nokia Networks | Juergen.Merkel@nsn.com | Rel-12 | 56 | Alain | GCSE_LTE |  | Public Safety (A-A) |
| 5249 | 1900.1 | Stage 1 for Group Communication System Enablers for LTE | 267d? | 2012-06-18 A | 2013-06-19 A | 100% | 2012-06-18 | 2013-06-19 | 267d? | finish no earlier than 2013-06-19 | S1 | 2128h | 2128h | GCSE_LTE | 29 | New 22.468 | Nokia Networks | Juergen.Merkel@nsn.com | Rel-12 | 56 | Alain |  |  | Public Safety (A-A) |
| 5250 | 1900.2 | TR on Architecture enhancements to support Group Communication System Enablers for LTE | 267d? | 2013-03-07 A | 2014-03-07 A | 100% | 2013-03-07 | 2014-03-07 | 267d? | finish no earlier than 2014-03-07 | S2 | 2128h | 2128h | GCSE_LTE | 30 | New 23.768 | Nokia Networks | rainer.liebhart@nsn.com | Rel-12 | 59 | Maurice |  |  | Public Safety (A-A) |
| 5251 | 1900.3 | Stage 2 for Group Communication System Enablers for LTE | 402d? | 2013-03-12 A | 2014-09-16 A | 100% | 2013-03-12 | 2014-09-17 | 402d? | finish no earlier than 2014-09-17 | S2 | 3208h | 3208h | GCSE_LTE | 30 | New 23.468 | Nokia Networks | rainer.liebhart@nsn.com | Rel-12 | 59 | Maurice |  |  | Public Safety (A-A) |
| 5252 | 1900.4 | TR on Security for Group Communication System Enablers for LTE (Stage 2) | 201d? | 2013-09-12 A | 2014-06-18 A | 100% | 2013-09-12 | 2014-06-18 | 201d? | finish no earlier than 2014-06-18 | S3 | 1608h | 1608h | GCSE_LTE | 31 | New 33.888 | Nokia Networks | anja.jerichow@nsn.com | Rel-12 | 61 | Mirko |  |  | Public Safety (A-A) |
| 5253 | 1900.5 | Security for Group Communication System Enablers for LTE (Stage 2) | 201d? | 2013-09-13 A | 2014-06-18 A | 100% | 2013-09-13 | 2014-06-18 | 201d? | finish no earlier than 2014-06-18 | S3 | 1608h | 1608h | GCSE_LTE | 31 | 33.246 | Nokia Networks | anja.jerichow@nsn.com | Rel-12 | 61 | Mirko |  |  | Public Safety (A-A) |
| 5254 | 1900.6 | **CT aspects of Group Communication System Enablers for LTE** | 186.12d? | 2014-06-13 A | 2014-12-09 A | 100% | 2014-06-13 | 2014-09-12 | 66d? |  | C3; C4; C1 | 4152h | 4152h | GCSE_LTE-CT | 33 | Stage 3 | Nokia Networks | thomas.belling@nsn.com | Rel-12 | 64 |  | GCSE_LTE-CT |  | Public Safety (A-A) |
| 5255 | 1900.6.1 | CT3 part of Group Communication System Enablers for LTE | 66d? | 2014-06-13 A | 2014-09-11 A | 100% | 2014-06-13 | 2014-09-12 | 66d? | finish no earlier than 2014-09-12 | C3 | 528h | 528h | GCSE_LTE-CT | 33 | 29.212; 29.213; 29.214; 29.274; New 29.468 | Nokia Networks | thomas.belling@nsn.com | Rel-12 | 64 |  |  |  | Public Safety (A-A) |
| 5256 | 1900.6.2 | CT4 part of Group Communication System Enablers for LTE | 128d? | 2014-06-13 A | 2014-12-09 A | 100% | 2014-06-13 | 2014-09-12 | 66d? | finish no earlier than 2014-12-09 | C4 | 1024h | 1024h | GCSE_LTE-CT | 33 | 23.007; 23.008 | Nokia Networks | thomas.belling@nsn.com | Rel-12 | 64 |  |  | CP-140725 | Public Safety (A-A) |
| 5257 | 1900.6.3 | CT1 part of Group Communication System Enablers for LTE | 63d? | 2014-09-12 A | 2014-12-09 A | 100% |  |  |  | finish no earlier than 2014-12-09 | C1 | 504h | 504h | GCSE_LTE-CT | 33 | 24.301 | Nokia Networks | thomas.belling@nsn.com | Rel-12 | 65 |  |  | CP-140614 | Public Safety (A-A) |

Notes:
- 5233: CP#62 completed. Address scenario IMS client to IMS client SMS (comprises SMS receive and send SMS without requiring an MSISDN associated as part of their subscription record in HSS
- 5234: CP#62 completed
- 5235: CP#61 completed
- 5236: This feature does not introduce any changes to the IMS architecture, and no stage 2 impacts are identified
- 5237: SP#56 completed. 2/4/15: acronym changed to IMS_TELEP
- 5238: CP#65 updated WID CP-140196=>CP-140624. 2/4/15: acronym changed to IMS_TELEP
- 5239: CP#64 completed. 2/4/15: acronym changed to IMS_TELEP
- 5240: CP#65 TS 24.103v100 for Information. Updated WID CP-140196=>CP-140624. Completion 09/14=>12/14. Exception in CP-140616. Dec.14: 90->100%. 2/4/15: acronym changed to IMS_TELEP
- 5241: work in progress. 2/4/15: acronym changed to IMS_TELEP. Was (IETF) CT1 part of IMS Telepresence (draft-ietf-mmusic-sctp-sdp).; 23/4/20: 50%->90; 9/4/21: RFC 8842 added;
- 5242: work in progress. 2/4/15: acronym changed to IMS_TELEP; 23/4/20: 50%->90. Was (IETF) CT1 part of IMS Telepresence (draft-ietf-clue-framework ); 9/4/21: RFC 8845 added;
- 5243: work in progress. 2/4/15: acronym changed to IMS_TELEP; 23/4/20: 50%->90. Was (IETF) CT1 part of IMS Telepresence (draft-ietf-clue-datachannel); 9/4/21: RFC 8850 added;
- 5244: work in progress. 2/4/15: acronym changed to IMS_TELEP; 23/4/20: 50%->90. Was (IETF) CT1 part of IMS Telepresence (draft-ietf-clue-signaling); 9/4/21: RFC 8848 added;
- 5245: work in progress. 2/4/15: acronym changed to IMS_TELEP; 23/4/20: 50%->90. Was (IETF) CT1 part of IMS Telepresence (draft-ietf-clue-data-model-schema); 9/4/21: RFC 8846 added;
- 5246: CP#65 completed. 2/4/15: acronym changed to IMS_TELEP
- 5247: CP#65 updated WID CP-140196=>CP-140624. Completion 09/14=>12/14. Exception in CP-140477. Mar.15: 0->100%. 2/4/15: acronym changed to IMS_TELEP
- 5248: Linked to Rel-12 FS_ProSe TR 22.803 Study on Proximity-based Services. External requirements: NIST, MESA, APCO Global Alliance, TCCA. Specify 3GPP system enablers to support group communication over LTE for Public Safety
- 5249: SP#60 completed. TS 22.468 v100 for 1-step Approval
- 5250: SP#63 completed. TR 23.768v200 for Approval
- 5251: SP#65 completed. Updated WID SP-140113=>SP-140433. SP#63 TS 23.468v100 for 1-step Approval
- 5252: SP#64 completed. TR 33.888v100 for 1-step Approval
- 5253: SP#64 completed
- 5254: CP#65 updated WID CP-140452=>C3-143199 (added CT1 part)
- 5255: CP#65 completed. TS 29.468v200 for Approval
- 5256: CP#65 completion 09/14=>12/14. Exception in CP-140725. Dec.14: 35->100
- 5257: CP#65 updated WID CP-140452=>CP-140559 (added CT1 part). Exception in CP-140614. Dec.14: 90->100%

| ID | WBS | Task | Duration | Start | Finish | Complete | Remaining | Baseline start | Baseline finish | Baseline duration | Total slack | Constraint | Resources | Work | Actual work | Acronym | PCG approved | Impacted TSs and TRs | WI rapporteur name | WI rapporteur e-mail | Release | TSG approved | Special Focus Doc | Acronym_3GU_Export | Status Report | MCC resp | PCG stopped | TSG stopped |
| --- | --- | --- | --- | --- | --- | --- | --- | --- | --- | --- | --- | --- | --- | --- | --- | --- | --- | --- | --- | --- | --- | --- | --- | --- | --- | --- | --- | --- |
| 5258 | 1900.7 | **Group Call eMBMS congestion management for LTE** | 280.12d? | 2014-06-16 A | 2015-03-13 A | 100% |  | 2014-06-13 | 2014-09-12 | 66d? |  |  | R3 | 3152h | 3152h | GCSE_LTE-MBMS_CM | 33 | LTE | Alcatel-Lucent | hakon.helmers@alcatel-lucent.com | Rel-12 | 64 | Public Safety (A-A) | GCSE_LTE-MBMS_CM |  |  |  |  |
| 5259 | 1900.7.1 | Core part: Group Call eMBMS congestion management for LTE | 196d? | 2014-06-16 A | 2015-03-13 A | 100% |  | 2014-06-13 | 2014-09-12 | 66d? |  | finish no earlier than 2015-03-15 | R3 | 1568h | 1568h | GCSE_LTE-MBMS_CM-Core | 33 | 36.413 | Alcatel-Lucent | hakon.helmers@alcatel-lucent.com | Rel-12 | 64 | Public Safety (A-A) | GCSE_LTE-MBMS_CM-Core | RP-150081 |  |  |  |
| 5260 | 1901 | **Machine-Type and other mobile data applications Communications enhancements** | 2376d? | 2009-12-10 A | 2016-03-23 | 98% | 56.6d? | 2009-12-10 | 2014-09-12 | 1255d? | 41505.2d |  |  | 58859h | 57908.6h | MTCe | 29 | Stage 1/2/3 | Intel | puneet.jain@intel.com | Rel-12 | 56 | MTC, M2M | MTCe |  | Maurice |  |  |
| 5261 | 1901.1 | Stage 1 for Support for Interworking with M2M Service Enablement | 189d? | 2012-06-18 A | 2013-03-06 A | 100% |  | 2012-06-18 | 2013-03-06 | 189d? |  | finish no earlier than 2013-03-06 | S1 | 1504h | 1504h | MTCe-SIMSE | 29 | 22.368 | KPN | toon.norp@tno.nl | Rel-12 | 56 | MTC, M2M | MTCe-SIMSE |  | Alain |  |  |
| 5262 | 1901.2 | Stage 1 for Machine-Type and other mobile data applications Communications – Service Requirement Maintenance | 127d? | 2012-09-13 A | 2013-03-06 A | 100% |  | 2012-09-13 | 2013-03-06 | 127d? |  | finish no earlier than 2013-03-06 | S1 | 1008h | 1008h | MTCe-SRM | 29 | 22.101; 22.368 | KPN | toon.norp@tno.nl | Rel-12 | 57 | MTC, M2M | MTCe-SRM |  | Alain |  |  |
| 5263 | 1901.3 | TR on Security aspects of Machine-Type Communications | 1113d? | 2009-12-10 A | 2014-03-07 A | 100% |  | 2009-12-10 | 2014-03-07 | 1113d? |  | finish no earlier than 2014-03-07 | S3 | 8896h | 8896h | MTCe-SA3TR | 29 | New 33.868 | Samsung | Rajavelsamy R (rajvel@samsung.com) | Rel-12 | 56 | MTC, M2M |  |  | Mirko |  |  |
| 5264 | 1901.4 | Security and Privacy aspects for Machine-Type and other mobile data applications Communications enhancements (Stage 2) | 452d? | 2012-06-22 A | 2014-03-07 A | 100% |  | 2012-06-22 | 2014-03-07 | 452d? |  | finish no earlier than 2014-03-07 | S3 | 3608h | 3608h | MTCe-SA3 | 29 | New 33.187 | Samsung | Rajavelsamy R (rajvel@samsung.com) | Rel-12 | 56 | MTC, M2M |  |  | Mirko |  |  |
| 5265 | 1901.5 | **BB1: Small Data and Device Triggering Enhancements (SDDTE)** | 843.75d? | 2012-06-18 A | 2014-09-11 A | 100% |  | 2012-06-18 | 2014-09-12 | 594d? |  |  | S2; C4; C3 | 24400h | 24400h | MTCe-SDDTE | 29 |  | Intel | puneet.jain@intel.com | Rel-12 | 56 | MTC, M2M | MTCe-SDDTE |  | Maurice |  |  |
| 5266 | 1901.5.1 | TR on Stage 2 BB1: Small Data and Device Triggering Enhancements | 394d? | 2012-06-18 A | 2013-12-11 A | 100% |  | 2012-06-18 | 2013-12-11 | 394d? |  | finish no earlier than 2013-12-11 | S2 | 3128h | 3128h | MTCe-SDDTE | 29 | New 23.887 | Intel | puneet.jain@intel.com | Rel-12 | 56 | MTC, M2M |  |  | Maurice |  |  |
| 5267 | 1901.5.2 | Stage 2 for BB1: Small Data and Device Triggering Enhancements | 390d? | 2012-06-26 A | 2013-12-11 A | 100% |  | 2012-06-26 | 2013-12-11 | 390d? |  | finish no earlier than 2013-12-11 | S2 | 3120h | 3120h | MTCe-SDDTE | 29 | 23.682 | Intel | puneet.jain@intel.com | Rel-12 | 56 | MTC, M2M |  |  | Maurice |  |  |
| 5268 | 1901.5.3 | **Stage 3 for BB1: Small Data and Device Triggering Enhancements** | 197.62d? | 2014-03-05 A | 2014-09-11 A | 100% |  | 2014-03-05 | 2014-09-12 | 138d? |  |  | C4; C3 | 3896h | 3896h | MTCe-SDDTE-CT | 32 | Stage 3 | Huawei | peter.schmitt@huawei.com | Rel-12 | 63 | MTC, M2M | MTCe-SDDTE-CT |  | Kimmo |  |  |
| 5269 | 1901.5.3.1 | CT4 part of Stage 3 for BB1: Small Data and Device Triggering Enhancement | 138d? | 2014-03-05 A | 2014-09-11 A | 100% |  | 2014-03-05 | 2014-09-12 | 138d? |  | finish no earlier than 2014-09-12 | C4 | 1104h | 1104h | MTCe-SDDTE-CT | 32 | 29.002; 29.336; 23.008; 29.337; 29.338; 29.230 | Huawei | peter.schmitt@huawei.com | Rel-12 | 63 | MTC, M2M |  |  | Kimmo |  |  |
| 5270 | 1901.5.3.2 | CT3 part of Stage 3 for BB1: Small Data and Device Triggering Enhancement | 73d? | 2014-03-05 A | 2014-06-13 A | 100% |  | 2014-03-05 | 2014-06-13 | 73d? |  | finish no earlier than 2014-06-13 | C3 | 584h | 584h | MTCe-SDDTE-CT | 32 | 29.368 | Huawei | peter.schmitt@huawei.com | Rel-12 | 63 | MTC, M2M |  |  | Adrian |  |  |
| 5271 | 1901.6 | Deleted - BB2: Monitoring Enhancements (MONTE) | 131d? | 2012-06-18 A | 2012-12-12 A | 100% |  | 2012-06-18 | 2012-12-12 | 131d? |  | finish no earlier than 2012-12-12 | S2 | 1048h | 1048h | MTCe-MONTE | 29 | 23.682 | Intel | puneet.jain@intel.com | Rel-12 | 56 | MTC, M2M | MTCe-MONTE |  | Maurice | PCG-30 | SP-58 |
| 5272 | 1901.7 | **BB3: UE Power Consumptions Optimizations (UEPCOP)** | 1422.5d? | 2012-06-18 A | 2016-03-23 | 93% | 98.36d? | 2012-06-18 | 2014-09-12 | 594d? | 41505.2d |  |  | 13712h | 12761.6h | MTCe-UEPCOP | 29 |  | Ericsson | peter.hedman@ericsson.com | Rel-12 | 56 | MTC, M2M | MTCe-UEPCOP |  | Maurice |  |  |
| 5273 | 1901.7.1 | TR on Stage 2 BB3: UE Power Consumptions Optimizations (UEPCOP) | 394d? | 2012-06-18 A | 2013-12-11 A | 100% |  | 2012-06-18 | 2013-12-11 | 394d? |  | finish no earlier than 2013-12-11 | S2 | 3128h | 3128h | MTCe-UEPCOP | 29 | New 23.887 | Ericsson | peter.hedman@ericsson.com | Rel-12 | 56 | MTC, M2M |  |  | Maurice |  |  |
| 5274 | 1901.7.2 | Stage 2 for BB3: UE Power Consumptions Optimizations (UEPCOP) | 390d? | 2012-06-26 A | 2013-12-11 A | 100% |  | 2012-06-26 | 2013-12-11 | 390d? |  | finish no earlier than 2013-12-11 | S2 | 3120h | 3120h | MTCe-UEPCOP | 29 | 23.060; 23.401; 23.682 | Ericsson | peter.hedman@ericsson.com | Rel-12 | 56 | MTC, M2M |  |  | Maurice |  |  |
| 5275 | 1901.7.3 | **Stage 3 for BB3: UE Power Consumptions Optimizations (UEPCOP)** | 860.25d? | 2013-12-06 A | 2016-03-15 A | 100% |  | 2013-12-06 | 2014-09-12 | 202d? |  |  |  | 6368h | 6368h | MTCe-UEPCOP-CT | 32 | Stage 3 | Ericsson | mikael.wass@ericsson.com | Rel-12 | 62 | MTC, M2M | MTCe-UEPCOP-CT |  | Frederic |  |  |
| 5276 | 1901.7.3.1 | CT1 part of Stage 3 for BB3: UE Power Consumptions Optimizations (UEPCOP) | 202d? | 2013-12-06 A | 2014-09-11 A | 100% |  | 2013-12-06 | 2014-09-12 | 202d? |  | finish no earlier than 2014-09-12 | C1 | 1608h | 1608h | MTCe-UEPCOP-CT1 | 32 | 24.008; 24.301 | Ericsson | mikael.wass@ericsson.com | Rel-12 | 62 | MTC, M2M |  |  | Frederic |  |  |
| 5277 | 1901.7.3.2 | Deleted - CT4 part of Stage 3 for BB3: UE Power Consumptions Optimizations (UEPCOP) | 201d? | 2013-12-09 A | 2014-09-11 A | 100% |  | 2013-12-09 | 2014-09-12 | 201d? |  | finish no earlier than 2014-09-12 | C4 | 1608h | 1608h | MTCe-UEPCOP-CT4 | 32 | 29.274; 29.060; 23.008 | Ericsson | mikael.wass@ericsson.com | Rel-12 | 62 | MTC, M2M |  |  | Kimmo | PCG-33 | CP-65 |
| 5278 | 1901.7.3.3 | CT6 part of Stage 3 for BB3: UE Power Consumptions Optimizations (UEPCOP) | 263d? | 2013-12-09 A | 2014-12-09 A | 100% |  | 2013-12-09 | 2014-09-12 | 201d? |  | finish no earlier than 2014-12-09 | C6 | 2104h | 2104h | MTCe-UEPCOP-CT6 | 32 | 31.101; 31.102; 31.111 | Ericsson | mikael.wass@ericsson.com | Rel-12 | 62 | MTC, M2M |  | CP-140697 | Xavier |  |  |
| 5279 | 1901.7.3.4 | UE Conformance Test Aspects - UE Power Consumptions Optimizations (UEPCOP) | 131d? | 2015-09-15 A | 2016-03-15 A | 100% |  |  |  |  |  | finish no earlier than 2016-03-15 | R5 | 1048h | 1048h | MTCe-UEPCOP-UEConTest | 35 |  | Ericsson |  | Rel-12 | 69 |  |  |  |  |  |  |
| 5280 | 1901.7.4 | Support of Power Saving Mode in GERAN | 5d? | 2014-08-25 A | 2014-08-29 A | 100% |  |  |  |  |  | finish no earlier than 2014-08-29 | G1 | 40h | 40h | MTCe-UEPCOP-GERAN | 33 | 43.022 | Ericsson | sajal.kumar.das@ericsson.com | Rel-12 | 63 |  | MTCe-UEPCOP-GERAN |  |  |  |  |
| 5281 | 1901.7.5 | Testing of Support of Power Saving Mode in GERAN | 132d? | 2015-11-11 A | 2016-03-23 | 10% | 118.8d? |  |  |  | 41505.2d | finish no earlier than 2016-05-12 | G3 | 1056h | 105.6h | MTCe-UEPCOP_GERAN3new | 36 |  | Ericsson | sajal.kumar.das@ericsson.com | Rel-12 | 70 |  | MTCe-UEPCOP-GERAN |  |  |  |  |
| 5282 | 1901.8 | Deleted - BB4: Group based MTC feature (GROUP) | 129d? | 2012-06-20 A | 2012-12-12 A | 100% |  | 2012-06-20 | 2012-12-12 | 129d? |  | finish no earlier than 2012-12-12 | S2 | 1032h | 1032h | MTCe-GROUP | 29 | 23.682 | KPN | Annemieke Kips | Rel-12 | 56 | MTC, M2M | MTCe-GROUP |  | Maurice | PCG-30 | SP-58 |

Notes:
- 5258: -
- 5259: CD:Thu 11/12/14->Sun 15/03/15¦Compl:25%->80%¦Stat Rep: RP-141327->RP-141863 1st Apr 15: Compl:80%->100% 1st Apr 15: Stat Rep: RP-141863->RP-150081
- 5260: -
- 5261: SP#59 completed. Define requirements for interworking with M2M service enablement layer specified by ETSI TC M2M in TS 102 689 ( specification for Service Enablement layer)
- 5262: SP#59 completed. Updated WID SP-120541=>SP-130105
- 5263: SP#63 completed. TR 33.868v100 for 1-step Approval. Was Rel-10 UID_460023 (Security for NIMTC). Was Rel-11 UID_490028 (TR on Security aspects of MTC). SP#56 activity transferred to Rel-12 Feature MTCe
- 5264: SP#63 completed. TS 33.187v100 for 1-step Approval
- 5265: -
- 5266: SP#62 completed. TR 23.887v200 for Approval
- 5267: SP#62 completed
- 5268: CP#65 updated WID CP-140272=>CP-140489
- 5269: CP#65 completed. Updated WID CP-140272=>CP-140489
- 5270: CP#64 completed
- 5271: SP#58 stopped (at 20% completion)
- 5272: -
- 5273: SP#62 completed. TR 23.887v200 for Approval
- 5274: SP#62 completed
- 5275: -
- 5276: CP#65 completed
- 5277: CP#65 stopped (no inpact on CT4)
- 5278: CP#65 completion 09/14=>12/14. Exception in CP-140697¦June2015: Compl:90%->100
- 5279: tested: MTCe-UEPCOP was a REL-12 SA2 WI¦NAS over LTE and UTRA;1/1/16: Compl:0%->25%22/3/16: C
- 5280: GP#63 approved WID and completed
- 5281: 7/12/15: created.02/3/16: acronym: MTCe-UEPCOP-GERAN_test->MTCe-UEPCOP_GERAN3new¦2/3/16: 0%->10
- 5282: SP#58 stopped (at 25% completion)

| ID | WBS | Task | Duration | Start | Finish | Complete | Baseline start | Baseline finish | Baseline duration | Constraint | Resources | Work | Actual work | Acronym | PCG approved | WI rapporteur name | WI rapporteur e-mail | Release | TSG approved | MCC resp | Special Focus Doc | Acronym_3GU_Export | Status Report | PCG stopped | TSG stopped |
| --- | --- | --- | --- | --- | --- | --- | --- | --- | --- | --- | --- | --- | --- | --- | --- | --- | --- | --- | --- | --- | --- | --- | --- | --- | --- |
| 5283 | 1901.9 | **RAN enhancements for Machine-Type and other mobile data applications Communications** | 228.7d? | 2014-02-03 A | 2014-09-12 A | 100% | 2014-02-03 | 2014-09-12 | 160.2d? |  | R2; R3 | 3651h | 3651h | MTCe-RAN | 32 | ZTE | sergio.parolari@zte.com.cn | Rel-12 | 62 | Yong-Jun | MTC, M2M | MTCe-RAN |  |  |  |
| 5284 | 1901.9.1 | Core part: RAN enhancements for Machine-Type and other mobile data applications Communications | 133d? | 2014-02-03 A | 2014-09-12 A | 100% | 2014-02-03 | 2014-09-12 | 133d? | finish no earlier than 2014-09-12 | R2; R3 | 2128h | 2128h | MTCe-RAN-Core | 32 | ZTE | sergio.parolari@zte.com.cn | Rel-12 | 62 | Yong-Jun | MTC, M2M | MTCe-RAN-Core | RP-141096 |  |  |
| 5285 | 1902 | **Low cost & enhanced coverage MTC UE for LTE** | 1324.75d? | 2013-06-15 A | 2016-12-15 A | 100% | 2013-06-20 | 2015-03-13 | 456d? |  | R1; R2; R4 | 34104h | 34104h | LC_MTC_LTE | 31 | Vodafone | eric.bouton@vodafone.com | Rel-12 | 60 | Patrick | MTC, M2M | LC_MTC_LTE |  |  |  |
| 5286 | 1902.1 | Core part: Low cost & enhanced coverage MTC UE for LTE | 174.67d? | 2013-06-15 A | 2014-12-15 A | 100% | 2013-10-15 | 2014-09-12 | 108.67d? | finish no earlier than 2014-12-15 | R1; R2; R4 | 4192h | 4192h | LC_MTC_LTE-Core | 31 | Vodafone | eric.bouton@vodafone.com | Rel-12 | 60 | Patrick | MTC, M2M | LC_MTC_LTE-Core | RP-142024 |  |  |
| 5287 | 1902.2 | Perf. part: Low cost & enhanced coverage MTC UE for LTE | 522d? | 2013-06-15 A | 2015-06-15 A | 100% | 2013-06-20 | 2015-03-13 | 456d? | finish no earlier than 2015-06-15 | R4 | 4176h | 4176h | LC_MTC_LTE-Perf | 31 | Vodafone | eric.bouton@vodafone.com | Rel-12 | 60 | Issam | MTC, M2M | LC_MTC_LTE-Perf | RP-150915 |  |  |
| 5288 | 1902.3 | UE Conformance Test Aspects - Low cost & enhanced coverage MTC UE for LTE | 460d? | 2015-03-16 A | 2016-12-15 A | 100% |  |  |  | finish no earlier than 2016-12-15 | R5 | 3680h | 3680h | LC_MTC_LTE-UEConTest | 34 | Ericsson |  | Rel-12 | 67 |  |  |  |  |  |  |
| 5289 | 1903 | **Policy and Charging Control for supporting fixed broadband access networks** | 936.75d? | 2012-06-20 A | 2014-12-12 A | 100% | 2012-06-20 | 2014-09-17 | 595d? |  | S2; S1; S5; C3; C1; C4 | 84075.4h | 84075.4h | P4C | 29 | Huawei | marco.spini@huawei.com | Rel-12 | 56 | Maurice |  | P4C |  |  |  |
| 5290 | 1903.1 | Stage 1 for Policy and Charging Support for Fixed Mobile Convergence | 3d? | 2012-09-10 A | 2012-09-12 A | 100% | 2012-09-10 | 2012-09-12 | 3d? | finish no earlier than 2012-09-12 | S1 | 24h | 24h | P4C-FMC | 29 | Huawei | amar.deol@huawei.com | Rel-12 | 57 | Alain |  | P4C-FMC |  |  |  |
| 5291 | 1903.2 | **BB1: Policy and Charging Control for supporting traffic from fixed terminals and NSWO (Non Seamless WLAN Offload) traffic from 3GPP UEs in fixed broadband access networks (P4C-F)** | 936.75d? | 2012-06-20 A | 2014-12-12 A | 100% | 2012-06-20 | 2014-09-17 | 595d? |  | S2; S5; C3; C1; C4 | 45657.3h | 45657.3h | P4C-F | 29 | Huawei | marco.spini@huawei.com | Rel-12 | 56 | Maurice | WLAN | P4C-F |  |  |  |
| 5292 | 1903.2.1 | TR on Stage 2 for BB1: Policy and Charging Control for supporting traffic from fixed terminals and NSWO traffic from 3GPP UEs in fixed broadband access networks (P4C-F) | 539.9d? | 2012-06-20 A | 2014-12-12 A | 100% | 2012-06-20 | 2014-09-17 | 476.9d? | finish no earlier than 2014-12-12 | S2 | 4290.1h | 4290.1h | P4C-F-SA2TR | 29 | Huawei | marco.spini@huawei.com | Rel-12 | 56 | Maurice | WLAN |  |  |  |  |
| 5293 | 1903.2.2 | Stage 2 for BB1: Policy and Charging Control for supporting traffic from fixed terminals and NSWO traffic from 3GPP UEs in fixed broadband access networks (P4C-F) | 272.9d? | 2012-06-20 A | 2013-12-11 A | 100% | 2012-06-20 | 2013-12-11 | 272.9d? | finish no earlier than 2013-12-11 | S2 | 2183.2h | 2183.2h | P4C-F-SA2 | 29 | Huawei | marco.spini@huawei.com | Rel-12 | 56 | Maurice | WLAN |  |  |  |  |
| 5294 | 1903.2.3 | **Stage 3 for BB1: Policy and Charging Control for supporting traffic from fixed terminals and NSWO traffic from 3GPP UEs in fixed broadband access networks** | 290.75d? | 2013-09-06 A | 2014-06-13 A | 100% | 2013-09-06 | 2014-06-13 | 203d? |  | C3; C1; C4 | 8088h | 8088h | P4C-F-CT3 | 31 | Huawei | Xia Haitao (xiahaitao@huawei.com) | Rel-12 | 61 | Adrian | WLAN | P4C-F-CT3 |  |  |  |
| 5295 | 1903.2.3.1 | CT3 part of Stage 3 for BB1: Policy and Charging Control for supporting traffic from fixed terminals and NSWO traffic from 3GPP UEs in fixed broadband access networks | 203d? | 2013-09-06 A | 2014-06-13 A | 100% | 2013-09-06 | 2014-06-13 | 203d? | finish no earlier than 2014-06-13 | C3 | 1608h | 1608h | P4C-F-CT3 | 31 | Huawei | Xia Haitao (xiahaitao@huawei.com) | Rel-12 | 61 | Adrian | WLAN |  |  |  |  |
| 5296 | 1903.2.3.2 | CT1 part of Stage 3 for BB1: Policy and Charging Control for supporting traffic from fixed terminals and NSWO traffic from 3GPP UEs in fixed broadband access networks | 65d? | 2013-12-06 A | 2014-03-05 A | 100% | 2013-12-06 | 2014-03-05 | 65d? | finish no earlier than 2014-03-05 | C1 | 512h | 512h | P4C-F-CT3 | 32 | Huawei | Xia Haitao (xiahaitao@huawei.com) | Rel-12 | 62 | Frederic | WLAN |  |  |  |  |
| 5297 | 1903.2.3.3 | CT4 part of Stage 3 for BB1: Policy and Charging Control for supporting traffic from fixed terminals and NSWO traffic from 3GPP UEs in fixed broadband access networks | 137d? | 2013-12-06 A | 2014-06-13 A | 100% | 2013-12-06 | 2014-06-13 | 137d? | finish no earlier than 2014-06-13 | C4 | 1096h | 1096h | P4C-F-CT3 | 32 | Huawei | Xia Haitao (xiahaitao@huawei.com) | Rel-12 | 62 | Kimmo | WLAN |  |  |  |  |
| 5298 | 1903.2.4 | Policy and Charging Enforcement Function (PCEF) based Charging for traffic from fixed terminals and NSWO traffic from 3GPP UEs in fixed broadband access networks (Stage 2/3) | 326d? | 2013-06-21 A | 2014-09-17 A | 100% | 2013-06-21 | 2014-09-17 | 326d? | finish no earlier than 2014-09-17 | S5 | 2608h | 2608h | P4C-F-CH_P | 31 | Alcatel-Lucent | maryse.gardella@alcatel-lucent.com | Rel-12 | 60 | Mirko | WLAN | P4C-F-CH_P |  |  |  |
| 5299 | 1903.2.5 | Traffic Detection Function (TDF) based Charging for traffic from fixed terminals and NSWO traffic from 3GPP UEs in fixed broadband access networks (Stage 2/3) | 261d? | 2013-06-24 A | 2014-06-18 A | 100% | 2013-06-24 | 2014-06-18 | 261d? | finish no earlier than 2014-06-18 | S5 | 2088h | 2088h | P4C-F-CH_T | 31 | Openet Telecom | alan.mcnamee@openet.com | Rel-12 | 60 | Mirko | WLAN | P4C-F-CH_T |  |  |  |
| 5300 | 1903.3 | **BB2: Policy and Charging Control for 3GPP UEs connected to BroadBand Forum access network as Trusted network in Interworking scenario (P4C-TI)** | 377.38d? | 2012-06-20 A | 2013-06-19 A | 100% | 2012-06-20 | 2013-06-19 | 266d? |  | S2 | 2610.07h | 2610.07h | P4C-TI | 29 | Alcatel-Lucent | konstantin.livanos@alcatel-lucent.com | Rel-12 | 56 | Maurice |  | P4C-TI |  |  |  |
| 5301 | 1903.3.1 | TR on Stage 2 for BB2: Policy and Charging Control for 3GPP UEs connected to BroadBand Forum access network as Trusted network in Interworking scenario (P4C-TI) | 109.2d? | 2012-06-20 A | 2013-06-19 A | 100% | 2012-06-20 | 2013-06-19 | 109.2d? | finish no earlier than 2013-06-06 | S2 | 862.87h | 862.87h | P4C-TI-SA2TR | 29 | Alcatel-Lucent | konstantin.livanos@alcatel-lucent.com | Rel-12 | 56 | Maurice |  |  |  |  |  |
| 5302 | 1903.3.2 | Stage 2 for BB2: Policy and Charging Control for 3GPP UEs connected to BroadBand Forum access network as Trusted network in Interworking scenario (P4C-TI) | 109.2d? | 2012-06-20 A | 2013-06-19 A | 100% | 2012-06-20 | 2013-06-19 | 109.2d? | finish no earlier than 2013-06-19 | S2 | 873.6h | 873.6h | P4C-TI-SA2 | 29 | Alcatel-Lucent | konstantin.livanos@alcatel-lucent.com | Rel-12 | 56 | Maurice |  |  |  |  |  |
| 5303 | 1903.4 | Deleted - BB3: Policy and Charging Control for 3GPP UEs connected to fixed broadband access network via S2b and S2c reference points for EPC routed traffic (P4C-S2bc) | 128d? | 2012-06-21 A | 2012-12-12 A | 100% | 2012-06-21 | 2012-12-12 | 128d? | finish no earlier than 2012-12-12 | S2 | 1024h | 1024h | P4C-S2bc | 29 | ZTE | Tricci So (tso@zteusa.com) | Rel-12 | 56 | Maurice |  | P4C-S2bc |  | PCG-30 | SP-58 |
| 5304 | 1903.5 | Deleted - BB4: Policy and Charging Control for EPC routed traffic over fixed broadband access networks of 3GPP UEs connected via H(e)NB in convergent scenarios (P4C-HeNB) | 128d? | 2012-06-21 A | 2012-12-12 A | 100% | 2012-06-21 | 2012-12-12 | 128d? | finish no earlier than 2012-12-12 | S2 | 1024h | 1024h | P4C-HeNB | 29 | NEC | Stefan.Schmid@neclab.eu | Rel-12 | 56 | Maurice |  | P4C-HeNB |  | PCG-30 | SP-58 |
| 5305 | 1903.6 | Deleted - BB5: Policy and Charging Control for supporting Layer 2 traffic in fixed broadband access network (P4C-FL2) | 128d? | 2012-06-21 A | 2012-12-12 A | 100% | 2012-06-21 | 2012-12-12 | 128d? | finish no earlier than 2012-12-12 | S2 | 1024h | 1024h | P4C-FL2 | 29 | Huawei | marco.spini@huawei.com | Rel-12 | 56 | Maurice |  | P4C-FL2 |  | PCG-30 | SP-58 |
| 5306 | 1903.7 | Deleted - BB6: Policy and Charging Control for 3GPP UEs connected to fixed broadband access networks via S2a reference point for EPC routed traffic in convergence (P4C-TC) | 129d? | 2012-06-20 A | 2012-12-12 A | 100% | 2012-06-20 | 2012-12-12 | 129d? | finish no earlier than 2012-12-12 | S2 | 1032h | 1032h | P4C-TC | 29 | ZTE | Tricci So (tso@zteusa.com) | Rel-12 | 56 | Maurice |  | P4C-TC |  | PCG-30 | SP-58 |

Notes:
- 5283: Triggered by TR 23.887 Machine Type and other mobile data applications Communications Enhancements (MTCe), TR 37.869 Study on Enhancements MTC and other Mobile Data Applications¦RAN aspects (FS_MTCe_RAN), Rel-11 TR 23.888 SIMTC / Impacted TSs and TRs: UTRA; LTE
- 5284: RP#65 completed / Impacted TSs and TRs: 25.300; 25.304; 25.413; 36.300; 36.304; 36.413; 36.423
- 5285: Triggered by Rel-11 TR 36.888 (FS_LC_MTC_UE) / Impacted TSs and TRs: LTE
- 5286: ¦CD:Thu 18/06/15->Mon 15/06/15¦WID: RP-130848->RP-140522¦Stat Rep: RP-141221->RP-142024 / Impacted TSs and TRs: 36.101; 36.104; 36.133; 36.201; 36.211; 36.212; 36.213; 36.300; 36.302; 36.306; 36.321; 36.331
- 5287: ¦CD:Thu 18/06/15->Mon 15/06/15¦WID: RP-130848->RP-140522¦Stat Rep: RP-141221->RP-142024 1st Apr 15: Compl:65%->90% 1st Apr 15: CD:Sun 15/03/15->Mon 15/06/15 1st Apr 15: Stat Rep: RP-142024->RP-150149 03/07/15: Compl:90%->100% 03/07/15: WID: RP-14052 / Impacted TSs and TRs: 36.101; 36.104; 36.133
- 5288: 03/07/15: Compl:0%->13% 03/07/15: WID: RP-150135->RP-150838 03/07/15: Stat Rep: ->RP-150833 29/09/15: Compl:13%->25% 29/09/15: Stat Rep: RP-150833->RP-151165 ¦1/1/16: Compl:25%->70% ¦1/1/16: CD:Tue 15/12/15->Tue 15/03/16
- 5289: Linked to BBF, IETF work. SP#58 stopped BB3 to BB6. Split BB1 and BB2 into TR and Stage 2 work / Impacted TSs and TRs: Stage 1/2/3
- 5290: SP#57 completed / Impacted TSs and TRs: 22.278
- 5291: -
- 5292: SP#64 TR 23.896 was never sent for approval due to incomplete P4C BBs. SP#61 TR 23.896v100 for Information. Dec.14: 90->100%. Mar15: 23.896 for approval. / Impacted TSs and TRs: new 23.896
- 5293: SP#62 completed / Impacted TSs and TRs: 23.139; 23.203
- 5294: - / Impacted TSs and TRs: Stage 3
- 5295: CP#64 completed / Impacted TSs and TRs: 29.212; 29.213; 29.215; 29.219
- 5296: CP#63 completed / Impacted TSs and TRs: 24.302
- 5297: CP#64 completed / Impacted TSs and TRs: 29.273
- 5298: SP#65 completed. Introduce Charging Characteristics in Convergent scenario, Include missing fixed user location information for NSWO / Impacted TSs and TRs: Stage 2 (32.240; 32.251); Stage 3 (32.298; 32.299)
- 5299: SP#64 completed / Impacted TSs and TRs: Stage 2 (32.240; 32.251); Stage 3 (32.298; 32.299)
- 5300: -
- 5301: SP#60 completed / Impacted TSs and TRs: new 23.839
- 5302: SP#60 completed / Impacted TSs and TRs: 23.139; 23.203
- 5303: SP#58 stopped (at 0% completion) / Impacted TSs and TRs: 23.139; 23.203; new 23.896
- 5304: SP#58 stopped (at 0% completion) / Impacted TSs and TRs: 23.139; 23.203; new 23.896
- 5305: SP#58 stopped (at 0% completion) / Impacted TSs and TRs: 23.139; 23.203; new 23.896
- 5306: SP#58 stopped (at 30% completion) / Impacted TSs and TRs: 23.139; 23.203; new 23.896

| ID | WBS | Task | Duration | Start | Finish | Complete | Baseline start | Baseline finish | Baseline duration | Constraint | Resources | Work | Actual work | Acronym | PCG approved | Impacted TSs and TRs | WI rapporteur name | WI rapporteur e-mail | Release | TSG approved | MCC resp | Acronym_3GU_Export | Status Report | Special Focus Doc | PCG stopped | TSG stopped |
| --- | --- | --- | --- | --- | --- | --- | --- | --- | --- | --- | --- | --- | --- | --- | --- | --- | --- | --- | --- | --- | --- | --- | --- | --- | --- | --- |
| 5307 | 1904 | **IMS Business Trunking for IP-PBX in Static Mode of Operation** | 1208.22d? | 2011-09-28 A | 2014-12-09 A | 100% | 2011-09-28 | 2014-09-12 | 782.1d? |  | S2; S1; C1; C3 | 43555.2h | 43555.2h | BusTI | 29 | Stage 1/2/3 | Deutsche Telekom | michele.zarri@telekom.com | Rel-12 | 56 | Maurice | BusTI |  |  |  |  |
| 5308 | 1904.1 | Stage 1 for IMS Business Trunking for IP-PBX in Static Mode of Operation | 64d? | 2011-09-28 A | 2012-09-12 A | 100% | 2011-09-28 | 2012-09-12 | 64d? | finish no earlier than 2012-08-30 | S1 | 504h | 504h | BusTI-SA1 | 29 | 22.228 | Deutsche Telekom | kurt.bischinger@t-mobile.at | Rel-12 | 56 | Alain |  |  |  |  |  |
| 5309 | 1904.2 | TR on IMS Business Trunking for IP-PBX in Static Mode of Operation | 268d? | 2012-06-18 A | 2013-06-19 A | 100% | 2012-06-18 | 2013-06-19 | 268d? | finish no earlier than 2013-06-19 | S2; S1 | 4288h | 4288h | BusTI-SATR | 29 | new 23.897 | Deutsche Telekom | michele.zarri@telekom.com | Rel-12 | 56 | Maurice |  |  |  |  |  |
| 5310 | 1904.3 | Stage 2 for IMS Business Trunking for IP-PBX in Static Mode of Operation | 263d? | 2012-06-25 A | 2013-06-19 A | 100% | 2012-06-25 | 2013-06-19 | 263d? | finish no earlier than 2013-06-19 | S2 | 2104h | 2104h | BusTI-SA2 | 29 | 23.228 | Deutsche Telekom | michele.zarri@telekom.com | Rel-12 | 56 | Maurice |  |  |  |  |  |
| 5311 | 1904.4 | **CT aspects of IMS Business Trunking for IP-PBX in Static Mode of Operation (Stage 3)** | 475.88d? | 2013-09-06 A | 2014-12-09 A | 100% | 2013-09-06 | 2014-09-12 | 268d? |  | C1; C3 | 9552h | 9552h | BusTI-CT | 31 | Stage 3 | Deutsche Telekom | michael.kreipl@telekom.de | Rel-12 | 61 | Frederic | BusTI-CT |  |  |  |  |
| 5312 | 1904.4.1 | CT1 part of CT aspects of IMS Business Trunking for IP-PBX in Static Mode of Operation (Stage 3) | 329d? | 2013-09-06 A | 2014-12-09 A | 100% | 2013-09-06 | 2014-09-12 | 267d? | finish no earlier than 2014-12-09 | C1 | 2632h | 2632h | BusTI-CT | 31 | 23.218; 24.229; 24.525 (transfer of ETSI 182 025) | Deutsche Telekom | michael.kreipl@telekom.de | Rel-12 | 61 | Frederic |  | CP-140607 |  |  |  |
| 5313 | 1904.4.2 | CT3 part of CT aspects of IMS Business Trunking for IP-PBX in Static Mode of Operation (Stage 3) | 201d? | 2013-09-06 A | 2014-06-11 A | 100% | 2013-09-06 | 2014-06-13 | 201d? | finish no earlier than 2014-06-13 | C3 | 1608h | 1608h | BusTI-CT | 31 | 29.165 | Deutsche Telekom | michael.kreipl@telekom.de | Rel-12 | 61 | Adrian |  |  |  |  |  |
| 5314 | 1905 | **WLAN Network Selection for 3GPP Terminals** | 935.75d? | 2012-06-18 A | 2014-12-09 A | 100% | 2012-06-18 | 2014-09-12 | 594d? |  | S2; S1; S3; C1 | 35272h | 35272h | WLAN_NS | 29 | Stage 1/2/3 | Intel | vivek.g.gupta@intel.com | Rel-12 | 56 | Maurice | WLAN_NS |  | WLAN |  |  |
| 5315 | 1905.1 | TR on Stage 2 for WLAN Network Selection for 3GPP Terminals | 396d? | 2012-06-18 A | 2013-12-11 A | 100% | 2012-06-18 | 2013-12-11 | 396d? | finish no earlier than 2013-12-11 | S2; S1 | 6336h | 6336h | WLAN_NS-SATR | 29 | New 23.865 | Intel | vivek.g.gupta@intel.com | Rel-12 | 56 | Maurice |  |  | WLAN |  |  |
| 5316 | 1905.2 | Stage 2 for WLAN Network Selection for 3GPP Terminals | 392d? | 2012-06-22 A | 2013-12-11 A | 100% | 2012-06-22 | 2013-12-11 | 392d? | finish no earlier than 2013-12-11 | S2 | 3136h | 3136h | WLAN_NS-SA2 | 29 | 23.402; 23.865 | Intel | vivek.g.gupta@intel.com | Rel-12 | 56 | Maurice |  |  | WLAN |  |  |
| 5317 | 1905.3 | Deleted - TR on Security Aspects of WLAN Network Selection for 3GPP Terminals | 326d? | 2012-12-13 A | 2014-03-07 A | 100% | 2012-12-13 | 2014-03-07 | 326d? | finish no earlier than 2014-03-07 | S3 | 2608h | 2608h | WLAN_Nsdel | 30 | New 33.865 | Huawei | Lydia Xu (xuyixian@huawei.com) | Rel-12 | 58 | Mirko |  |  | WLAN | PCG-32 | CP-63 |
| 5318 | 1905.4 | CT aspects of WLAN Network Selection for 3GPP Terminals (Stage 3) | 263d? | 2013-12-06 A | 2014-12-09 A | 100% | 2013-12-06 | 2014-09-12 | 201d? | finish no earlier than 2014-12-09 | C1 | 2104h | 2104h | WLAN_NS-CT | 32 | 24.302; 24.312 | Qualcomm | Amer Catovic, amerc@qualcomm.com | Rel-12 | 62 | Frederic | WLAN_NS-CT | CP-140622 | WLAN |  |  |
| 5319 | 1906 | **Deleted - IMS Registration Control** | 704.12d? | 2012-01-31 A | 2013-12-11 A | 100% | 2012-01-31 | 2013-12-11 | 496d? |  | S1; S2; C1; C4 | 23400h | 23400h | IMS_RegCon | 29 | Stage 1/2/3 | China Mobile | lulu@chinamobile.com | Rel-12 | 57 | Alain | IMS_RegCon |  |  | PCG-32 | SP-62 |
| 5320 | 1906.1 | Deleted - Stage 1 for IMS Registration Control | 164d? | 2012-01-31 A | 2012-09-12 A | 100% | 2012-01-31 | 2012-09-12 | 164d? | finish no earlier than 2012-09-12 | S1 | 1304h | 1304h | IMS_RegCon-del1 | 29 | 22.228 | China Mobile | lulu@chinamobile.com | Rel-12 | 57 | Alain |  |  |  | PCG-32 | SP-62 |
| 5321 | 1906.2 | Deleted - Stage 2 for IMS Registration Control | 262d? | 2012-12-13 A | 2013-12-11 A | 100% | 2012-12-13 | 2013-12-11 | 262d? | finish no earlier than 2013-12-11 | S2 | 2096h | 2096h | IMS_RegCon-del2 | 30 | 23.228 | China Mobile | Jiang Yi (jiangyi@chinamobile.com) | Rel-12 | 58 | Maurice |  |  |  | PCG-32 | SP-62 |
| 5322 | 1906.3 | **Deleted - CT aspects of IMS registration control** | 181.88d? | 2013-06-19 A | 2013-12-11 A | 100% | 2013-06-19 | 2013-12-11 | 129d? |  | C1; C4 | 4128h | 4128h | IMS_RegCon-CT | 31 | Stage 2/3 | China Mobile | Jiang Yi (jiangyi@chinamobile.com) | Rel-12 | 60 | Frederic | IMS_RegCon-CT |  |  | PCG-32 | SP-62 |
| 5323 | 1906.3.1 | Deleted - CT1 aspects of CT aspects of IMS registration control (Stage 2/3) | 129d? | 2013-06-19 A | 2013-12-11 A | 100% | 2013-06-19 | 2013-12-11 | 129d? | finish no earlier than 2013-12-11 | C1 | 1032h | 1032h | IMS_RegCon-CT1 | 31 | 23.218; 24.229 | China Mobile | Jiang Yi (jiangyi@chinamobile.com) | Rel-12 | 60 | Frederic |  |  |  | PCG-32 | SP-62 |
| 5324 | 1906.3.2 | Deleted - CT4 aspects of CT aspects of IMS registration control (Stage 3) | 129d? | 2013-06-19 A | 2013-12-11 A | 100% | 2013-06-19 | 2013-12-11 | 129d? | finish no earlier than 2013-12-11 | C4 | 1032h | 1032h | IMS_RegCon-CT4 | 31 | 29.228; 29.229; 23.008 | China Mobile | Jiang Yi (jiangyi@chinamobile.com) | Rel-12 | 60 | Kimmo |  |  |  | PCG-32 | SP-62 |
| 5325 | 1907 | **Proximity-based Services** | 1703.5d? | 2012-12-13 A | 2017-06-15 A | 100% | 2012-12-13 | 2015-03-13 | 593d? |  |  | 36376.8h | 36376.8h | ProSe | 30 | Stage 1/2 | Qualcomm | Rich Hovey (rhovey@qualcomm.com) | Rel-12 | 58 | Alain | ProSe |  | Public Safety (A-A) |  |  |
| 5326 | 1907.1 | Stage 1 for Proximity-based Services | 137d? | 2012-12-13 A | 2013-06-19 A | 100% | 2012-12-13 | 2013-06-19 | 137d? | finish no earlier than 2013-06-19 | S1 | 1088h | 1088h | ProSe-SA1 | 30 | 22.115; 22.278 | Qualcomm | Rich Hovey (rhovey@qualcomm.com) | Rel-12 | 58 | Alain |  |  | Public Safety (A-A) |  |  |
| 5327 | 1907.2 | TR on Stage 2 for Proximity-based Services | 327d? | 2012-12-13 A | 2014-03-07 A | 100% | 2012-12-13 | 2014-03-07 | 327d? | finish no earlier than 2014-03-07 | S2 | 2608h | 2608h | ProSe-SA2TR | 30 | New 23.703 | Qualcomm | Haris Zisimopoulos (harisz@qti.qualcomm.com) | Rel-12 | 58 | Maurice |  |  | Public Safety (A-A) |  |  |
| 5328 | 1907.3 | Stage 2 for Proximity-based Services | 397d? | 2012-12-19 A | 2014-06-18 A | 100% | 2012-12-19 | 2014-06-18 | 397d? | finish no earlier than 2014-06-18 | S2 | 3168.8h | 3168.8h | ProSe-SA2 | 30 | New 23.303 | Qualcomm | Haris Zisimopoulos (harisz@qti.qualcomm.com) | Rel-12 | 58 | Maurice |  |  | Public Safety (A-A) |  |  |
| 5329 | 1907.4 | Security for Proximity-based Services | 464d? | 2013-03-13 A | 2014-12-12 A | 100% | 2013-03-13 | 2014-06-18 | 336d? | finish no earlier than 2014-12-12 | S3 | 3712h | 3712h | ProSe-SA3 | 30 | 33.220; New 33.303 | Qualcomm | Adrian Escott (aescott@qti.qualcomm.com) | Rel-12 | 59 | Mirko |  | SP-140584 | Public Safety (A-A) |  |  |
| 5330 | 1907.5 | (IETF) Security for Proximity-based Services (ietf-avtcore-srtp-aes-gcm) | 63d? | 2014-09-12 A | 2014-12-09 A | 100% |  |  |  | finish no earlier than 2014-12-09 | S3-IETF | 504h | 504h | ProSe | 33 | RFC 7714 (was ietf-avtcore-srtp-aes-gcm); RFC 7714 | Atle Monrad | atle.monrad@ericsson.com | Rel-12 | 65 |  |  |  | Public Safety (A-A) |  |  |

Notes:
- 5307: Linked to Rel-11 IPXS Feature UID_470051 Advanced IP Interconnection of Services. This WI defines a generic framework for interconnecting with any type of IMS based network including IP-PBXs.
- 5308: SP#57 completed. 22.228CR#0171
- 5309: SP#60 completed
- 5310: SP#60 completed
- 5311: -
- 5312: CP#65 completion 09/14=>12/14. Exception in CP-140607. Dec.14: 85->100%
- 5313: CP#64 completed
- 5314: Evaluate and if needed enhance existing 3GPP solutions for WLAN network selection taking into account WFA Hotspot 2.0 solutions
- 5315: SP#62 completed
- 5316: SP#62 completed
- 5317: SP#63 stopped (84% complete)
- 5318: CP#65 completion 09/14=>12/14. CP#65 exception CP-140622. Dec.14: 95->100%
- 5319: SP#62 stopped. Specify for fixed line the requirement of controlling user registration to IMS based on network information related to user location (e.g. IP address, DSLAM information)
- 5320: SP#57 completed
- 5321: SP#62 stopped at 50% completion
- 5322: SP#62 no CT/Stage 3 work is needed (stopped at 0% completion)
- 5323: SP#62 no CT/Stage 3 work is needed (stopped at 0% completion)
- 5324: SP#62 no CT/Stage 3 work is needed (stopped at 0% completion)
- 5325: SP#65 SA3 updated the SA-wide WID SP-140300=>SP-140574 (Moved the TR phase to Rel-13 as a stand-alone Study). Triggered by Rel-12 TR 22.803 Study on Proximity-based Services (FS_ProSe) UID_530044
- 5326: SP#60 completed
- 5327: SP#63 completed. TR 23.703v200 for Approval
- 5328: SP#64 completed open issue/alignment to RAN/SA3 decisions. SP#63 TS 23.303v100 for 1-step Approval
- 5329: SP#65 re-opened. Completion 06/14=>12/14. Exception in SP-140584. Updated WID SP-140300=>SP-140574 (Moved the TR phase to Rel-13 as a stand-alone Study). SP#64 completed. TS 33.303 v100 for 1-step Approval¦Aug2015: 90%->100
- 5330: Submitted to IESG for publication¦7/3/16: 75%->100; 9/4/21: RFC 7714 added;

| ID | WBS | Task | Duration | Start | Finish | Complete | Baseline start | Baseline finish | Baseline duration | Constraint | Resources | Work | Actual work | Acronym | PCG approved | WI rapporteur name | WI rapporteur e-mail | Release | TSG approved | Status Report | Special Focus Doc | Acronym_3GU_Export | MCC resp |
| --- | --- | --- | --- | --- | --- | --- | --- | --- | --- | --- | --- | --- | --- | --- | --- | --- | --- | --- | --- | --- | --- | --- | --- |
| 5331 | 1907.6 | **Charging Aspects of Proximity-based Services** | 277.12d? | 2014-06-19 A | 2015-03-13 A | 100% | 2014-06-18 | 2014-09-17 | 66d? |  | S5 | 4160h | 4160h | ProSe-CH | 33 | Qualcomm | Cheng Hong (hongc@qti.qualcomm.com) | Rel-12 | 64 | SP-140543 | Public Safety (A-A) | ProSe-CH |  |
| 5332 | 1907.6.1 | Study on Charging support for ProSe one-to-many Direct Communication for Public Safety use | 130d? | 2014-06-19 A | 2014-12-12 A | 100% | 2014-06-18 | 2014-09-17 | 66d? | finish no earlier than 2014-12-12 | S5 | 1040h | 1040h | ProSe-CH-SA5TR | 33 | Qualcomm | Cheng Hong (hongc@qti.qualcomm.com) | Rel-12 | 64 | SP-140543 | Public Safety (A-A) |  |  |
| 5333 | 1907.6.2 | Specification of Charging Aspects of Proximity-based Services | 195d? | 2014-06-19 A | 2015-03-13 A | 100% | 2014-06-18 | 2014-09-17 | 66d? | finish no earlier than 2015-03-13 | S5 | 1560h | 1560h | ProSe-CH-SA5 | 33 | Qualcomm | Cheng Hong (hongc@qti.qualcomm.com) | Rel-12 | 64 | SP-140543 | Public Safety (A-A) |  |  |
| 5334 | 1907.7 | **CT aspects of Proximity-based Services (Stage 3)** | 289.62d? | 2014-03-05 A | 2014-12-09 A | 100% | 2014-03-05 | 2014-09-12 | 138d? |  |  | 6392h | 6392h | ProSe-CT | 32 | Qualcomm | Lena Chaponniere (lguellec@qti.qualcomm.com) | Rel-12 | 63 |  | Public Safety (A-A) | ProSe-CT | Frederic |
| 5335 | 1907.7.1 | CT1 part of CT aspects of Proximity-based Services | 200d? | 2014-03-05 A | 2014-12-09 A | 100% | 2014-03-05 | 2014-09-12 | 138d? | finish no earlier than 2014-12-09 | C1 | 1600h | 1600h | ProSe-CT | 32 | Qualcomm | Lena Chaponniere (lguellec@qti.qualcomm.com) | Rel-12 | 63 | CP-140615 | Public Safety (A-A) |  | Frederic |
| 5336 | 1907.7.2 | CT3 part of CT aspects of Proximity-based Services | 200d? | 2014-03-05 A | 2014-12-09 A | 100% | 2014-03-05 | 2014-09-12 | 138d? | finish no earlier than 2014-12-09 | C3 | 1600h | 1600h | ProSe-CT | 32 | Qualcomm | Lena Chaponniere (lguellec@qti.qualcomm.com) | Rel-12 | 63 | CP-140568 | Public Safety (A-A) |  | Adrian |
| 5337 | 1907.7.3 | CT4 part of CT aspects of Proximity-based Services | 200d? | 2014-03-05 A | 2014-12-09 A | 100% | 2014-03-05 | 2014-09-12 | 138d? | finish no earlier than 2014-12-09 | C4 | 1600h | 1600h | ProSe-CT | 32 | Qualcomm | Lena Chaponniere (lguellec@qti.qualcomm.com) | Rel-12 | 63 | CP-140484 | Public Safety (A-A) |  | Kimmo |
| 5338 | 1907.7.4 | CT6 part of CT aspects of Proximity-based Services | 199d? | 2014-03-06 A | 2014-12-09 A | 100% | 2014-03-06 | 2014-09-12 | 137d? | finish no earlier than 2014-12-09 | C6 | 1592h | 1592h | ProSe-CT | 32 | Qualcomm | Lena Chaponniere (lguellec@qti.qualcomm.com) | Rel-12 | 63 | CP-140695 | Public Safety (A-A) |  | Xavier |
| 5339 | 1907.8 | **LTE Device to Device Proximity Services** | 1235d? | 2014-03-11 A | 2017-06-15 A | 100% | 2014-03-06 | 2015-03-13 | 267d? |  |  | 14744h | 14744h | LTE_D2D_Prox | 32 | Qualcomm | Shailesh Patil (patil@qti.qualcomm.com) | Rel-12 | 63 |  | Public Safety (A-A) | LTE_D2D_Prox | Patrick |
| 5340 | 1907.8.1 | Core part: LTE Device to Device Proximity Services | 263d? | 2014-03-15 A | 2015-03-13 A | 100% | 2014-07-11 | 2014-09-12 | 45.67d? | finish no earlier than 2015-03-15 | R1; R2; R4 | 6312h | 6312h | LTE_D2D_Prox-Core | 32 | Qualcomm | Shailesh Patil (patil@qti.qualcomm.com) | Rel-12 | 63 | RP-150094 | Public Safety (A-A) | LTE_D2D_Prox-Core | Patrick |
| 5341 | 1907.8.2 | Perf. part: LTE Device to Device Proximity Services | 464d? | 2014-03-11 A | 2015-12-15 A | 100% | 2014-03-06 | 2015-03-13 | 267d? | finish no earlier than 2015-12-15 | R4 | 3712h | 3712h | LTE_D2D_Prox-Perf | 32 | Qualcomm | Shailesh Patil (patil@qti.qualcomm.com) | Rel-12 | 63 | RP-151276 | Public Safety (A-A) | LTE_D2D_Prox-Perf | Issam |
| 5342 | 1907.8.3 | UE Conformance Test Aspects – LTE Device-to-Device Proximity Services | 590d? | 2015-03-16 A | 2017-06-15 A | 100% |  |  |  | finish no earlier than 2017-06-15 | R5 | 4720h | 4720h | LTE_D2D_Prox-UEConTest | 34 | Qualcomm | svora@qti.qualcomm.com | Rel-12 | 67 |  |  |  |  |
| 5343 | 1908 | **Web Real Time Communication access to IMS** | 2355d? | 2012-12-14 A | 2019-03-07 A | 100% | 2012-12-14 | 2014-12-10 | 525d? |  | S1; S2; S3 | 91745.9h | 91745.9h | IMS_WebRTC | 30 | China Mobile | lulu@chinamobile.com | Rel-12 | 58 |  |  | IMS_WebRTC | Alain |
| 5344 | 1908.1 | Stage 1 for Web Real Time Communication access to IMS | 136d? | 2012-12-14 A | 2013-06-19 A | 100% | 2012-12-14 | 2013-06-19 | 136d? | finish no earlier than 2013-06-19 | S1 | 1088h | 1088h | IMS_WebRTC | 30 | China Mobile | lulu@chinamobile.com | Rel-12 | 58 |  |  |  | Alain |
| 5345 | 1908.2 | TR on Stage 2 for Web Real Time Communication access to IMS | 126d? | 2013-06-19 A | 2013-12-11 A | 100% | 2013-06-19 | 2013-12-11 | 126d? | finish no earlier than 2013-12-11 | S2 | 1008h | 1008h | IMS_WebRTC | 31 | China Mobile | Yu Qing (yuqing@chinamobile.com) | Rel-12 | 60 |  |  |  | Maurice |
| 5346 | 1908.3 | Stage 2 for Web Real Time Communication access to IMS | 192d? | 2013-06-19 A | 2014-03-07 A | 100% | 2013-06-19 | 2014-03-07 | 192d? | finish no earlier than 2014-03-07 | S2 | 1528h | 1528h | IMS_WebRTC | 31 | China Mobile | Yu Qing (yuqing@chinamobile.com) | Rel-12 | 60 |  |  |  | Maurice |
| 5347 | 1908.4 | (IETF) Web Real Time Communication access to IMS (draft-ietf-rtcweb-overview) | 391d? | 2013-06-25 A | 2014-12-12 A | 100% | 2013-06-19 | 2014-12-10 | 389d? | finish no earlier than 2014-12-12 | C1-IETF | 3128h | 3128h | IMS_WebRTC | 32 | Uwe Rauschenbach | Uwe Rauschenbach | Rel-12 | 63 |  |  |  |  |
| 5348 | 1908.5 | (IETF) WebRTC Data Channel Establishment Protocol (draft-ietf-rtcweb-data-protocol) | 391d | 2013-06-25 A | 2014-12-12 A | 100% |  |  |  | finish no earlier than 2014-12-12 | C1-IETF | 3128h | 3128h | IMS_WebRTC | 45 |  |  | Rel-12 | 88 |  |  |  |  |
| 5349 | 1908.6 | TR on Security for Web Real Time Communication access to IMS | 202d? | 2013-12-11 A | 2014-09-17 A | 100% | 2013-12-11 | 2014-09-17 | 202d? | finish no earlier than 2014-09-17 | S3 | 1608h | 1608h | IMS_WebRTC | 32 | Ericsson | oscar.ohlsson@ericsson.com | Rel-12 | 62 |  |  |  | Mirko |
| 5350 | 1908.7 | Security for Web Real Time Communication access to IMS | 202d? | 2013-09-12 A | 2014-06-18 A | 100% | 2013-09-12 | 2014-06-18 | 202d? | finish no earlier than 2014-06-18 | S3 | 1609.85h | 1609.85h | IMS_WebRTC | 31 | Ericsson | oscar.ohlsson@ericsson.com | Rel-12 | 61 |  |  |  | Mirko |
| 5351 | 1908.8 | **CT aspects of Web Real Time Communication (WebRTC) Access to IMS** | 1893.75d? | 2014-03-05 A | 2019-03-07 A | 100% | 2014-03-05 | 2014-12-05 | 198d? |  | C1; C4; IETF | 39408h | 39408h | IMS_WebRTC-CT | 32 | China Mobile | Jiang Yi (jiangyi@chinamobile.com) | Rel-12 | 63 |  |  | IMS_WebRTC-CT | Frederic |
| 5352 | 1908.8.1 | (IETF) Trickle ICE: Incremental Provisioning of Candidates for the Interactive Connectivity Establishment (ICE) Protocol (draft-ietf-ice-trickle) | 1d | 2019-03-07 A | 2019-03-07 A | 100% |  |  |  |  | C1-IETF | 8h | 8h | IMS_WebRTC-CT | 44 |  |  | Rel-12 | 87 |  |  |  |  |
| 5353 | 1908.8.2 | (IETF) Trickle ICE: Incremental Provisioning of Candidates for the Interactive Connectivity Establishment (ICE) Protocol (draft-ietf-ice-trickle) | 1d | 2019-03-07 A | 2019-03-07 A | 100% |  |  |  |  | C1-IETF | 8h | 8h | IMS_WebRTC-CT | 44 |  |  | Rel-12 | 87 |  |  |  |  |
| 5354 | 1908.8.3 | CT1 part of CT aspects of Web Real Time Communication (WebRTC) Access to IMS | 200d? | 2014-03-05 A | 2014-12-09 A | 100% | 2014-03-05 | 2014-09-12 | 138d? | finish no earlier than 2014-12-09 | C1 | 1600h | 1600h | IMS_WebRTC-CT1 | 32 | China Mobile | Jiang Yi (jiangyi@chinamobile.com) | Rel-12 | 63 | CP-140621 |  |  | Frederic |
| 5355 | 1908.8.4 | (IETF) Web Real Time Communication access to IMS (draft-ietf-rtcweb-data-channel) | 200d? | 2014-03-06 A | 2014-12-09 A | 100% | 2014-03-05 | 2014-12-05 | 198d? | finish no earlier than 2014-12-09 | C1-IETF | 1600h | 1600h | IMS_WebRTC-data | 33 | christer.holmberg@ericsson.com | christer.holmberg@ericsson.com | Rel-12 | 64 |  |  |  |  |
| 5356 | 1908.8.5 | (IETF) Web Real Time Communication access to IMS (draft-ietf-rtcweb-stun-consent-freshness) | 200d? | 2014-03-06 A | 2014-12-09 A | 100% | 2014-03-05 | 2014-12-05 | 198d? | finish no earlier than 2014-12-09 | C1-IETF | 1600h | 1600h | IMS_WebRTC-stun | 33 | christer.holmberg@ericsson.com | christer.holmberg@ericsson.com | Rel-12 | 64 |  |  |  |  |
| 5357 | 1908.8.6 | Deleted - (IETF) Web Real Time Communication access to IMS (draft-ietf-sipcore-sip-authn) | 63d? | 2014-09-12 A | 2014-12-05 A | 100% |  |  |  | finish no earlier than 2014-12-09 | C1-IETF | 504h | 504h | IMS_WebRTC-yusef | 33 | christer.holmberg@ericsson.com | christer.holmberg@ericsson.com | Rel-12 | 65 |  |  |  |  |
| 5358 | 1908.8.7 | (IETF) Third-Party Token-based Authentication and Authorization for Session Initiation Protocol (SIP) (draft-ietf-sipcore-sip-token-authnz) | 63d? | 2014-09-12 A | 2014-12-05 A | 100% |  |  |  | finish no earlier than 2014-12-09 | C1-IETF | 504h | 504h | IMS_WebRTC-yusef | 44 |  |  | Rel-12 | 87 |  |  |  |  |
| 5359 | 1908.8.8 | Deleted - (IETF) Web Real Time Communication access to IMS (draft-holmberg-sipcore-auth-id) | 65d? | 2014-09-12 A | 2014-12-09 A | 100% |  |  |  | start no earlier than 2014-09-12 | C1-IETF | 520h | 520h | IMS_WebRTC-holmb | 34 | christer.holmberg@ericsson.com |  | Rel-12 | 66 |  |  |  |  |
| 5360 | 1908.8.9 | CT4 part of CT aspects of Web Real Time Communication (WebRTC) Access to IMS | 200d? | 2014-03-05 A | 2014-12-09 A | 100% | 2014-03-05 | 2014-09-19 | 143d? | finish no earlier than 2014-12-09 | C4 | 1600h | 1600h | IMS_WebRTC-CT4 | 32 | China Mobile | Jiang Yi (jiangyi@chinamobile.com) | Rel-12 | 63 | CP-140732 |  |  | Kimmo |

Notes:
- 5331: SP#65 exception in SP-140543. Mar15: 85->100% / Impacted TSs and TRs: Stage 2/3
- 5332: SP#65 completion 09/14=>12/14. Exception in SP-140543. TR 32.844v100 for Information. Dec.14: CD: 09/14->12/14, 60->100% / Impacted TSs and TRs: New 32.844
- 5333: SP#65 completion 09/14=>12/14. Exception in SP-140543. SP#65 TR 32.277v100 for Information. Dec.14: CD: 09/14->03/15, 40->75%. Mar15: 75->100% / Impacted TSs and TRs: 32.240; 32.297; 32.298; 32.299; New 32.277
- 5334: CP#64 updated WID CP-140194=>CP-140290 / Impacted TSs and TRs: Stage 3
- 5335: CP#65 completion 09/14=>12/14. Exception in CP-140615. TS 24.333/4v200 for Approval. Dec.14: 90->100% / Impacted TSs and TRs: 24.301; 23.122; New TSs (24.333; 24.334)
- 5336: CP#65 completion 09/14=>12/14. TS 29.343v100 for 1-step Approval. Exception in CP-140568. Dec.14: 90->100 / Impacted TSs and TRs: New 29.343
- 5337: CP#65 completion 09/14=>12/14. TS 29.344/5v100 for 1-step Approval. Exception in CP-140484. Dec.14: 90->100 / Impacted TSs and TRs: 29.272; 23.008; 23.003; New TSs (29.344; 29.345)
- 5338: CP#65 completion 09/14=>12/14. Exception in CP-140695. Dec.14: 60->100% / Impacted TSs and TRs: 31.102
- 5339: follow-up of TR 36.843 FS_LTE_D2D_Prox / Impacted TSs and TRs: LTE
- 5340: ¦CD:Sat 15/03/14->Sun 15/03/15Compl:0%->95%¦CD:Fri 13/03/15->Sun 15/03/15¦Stat Rep: RP-141244->RP-141894 1st Apr 15: Compl:95%->100% 1st Apr 15: Stat Rep: RP-141894->RP-150094 / Impacted TSs and TRs: 36.101; 36.133; 36.211; 36.212; 36.213; 36.214; 36.300; 36.304; 36.306; 36.321; 36.322; 36.323; 36.331; 36.413; 36.423; New 36.877
- 5341: ¦CD:Sat 15/03/14->Sun 15/03/15¦Stat Rep: RP-141244->RP-141894 1st Apr 15: Compl:10%->25% 1st Apr 15: Stat Rep: RP-141894->RP-150094 03/07/15: Compl:25%->70% 03/07/15: Stat Rep: RP-150094->RP-150760 29/09/15: Compl:70%->95% 29/09/15: CD:Tue 15/09/15-> / Impacted TSs and TRs: 36.101; 36.133
- 5342: rapporteur e-mail added 03/07/15: Compl:0%->10% 03/07/15: Stat Rep: ->RP-150765 29/09/15: Compl:10%->30% 29/09/15: CD:Tue 15/12/15->Wed 15/06/16 29/09/15: Stat Rep: RP-150765->RP-151280 1/1/16: Compl:30%->45% 1/1/16: WID: RP-1¦ ;
- 5343: IETF RTCWEB and W3C WEBRTC groups are specifying a browser-based client to support communication services. Interoperability for WebRTC clients to access 3GPP IMS is needed. / Impacted TSs and TRs: Stage 1/2
- 5344: SP#60 completed / Impacted TSs and TRs: 22.101; 22.228
- 5345: SP#62 completed. TR 23.701v100 for Information & Approval / Impacted TSs and TRs: New 23.701
- 5346: SP#63 completed / Impacted TSs and TRs: 23.228
- 5347: In WGLC. Mar15: responsible WG changed from S2-IETF; 23/4/20: 50%->90; 9/4/21: RFC 8825 added; / Impacted TSs and TRs: draft-ietf-rtcweb-overview; RFC 8825
- 5348: 9/4/21: RFC 8832 added; / Impacted TSs and TRs: RFC 8832
- 5349: SP#65 completed. TR 33.871v200 for Approval / Impacted TSs and TRs: New 33.871
- 5350: SP#64 completed / Impacted TSs and TRs: 33.203; 33.328
- 5351: - / Impacted TSs and TRs: Stage 3
- 5352: 9/4/21: RFC 8838 added; / Impacted TSs and TRs: RFC 8838
- 5353: 9/4/21: RFC 8838 added; / Impacted TSs and TRs: RFC 8838
- 5354: CP#65 TS 24.371v100 for Information. Completion 09/14=>12/14. Exception in CP-140621. Dec.14: 70->90%. 3/3/15: 100% cpltd. / Impacted TSs and TRs: 24.229; New 24.371
- 5355: Submitted to IESG for publication. Mar15: In RFC-Editors queue; 9/4/21: RFC 8831 added; / Impacted TSs and TRs: draft-ietf-rtcweb-data-channel; RFC 8831
- 5356: Mar15: Publication requested¦7/3/16: 50%->100; 9/4/21: RFC 7675 added; / Impacted TSs and TRs: draft-ietf-rtcweb-stun-consent-freshness; RFC 7675
- 5357: work in progress; 23/4/20: 25%->100 / Impacted TSs and TRs: draft-yusef-sipcore-sip-oaut; Replaced by replaced by draft-ietf-sipcore-sip-token-authnz
- 5358: 9/4/21: RFC 8898 added; / Impacted TSs and TRs: RFC 8898
- 5359: 7/3/16: 25%->100 since deleted (draft no longer needed). / Impacted TSs and TRs: draft-holmberg-sipcore-auth-id
- 5360: CP#65 completion 09/14=>12/14. Exception in CP-140732. Dec.14: 30->80%. Mar. 15: 100% / Impacted TSs and TRs: 23.334; 29.334

| ID | WBS | Task | Duration | Start | Finish | Complete | Baseline start | Baseline finish | Baseline duration | Constraint | Resources | Work | Actual work | Acronym | PCG approved | WI rapporteur name | WI rapporteur e-mail | Release | TSG approved | MCC resp | Acronym_3GU_Export | Special Focus Doc | Status Report |
| --- | --- | --- | --- | --- | --- | --- | --- | --- | --- | --- | --- | --- | --- | --- | --- | --- | --- | --- | --- | --- | --- | --- | --- |
| 5361 | 1909 | **Usage Monitoring Control PCC enhancement** | 277d? | 2012-12-13 A | 2013-09-06 A | 100% | 2012-12-13 | 2013-09-06 | 196d? |  | S2; C3 | 4112h | 4112h | UMONC | 30 | ZTE | bi.yifeng@zte.com.cn | Rel-12 | 58 | Maurice | UMONC |  |  |
| 5362 | 1909.1 | Stage 2 for Usage Monitoring Control PCC enhancement | 61d? | 2012-12-13 A | 2013-03-06 A | 100% | 2012-12-13 | 2013-03-06 | 61d? | finish no earlier than 2013-03-06 | S2 | 488h | 488h | UMONC | 30 | ZTE | bi.yifeng@zte.com.cn | Rel-12 | 58 | Maurice |  |  |  |
| 5363 | 1909.2 | CT3 aspects of Usage Monitoring Control PCC enhancement (Stage 3) | 63d? | 2013-06-14 A | 2013-09-06 A | 100% | 2013-06-14 | 2013-09-06 | 63d? | finish no earlier than 2013-09-06 | C3 | 488h | 488h | UMONC-CT3 | 31 | ZTE | zhou.xiaoyun@zte.com.cn | Rel-12 | 60 | Adrian | UMONC-CT3 |  |  |
| 5364 | 1910 | **Application Based Charging** | 485.12d? | 2013-03-07 A | 2014-06-18 A | 100% | 2013-03-07 | 2014-06-18 | 340d? |  | S2; S5; C3 | 11612h | 11612h | ABC | 30 | Allot | Alla Goldner (agoldner@allot.com) | Rel-12 | 59 | Maurice | ABC |  |  |
| 5365 | 1910.1 | Stage 2 for Application Based Charging | 76d? | 2013-03-07 A | 2013-06-19 A | 100% | 2013-03-07 | 2013-06-19 | 76d? | finish no earlier than 2013-12-11 | S2 | 608h | 608h | ABC-SA2 | 30 | Allot | Alla Goldner (agoldner@allot.com) | Rel-12 | 59 | Maurice |  |  |  |
| 5366 | 1910.2 | Charging for Application Based Charging | 232.5d? | 2013-06-19 A | 2014-06-18 A | 100% | 2013-06-19 | 2014-06-18 | 232.5d? | finish no earlier than 2014-06-18 | S5 | 1836h | 1836h | ABC-CT5 | 31 | Openet Telecom | alan.mcnamee@openet.com | Rel-12 | 60 | Mirko |  |  |  |
| 5367 | 1910.3 | CT3 aspects of Application Based Charging (Stage 3) | 127d? | 2013-06-14 A | 2013-12-06 A | 100% | 2013-06-14 | 2013-12-06 | 127d? | finish no earlier than 2013-12-06 | C3 | 1008h | 1008h | ABC-CT3 | 31 | Allot | Alla Goldner (agoldner@allot.com) | Rel-12 | 60 | Adrian | ABC-CT3 |  |  |
| 5368 | 1911 | **Enhanced S2a Mobility Over trusted WLAN access to EPC** | 472.62d? | 2013-09-09 A | 2014-12-09 A | 100% | 2013-09-09 | 2014-09-12 | 267d? |  | S2; C1; C4 | 19024h | 19024h | eSaMOG | 31 | ZTE | Tricci So (tso@zteusa.com) | Rel-12 | 61 | Maurice | eSaMOG | WLAN |  |
| 5369 | 1911.1 | Stage 2 for Enhanced S2a Mobility Over trusted WLAN access to EPC | 130d? | 2013-09-11 A | 2014-03-07 A | 100% | 2013-09-11 | 2014-03-07 | 130d? | finish no earlier than 2014-03-07 | S2 | 1032h | 1032h | eSaMOG-SA2 | 31 | ZTE | Tricci So (tso@zteusa.com) | Rel-12 | 61 | Maurice |  | WLAN |  |
| 5370 | 1911.2 | **Stage 3 for Enhanced S2a Mobility Over trusted WLAN access to EPC** | 472.62d? | 2013-09-09 A | 2014-12-09 A | 100% | 2013-09-09 | 2014-09-12 | 267d? |  | C1; C4 | 10048h | 10048h | eSaMOG-St3 | 31 | ZTE | Joy Zhou (zhou.xingyue@zte.com.cn) | Rel-12 | 61 | Frederic | eSaMOG-St3 | WLAN |  |
| 5371 | 1911.2.1 | CT1 part of Stage 3 for Enhanced S2a Mobility Over trusted WLAN access to EPC | 329d? | 2013-09-09 A | 2014-12-09 A | 100% | 2013-09-09 | 2014-09-12 | 267d? | finish no earlier than 2014-12-09 | C1 | 2624h | 2624h | eSaMOG-St3 | 31 | ZTE | Joy Zhou (zhou.xingyue@zte.com.cn) | Rel-12 | 61 | Frederic |  | WLAN | CP-140608 |
| 5372 | 1911.2.2 | CT4 part of Stage 3 for Enhanced S2a Mobility Over trusted WLAN access to EPC | 266d? | 2013-09-09 A | 2014-09-11 A | 100% | 2013-09-09 | 2014-09-12 | 266d? | finish no earlier than 2014-09-12 | C4 | 2128h | 2128h | eSaMOG-St3 | 31 | ZTE | Joy Zhou (zhou.xingyue@zte.com.cn) | Rel-12 | 61 | Kimmo |  | WLAN |  |
| 5373 | 1912 | **Optimized Offloading to WLAN in 3GPP-RAT Mobility** | 284.5d? | 2013-09-12 A | 2014-06-13 A | 100% | 2013-09-12 | 2014-06-13 | 199d? |  | S2; C1 | 4800h | 4800h | WORM | 31 | BlackBerry | Steve Barrett (sbarrett@blackberry.com) | Rel-12 | 61 | Maurice | WORM | WLAN |  |
| 5374 | 1912.1 | Stage 2 for Optimized Offloading to WLAN in 3GPP-RAT Mobility | 66d? | 2013-09-12 A | 2013-12-11 A | 100% | 2013-09-12 | 2013-12-11 | 66d? | finish no earlier than 2013-12-11 | S2 | 528h | 528h | WORM-SA2 | 31 | BlackBerry | Steve Barrett (sbarrett@blackberry.com) | Rel-12 | 61 | Maurice |  | WLAN |  |
| 5375 | 1912.2 | CT aspects of Optimized Offloading to WLAN in 3GPP-RAT Mobility (Stage 3) | 136d? | 2013-12-06 A | 2014-06-13 A | 100% | 2013-12-06 | 2014-06-13 | 136d? | finish no earlier than 2014-06-13 | C1 | 1088h | 1088h | WORM-CT | 32 | Intel | Chen-ho Chin (chen-hox.chin@intel.com) | Rel-12 | 62 | Frederic | WORM-CT | WLAN |  |
| 5376 | 1913 | **Network-provided Location information for IMS Trusted WLAN Access Network (TWAN) case** | 377.62d? | 2013-09-12 A | 2014-09-11 A | 100% | 2013-09-12 | 2014-09-12 | 264d? |  | S2; C3; C1; C4 | 18624h | 18624h | NETLOC_TWAN | 31 | Alcatel-Lucent | Laurent.thiebaut@alcatel-lucent.com | Rel-12 | 61 | Maurice | NETLOC_TWAN | WLAN |  |
| 5377 | 1913.1 | Stage 2 for Network-provided Location information for IMS Trusted WLAN Access Network (TWAN) case | 129d? | 2013-09-12 A | 2014-03-07 A | 100% | 2013-09-12 | 2014-03-07 | 129d? | finish no earlier than 2014-03-07 | S2 | 1024h | 1024h | NETLOC_TWAN-SA2 | 31 | Alcatel-Lucent | Laurent.thiebaut@alcatel-lucent.com | Rel-12 | 61 | Maurice |  |  |  |
| 5378 | 1913.2 | **CT aspects of Network-provided Location information for IMS Trusted WLAN Access Network (TWAN) case (Stage 3)** | 289.75d? | 2013-12-06 A | 2014-09-11 A | 100% | 2013-12-06 | 2014-09-12 | 202d? |  | C3; C1; C4 | 9152h | 9152h | NETLOC_TWAN-CT | 32 | China Telecom | Xia Xu (xiaxu@ctbri.com.cn) | Rel-12 | 62 | Adrian | NETLOC_TWAN-CT |  |  |
| 5379 | 1913.2.1 | CT3 part of Network-provided Location information for IMS Trusted WLAN Access Network (TWAN) case | 137d? | 2013-12-06 A | 2014-06-13 A | 100% | 2013-12-06 | 2014-06-13 | 137d? | finish no earlier than 2014-06-13 | C3 | 1088h | 1088h | NETLOC_TWAN-CT | 32 | China Telecom | Xia Xu (xiaxu@ctbri.com.cn) | Rel-12 | 62 | Adrian |  |  |  |
| 5380 | 1913.2.2 | CT1 part of Network-provided Location information for IMS Trusted WLAN Access Network (TWAN) case | 201d? | 2013-12-09 A | 2014-09-11 A | 100% | 2013-12-09 | 2014-09-12 | 201d? | finish no earlier than 2014-09-12 | C1 | 1608h | 1608h | NETLOC_TWAN-CT | 32 | China Telecom | Xia Xu (xiaxu@ctbri.com.cn) | Rel-12 | 62 | Frederic |  |  |  |
| 5381 | 1913.2.3 | CT4 part of Network-provided Location information for IMS Trusted WLAN Access Network (TWAN) case | 201d? | 2013-12-06 A | 2014-09-11 A | 100% | 2013-12-06 | 2014-09-12 | 201d? | finish no earlier than 2014-09-12 | C4 | 1608h | 1608h | NETLOC_TWAN-CT | 32 | China Telecom | Xia Xu (xiaxu@ctbri.com.cn) | Rel-12 | 62 | Kimmo |  |  |  |
| 5382 | 1914 | **Core Network Overload - User Location Information reporting improvement** | 290.75d? | 2013-12-11 A | 2014-09-17 A | 100% | 2013-12-11 | 2014-09-12 | 199d? |  | S2; C3; C4; S5 | 10920h | 10920h | CNO_ULI | 32 | Alcatel-Lucent | nicolas.drevon@alcatel-lucent.com | Rel-12 | 62 | Maurice | CNO_ULI |  |  |
| 5383 | 1914.1 | Stage 2 for Core Network Overload - User Location Information reporting improvement | 64d? | 2013-12-11 A | 2014-03-07 A | 100% | 2013-12-11 | 2014-03-07 | 64d? | finish no earlier than 2014-03-07 | S2 | 504h | 504h | CNO_ULI-SA2 | 32 | Alcatel-Lucent | nicolas.drevon@alcatel-lucent.com | Rel-12 | 62 | Maurice |  |  |  |
| 5384 | 1914.2 | Charging aspects of Core Network Overload – User Location Information reporting improvements | 3d? | 2014-09-15 A | 2014-09-17 A | 100% |  |  |  | finish no earlier than 2014-09-17 | S5 | 24h | 24h | CNO_ULI-CH | 33 | Alcatel-Lucent | maryse.gardella@alcatel-lucent.com | Rel-12 | 65 |  | CNO_ULI-CH |  |  |

Notes:
- 5361: SP#59 Stage 2 completed. Triggered by Rel-12 TR 23.858 Study on Usage Monitoring Control enhancement (UID_520035) / Impacted TSs and TRs: Stage 2/3
- 5362: SP#59 completed. 23.203 CR#0782 (Time Based Usage Monitoring), CR#0784 (Usage Monitoring via Online Charging System) / Impacted TSs and TRs: 23.203
- 5363: CP#61 completed. 2/4/15: acronym changed to "UMONC-CT3" / Impacted TSs and TRs: 29.212; 29.214; 29.215
- 5364: Triggered by TR 23.800 Study on Application Based Charging (FS_ABC) UID_560038 / Impacted TSs and TRs: Stage 2/3
- 5365: SP#60 completed / Impacted TSs and TRs: 23.203
- 5366: SP#64 completed / Impacted TSs and TRs: 32.240; 32.251; 32.296; 32.298; 32.299
- 5367: CP#62 completed / Impacted TSs and TRs: 29.212; 29.213; 29.214; 29.215; 29.219
- 5368: - / Impacted TSs and TRs: Stage 2/3
- 5369: SP#63 completed / Impacted TSs and TRs: 23.402
- 5370: CP#62 updated WID CP-130580=>CP-130715 / Impacted TSs and TRs: Stage 3
- 5371: CP#65 completion 09/14=>12/14. Exception in CP-140608. TS 24.244 v200 for Approval. Dec.14: 95->100% / Impacted TSs and TRs: 24.302; New 24.244 (WLAN control plane protocol for trusted WLAN access to EPC)
- 5372: CP#65 completed / Impacted TSs and TRs: 29.273; 29.274; 29.275
- 5373: Linked to TR 23.890 Study on Optimized Offloading to WLAN in 3GPP-RAT mobility (FS_WORM), SAE for support for non-3GPP accesses, Multi-Access PDN Connectivity (MAPCON), IP Flow Mobility and Seamless WLAN Offload (IFOM), CS Fallback in EPS (SAES-CSFB) / Impacted TSs and TRs: Stage 2/3
- 5374: SP#62 completed / Impacted TSs and TRs: 23.272; 23.401; 23.402
- 5375: CP#64 completed. Stage 3 enabling differentiation/prioritization of 3GPP RATs relative to WLAN for traffic flow routing based on Inter-System Routing Policies / Impacted TSs and TRs: 24.302; 24.312
- 5376: Rel-11 Network Provided Location Information for IMS (NWK-PL2IMS) covers the case where UE is served by a 3GPP RAN. This WI covers the case where the UE is served by a TWAN / Impacted TSs and TRs: Stage 2/3
- 5377: SP#63 completed / Impacted TSs and TRs: 23.203; 23.228; 23.402
- 5378: - / Impacted TSs and TRs: Stage 3
- 5379: CP#64 completed / Impacted TSs and TRs: 29.212; 29.214
- 5380: CP#65 completed / Impacted TSs and TRs: 24.229
- 5381: CP#65 completed / Impacted TSs and TRs: 29.273; 29.274; 29.275; 29.328; 29.329
- 5382: - / Impacted TSs and TRs: Stage 2/3
- 5383: SP#63 completed / Impacted TSs and TRs: 23.060; 23.203; 23.401
- 5384: SP#65 New WID approved & completed. Introduction of Presence Reporting Areas for Charging / Impacted TSs and TRs: 32.251; 32.298; 32.299

| ID | WBS | Task | Duration | Start | Finish | Complete | Baseline start | Baseline finish | Baseline duration | Constraint | Resources | Work | Actual work | Acronym | PCG approved | Impacted TSs and TRs | WI rapporteur name | Release | TSG approved | MCC resp | Acronym_3GU_Export | Special Focus Doc | PCG stopped | TSG stopped | Status Report |
| --- | --- | --- | --- | --- | --- | --- | --- | --- | --- | --- | --- | --- | --- | --- | --- | --- | --- | --- | --- | --- | --- | --- | --- | --- | --- |
| 5385 | 1914.3 | **CT aspects of Core Network Overload – User Location Information reporting improvements** | 197.62d? | 2014-03-05 A | 2014-09-11 A | 100% | 2014-03-05 | 2014-09-12 | 138d? |  | C3; C4 | 3896h | 3896h | CNO_ULI-CT | 32 | Stage 3 | Alcatel-Lucent | Rel-12 | 63 | Adrian | CNO_ULI-CT |  |  |  |  |
| 5386 | 1914.3.1 | CT3 part of CT aspects of Core Network Overload – User Location Information reporting improvements | 73d? | 2014-03-05 A | 2014-06-13 A | 100% | 2014-03-05 | 2014-06-13 | 73d? | finish no earlier than 2014-06-13 | C3 | 584h | 584h | CNO_ULI-CT | 32 | 29.212; 29.213 | Alcatel-Lucent | Rel-12 | 63 | Adrian |  |  |  |  |  |
| 5387 | 1914.3.2 | CT4 part of CT aspects of Core Network Overload – User Location Information reporting improvements | 138d? | 2014-03-05 A | 2014-09-11 A | 100% | 2014-03-05 | 2014-09-12 | 138d? | finish no earlier than 2014-09-12 | C4 | 1104h | 1104h | CNO_ULI-CT | 32 | 23.008; 29.060; 29.274 | Alcatel-Lucent | Rel-12 | 63 | Kimmo |  |  |  |  |  |
| 5388 | 1915 | Rel-12 Security small Enhancements | 923d? | 2011-03-23 A | 2014-09-17 A | 100% | 2011-03-23 | 2014-06-18 | 859d? | finish no earlier than 2014-09-17 | S3 | 7384h | 7384h | SEC12 | 29 | Stage 2/3 |  | Rel-12 | 56 | Mirko | SEC12 |  |  |  |  |
| 5389 | 1916 | **Security aspects of Public Warning System** | 1318.75d? | 2011-03-23 A | 2014-09-17 A | 100% | 2011-03-23 | 2014-09-17 | 924d? |  | S3; S1 | 36832h | 36832h | PWS_Sec | 26 |  | ST-Ericsson | Rel-12 | 51 | Mirko | PWS_Sec | Public Safety (I-A) |  |  |  |
| 5390 | 1916.1 | Stage 1 for Protection against false PWS Warning Notifications | 65d? | 2012-06-15 A | 2012-09-12 A | 100% | 2012-06-15 | 2012-09-12 | 65d? | finish no earlier than 2012-09-12 | S1 | 512h | 512h | PWS_Sec-SA1 | 29 | 22.268 | Vodafone | Rel-12 | 56 | Alain |  | Public Safety (I-A) |  |  |  |
| 5391 | 1916.2 | TR on SA3 part for Security aspects of Public Warning System | 921d? | 2011-03-23 A | 2014-09-17 A | 100% | 2011-03-23 | 2014-09-17 | 921d? | finish no earlier than 2014-09-17 | S3 | 7360h | 7360h | PWS_Sec-SA3TR | 26 | New 33.869 changed to 33.969 | ST-Ericsson | Rel-12 | 51 | Mirko |  | Public Safety (I-A) |  |  |  |
| 5392 | 1916.3 | Deleted - SA3 part for Security aspects of Public Warning System | 852d? | 2011-03-30 A | 2014-06-18 A | 100% | 2011-03-30 | 2014-06-18 | 852d? | finish no earlier than 2014-06-18 | S3 | 6808h | 6808h | PWS_Sec-del1 | 26 | New 33.269 | ST-Ericsson | Rel-12 | 51 | Mirko |  | Public Safety (I-A) | PCG-33 | SP-64 |  |
| 5393 | 1916.4 | Deleted - Stage 1 for Security aspects of Public Warning System | 330d? | 2011-03-23 A | 2012-06-20 A | 100% | 2011-03-23 | 2012-06-20 | 330d? | start no earlier than 2011-03-23 | S1 | 2640h | 2640h | PWS_Sec-del2 | 26 | 22.268 | ST-Ericsson | Rel-12 | 51 | Alain |  | Public Safety (I-A) | PCG-29 | SP-56 |  |
| 5394 | 1916.5 | Deleted - Stage 2 for Security aspects of Public Warning System | 133d? | 2011-03-23 A | 2011-09-21 A | 100% | 2011-03-23 | 2011-09-21 | 133d? | start no earlier than 2011-03-23 | S2 | 1064h | 1064h | PWS_Sec-del3 | 26 | 23.401 | ST-Ericsson | Rel-12 | 51 | Maurice |  | Public Safety (I-A) | PCG-27 | SP-53 |  |
| 5395 | 1916.6 | Deleted - CT1 part for Security aspects of Public Warning System | 328d? | 2011-03-25 A | 2012-06-20 A | 100% | 2011-03-25 | 2012-06-20 | 328d? | finish no earlier than 2012-06-20 | C1 | 2624h | 2624h | PWS_Sec-del4 | 26 | 23.041 | ST-Ericsson | Rel-12 | 51 | Frederic |  | Public Safety (I-A) | PCG-29 | SP-56 |  |
| 5396 | 1916.7 | Deleted - RAN2 part for Security aspects of Public Warning System | 128d? | 2011-03-25 A | 2011-09-16 A | 100% | 2011-03-25 | 2011-09-16 | 128d? | start no earlier than 2011-03-25 | R2 | 1024h | 1024h | PWS_Sec-del5 | 26 | 36.331 | ST-Ericsson | Rel-12 | 51 | Yong-Jun |  | Public Safety (I-A) | PCG-27 | RP-53 |  |
| 5397 | 1917 | Security enhancements for usage of Generic Bootstrapping Architecture (GBA) from the browser (Stage 2) | 536d? | 2011-06-08 A | 2013-06-19 A | 100% | 2011-06-08 | 2013-06-19 | 536d? | finish no earlier than 2013-06-19 | S3 | 4256h | 4256h | Web_GBA | 27 | 33.220; 33.222; New 33.823 | Nokia | Rel-12 | 52 | Mirko | Web_GBA |  |  |  |  |
| 5398 | 1918 | **Extended IMS media plane security features** | 933.75d? | 2012-06-20 A | 2014-12-09 A | 100% | 2012-06-20 | 2014-12-10 | 655d? |  | S3; C4; C1; C3; IETF | 73585.2h | 73585.2h | eMEDIASEC | 29 | Stage 2/3 | Vodafone | Rel-12 | 56 | Mirko | eMEDIASEC |  |  |  |  |
| 5399 | 1918.1 | SA3 part of Extended IMS media plane security features (Stage 2) | 530d? | 2012-06-20 A | 2014-06-18 A | 100% | 2012-06-20 | 2014-06-18 | 530d? | finish no earlier than 2014-06-18 | S3 | 4185.2h | 4185.2h | eMEDIASEC-SA3 | 29 | 33.328 | Vodafone | Rel-12 | 56 | Mirko |  |  |  |  |  |
| 5400 | 1918.2 | (IETF) SA3 part of Extended IMS media plane security features (RFC 7345) | 591d? | 2012-06-20 A | 2014-09-12 A | 100% | 2012-06-20 | 2014-12-10 | 654d? | finish no earlier than 2014-09-12 | S3-IETF | 4728h | 4728h | eMEDIASECSA3IETF | 31 | RFC 7345 (was draft-ietf-mmusic-udptl-dtls) | christer.holmberg@ericsson.com | Rel-12 | 61 |  |  |  |  |  |  |
| 5401 | 1918.3 | **CT aspects of Extended IMS media plane security features (Stage 2/3)** | 751.88d? | 2012-12-13 A | 2014-12-09 A | 100% | 2012-12-13 | 2014-12-05 | 523d? |  | C4; C1; C3; IETF | 38392h | 38392h | eMEDIASEC-CT | 30 | Stage 2/3 | Alcatel-Lucent | Rel-12 | 58 | Kimmo | eMEDIASEC-CT |  |  |  |  |
| 5402 | 1918.3.1 | TR on Extended IMS media plane security features and TCP related NAT traversal support; IMS H.248 profiles aspects | 461d? | 2012-12-13 A | 2014-09-11 A | 100% | 2012-12-13 | 2014-09-12 | 461d? | finish no earlier than 2014-09-12 | C4 | 3688h | 3688h | eMEDIASEC-CT | 30 | New 29.828 | Alcatel-Lucent | Rel-12 | 58 | Kimmo |  |  |  |  |  |
| 5403 | 1918.3.2 | CT4 part of CT aspects of Extended IMS media plane security features | 520d? | 2012-12-19 A | 2014-12-09 A | 100% | 2012-12-19 | 2014-09-12 | 458d? | finish no earlier than 2014-12-09 | C4 | 4160h | 4160h | eMEDIASEC-CT | 30 | 23.334; 29.334; 29.238; 23.333; 29.333 | Alcatel-Lucent | Rel-12 | 58 | Kimmo |  |  |  |  | CP-140479 |
| 5404 | 1918.3.3 | (IETF) CT4 part of Extended IMS media plane security features (RFC 7345) | 457d? | 2012-12-18 A | 2014-09-11 A | 100% | 2012-12-18 | 2014-12-05 | 519d? | finish no earlier than 2014-09-11 | C4-IETF | 3656h | 3656h | eMEDIASEC-CT | 32 | RFC 7345 (was draft-ietf-mmusic-udptl-dtls) | christer.holmberg@ericsson.com | Rel-12 | 62 |  |  |  |  |  |  |
| 5405 | 1918.3.4 | (IETF) CT4 part of Extended IMS media plane security features (draft-schwarz-mmusic-sdp-for-gw) | 129d? | 2014-06-12 A | 2014-12-09 A | 100% | 2014-06-12 | 2014-12-05 | 127d? | finish no earlier than 2014-12-09 | C4-IETF | 1032h | 1032h | eMEDIASEC-CT | 33 | draft-schwarz-mmusic-sdp-for-gw | christer.holmberg@ericsson.com | Rel-12 | 64 |  |  |  |  |  |  |
| 5406 | 1918.3.5 | CT1 part of CT aspects of Extended IMS media plane security features | 463d? | 2012-12-13 A | 2014-09-11 A | 100% | 2012-12-13 | 2014-09-12 | 463d? | finish no earlier than 2014-09-12 | C1 | 3696h | 3696h | eMEDIASEC-CT | 30 | 23.218; 24.147; 24.229; 24.247 | Alcatel-Lucent | Rel-12 | 58 | Frederic |  |  |  |  |  |
| 5407 | 1918.3.6 | (IETF) CT1 part of Extended IMS media plane security features (RFC 7345) | 137d? | 2014-03-06 A | 2014-09-11 A | 100% | 2014-03-06 | 2014-12-05 | 197d? | finish no earlier than 2014-09-11 | C1-IETF | 1096h | 1096h | eMEDIASEC-CT | 32 | RFC 7345 (was draft-ietf-mmusic-udptl-dtls) | christer.holmberg@ericsson.com | Rel-12 | 62 |  |  |  |  |  |  |
| 5408 | 1918.3.7 | CT3 part of CT aspects of Extended IMS media plane security features | 521d? | 2012-12-19 A | 2014-12-09 A | 100% | 2012-12-19 | 2014-06-13 | 394d? | finish no earlier than 2014-12-09 | C3 | 4168h | 4168h | eMEDIASEC-CT | 30 | 29.162 | Alcatel-Lucent | Rel-12 | 58 | Adrian |  |  |  |  | CP-140569 |
| 5409 | 1919 | Lawful Interception in the 3GPP Rel-12 | 592d? | 2012-09-17 A | 2014-12-12 A | 100% | 2012-09-17 | 2014-09-12 | 526d? | finish no earlier than 2014-12-12 | S3 | 4736h | 4736h | LI12 | 29 | 33.106; 33.107; 33.108 | PIDS, Alcatel-Lucent | Rel-12 | 57 | Mirko | LI12 |  |  |  |  |

Notes:
- 5385: Specify Stage 3 procedures to support the ULI signalling optimizations / WI rapporteur e-mail: horst.brinkmann@alcatel-lucent.com
- 5386: CP#64 completed / WI rapporteur e-mail: horst.brinkmann@alcatel-lucent.com
- 5387: CP#65 completed / WI rapporteur e-mail: horst.brinkmann@alcatel-lucent.com
- 5388: SEC12 is an umbrella Feature for Security related TEI12 type of changes that are not part of any other dedicated feature
- 5389: - / WI rapporteur e-mail: john.mattsson@ericsson.com
- 5390: SP#57 completed. Specify reqs to protect against false PWS Warning Notifications (Optional as not all regions/countries require this functionality). WID covers all objectivES in CP-150SA3 PWS_Sec Feature-level WID replacing the original Stage 1 UID_510154 / WI rapporteur e-mail: adrian.neal@vodafone.com
- 5391: SP#65 completed. TR 33.969v100 for 1-step Approval. Former TR 33.869 changed to 33.969. / WI rapporteur e-mail: john.mattsson@ericsson.com
- 5392: SP#64 stopped / WI rapporteur e-mail: john.mattsson@ericsson.com
- 5393: Completed in Rel-9 under PWS. SP#55 stopped, Stage 1 requirements removed from Rel-9 onwards (SP-120172). AP 55/1: SA1 to align Stage 1 PWS security for Rel-12. SA1 new WID PWS Security UID_560029. / WI rapporteur e-mail: john.mattsson@ericsson.com
- 5394: SP#53 work stopped as already done in previous releases / WI rapporteur e-mail: john.mattsson@ericsson.com
- 5395: TSG#56 work stopped. SP#56 updated WID SP-110223=>SP-120334 (removed all but SA3 impacted specs) / WI rapporteur e-mail: mikael.wass@ericsson.com
- 5396: RP#53 work stopped as no WI in RAN / WI rapporteur e-mail: john.mattsson@ericsson.com
- 5397: SP#60 completed / WI rapporteur e-mail: Silke.Holtmanns@nokia.com
- 5398: Triggered by Rel-11 TR 33.829 Study on Extended IMS media plane security features (FS_eMEDIASEC) / WI rapporteur e-mail: Aguibou.Barry@vodafone.com
- 5399: SP#64 completed / WI rapporteur e-mail: Aguibou.Barry@vodafone.com
- 5400: SP#65 completed / WI rapporteur e-mail: christer.holmberg@ericsson.com
- 5401: - / WI rapporteur e-mail: bruno.landais@alcatel-lucent.com
- 5402: CP#65 completed. TR 29.828v200 for Approval. 2/4/15: acronym changed to eMEDIASEC-CT / WI rapporteur e-mail: bruno.landais@alcatel-lucent.com
- 5403: CP#65 completion 09/14=>12/14. Exception in CP-140479. Dec.14: 90->100. 2/4/15: acronym changed to eMEDIASEC-CT / WI rapporteur e-mail: bruno.landais@alcatel-lucent.com
- 5404: CP#65 completed. 2/4/15: acronym changed to eMEDIASEC-CT / WI rapporteur e-mail: christer.holmberg@ericsson.com
- 5405: Work in progress. 2/4/15: acronym changed to eMEDIASEC-CT¦22/3/18: 100%->0; 2/4/24: 50%->100 / WI rapporteur e-mail: christer.holmberg@ericsson.com
- 5406: CP#65 completed. 2/4/15: acronym changed to eMEDIASEC-CT / WI rapporteur e-mail: bruno.landais@alcatel-lucent.com
- 5407: CP#65 completed. 2/4/15: acronym changed to eMEDIASEC-CT / WI rapporteur e-mail: christer.holmberg@ericsson.com
- 5408: CP#65 completion 06/14=>12/14. Level 100%=>80%. Exception in CP-140569. CP#64 completed. Dec.14: 80->100. 2/4/15: acronym changed to eMEDIASEC-CT / WI rapporteur e-mail: bruno.landais@alcatel-lucent.com
- 5409: 3/3/15: 75->100% / WI rapporteur e-mail: Koen Jaspers (k.b.jaspers@minjus.nl), terry.jacobson@alcatel-lucent.com

| ID | WBS | Task | Duration | Start | Finish | Complete | Baseline start | Baseline finish | Baseline duration | Constraint | Resources | Work | Actual work | Acronym | PCG approved | WI rapporteur name | WI rapporteur e-mail | Release | TSG approved | MCC resp | Acronym_3GU_Export | Status Report |
| --- | --- | --- | --- | --- | --- | --- | --- | --- | --- | --- | --- | --- | --- | --- | --- | --- | --- | --- | --- | --- | --- | --- |
| 5410 | 1920 | **Tunneling of UE Services over Restrictive Access Networks (Stage 2/3)** | 572d? | 2012-12-13 A | 2014-06-18 A | 100% | 2012-12-13 | 2014-06-18 | 401d? |  | S3; C1 | 11662.5h | 11662.5h | TURAN | 30 | Acme Packet | Prashant Kumar (PKumar@acmepacket.com) | Rel-12 | 58 | Mirko | TURAN |  |
| 5411 | 1920.1 | SA3 part of Tunneling of UE Services over Restrictive Access Networks (Stage 2/3) | 400d? | 2012-12-13 A | 2014-06-18 A | 100% | 2012-12-13 | 2014-06-18 | 400d? | finish no earlier than 2014-06-18 | S3 | 3168h | 3168h | TURAN-SA3 | 30 | Acme Packet | Prashant Kumar (PKumar@acmepacket.com) | Rel-12 | 58 | Mirko |  |  |
| 5412 | 1920.2 | CT aspects of Tunneling of UE Services over Restrictive Access Networks (Stage 3) | 264d? | 2013-06-14 A | 2014-06-13 A | 100% | 2013-06-14 | 2014-06-13 | 264d? | finish no earlier than 2014-06-13 | C1 | 2094.45h | 2094.45h | TURAN-CT | 31 | Huawei | Haitao Wei (weihaitao@huawei.com) | Rel-12 | 60 | Frederic | TURAN-CT |  |
| 5413 | 1921 | Specification of the TUAK Algorithm Set | 139d? | 2013-12-09 A | 2014-06-18 A | 100% | 2013-12-09 | 2014-06-18 | 139d? | finish no earlier than 2014-06-18 | S3 | 1112h | 1112h | STAS | 32 | Vodafone | aguibou.barry@vodafone.com | Rel-12 | 62 | Mirko | STAS |  |
| 5414 | 1922 | **Codec for Enhanced Voice Services** | 2259d? | 2010-03-25 A | 2016-03-15 A | 100% | 2010-03-25 | 2014-12-12 | 1245d? |  | S4; S1; C4; C1; C3 | 87912h | 87912h | EVS_codec | 24 | Huawei | lei.miao@huawei.com | Rel-12 | 47 | Paolo | EVS_codec |  |
| 5415 | 1922.1 | Stage 1 for Codec for Enhanced Voice Services | 1d? | 2010-03-25 A | 2010-03-25 A | 100% | 2010-03-25 | 2010-03-25 | 1d? | start no earlier than 2010-03-25 | S1 | 8h | 8h | EVS_codec-SA1 | 24 | Huawei | lei.miao@huawei.com | Rel-12 | 47 | Paolo |  |  |
| 5416 | 1922.2 | Stage 2/3 for Codec for Enhanced Voice Services | 1240d? | 2010-03-25 A | 2014-12-12 A | 100% | 2010-03-25 | 2014-09-17 | 1178d? | finish no earlier than 2014-12-12 | S4 | 9896h | 9896h | EVS_codec-SA4 | 24 | Huawei | lei.miao@huawei.com | Rel-12 | 47 | Paolo |  | SP-140467 |
| 5417 | 1922.3 | TR on Performance characterization of Codec for Enhanced Voice Services | 1239d? | 2010-03-25 A | 2014-12-12 A | 100% | 2010-03-25 | 2014-12-12 | 1239d? | finish no earlier than 2014-12-12 | S4 | 9888h | 9888h | EVS_codec-SA4TR | 24 | Huawei | lei.miao@huawei.com | Rel-12 | 47 | Paolo |  | SP-140467 |
| 5418 | 1922.4 | **CT impacts of codec for Enhanced Voice Services** | 87.75d? | 2014-09-16 A | 2014-12-09 A | 100% |  |  |  |  | C4; C1; C3 | 3024h | 3024h | EVS_codec-CT | 33 | Nokia Networks | Jan.Kall@nsn.com | Rel-12 | 65 |  | EVS_codec-CT |  |
| 5419 | 1922.4.1 | CT4 part of CT impacts of codec for Enhanced Voice Services | 63d? | 2014-09-16 A | 2014-12-09 A | 100% |  |  |  | finish no earlier than 2014-12-09 | C4 | 504h | 504h | EVS_codec-CT | 33 | Nokia Networks | Jan.Kall@nsn.com | Rel-12 | 65 |  |  | CP-140478 |
| 5420 | 1922.4.2 | CT1 part of CT impacts of codec for Enhanced Voice Services | 63d? | 2014-09-16 A | 2014-12-09 A | 100% |  |  |  | finish no earlier than 2014-12-09 | C1 | 504h | 504h | EVS_codec-CT | 33 | Nokia Networks | Jan.Kall@nsn.com | Rel-12 | 65 |  |  | CP-140618 |
| 5421 | 1922.4.3 | CT3 part of CT impacts of codec for Enhanced Voice Services | 63d? | 2014-09-16 A | 2014-12-09 A | 100% |  |  |  | finish no earlier than 2014-12-09 | C3 | 504h | 504h | EVS_codec-CT | 33 | Nokia Networks | Jan.Kall@nsn.com | Rel-12 | 65 |  |  | CP-140560 |
| 5422 | 1922.5 | UE Conformance Test Aspects - Codec for Enhanced Voice Services (EVS) | 262d? | 2015-03-16 A | 2016-03-15 A | 100% |  |  |  | finish no earlier than 2016-03-15 | R5 | 2096h | 2096h | EVS_codec-UEConTest | 34 | Ericsson |  | Rel-12 | 67 |  |  | RP-151164 |
| 5423 | 1923 | **Coordination of Video Orientation** | 566.5d? | 2012-06-07 A | 2013-12-06 A | 100% | 2012-06-07 | 2013-12-06 | 400d? |  | S4; C4; C1; C3 | 20496.8h | 20496.8h | CVO | 29 | Ericsson | frederic.gabin@ericsson.com | Rel-12 | 56 | Paolo | CVO |  |
| 5424 | 1923.1 | SA4 part of Coordination of Video Orientation | 196d? | 2012-06-07 A | 2013-03-06 A | 100% | 2012-06-07 | 2013-03-06 | 196d? | finish no earlier than 2013-03-06 | S4 | 1560h | 1560h | CVO-SA4 | 29 | Ericsson | frederic.gabin@ericsson.com | Rel-12 | 56 | Paolo |  |  |
| 5425 | 1923.2 | **CT aspects of Coordination of Video Orientation** | 181.88d? | 2013-06-14 A | 2013-12-06 A | 100% | 2013-06-14 | 2013-12-06 | 129d? |  | C4; C1; C3 | 6136.8h | 6136.8h | CVO-CT | 31 | Ericsson | nevenka.biondic@ericsson.com | Rel-12 | 60 | Kimmo | CVO-CT |  |
| 5426 | 1923.2.1 | CT4 part of CT aspects of Coordination of Video Orientation | 128.05d? | 2013-06-14 A | 2013-12-06 A | 100% | 2013-06-14 | 2013-12-06 | 128.05d? | finish no earlier than 2013-12-06 | C4 | 1008.4h | 1008.4h | CVO-CT | 31 | Ericsson | nevenka.biondic@ericsson.com | Rel-12 | 60 | Kimmo |  |  |
| 5427 | 1923.2.2 | CT1 part of CT aspects of Coordination of Video Orientation | 129d? | 2013-06-14 A | 2013-12-06 A | 100% | 2013-06-14 | 2013-12-06 | 129d? | finish no earlier than 2013-12-06 | C1 | 1016h | 1016h | CVO-CT | 31 | Ericsson | nevenka.biondic@ericsson.com | Rel-12 | 60 | Frederic |  |  |
| 5428 | 1923.2.3 | CT3 part of CT aspects of Coordination of Video Orientation | 127.05d? | 2013-06-14 A | 2013-12-06 A | 100% | 2013-06-14 | 2013-12-06 | 127.05d? | finish no earlier than 2013-12-06 | C3 | 1016.4h | 1016.4h | CVO-CT | 31 | Ericsson | nevenka.biondic@ericsson.com | Rel-12 | 60 | Adrian |  |  |
| 5429 | 1924 | **High Efficiency Video Coding** | 842.62d? | 2012-09-12 A | 2014-12-05 A | 100% | 2012-09-12 | 2014-12-05 | 591d? |  | S4; IETF | 21576h | 21576h | HEVC | 29 | Qualcomm | Ye-Kui Wang (yekuiw@qti.qualcomm.com) | Rel-12 | 57 | Paolo | HEVC |  |
| 5430 | 1924.1 | TR on Evaluation of High Efficiency Video Coding for 3GPP Services | 464d? | 2012-09-12 A | 2014-06-19 A | 100% | 2012-09-12 | 2014-06-19 | 464d? | finish no earlier than 2014-06-18 | S4 | 3704h | 3704h | HEVC-SA4TR | 29 | Qualcomm | Ye-Kui Wang (yekuiw@qti.qualcomm.com) | Rel-12 | 57 | Paolo |  |  |
| 5431 | 1924.2 | High Efficiency Video Coding in 3GPP services PSS, MBMS, DASH, MMS, MTSI, IMS Messaging and Presence | 462d? | 2012-09-17 A | 2014-06-18 A | 100% | 2012-09-17 | 2014-06-18 | 462d? | finish no earlier than 2014-06-18 | S4 | 3688h | 3688h | HEVC-SA4 | 29 | Qualcomm | Ye-Kui Wang (yekuiw@qti.qualcomm.com) | Rel-12 | 57 | Paolo |  |  |
| 5432 | 1924.3 | (IETF) High Efficiency Video Coding | 587d? | 2012-09-17 A | 2014-12-05 A | 100% | 2012-09-17 | 2014-12-05 | 587d? | finish no earlier than 2014-12-05 | S4-IETF | 4696h | 4696h | HEVC-SA4IETF | 32 | Thomas Stockhammer, Qualcomm Incorporated | tsto@qti.qualcomm.com | Rel-12 | 63 |  |  |  |
| 5433 | 1925 | Mobile stereoscopic 3D services extensions | 200d? | 2012-12-12 A | 2013-09-11 A | 100% | 2012-12-12 | 2013-09-11 | 200d? | finish no earlier than 2013-09-11 | S4 | 1568h | 1568h | M3DV_Ext | 30 | Huawei | lukasz.kondrad@huawei.com | Rel-12 | 58 | Paolo | M3DV_Ext |  |

Notes:
- 5410: Linked to Rel-12 SMURFs. Related to TS 22.278 (EPS) cl.7.1.8 Service Reachability (Firewall traversal for IP based services for non-3GPP access), TS 22.228 (IMS) cl.5 (support Firewall traversal), TR 33.830 (Study on Firewall traversal) / Impacted TSs and TRs: Stage 2/3
- 5411: SP#64 completed / Impacted TSs and TRs: 33.203; 33.402
- 5412: CP#64 completed. Stage 3 for 2 new SA3 solutions for firewall traversal: 1) UE access to PLMN IP-based services via restrictive non-3GPP Ans, 2) UE access to IMS services via restrictive ANs / Impacted TSs and TRs: 24.229; 24.302; New 24.322
- 5413: SP#64 completed. Triggered by SP-130602 LS from ETSI SAGE (TUAK as alternative to Milenage). 12/14: new TS added / Impacted TSs and TRs: New TSs: 35.231; 35.232; 35.233; 35.9nn; 35.9nn; 35.9nn
- 5414: Triggered by UID_370045 Study on enhanced voice service requirements for EPS (TR 22.813)
- 5415: SP#47 completed / Impacted TSs and TRs: 22.173
- 5416: SP#65 completion 09/14=>12/14. Exception in SP-140467. TS 26.441v200 for Approval. TSs 26.442/44/45/46/47/48/49/50/51v100 for 1-step Approval. Ongoing TS 26.443 EVS Codec ANSI C code (floating point). Dec.14: 90->95 / Impacted TSs and TRs: 26.114; New (26.441; 26.442; 26.443; 26.444; 26.445; 26.446; 26.447; 26.448; 26.449; 26.450; 26.451)
- 5417: SP#65 completion 09/14=>12/14. Ongoing TR 26.952 EVS Codec Performance Characterization. Exception in SP-140467 / Impacted TSs and TRs: New 26.952
- 5418: Stage 3¦WID: CP-140492-> CP-140800
- 5419: CP#65 exception in CP-140478. Dec.14: 0->100¦WID: CP-140492-> CP-140800 / Impacted TSs and TRs: 23.334; 29.232; 29.238; 29.332; 29.333; 29.334
- 5420: CP#65 exception in CP-140618. Dec.14: 0->100%¦WID: CP-140492-> CP-140800 / Impacted TSs and TRs: 24.229
- 5421: CP#65 exception in CP-140560. Dec.14: 20->100¦WID: CP-140492-> CP-140800 / Impacted TSs and TRs: 29.163; 29.292
- 5422: 03/07/15: Compl:0%->25% 03/07/15: WID: RP-150137->RP-150836 03/07/15: Stat Rep: ->RP-150831 29/09/15: Compl:25%->75% 29/09/15: Stat Rep: RP-150831->RP-1511641/1/16: Compl:75%->95%1/1/16: CD:Tue 15/12/15->Tue 15/03/16;
- 5423: CP#62 completed. Resolve backward compatible video orientation mis-alignment in MTSI real-time video communication via interaction between MTSI video clients at call setup & during mid-call of the video orientation for correct local rendering
- 5424: SP#59 completed. Resolve backward compatible video orientation mis-alignment in MTSI real-time video communication via interaction between MTSI video clients at call setup & during mid-call of the video orientation for correct local rendering / Impacted TSs and TRs: 26.114; 26.141; 26.234; 26.346
- 5425: Complete CVO support (both, basic 2 bit orientation and additional option for extra 6 bit granularity) within CN protocols/procedures for IMS nodes, e.g. IMS ALG/AGW,IBCF/TrGW,MRFC/MRFP & add support of CVO-related SDP attributes to be negotiated by UE / Impacted TSs and TRs: Stage 2/3
- 5426: CP#62 completed / Impacted TSs and TRs: 23.333; 23.334; 29.238; 29.332; 29.333; 29.334
- 5427: CP#62 completed / Impacted TSs and TRs: 24.229
- 5428: CP#62 completed / Impacted TSs and TRs: 29.162; 29.163
- 5429: Specify the support of HEVC in 3GPP services (PSS, DASH, MTSI, MMS, MBMS, IMS Messaging and Presence)
- 5430: SP#64 completed. TR 26.906v200 for Approval / Impacted TSs and TRs: New 26.906
- 5431: SP#64 completed / Impacted TSs and TRs: 26.114; 26.140; 26.141; 26.234; 26.244; 26.247; 26.346
- 5432: Submitted to IESG for publication. 7/10/15: Rapporteur added¦7/3/16: 50%->95¦13/6/16: 95%->100 / Impacted TSs and TRs: draft-ietf-payload-rtp-h265=>RFC7798
- 5433: SP#61 completed. Related to Rel-11 Study On Mobile 3D Video Coding (FS_M3DVC) TR 26.905 and Rel-11 Mobile 3D Video Coding (M3DVC) / Impacted TSs and TRs: 26.114; 26.245; 26.247; 26.430

| ID | WBS | Task | Duration | Start | Finish | Complete | Baseline start | Baseline finish | Baseline duration | Constraint | Resources | Work | Actual work | Acronym | PCG approved | WI rapporteur name | WI rapporteur e-mail | Release | TSG approved | MCC resp | Acronym_3GU_Export | Impacted TSs and TRs | Status Report | Special Focus Doc |
| --- | --- | --- | --- | --- | --- | --- | --- | --- | --- | --- | --- | --- | --- | --- | --- | --- | --- | --- | --- | --- | --- | --- | --- | --- |
| 5434 | 1926 | **IMS-based Streaming and Download Delivery Enhancements** | 466.25d? | 2012-12-12 A | 2014-03-07 A | 100% | 2012-12-12 | 2014-03-07 | 329d? |  | S4 | 7800h | 7800h | IMS_SDE | 30 | Intel | ozgur.oyman@intel.com | Rel-12 | 58 | Paolo | IMS_SDE |  |  |  |
| 5435 | 1926.1 | TR on IMS-based Streaming and Download Delivery Enhancements | 326d? | 2012-12-12 A | 2014-03-07 A | 100% | 2012-12-12 | 2014-03-07 | 326d? | finish no earlier than 2014-03-07 | S4 | 2584h | 2584h | IMS_SDE-SA4TR | 30 | Intel | ozgur.oyman@intel.com | Rel-12 | 58 | Paolo |  | new 26.827 |  |  |
| 5436 | 1926.2 | Specification on IMS-based Streaming and Download Delivery Enhancements | 327d? | 2012-12-13 A | 2014-03-07 A | 100% | 2012-12-13 | 2014-03-07 | 327d? | finish no earlier than 2014-03-07 | S4 | 2584h | 2584h | IMS_SDE-SA4 | 30 | Intel | ozgur.oyman@intel.com | Rel-12 | 58 | Paolo |  | 26.237 |  |  |
| 5437 | 1927 | **Acoustic Requirements and Test methods for IMS-based conversational speech services over LTE** | 755.88d? | 2012-12-12 A | 2014-12-12 A | 100% | 2012-12-12 | 2014-09-17 | 467d? |  | S4 | 14224h | 14224h | ART_LTE | 30 | Qualcomm | Andre Schevciw (aschevci@qualcomm.com) | Rel-12 | 58 | Paolo | ART_LTE | Stage 3 |  |  |
| 5438 | 1927.1 | Acoustic Requirements and Test methods for IMS-based conversational speech services over LTE - NarrowBand and WideBand aspects | 265d? | 2012-12-12 A | 2013-12-11 A | 100% | 2012-12-12 | 2013-12-11 | 265d? | finish no earlier than 2013-12-11 | S4 | 2088h | 2088h | ART_LTE-NBWB | 30 | Sony Mobile Communications | Peter.Isberg@sony.com | Rel-12 | 58 | Paolo | ART_LTE-NBWB | 26.131; 26.132 |  |  |
| 5439 | 1927.2 | Acoustic Requirements and Test methods for IMS-based conversational speech services over LTE - UE Delay aspects | 462d? | 2012-12-12 A | 2014-09-17 A | 100% | 2012-12-12 | 2014-09-17 | 461d? | finish no earlier than 2014-09-17 | S4 | 3696h | 3696h | ART_LTE-UED | 30 | AT&T, Orange | luisa.marchetto@att.com, stephane.ragot@orange.com | Rel-12 | 58 | Paolo | ART_LTE-UED | 26.131; 26.132 |  |  |
| 5440 | 1927.3 | Acoustic Requirements and Test methods for IMS-based conversational speech services over LTE - Super wideband and fullband aspects | 523d? | 2012-12-12 A | 2014-12-12 A | 100% | 2012-12-12 | 2014-09-17 | 461d? | finish no earlier than 2014-12-12 | S4 | 4184h | 4184h | ART_LTE-SUPER | 30 | Sony Mobile Communications | peter.isberg@sonymobile.com | Rel-12 | 58 | Paolo | ART_LTE-SUPER | 26.131; 26.132 | SP-140470 |  |
| 5441 | 1928 | **MBMS Improvements** | 669d? | 2013-03-06 A | 2014-12-12 A | 100% | 2013-03-06 | 2014-09-17 | 406d? |  | S4 | 18584h | 18584h | MI | 30 | Ericsson | eric.turcotte@ericsson.com | Rel-12 | 59 | Paolo | MI |  | SP-140471 |  |
| 5442 | 1928.1 | TR on Enhanced MBMS Operation | 463d? | 2013-03-06 A | 2014-12-12 A | 100% | 2013-03-06 | 2014-09-17 | 401d? | finish no earlier than 2014-12-12 | S4 | 3704h | 3704h | MI-EMOTR | 30 | Huawei | Zhiming Li (lizhiming@huawei.com) | Rel-12 | 59 | Paolo |  | New 26.848 | SP-140471 |  |
| 5443 | 1928.2 | Enhanced MBMS Operation | 463d? | 2013-03-06 A | 2014-12-12 A | 100% | 2013-03-06 | 2014-09-17 | 401d? | finish no earlier than 2014-12-12 | S4 | 3704h | 3704h | MI-EMO | 30 | Huawei | Zhiming Li (lizhiming@huawei.com) | Rel-12 | 59 | Paolo | MI-EMO | 26.247; 26.346 | SP-140471 |  |
| 5444 | 1928.3 | TR on MBMS operation on Demand | 463d? | 2013-03-06 A | 2014-12-12 A | 100% | 2013-03-06 | 2014-09-17 | 401d? | finish no earlier than 2014-12-12 | S4 | 3704h | 3704h | MI-MooDTR | 30 | Qualcomm | Charles Lo (clo@qti.qualcomm.com) | Rel-12 | 59 | Paolo |  | New 26.849 | SP-140471 |  |
| 5445 | 1928.4 | MBMS operation on Demand | 463d? | 2013-03-06 A | 2014-12-12 A | 100% | 2013-03-06 | 2014-09-17 | 401d? | finish no earlier than 2014-12-12 | S4 | 3704h | 3704h | MI-MooD | 30 | Qualcomm | Charles Lo (clo@qti.qualcomm.com) | Rel-12 | 59 | Paolo | MI-MooD | 26.346 | SP-140471 |  |
| 5446 | 1929 | **End-to-End Multimedia Telephony Service for IMS (MTSI) extensions** | 955d? | 2013-03-06 A | 2015-09-14 A | 100% | 2013-03-06 | 2015-03-13 | 533d? |  | S4 | 32648h | 32648h | E2EMTSI | 30 | Ericsson | tomas.frankkila@ericsson.com | Rel-12 | 59 | Paolo | E2EMTSI | 26.114 |  |  |
| 5447 | 1929.1 | S4 aspects of End-to-End Multimedia Telephony Service for IMS (MTSI) extensions | 406d? | 2013-03-06 A | 2014-09-16 A | 100% | 2013-03-06 | 2015-03-13 | 533d? | finish no earlier than 2014-09-17 | S4 | 3248h | 3248h | E2EMTSI | 30 | Ericsson | tomas.frankkila@ericsson.com | Rel-12 | 59 | Paolo | E2EMTSI | 26.114 |  |  |
| 5448 | 1929.2 | **CT aspects of End-to-End Multimedia Telephony Service for IMS (MTSI) extensions** | 844.38d? | 2013-06-21 A | 2015-09-14 A | 100% | 2013-06-20 | 2014-09-12 | 326d? |  | C3; C1; C4 | 24064h | 24064h | E2EMTSI-CT | 31 | Ericsson | susana.fernandez@ericsson.com | Rel-12 | 60 | Adrian |  | Stage 2/3 |  |  |
| 5449 | 1929.2.1 | CT3 part of CT aspects of End-to-End Multimedia Telephony Service for IMS (MTSI) extensions | 589d? | 2013-06-21 A | 2015-09-14 A | 100% | 2013-06-20 | 2014-09-12 | 326d? | finish no earlier than 2015-09-14 | C3 | 4712h | 4712h | E2EMTSI-CT | 31 | Ericsson | susana.fernandez@ericsson.com | Rel-12 | 60 | Adrian |  | 29.162; 29.163; 29.213; 29.214 |  |  |
| 5450 | 1929.2.2 | CT1 part of CT aspects of End-to-End Multimedia Telephony Service for IMS (MTSI) extensions | 326d? | 2013-06-21 A | 2014-09-12 A | 100% | 2013-06-20 | 2014-09-12 | 326d? | finish no earlier than 2014-09-12 | C1 | 2608h | 2608h | E2EMTSI-CT | 31 | Ericsson | susana.fernandez@ericsson.com | Rel-12 | 60 | Frederic |  | 24.229 |  |  |
| 5451 | 1929.2.3 | CT4 part of CT aspects of End-to-End Multimedia Telephony Service for IMS (MTSI) extensions | 326d? | 2013-06-21 A | 2014-09-12 A | 100% | 2013-06-20 | 2014-09-12 | 326d? | finish no earlier than 2014-09-12 | C4 | 2608h | 2608h | E2EMTSI-CT | 31 | Ericsson | susana.fernandez@ericsson.com | Rel-12 | 60 | Kimmo |  | 23.333; 23.334; 29.238; 29.332; 29.333; 29.334 |  |  |
| 5452 | 1930 | Video Coding Enhancements in IMS Messaging and Presence | 64d? | 2013-12-11 A | 2014-03-07 A | 100% | 2013-12-11 | 2014-03-07 | 64d? | finish no earlier than 2014-03-07 | S4 | 504h | 504h | VCEIMP | 32 | Ericsson | frederic.gabin@ericsson.com | Rel-12 | 62 | Paolo | VCEIMP | 26.141 |  |  |
| 5453 | 1931 | Video Telephony Robustness Improvements | 66d? | 2014-06-18 A | 2014-09-16 A | 100% | 2014-06-18 | 2014-09-17 | 66d? | finish no earlier than 2014-09-17 | S4 | 528h | 528h | VTRI | 33 | Qualcomm | Muhammed Coban (mcoban@qti.qualcomm.com) | Rel-12 | 64 |  | VTRI | 26.114 |  |  |
| 5454 | 1932 | **Rel-12 Operations, Administration, Maintenance and Provisioning (OAM&P)** | 1219.25d? | 2011-09-21 A | 2014-12-12 A | 100% | 2011-09-21 | 2014-09-17 | 792d? |  | S5 | 58352.5h | 58352.5h | OAM12 | 29 |  |  | Rel-12 | 56 | Mirko | OAM12 |  |  |  |
| 5455 | 1932.1 | **Rel-12 Self-Organizing Networks (SON) - OAM aspects** | 840.75d? | 2011-09-21 A | 2013-12-11 A | 100% | 2011-09-21 | 2013-12-11 | 591d? |  | S5 | 9408h | 9408h | OAM12-SON | 29 |  |  | Rel-12 | 56 | Mirko | OAM12-SON |  |  | HNB, SON |
| 5456 | 1932.1.1 | Multi-vendor Plug and Play eNB connection to the network | 586d? | 2011-09-21 A | 2013-12-11 A | 100% | 2011-09-21 | 2013-12-11 | 586d? | finish no earlier than 2013-12-11 | S5 | 4680h | 4680h | SON-NM-MUPPET | 29 | NSN | anatoly.andrianov@nsn.com | Rel-12 | 56 | Mirko | SON-NM-MUPPET | 32.501; New TSs (32.508; 32.509) |  | HNB, SON |
| 5457 | 1932.2 | **Compliance of 3GPP SA5 specifications to the NGMN Next Generation Converged Operations Requirements (NGCOR)** | 848d? | 2012-06-20 A | 2014-09-17 A | 100% | 2012-06-20 | 2014-09-17 | 595d? |  | S5 | 11616.5h | 11616.5h | OAM-NGMN_NGCOR | 29 | Huawei | christian.toche@huawei.com | Rel-12 | 56 | Mirko | OAM-NGMN_NGCOR |  |  |  |
| 5458 | 1932.2.1 | Converged Management Model Alignment (Phase 2) | 593d? | 2012-06-20 A | 2014-09-17 A | 100% | 2012-06-20 | 2014-09-17 | 593d? | finish no earlier than 2014-09-17 | S5 | 4744h | 4744h | OAM-MODAL | 29 | NSN | olaf.pollakowski@nsn.com | Rel-12 | 56 | Mirko | OAM-MODAL | 32.156; new 28.820 |  |  |
| 5459 | 1932.2.2 | 3GPP Fault Management Solution Profile for NGMN NGCOR | 266d? | 2012-06-20 A | 2013-06-19 A | 100% | 2012-06-20 | 2013-06-19 | 266d? | finish no earlier than 2013-06-19 | S5 | 2104.53h | 2104.53h | OAM-FMSP | 29 | Ericsson | thomas.tovinger@ericsson.com | Rel-12 | 56 | Mirko | OAM-FMSP | new 28.390 |  |  |

Notes:
- 5434: Provide an extension of IMS based PSS and MBMS user services
- 5435: SP#63 completed. Identify use cases and requirements based on Rel-10/11 PSS and MBMS functionality to be addressed for IMS-based streaming and download enhancements
- 5436: SP#63 completed. Develop procedures towards enabling the IMS-based extensions of the identified use casES in CP-150TS 26.237. Refine existing MBMS download procedures to enable IMS-based MBMS file repair with the use of conventional HTTP web servers.
- 5437: Triggered by Rel-12 Feature Codec for Enhanced Voice Services (EVS_codec) UID_470030. Need for super wideband acoustic requirements and test methods
- 5438: SP#62 completed
- 5439: SP#65 completed
- 5440: SP#65 completion 09/14=>12/14. Exception in SP-140470. Dec.14: 65->100
- 5441: Stage 3 based on existing Stage 2 in TS 23.246 MBMS Architecture and functional description
- 5442: SP#65 completion 09/14=>12/14. Exception in SP-140471. SP#63 TR 26.848v100 for Information. Dec.14: 85->100.
- 5443: SP#65 completion 09/14=>12/14. Exception in SP-140471. Dec.14: 85->100
- 5444: SP#65 completion 09/14=>12/14. Exception in SP-140471. SP#63 TR 26.849v100 for Information. Dec.14: 75->100
- 5445: SP#65 completion 09/14=>12/14. Exception in SP-140471. Dec.14: 75->100
- 5446: SP#65 completed. Updated WID SP-130670=>SP-140594. Reduced Scope & Objectives. Moved work on new TR 26.924, etc. to Rel-13. Co-ordinate with CT1/3/4. Linked to SA4 Rel-7 Media handling and interaction in MTSI (MTSI-MHI) UID_7040
- 5447: SP#65 completed. Updated WID SP-130670=>SP-140594. Reduced Scope & Objectives. Moved work on new TR 26.924, etc. to Rel-13. Co-ordinate with CT1/3/4. Linked to SA4 Rel-7 Media handling and interaction in MTSI (MTSI-MHI) UID_7040
- 5448: Stage 2/3. 5/5/15: corrected to be Rel-12. Nothing to be done in the end (covered by Rel-13 QOSE2EMTSI-CT), so 100%
- 5449: Dec.14: CD: 09/14->09/15. 5/5/15: corrected to be Rel-12. Nothing to be done in the end (covered by Rel-13 QOSE2EMTSI-CT), so 100%
- 5450: CP#64 completion 06/14=>09/14. 5/5/15: corrected to be Rel-12. Nothing to be done in the end (covered by Rel-13 QOSE2EMTSI-CT), so 100%
- 5451: CP#64 completion 06/14=>09/14. 5/5/15: corrected to be Rel-12. Nothing to be done in the end (covered by Rel-13 QOSE2EMTSI-CT), so 100%
- 5452: SP#63 completed. Linked to Rel-6 Media Codecs and Formats for IMS Messaging and Presence (PRESNC-COFIMP) UID_34025. Work item which gave rise to TS 26.141
- 5453: SP#65 completed. Linked to E2EMTSI (End-to-End Multimedia Telephony Service for IMS extensions). Add Reqs&guidelines for video telephony robustness to improve service perf. for PLI, Generic NACK, and FIR messages within overall bitrate limit
- 5454: OAM12 is an umbrella Feature for changes that are not part of any other dedicated feature/WI
- 5455: OAM12-SON is an umbrella BB also for SON related TEI12 type of changes that are not part of any other dedicated feature/WI
- 5456: SP#62 completed. TS 32.508v200 for Approval, TS 32.509v100 for 1-step Approval
- 5457: SP#65 moved to Rel-13 OAM-PMID (Converged management Performance Management Interface Definition) UID_560235
- 5458: SP#65 completed. TR 28.280v100 for 1-step Approval
- 5459: SP#60 completed. TS 28.390v200 for Approval

| ID | WBS | Task | Duration | Start | Finish | Complete | Baseline start | Baseline finish | Baseline duration | Constraint | Resources | Work | Actual work | Acronym | PCG approved | WI rapporteur name | WI rapporteur e-mail | Release | TSG approved | MCC resp | Special Focus Doc | Acronym_3GU_Export | Status Report | TSG stopped |
| --- | --- | --- | --- | --- | --- | --- | --- | --- | --- | --- | --- | --- | --- | --- | --- | --- | --- | --- | --- | --- | --- | --- | --- | --- |
| 5460 | 1932.3 | **Network Management for 3GPP Interworking WLAN** | 1130.5d? | 2011-09-21 A | 2014-09-17 A | 100% | 2011-09-21 | 2014-06-18 | 727d? |  | S5 | 17232h | 17232h | OAM-IWLAN | 27 | China Mobile | Chengang@chinamobile.com, lijian@chinamobile.com | Rel-12 | 53 | Mirko | WLAN | OAM-IWLAN |  |  |
| 5461 | 1932.3.1 | Performance measurements part Network Management for 3GPP Interworking WLAN | 785d? | 2011-09-22 A | 2014-09-17 A | 100% | 2011-09-22 | 2014-06-18 | 720d? | finish no earlier than 2014-09-17 | S5 | 6272h | 6272h | OAM-IWLAN-SA5P | 27 | China Mobile | Chengang@chinamobile.com, lijian@chinamobile.com | Rel-12 | 53 | Mirko | WLAN |  |  |  |
| 5462 | 1932.3.2 | NIM part Network Management for 3GPP Interworking WLAN | 585d? | 2011-09-21 A | 2013-12-11 A | 100% | 2011-09-21 | 2013-12-11 | 585d? | finish no earlier than 2013-12-11 | S5 | 4672h | 4672h | OAM-IWLAN-SA5NM | 27 | China Mobile | Chengang@chinamobile.com, lijian@chinamobile.com | Rel-12 | 53 | Mirko | WLAN |  |  |  |
| 5463 | 1932.4 | **Rel-12 Network Infrastructure Management** | 379.5d? | 2013-12-11 A | 2014-12-12 A | 100% | 2013-12-11 | 2014-09-17 | 202d? |  | S5 | 5848h | 5848h | OAM12-NIM | 30 |  |  | Rel-12 | 58 | Mirko |  | OAM12-NIM |  |  |
| 5464 | 1932.4.1 | Alarm quality improvements | 263d? | 2013-12-11 A | 2014-12-12 A | 100% | 2013-12-11 | 2014-09-17 | 201d? | finish no earlier than 2014-12-12 | S5 | 2104h | 2104h | OAM-AMI-SA5 | 32 | TeliaSonera | tommy.berggren@teliasonera.com | Rel-12 | 62 | Mirko |  | OAM-AMI | SP-140544 |  |
| 5465 | 1932.4.2 | Radio Planning Tool (RPT) interface | 201d? | 2014-03-07 A | 2014-12-12 A | 100% | 2014-03-07 | 2014-09-17 | 139d? | finish no earlier than 2014-12-12 | S5 | 1608h | 1608h | OAM-RPTi-SA5 | 32 | Nokia Networks | olaf.pollakowski@nsn.com | Rel-12 | 63 | Mirko |  | OAM-RPTi | SP-140546 |  |
| 5466 | 1932.5 | Deleted - Rel-12 Performance Management | 468.62d? | 2013-06-21 A | 2014-09-16 A | 100% | 2013-06-21 | 2014-09-17 | 328d? |  | S5 | 2624h | 2624h | OAM12-PM | 30 |  |  | Rel-12 | 58 | Mirko |  | OAM12-PM |  | SP-69 |
| 5467 | 1932.6 | **OAM aspects of Network Sharing** | 379.5d? | 2013-12-11 A | 2014-12-12 A | 100% | 2013-12-11 | 2014-09-17 | 202d? |  | S5 | 6344h | 6344h | OAM-SHARE | 32 | Orange | jeanmichel.cornily@orange.com | Rel-12 | 62 | Mirko |  | OAM-SHARE | SP-140545 |  |
| 5468 | 1932.6.1 | OAM aspects of Network Sharing - Concepts and high-level requirements | 263d? | 2013-12-11 A | 2014-12-12 A | 100% | 2013-12-11 | 2014-09-17 | 201d? | finish no earlier than 2014-12-12 | S5 | 2104h | 2104h | OAM-SHARE-SA5c | 32 | Orange | jeanmichel.cornily@orange.com | Rel-12 | 62 | Mirko |  |  | SP-140545 |  |
| 5469 | 1932.6.2 | OAM aspects of Network Sharing - Impacts on existing specifications | 263d? | 2013-12-12 A | 2014-12-12 A | 100% | 2013-12-12 | 2014-09-17 | 201d? | finish no earlier than 2014-12-12 | S5 | 2104h | 2104h | OAM-SHARE-SA5imp | 32 | Orange | jeanmichel.cornily@orange.com | Rel-12 | 62 | Mirko |  |  | SP-140545 |  |
| 5470 | 1933 | **Rel-12 Charging** | 573d? | 2012-12-12 A | 2014-06-18 A | 100% | 2012-12-12 | 2014-06-18 | 402d? |  | S5 | 10112h | 10112h | CH12 | 29 |  |  | Rel-12 | 57 | Mirko |  | CH12 |  |  |
| 5471 | 1933.1 | Short Message Service - Service Center (SMS-SC) Offline Charging | 325d? | 2012-12-12 A | 2014-03-07 A | 100% | 2012-12-12 | 2014-03-07 | 325d? | finish no earlier than 2014-03-07 | S5 | 2592h | 2592h | SMS-SC-CH | 30 | Alcatel-Lucent | maryse.gardella@alcatel-lucent.com | Rel-12 | 58 | Mirko |  | SMS-SC-CH |  |  |
| 5472 | 1933.2 | Charging per IP - Connectivity Access Network (IP-CAN) Session (Stage 2/3) | 201d? | 2013-09-12 A | 2014-06-18 A | 100% | 2013-09-12 | 2014-06-18 | 201d? | finish no earlier than 2014-06-18 | S5 | 1608h | 1608h | CHIPS | 31 | Ericsson | david.shrader@ericsson.com | Rel-12 | 61 | Mirko |  | CHIPS |  |  |
| 5473 | 1933.3 | Charging using an Alternative Roaming Provider (Stage 2/3) | 202d? | 2013-09-12 A | 2014-06-18 A | 100% | 2013-09-12 | 2014-06-18 | 202d? | finish no earlier than 2014-06-18 | S5 | 1608h | 1608h | CHARP | 31 | Ericsson | david.shrader@ericsson.com | Rel-12 | 61 | Mirko |  | CHARP |  |  |
| 5474 | 1933.4 | Charging for IMS centralized service (ICS) control (Stage 2/3) | 137d? | 2013-12-11 A | 2014-06-18 A | 100% | 2013-12-11 | 2014-06-18 | 137d? | finish no earlier than 2014-06-18 | S5 | 1088h | 1088h | CHICS | 32 | NSN | Gerald.Goermer@nsn.com | Rel-12 | 62 | Mirko |  | CHICS |  |  |
| 5475 | 1934 | **IMS Emergency PSAP Callback (Stage 3)** | 1031.12d? | 2011-09-21 A | 2014-06-13 A | 100% | 2011-09-21 | 2014-06-13 | 724d? |  | C1; C3; IETF | 38848h | 38848h | EMC_PC | 27 | Ericsson | christer.holmberg@ericsson.com | Rel-12 | 53 | Frederic | Public Safety (I-A) | EMC_PC |  |  |
| 5476 | 1934.1 | CT1 part of IMS Emergency PSAP Callback | 721d? | 2011-09-22 A | 2014-06-13 A | 100% | 2011-09-22 | 2014-06-13 | 721d? | finish no earlier than 2014-06-13 | C1 | 5760h | 5760h | EMC_PC | 27 | Ericsson | christer.holmberg@ericsson.com | Rel-12 | 53 | Frederic | Public Safety (I-A) |  |  |  |
| 5477 | 1934.2 | (IETF) CT1 part of IMS Emergency PSAP Callback (RFC 7090) | 723d? | 2011-09-21 A | 2014-06-13 A | 100% | 2011-09-21 | 2014-06-13 | 723d? | finish no earlier than 2014-06-13 | C1-IETF | 5776h | 5776h | EMC_PC | 27 | christer.holmberg@ericsson.com | christer.holmberg@ericsson.com | Rel-12 | 53 | Frederic | Public Safety (I-A) |  |  |  |
| 5478 | 1934.3 | CT3 part of IMS Emergency PSAP Callback | 519d? | 2011-09-24 A | 2013-09-06 A | 100% | 2011-09-24 | 2013-09-06 | 519d? | finish no earlier than 2013-09-06 | C3 | 4152h | 4152h | EMC_PC | 27 | Ericsson | christer.holmberg@ericsson.com | Rel-12 | 53 | Adrian | Public Safety (I-A) |  |  |  |
| 5479 | 1934.4 | (IETF) CT3 part of IMS Emergency PSAP Callback (RFC 7090) | 724d? | 2011-09-21 A | 2014-06-13 A | 100% | 2011-09-21 | 2014-06-13 | 724d? | finish no earlier than 2014-06-13 | C3-IETF | 5784h | 5784h | EMC_PC | 31 | christer.holmberg@ericsson.com | christer.holmberg@ericsson.com | Rel-12 | 60 | Adrian | Public Safety (I-A) |  |  |  |
| 5480 | 1935 | Interworking between a PLMN with WLAN to access the EPC and a PDN (Stage 3) | 265d? | 2012-09-10 A | 2013-09-06 A | 100% | 2012-09-10 | 2013-09-06 | 265d? | finish no earlier than 2013-08-12 | C3 | 2091.72h | 2091.72h | SAES_WLAN_EPC_intwk | 29 | Huawei | Christian.Herrero@huawei.com | Rel-12 | 57 | Adrian | WLAN | SAES_WLAN_EPC_intwk |  |  |
| 5481 | 1936 | **Reporting Enhancements in Warning Message Delivery (Stage 2/3)** | 573d? | 2012-12-07 A | 2014-06-13 A | 100% | 2012-12-07 | 2014-06-13 | 402d? |  | C1; C4; R3 | 20832.2h | 20832.2h | REP_WMD | 30 | one2many | peter.sanders@one2many.eu | Rel-12 | 58 | Frederic | Public Safety (I-A) | REP_WMD |  |  |
| 5482 | 1936.1 | CT1 part of Reporting Enhancements in Warning Message Delivery (Stage 2) | 329d? | 2012-12-07 A | 2014-03-04 A | 100% | 2012-12-07 | 2014-03-04 | 329d? | finish no earlier than 2014-03-06 | C1 | 2592.18h | 2592.18h | REP_WMD-CT1 | 30 | one2many | peter.sanders@one2many.eu | Rel-12 | 58 | Frederic | Public Safety (I-A) |  |  |  |
| 5483 | 1936.2 | CT4 part of Reporting Enhancements in Warning Message Delivery (Stage 2/3) | 400d? | 2012-12-10 A | 2014-06-13 A | 100% | 2012-12-10 | 2014-06-13 | 400d? | finish no earlier than 2014-06-13 | C4 | 3168h | 3168h | REP_WMD-CT4 | 30 | one2many | peter.sanders@one2many.eu | Rel-12 | 58 | Kimmo | Public Safety (I-A) |  |  |  |

Notes:
- 5460: SP#65 updated WID SP-120779=>SP-140542 (removed parts on CN and non-3GPP access). Discontinue I-WLAN spec.
- 5461: SP#65 completed. TS 28.402v100 for 1-step Approval, withdraw New TS 28.401 (CN and non-3GPP access i/w PMs). Moved PMs for EPC and non-3GPP access i/w from 28.401=>28.402 / Impacted TSs and TRs: new 28.401; withdrawn new 28.402
- 5462: SP#65 discontinue I-WLAN specs: Move parts (e.g. IOCs) applicable for EPC and non-3GPP access interworking NRMs from 28.601/2/6 to 28.611/2/6. Withdraw 28.601/2/6 (CN and non-3GPP access i/w NRMs). SP#62 completed. TSs 28.601/2/6/11/12/16 for Approval / Impacted TSs and TRs: 32.632; 32.636; 32.752; 32.756; new (28.611; 28.612; 28.616; withdrawn 28.601; 28.602; 28.606)
- 5463: -
- 5464: SP#65 completion 09/14=>12/14. Exception in SP-140544. Triggered by Rel-12 TR 32.859 Study on Alarm Management (FS_OAM_AM) . Dec.14: 50->100 / Impacted TSs and TRs: 32.111-1; 32.111-2; 32.111-6
- 5465: SP#65 completion 09/14=>12/14. Exception in SP-140546. SP#65 v100 TS 28.667/8 for Information. Dec.14: 60->100 / Impacted TSs and TRs: 32.101; New TSs (28.667; 28.668; 28.669)
- 5466: OAM12-PM is an umbrella BB also for PM related TEI12 type of changes that are not part of any other dedicated feature/WI
- 5467: SP#65 completion 09/14=>12/14. Exception in SP-140545. Triggered by Rel-12 TR 32.851 Study on OAM aspects of Network Sharing (FS_OAM_SHARE), Rel-6 Network Sharing (NTShar) UID_31018 / Impacted TSs and TRs: Stage 1/2/3
- 5468: SP#65 completion 09/14=>12/14. Exception in SP-140545. LM 80->100 / Impacted TSs and TRs: new 32.130
- 5469: SP#65 completion 09/14=>12/14. Exception in SP-140545. Dec.14: 60->100 / Impacted TSs and TRs: 28.401.28.621/2/3.28.651/2/3.28.654/5/6.28.657/8/9.28.701/2/3.28.731/2/3.28.734/5/6.32.101/2.32.111-1/2/3/6.32.121/2/6.32.155.32.171/2/6.32.300/1/2/6.32.311/2/6.32.321/2/6.32.331/2/6.32.341/2/6.32.351/352/6.32.361/2/6.32.381/2/6.32.405/6/7/8/9/10/11/12/41
- 5470: CH12 is an umbrella Feature for changes that are not part of any other dedicated feature/WI
- 5471: Stage 2/3. SP#63 completed. Updated WID SP-120775=>SP-140027 / Impacted TSs and TRs: 32.240; 32.274; 32.297; 32.298; 32.299
- 5472: SP#64 completed. 12/15: Acronym reverted back from CHIPCAN to CHIPS / Impacted TSs and TRs: 32.251; 32.298; 32.299
- 5473: SP#64 completed. TS 32.276v200 for Approval, 32.293v100 for 1-step Approval / Impacted TSs and TRs: 32.240; 32.299; New TSs [32.276 (Voice Call Service Charging); 32.293 (Proxy Function)]
- 5474: SP#64 completed. Align SA5 Charging specifications with Rel-8 Feature IMS Centralized Service control (ICSRA) and subsequent enhancements under TEIx (SA2 23.292 ICSRA Stage 2, CT3 29.292, CT1 24.607, 24.611) / Impacted TSs and TRs: 32.250; 32.298
- 5475: Dep. IETF ECRIT on PSAP call back. Fulfill SA1/2 Rel-7 EMC1 reqs UID_32045 PS domain and IMS impacts for supporting IMS Emergency calls (related to BB UID_1653 Emergency Call Enhancements for IP& PS Based Calls / Impacted TSs and TRs: Stage 3
- 5476: CP#64 completed. 2/4/15: acronym changed to EMC_PC / Impacted TSs and TRs: 24.229; tied to completion of IETF dependencies: 24.604; 24.605; 24.610; 24.611; 24.629
- 5477: CP#64 completed. 2/4/15: acronym changed to EMC_PC / Impacted TSs and TRs: RFC 7090 (was draft-ietf-ecrit-psap-callback
- 5478: CP#61 completed. 2/4/15: acronym changed to EMC_PC / Impacted TSs and TRs: 29.163; 29.165
- 5479: CP#64 completed. 2/4/15: acronym changed to EMC_PC / Impacted TSs and TRs: RFC 7090 (was draft-ietf-ecrit-psap-callback)
- 5480: CP#61 completed. Linked to Rel-8 Feature SAES in CP-150System Architecture Evolution specification - Evolved Packet System (non RAN aspects) UID_320005 / Impacted TSs and TRs: 29.061
- 5481: Stage 1 for Cell Broadcast does not exist. This WID enhances the reporting capabilities of Warning Message Delivery. Introduce LTE functionality requested by regulators, equivalent to existing 2G/3G functionality. / Impacted TSs and TRs: Stage 2/3
- 5482: CP#63 completed / Impacted TSs and TRs: 23.041
- 5483: CP#64 completed / Impacted TSs and TRs: 23.007; 29.168

| ID | WBS | Task | Duration | Start | Finish | Complete | Baseline start | Baseline finish | Baseline duration | Constraint | Resources | Work | Actual work | Acronym | PCG approved | WI rapporteur name | Release | TSG approved | MCC resp | Special Focus Doc | Acronym_3GU_Export | Status Report |
| --- | --- | --- | --- | --- | --- | --- | --- | --- | --- | --- | --- | --- | --- | --- | --- | --- | --- | --- | --- | --- | --- | --- |
| 5484 | 1936.3 | **Public Warning System - Reset/Failure/Restart in Warning Message Delivery in LTE** | 482.88d? | 2013-03-04 A | 2014-06-13 A | 100% | 2013-03-04 | 2014-06-13 | 340d? |  | R3 | 5424h | 5424h | REP_WMD-RFR_PWS | 30 | one2many, Huawei | Rel-12 | 59 | Juha | Public Safety (I-A) | REP_WMD-RFR_PWS |  |
| 5485 | 1936.3.1 | Core part: PWS - Reset/Failure/Restart in Warning Message Delivery in LTE | 338d? | 2013-03-04 A | 2014-06-13 A | 100% | 2013-03-04 | 2014-06-13 | 338d? | finish no earlier than 2014-06-13 | R3 | 2704h | 2704h | REP_WMD-RFR_PWS-Core | 30 | one2many, Huawei | Rel-12 | 59 | Juha | Public Safety (I-A) | REP_WMD-RFR_PWS-Core | RP-140637 |
| 5486 | 1937 | **Single Radio Voice Call Continuity (SRVCC) before ringing (Stage 3)** | 470.5d? | 2012-12-07 A | 2014-03-06 A | 100% | 2012-12-07 | 2014-03-06 | 331d? |  | C1; C3; R5 | 9584h | 9584h | bSRVCC | 30 | NTT DOCOMO | Rel-12 | 58 | Frederic |  | bSRVCC |  |
| 5487 | 1937.1 | CT1 part of Single Radio Voice Call Continuity (SRVCC) before ringing | 138d? | 2012-12-07 A | 2013-06-14 A | 100% | 2012-12-07 | 2013-06-14 | 138d? | finish no earlier than 2013-06-14 | C1 | 1096h | 1096h | bSRVCC | 30 | NTT DOCOMO | Rel-12 | 58 | Frederic |  |  |  |
| 5488 | 1937.2 | CT3 part of Single Radio Voice Call Continuity (SRVCC) before ringing | 3d? | 2013-06-12 A | 2013-06-14 A | 100% | 2013-06-12 | 2013-06-14 | 3d? | finish no earlier than 2013-06-14 | C3 | 24h | 24h | bSRVCC | 31 | NTT DOCOMO | Rel-12 | 60 | Adrian |  |  |  |
| 5489 | 1937.3 | Test part: Single Radio Voice Call Continuity (SRVCC) before ringing | 65d? | 2013-12-06 A | 2014-03-06 A | 100% | 2013-12-06 | 2014-03-06 | 65d? | finish no earlier than 2014-03-06 | R5 | 520h | 520h | bSRVCC-UEConTest | 32 | NTT DOCOMO | Rel-12 | 62 | Ingbert |  | bSRVCC-UEConTest | RP-140422 |
| 5490 | 1938 | **IMS Stage 3 IETF Protocol Alignment - phase 6** | 758.12d? | 2012-12-07 A | 2014-12-09 A | 100% | 2012-12-07 | 2014-12-05 | 527d? |  | C1; C3; IETF | 20640.6h | 20640.6h | IMSProtoc6 | 30 | Alcatel-Lucent | Rel-12 | 58 | Frederic |  | IMSProtoc6 |  |
| 5491 | 1938.1 | CT1 part of IMS Stage 3 IETF Protocol Alignment - phase 6 | 464d? | 2012-12-07 A | 2014-09-11 A | 100% | 2012-12-07 | 2014-09-12 | 464d? | finish no earlier than 2014-09-12 | C1 | 3712h | 3712h | IMSProtoc6 | 30 | Alcatel-Lucent | Rel-12 | 58 | Frederic |  |  |  |
| 5492 | 1938.2 | (IETF) CT1 part of IMS Stage 3 IETF Protocol Alignment - phase 6 (draft-holmberg-sipcore-received-realm) | 410d? | 2013-05-21 A | 2014-12-09 A | 100% | 2013-05-21 | 2014-12-05 | 408d? | finish no earlier than 2014-12-09 | C1-IETF | 3256.25h | 3256.25h | IMSProtoc6 | 31 | christer.holmberg@ericsson.com | Rel-12 | 60 | Frederic |  |  |  |
| 5493 | 1938.3 | Deleted - (IETF) CT1 part of IMS Stage 3 IETF Protocol Alignment - phase 6 (draft-jesske-sipcore-sip-tree-cap-indicators) | 63d? | 2014-09-12 A | 2014-12-05 A | 100% |  |  |  | finish no earlier than 2014-12-09 | C1-IETF | 504h | 504h | IMSProtoc6 | 33 | christer.holmberg@ericsson.com | Rel-12 | 65 |  |  |  |  |
| 5494 | 1938.4 | (IETF) CT1 part of IMS Stage 3 IETF Protocol Alignment - phase 6 (draft-ietf-insipid-session-id) | 65d? | 2014-09-12 A | 2014-12-09 A | 100% |  |  |  | start no earlier than 2014-09-12 | C1-IETF | 520h | 520h | IMSProtoc6 | 34 | christer.holmberg@ericsson.com | Rel-12 | 65 |  |  |  |  |
| 5495 | 1938.5 | CT3 part of IMS Stage 3 IETF Protocol Alignment - phase 6 | 71d? | 2014-06-06 A | 2014-09-11 A | 100% | 2014-06-06 | 2014-09-12 | 71d? | finish no earlier than 2014-09-12 | C3 | 568h | 568h | IMSProtoc6 | 30 | Alcatel-Lucent | Rel-12 | 58 | Adrian |  |  |  |
| 5496 | 1938.6 | (IETF) CT3 part of IMS Stage 3 IETF Protocol Alignment - phase 6 (draft-holmberg-sipcore-received-realm) | 327d? | 2013-09-06 A | 2014-12-05 A | 100% | 2013-09-06 | 2014-12-05 | 327d? | finish no earlier than 2014-12-05 | C3-IETF | 2608h | 2608h | IMSProtoc6 | 31 | christer.holmberg@ericsson.com | Rel-12 | 61 |  |  |  |  |
| 5497 | 1939 | **SAE Protocol Development - Phase 3** | 666.12d? | 2012-12-07 A | 2014-09-11 A | 100% | 2012-12-07 | 2014-09-12 | 467d? |  | C1 | 14920h | 14920h | SAES3 | 30 | InterDigital | Rel-12 | 58 | Frederic |  | SAES3 |  |
| 5498 | 1939.1 | SAE Protocol Development (Stage 3) - Phase 3 | 466d? | 2012-12-07 A | 2014-09-11 A | 100% | 2012-12-07 | 2014-09-12 | 466d? | finish no earlier than 2014-09-12 | C1 | 3728h | 3728h | SAES3-CT1 | 30 | InterDigital | Rel-12 | 58 | Frederic |  |  |  |
| 5499 | 1939.2 | CS Fallback in EPS - Phase 3 | 466d? | 2012-12-07 A | 2014-09-11 A | 100% | 2012-12-07 | 2014-09-12 | 466d? | finish no earlier than 2014-09-12 | C1 | 3728h | 3728h | SAES3-CSFB | 30 | InterDigital | Rel-12 | 58 | Frederic |  | SAES3-CSFB |  |
| 5500 | 1939.3 | SAE for support for non-3GPP accesses - Phase 3 | 466d? | 2012-12-07 A | 2014-09-11 A | 100% | 2012-12-07 | 2014-09-12 | 466d? | finish no earlier than 2014-09-12 | C1 | 3728h | 3728h | SAES3-non3GPP | 30 | InterDigital | Rel-12 | 58 | Frederic |  | SAES3-non3GPP |  |
| 5501 | 1940 | **IM-SSF Application Server Service Data Descriptions (Stage 2/3)** | 196.5d? | 2012-12-07 A | 2013-06-14 A | 100% | 2012-12-07 | 2013-06-14 | 138d? |  | C4; C1 | 3780h | 3780h | IMS_SSFDD | 30 | Huawei | Rel-12 | 58 | Kimmo |  | IMS_SSFDD |  |
| 5502 | 1940.1 | Stage 2 for IM-SSF Application Server Service Data Descriptions | 62d? | 2012-12-07 A | 2013-03-01 A | 100% | 2012-12-07 | 2013-03-01 | 62d? | finish no earlier than 2013-06-14 | C1 | 488h | 488h | IMS_SSFDD | 30 | Huawei | Rel-12 | 58 | Frederic |  |  |  |
| 5503 | 1940.2 | Stage 3 for IM-SSF Application Server Service Data Descriptions | 136.5d? | 2012-12-10 A | 2013-06-14 A | 100% | 2012-12-10 | 2013-06-14 | 136.5d? | finish no earlier than 2013-06-14 | C4 | 1084h | 1084h | IMS_SSFDD | 30 | Huawei | Rel-12 | 58 | Kimmo |  |  |  |
| 5504 | 1941 | **Diameter based interface between SGSN and SMS central functions (Stage 2/3)** | 374.12d? | 2012-12-10 A | 2013-12-06 A | 100% | 2012-12-10 | 2013-12-06 | 265d? |  | C4; C1 | 7952h | 7952h | Dia_SGSN_SMS | 30 | Alcatel-Lucent | Rel-12 | 58 | Kimmo |  | Dia_SGSN_SMS |  |
| 5505 | 1941.1 | Stage 2 for Diameter based interface between SGSN and SMS central functions | 201d? | 2013-03-07 A | 2013-12-06 A | 100% | 2013-03-07 | 2013-12-06 | 201d? | finish no earlier than 2013-12-06 | C1 | 1608h | 1608h | Dia_SGSN_SMS | 30 | Alcatel-Lucent | Rel-12 | 59 | Frederic |  |  |  |
| 5506 | 1941.2 | Stage 3 for Diameter based interface between SGSN and SMS central functions | 265d? | 2012-12-10 A | 2013-12-06 A | 100% | 2012-12-10 | 2013-12-06 | 265d? | finish no earlier than 2013-12-06 | C4 | 2104h | 2104h | Dia_SGSN_SMS | 30 | Alcatel-Lucent | Rel-12 | 58 | Kimmo |  |  |  |
| 5507 | 1942 | Diameter based interface between SGSN-GMLC (Stage 3) | 265d? | 2012-12-10 A | 2013-12-06 A | 100% | 2012-12-10 | 2013-12-06 | 265d? | finish no earlier than 2013-12-06 | C4 | 2096h | 2096h | Dia_SGSN_GMLC | 30 | Cisco | Rel-12 | 58 | Kimmo |  | Dia_SGSN_GMLC |  |
| 5508 | 1943 | IMS impacts on UICC Application Aspects (Stage 3) | 465d? | 2013-03-04 A | 2014-12-09 A | 100% | 2013-03-04 | 2014-09-12 | 403d? | finish no earlier than 2014-12-09 | C6 | 3720h | 3720h | IMS_UApAs | 30 | Giesecke & Devrient | Rel-12 | 59 | Xavier |  | IMS_UApAs | CP-140696 |

Notes:
- 5484: - / Impacted TSs and TRs: LTE / WI rapporteur e-mail: peter.sanders@one2many.eu, Dai Mingzeng (daimingzeng@huawei.com)
- 5485: RP#64 completed / Impacted TSs and TRs: 36.413 / WI rapporteur e-mail: peter.sanders@one2many.eu, Dai Mingzeng (daimingzeng@huawei.com)
- 5486: Linked to Rel-8 Feature IMS Service Continuity (IMS-Cont) UID_390056. TS 23.237 Rel-12 CR#0444 under TEI12 / Impacted TSs and TRs: GERAN; UTRA; LTE / WI rapporteur e-mail: keisuke.sasada.kx@nttdocomo.com
- 5487: CP#60 completed. 2/4/15: acronym changed to bSRVCC / Impacted TSs and TRs: 24.008; 24.237 / WI rapporteur e-mail: keisuke.sasada.kx@nttdocomo.com
- 5488: CP#60 completedbSRVCC / Impacted TSs and TRs: 29.165 / WI rapporteur e-mail: keisuke.sasada.kx@nttdocomo.com
- 5489: RP#63 completed. Testing for CT1 TS 24.237 (IMS service continuity Stage 3) / Impacted TSs and TRs: 34.229-1; 34.229-2; 36.523-1; 36.523-2 / WI rapporteur e-mail: Masahiro.Tamaoki.eu@nttdocomo.com
- 5490: - / Impacted TSs and TRs: Stage 3 / WI rapporteur e-mail: keith.drage@alcatel-lucent.com
- 5491: CP#65 completed. 4/2/15: acronym changed to IMSProtoc6 / Impacted TSs and TRs: 23.218; 24.229; 24.930 / WI rapporteur e-mail: keith.drage@alcatel-lucent.com
- 5492: Not completed internet-draft. 4/2/15: acronym changed to IMSProtoc6¦21/3/17: 50%->100 / Impacted TSs and TRs: draft-holmberg-sipcore-received-realm / WI rapporteur e-mail: christer.holmberg@ericsson.com
- 5493: Not completed internet-draft. 4/2/15: acronym changed to IMSProtoc6; 9/4/21: 25%->100 / Impacted TSs and TRs: draft-allen-sipcore-sip-tree-cap-indicators / WI rapporteur e-mail: christer.holmberg@ericsson.com
- 5494: work in progress. 4/2/15: acronym changed to IMSProtoc6¦21/3/17: 25%->100; 9/4/21: RFC 7989 added; / Impacted TSs and TRs: draft-ietf-insipid-session-id; RFC 7989
- 5495: CP#65 completed. 4/2/15: acronym changed to IMSProtoc6 / Impacted TSs and TRs: 29.163; 29.165 / WI rapporteur e-mail: keith.drage@alcatel-lucent.com
- 5496: Not completed internet-draft. 4/2/15: acronym changed to IMSProtoc6¦21/3/17: 50%->100 / Impacted TSs and TRs: draft-holmberg-sipcore-received-realm / WI rapporteur e-mail: christer.holmberg@ericsson.com
- 5497: Stage 3 continuation of Rel-8 Feature SAES (3GPP System Architecture Evolution Specification - Evolved Packet System) UID_320005 / Impacted TSs and TRs: Stage 2/3 / WI rapporteur e-mail: behrouz.aghili@interdigital.com
- 5498: CP#65 completed / Impacted TSs and TRs: 23.122; 24.008; 24.167; 24.229; 24.301; 24.302; 24.303; 24.304; 24.305; 24.312; 29.018; 29.118 / WI rapporteur e-mail: behrouz.aghili@interdigital.com
- 5499: CP#65 completed / Impacted TSs and TRs: 23.122; 24.008; 24.167; 24.229; 24.301; 24.302; 24.303; 24.304; 24.305; 24.312; 29.018; 29.118 / WI rapporteur e-mail: behrouz.aghili@interdigital.com
- 5500: CP#65 completed / Impacted TSs and TRs: 23.122; 24.008; 24.167; 24.229; 24.301; 24.302; 24.303; 24.304; 24.305; 24.312; 29.018; 29.118 / WI rapporteur e-mail: behrouz.aghili@interdigital.com
- 5501: CP#60 completed / Impacted TSs and TRs: Stage 2/3 / WI rapporteur e-mail: susan.shishufeng@huawei.com
- 5502: CP#59 completed / Impacted TSs and TRs: 23.218 / WI rapporteur e-mail: susan.shishufeng@huawei.com
- 5503: CP#60 completed / Impacted TSs and TRs: 29.328; 29.329; 29.364 / WI rapporteur e-mail: susan.shishufeng@huawei.com
- 5504: CP#62 completed / Impacted TSs and TRs: Stage 2/3 / WI rapporteur e-mail: jean-jacques.trottin@alcatel-lucent.com
- 5505: CP#62 completed / Impacted TSs and TRs: 23.040 / WI rapporteur e-mail: jean-jacques.trottin@alcatel-lucent.com
- 5506: CP#62 completed / Impacted TSs and TRs: 29.002; 29.230; 29.272; 29.305; 29.336; 29.337; 29.338 / WI rapporteur e-mail: jean-jacques.trottin@alcatel-lucent.com
- 5507: CP#62 completed. Updated WID CP-130273=>CP-130598. No Stage 2 impact. Define a Diameter variant for the protocol used over existing reference points between SGSN and GMLC for LCS (replace the use of MAP by Diameter protocol) / Impacted TSs and TRs: 29.002; 29.172; 29.173; 29.230; 29.272 / WI rapporteur e-mail: Nirav Salot (nsalot@cisco.com)
- 5508: CP#65 completion 09/14=>12/14. Exception in CP-140696. Dec.14: 85->100% / Impacted TSs and TRs: 31.102; 31.103; 31.111; 31.130 / WI rapporteur e-mail: sergi.espi@gi-de.com

| ID | WBS | Task | Duration | Start | Finish | Complete | Baseline start | Baseline finish | Baseline duration | Constraint | Resources | Work | Actual work | Acronym | PCG approved | Impacted TSs and TRs | WI rapporteur name | WI rapporteur e-mail | Release | TSG approved | MCC resp | Acronym_3GU_Export | Status Report |
| --- | --- | --- | --- | --- | --- | --- | --- | --- | --- | --- | --- | --- | --- | --- | --- | --- | --- | --- | --- | --- | --- | --- | --- |
| 5509 | 1944 | **eMBMS restoration procedures** | 579.25d? | 2013-03-01 A | 2014-09-11 A | 100% | 2013-03-01 | 2014-06-13 | 341d? |  | C4; C3 | 10272h | 10272h | eMBMS_Rest | 30 | Stage 3 | Alcatel-Lucent | bruno.landais@alcatel-lucent.com | Rel-12 | 59 | Kimmo | eMBMS_Rest |  |
| 5510 | 1944.1 | CT4 part of eMBMS restoration procedures | 205d? | 2013-03-01 A | 2013-12-06 A | 100% | 2013-03-01 | 2013-12-06 | 205d? | finish no earlier than 2013-12-06 | C4 | 1616h | 1616h | eMBMS_Rest | 30 | 23.007; 23.008; 29.274 | Alcatel-Lucent | bruno.landais@alcatel-lucent.com | Rel-12 | 59 | Kimmo |  |  |
| 5511 | 1944.2 | CT3 part of eMBMS restoration procedures | 270d? | 2013-09-04 A | 2014-09-11 A | 100% | 2013-09-04 | 2014-06-13 | 205d? | finish no earlier than 2014-09-12 | C3 | 2160h | 2160h | eMBMS_Rest | 31 | 29.061 | Alcatel-Lucent | bruno.landais@alcatel-lucent.com | Rel-12 | 61 | Kimmo |  |  |
| 5512 | 1945 | **Dual Radio VCC enhancements (Stage 2/3)** | 458.88d? | 2012-09-19 A | 2013-12-06 A | 100% | 2012-09-19 | 2013-12-06 | 325d? |  | C1; C3.S2 | 10866.2h | 10866.2h | eDRVCC | 30 | Stage 2/3 | Ericsson | Jan.Holm@ericsson.com | Rel-12 | 59 | Maurice | eDRVCC |  |
| 5513 | 1945.1 | Stage 2 for Dual Radio VCC enhancements | 57.55d? | 2012-09-19 A | 2013-03-01 A | 100% | 2012-09-19 | 2013-03-01 | 57.55d? | finish no earlier than 2013-03-01 | S2 | 460.4h | 460.4h | eDRVCC | 30 | 23.237 | Ericsson | Jan.Holm@ericsson.com | Rel-12 | 59 | Maurice |  |  |
| 5514 | 1945.2 | **Stage 3 for Dual Radio VCC enhancements** | 290.5d? | 2013-03-01 A | 2013-12-06 A | 100% | 2013-03-01 | 2013-12-06 | 205d? |  | C1; C3 | 5205.8h | 5205.8h | eDRVCC | 30 | Stage 3 | Ericsson | Jan.Holm@ericsson.com | Rel-12 | 59 | Frederic |  |  |
| 5515 | 1945.2.1 | CT1 part of Stage 3 for Dual Radio VCC enhancements | 205d? | 2013-03-01 A | 2013-12-06 A | 100% | 2013-03-01 | 2013-12-06 | 205d? | finish no earlier than 2013-12-06 | C1 | 1608h | 1608h | eDRVCC | 30 | 24.237; 24.292 | Ericsson | Jan.Holm@ericsson.com | Rel-12 | 59 | Frederic |  |  |
| 5516 | 1945.2.2 | CT3 part of Stage 3 for Dual Radio VCC enhancements | 41.7d? | 2013-03-01 A | 2013-09-06 A | 100% | 2013-03-01 | 2013-09-06 | 41.7d? | finish no earlier than 2013-09-06 | C3 | 317.8h | 317.8h | eDRVCC | 30 | 29.165 | Ericsson | Jan.Holm@ericsson.com | Rel-12 | 59 | Adrian |  |  |
| 5517 | 1946 | **CT aspects of Signalling of Image Size (Stage 2/3)** | 181.88d? | 2013-06-14 A | 2013-12-06 A | 100% | 2013-06-14 | 2013-12-06 | 129d? |  | C4; C1; C3 | 6136.8h | 6136.8h | SIS_CT | 31 | Stage 2/3 | Ericsson | nevenka.biondic@ericsson.com | Rel-12 | 60 | Kimmo | SIS_CT |  |
| 5518 | 1946.1 | CT4 part of Signalling of Image Size | 128.05d? | 2013-06-14 A | 2013-12-06 A | 100% | 2013-06-14 | 2013-12-06 | 128.05d? | finish no earlier than 2013-12-06 | C4 | 1008.4h | 1008.4h | SIS_CT | 31 | 23.333; 23.334; 29.238; 29.332; 29.333; 29.334 | Ericsson | nevenka.biondic@ericsson.com | Rel-12 | 60 | Kimmo |  |  |
| 5519 | 1946.2 | CT1 part of CT Aspects of Signalling of Image Size | 129d? | 2013-06-14 A | 2013-12-06 A | 100% | 2013-06-14 | 2013-12-06 | 129d? | finish no earlier than 2013-12-06 | C1 | 1016h | 1016h | SIS_CT | 31 | 24.229 | Ericsson | nevenka.biondic@ericsson.com | Rel-12 | 60 | Frederic |  |  |
| 5520 | 1946.3 | CT3 part of CT Aspects of Signalling of Image Size | 128.05d? | 2013-06-14 A | 2013-12-06 A | 100% | 2013-06-14 | 2013-12-06 | 128.05d? | finish no earlier than 2013-12-06 | C3 | 1016.4h | 1016.4h | SIS_CT | 31 | 29.162; 29.163 | Ericsson | nevenka.biondic@ericsson.com | Rel-12 | 60 | Adrian |  |  |
| 5521 | 1947 | IMS Centralized Services (ICS) InterWorking Enhancement in Mobile Switching Center Server (MSC-S) | 181.88d? | 2013-06-14 A | 2013-12-06 A | 100% | 2013-06-14 | 2013-12-06 | 129d? | finish no earlier than 2013-12-06 | C3 | 1008h | 1008h | ICS_IWE | 31 | 29.292 | Orange | marianne.mohali@orange.com | Rel-12 | 60 | Adrian | ICS_IWE |  |
| 5522 | 1948 | GPRS Tunnelling Protocol for the Control plane (GTP-C) Overload Control Mechanisms | 267d? | 2013-09-06 A | 2014-09-11 A | 100% | 2013-09-06 | 2014-09-12 | 267d? | finish no earlier than 2014-09-12 | C4 | 2136h | 2136h | GOCMe | 31 | 23.008; 29.230; 29.273; 29.274; 29.303; New 29.807 | Cisco | Nirav Salot (nsalot@cisco.com) | Rel-12 | 61 | Kimmo | GOCMe |  |
| 5523 | 1949 | **Proxy Call Session Control Function (P-CSCF) restoration enhancements (Stage 2/3)** | 636.1d? | 2013-04-03 A | 2014-12-09 A | 100% | 2013-04-03 | 2014-12-05 | 442.1d? |  | C4; C3; C1 | 54903.2h | 54903.2h | PCSCF_RES | 31 | Stage 2/3 | Ericsson | maria.cruz.bartolome@ericsson.com | Rel-12 | 61 | Kimmo | PCSCF_RES |  |
| 5524 | 1949.1 | TR on Proxy Call Session Control Function (P-CSCF) restoration enhancements | 266d? | 2013-09-06 A | 2014-09-11 A | 100% | 2013-09-06 | 2014-09-12 | 266d? | finish no earlier than 2014-09-12 | C4 | 2128h | 2128h | PCSCF_RES | 31 | New 29.806 | Ericsson | maria.cruz.bartolome@ericsson.com | Rel-12 | 61 | Kimmo |  |  |
| 5525 | 1949.2 | **Common for HSS & PCRF solutions** | 636.1d? | 2013-04-03 A | 2014-12-09 A | 100% |  |  |  |  | C4; C3; C1 | 18602.4h | 18602.4h | PCSCF_RES | 33 |  | Ericsson | maria.cruz.bartolome@ericsson.com | Rel-12 | 64 |  |  |  |
| 5526 | 1949.2.1 | CT4 part of Common for HSS & PCRF solutions | 328d? | 2013-09-06 A | 2014-12-09 A | 100% | 2013-09-06 | 2014-12-05 | 326d? | finish no earlier than 2014-12-09 | C4 | 2624h | 2624h | PCSCF_RES | 31 | 23.380; 29.060; 29.274 | Ericsson | maria.cruz.bartolome@ericsson.com | Rel-12 | 61 | Kimmo |  | CP-140481 |
| 5527 | 1949.2.2 | CT1 part of Common for HSS & PCRF solutions | 328d? | 2013-04-03 A | 2014-12-05 A | 100% | 2013-04-03 | 2014-12-05 | 326d? | finish no earlier than 2014-12-09 | C1 | 2624h | 2624h | PCSCF_RES | 33 | 24.008 | Ericsson | maria.cruz.bartolome@ericsson.com | Rel-12 | 64 | Kimmo |  |  |
| 5528 | 1949.2.3 | CT3 part of Common for HSS & PCRF solutions | 328d? | 2013-05-03 A | 2014-12-09 A | 100% | 2013-05-03 | 2014-12-05 | 326d? | finish no earlier than 2014-12-09 | C3 | 2624h | 2624h | PCSCF_RES | 33 | 29.061; 29.165 | Huawei | susan.shishufeng@huawei.com | Rel-12 | 65 | Kimmo |  | CP-140687 |
| 5529 | 1949.3 | **HSS based solution** | 636.1d? | 2013-04-03 A | 2014-12-09 A | 100% |  |  |  |  | C4; C1 | 12401.6h | 12401.6h | PCSCF_RES | 33 |  | Ericsson | maria.cruz.bartolome@ericsson.com | Rel-12 | 64 |  |  |  |
| 5530 | 1949.3.1 | CT4 part of HSS based solution | 328d? | 2013-09-06 A | 2014-12-09 A | 100% | 2013-09-06 | 2014-12-05 | 326d? | finish no earlier than 2014-12-09 | C4 | 2624h | 2624h | PCSCF_RES | 31 | 29.002; 29.228; 29.229; 29.272; 29.305 | Ericsson | maria.cruz.bartolome@ericsson.com | Rel-12 | 61 | Kimmo |  | CP-140481 |
| 5531 | 1949.3.2 | CT1 part of HSS based solution | 328d? | 2013-04-03 A | 2014-12-09 A | 100% | 2013-04-03 | 2014-12-05 | 326d? | finish no earlier than 2014-12-09 | C1 | 2624h | 2624h | PCSCF_RES | 33 | 24.229 | Ericsson | maria.cruz.bartolome@ericsson.com | Rel-12 | 64 | Kimmo |  | CP-140605 |
| 5532 | 1949.4 | **PCRF based solution** | 636.1d? | 2013-04-03 A | 2014-12-09 A | 100% |  |  |  |  | C3; C1 | 12401.6h | 12401.6h | PCSCF_RES | 33 |  | Huawei | susan.shishufeng@huawei.com | Rel-12 | 64 |  |  |  |
| 5533 | 1949.4.1 | CT3 part of PCRF based solution | 328d? | 2013-05-03 A | 2014-12-09 A | 100% | 2013-05-03 | 2014-12-05 | 326d? | finish no earlier than 2014-12-09 | C3 | 2624h | 2624h | PCSCF_RES | 33 | 29.212; 29.213; 29.214; 29.215 | Huawei | susan.shishufeng@huawei.com | Rel-12 | 64 | Kimmo |  | CP-140687 |
| 5534 | 1949.4.2 | CT1 part of PCRF based solution | 328d? | 2013-04-03 A | 2014-12-09 A | 100% | 2013-04-03 | 2014-12-05 | 326d? | finish no earlier than 2014-12-09 | C1 | 2624h | 2624h | PCSCF_RES | 33 | 24.229 | Huawei | susan.shishufeng@huawei.com | Rel-12 | 64 | Kimmo |  | CP-140605 |

Notes:
- 5509: CP#62 completed. Linked to Rel-9 MBMS support in EPS (MBMS_EPS). Rel-10 CT Features EPC Node Restoration with/out Idle mode Signalling Reduction (ISR) activated (EPC_NR/EPC_NR_ISR)
- 5510: CP#62 completed
- 5511: CP#65 completed
- 5512: CP#62 completed. Stage 2 in Rel-12 TEI12 TS 23.237 CR#0431, CR#0440, CR#0441, CR#0453 (pre-alerting). Stage 3 linked to Rel-8 Feature IMS Service Continuity (IMS-Cont) UID_390056 (Stage 2 in TS 23.237). 2/4/15: acronym changed to eDRVCC
- 5513: Stage 2 in Rel-12 TEI12 TS 23.237 CR#0431, CR#0440, CR#0441, CR#0453 (pre-alerting). 2/4/15: acronym changed to eDRVCC
- 5514: CP#62 completed
- 5515: CP#62 completed. 2/4/15: acronym changed to eDRVCC
- 5516: CP#61 completed. 2/4/15: acronym changed to eDRVCC
- 5517: CP#62 completed. SA4 Rel-8 MTSI Video: Dynamic Rate Adaptation/Signalling of Image Size UID_34041 has included service aspects to support image attribute (a=imageattr) in TS 26.114 as in RFC 6236. But associated CN aspects were not included
- 5518: CP#62 completed
- 5519: CP#62 completed
- 5520: CP#62 completed
- 5521: CP#62 completed. Stage 3 enhancement interworking between IMS and MSC-S for IMS Centralized Services (ICS)
- 5522: CP#65 completed. Updated WID CP-130433=>CP-140488
- 5523: CP#65 updated WID CP-140443=>CP-140490. Based TR 29.806, solutions B and D are selected for standardization. Dec.14: 95->100
- 5524: CP#65 completed. TR 29.806v200 for Approval
- 5525: -
- 5526: CP#65 completion 09/14=>12/14. Exception in CP-140481. Dec.14: 90->100
- 5527: CP#65 completed
- 5528: CP#65 updated WID CP-140443=>CP-140490 (added CT3 part). Exception in CP-140687
- 5529: -
- 5530: CP#65 completion 09/14=>12/14. Exception in CP-140481. Dec.14: 90->100
- 5531: CP#65 completion 09/14=>12/14. Exception in CP-140605. Dec.14: 65->100%
- 5532: -
- 5533: CP#65 updated WID CP-140443=>CP-140490 (added CT3 part). Exception in CP-140687
- 5534: CP#65 completion 09/14=>12/14. Exception in CP-140605. Dec.14: 65->100

| ID | WBS | Task | Duration | Start | Finish | Complete | Baseline start | Baseline finish | Baseline duration | Constraint | Resources | Work | Actual work | Acronym | PCG approved | WI rapporteur name | WI rapporteur e-mail | Release | TSG approved | MCC resp | Acronym_3GU_Export | Status Report |
| --- | --- | --- | --- | --- | --- | --- | --- | --- | --- | --- | --- | --- | --- | --- | --- | --- | --- | --- | --- | --- | --- | --- |
| 5535 | 1950 | **Updating IMS to conform to RFC 6665 (Stage 3)** | 569.88d? | 2013-09-09 A | 2015-03-13 A | 100% | 2013-09-09 | 2014-09-12 | 267d? |  | C1; C3 | 9576h | 9576h | UP6665 | 31 | BlackBerry | Andrew Allen (aallen@blackberry.com) | Rel-12 | 61 | Frederic | UP6665 |  |
| 5536 | 1950.1 | CT1 part of Updating IMS to conform to RFC 6665 | 329d? | 2013-09-09 A | 2014-12-09 A | 100% | 2013-09-09 | 2014-09-12 | 267d? | finish no earlier than 2014-12-09 | C1 | 2624h | 2624h | UP6665 | 31 | BlackBerry | Andrew Allen (aallen@blackberry.com) | Rel-12 | 61 | Frederic |  | CP-140620 |
| 5537 | 1950.2 | CT3 part of Updating IMS to conform to RFC 6665 | 66d? | 2013-09-09 A | 2013-12-06 A | 100% | 2013-09-09 | 2013-12-06 | 66d? | finish no earlier than 2013-12-06 | C3 | 528h | 528h | UP6665 | 31 | BlackBerry | Andrew Allen (aallen@blackberry.com) | Rel-12 | 61 | Maurice |  |  |
| 5538 | 1950.3 | (IETF) CT1 part of Updating IMS to conform to RFC 6665 (draft-ietf-sipcore-refer-clarifications) | 1d? | 2015-03-13 A | 2015-03-13 A | 100% |  |  |  |  | C1-IETF | 8h | 8h | UP6665 | 34 | BlackBerry | Andrew Allen (aallen@blackberry.com) | Rel-12 | 67 |  |  |  |
| 5539 | 1950.4 | (IETF) CT1 part of Updating IMS to conform to RFC 6665 (draft-ietf-sipcore-refer-explicit-subscription) | 1d? | 2015-03-13 A | 2015-03-13 A | 100% |  |  |  |  | C1-IETF | 8h | 8h | UP6665 | 34 | BlackBerry | Andrew Allen (aallen@blackberry.com) | Rel-12 | 67 |  |  |  |
| 5540 | 1950.5 | (IETF) CT1 part of Updating IMS to conform to RFC 6665 (draft-roach-sipcore-6665-clarifications) | 1d? | 2015-03-13 A | 2015-03-13 A | 100% |  |  |  |  | C1-IETF | 8h | 8h | UP6665 | 34 | BlackBerry | Andrew Allen (aallen@blackberry.com) | Rel-12 | 67 |  |  |  |
| 5541 | 1951 | **IMS Operator Determined Call Barring enhancements (Stage 3)** | 289.75d? | 2013-12-06 A | 2014-09-11 A | 100% | 2013-12-06 | 2014-06-13 | 137d? |  | C1; C3 | 5928h | 5928h | eIODB | 32 | Ericsson | Jorgen.Axell@ericsson.com | Rel-12 | 62 | Frederic | eIODB |  |
| 5542 | 1951.1 | CT1 part of IMS Operator Determined Call Barring enhancements | 136d? | 2013-12-06 A | 2014-06-13 A | 100% | 2013-12-06 | 2014-06-13 | 136d? | finish no earlier than 2014-06-13 | C1 | 1088h | 1088h | eIODB | 32 | Ericsson | Jorgen.Axell@ericsson.com | Rel-12 | 62 | Frederic |  |  |
| 5543 | 1951.2 | CT3 part of IMS Operator Determined Call Barring enhancements | 201d? | 2013-12-09 A | 2014-09-11 A | 100% | 2013-12-09 | 2014-06-13 | 136d? | finish no earlier than 2014-09-12 | C3 | 1608h | 1608h | eIODB | 32 | Ericsson | Jorgen.Axell@ericsson.com | Rel-12 | 62 | Adrian |  |  |
| 5544 | 1952 | Signalling Improvements for Network Efficiency (Stage 3) | 264d? | 2013-12-06 A | 2014-12-09 A | 100% | 2013-12-06 | 2014-09-12 | 202d? | finish no earlier than 2014-12-09 | C1 | 2112h | 2112h | SINE | 32 | Huawei | Lin Shu (shulin@huawei.com) | Rel-12 | 62 | Frederic | SINE | CP-140617 |
| 5545 | 1953 | **Interactive Connectivity Establishment (ICE, IETF RFC 5245) impacts on IMS H.248 profiles** | 197.62d? | 2014-03-05 A | 2014-09-11 A | 100% | 2014-03-05 | 2014-09-12 | 138d? |  | C4; C3 | 3896h | 3896h | ICEH248 | 32 | NSN | Jan.Kall@nsn.com | Rel-12 | 63 | Kimmo | ICEH248 |  |
| 5546 | 1953.1 | CT4 part of ICE impacts on IMS H.248 profiles (Stage 2/3) | 138d? | 2014-03-05 A | 2014-09-11 A | 100% | 2014-03-05 | 2014-09-12 | 138d? | finish no earlier than 2014-09-12 | C4 | 1104h | 1104h | ICEH248 | 32 | NSN | Jan.Kall@nsn.com | Rel-12 | 63 | Kimmo |  |  |
| 5547 | 1953.2 | CT3 part of ICE impacts on IMS H.248 profiles (Stage 2) | 73d? | 2014-03-05 A | 2014-06-13 A | 100% | 2014-03-05 | 2014-06-13 | 73d? | finish no earlier than 2014-06-13 | C3 | 584h | 584h | ICEH248 | 32 | NSN | Jan.Kall@nsn.com | Rel-12 | 63 | Adrian |  |  |
| 5548 | 1954 | **Transfer of ETSI business trunking specifications** | 289.62d? | 2014-03-05 A | 2014-12-09 A | 100% | 2014-03-05 | 2014-09-17 | 141d? |  | C1; S1 | 5976h | 5976h | IMS_Corp2 | 32 | Alcatel-Lucent | keith.drage@alcatel-lucent.com, Youssef Chadli | Rel-12 | 63 | Frederic | IMS_Corp2 |  |
| 5549 | 1954.1 | SA1 part of Transfer of ETSI business trunking specifications | 141d? | 2014-03-05 A | 2014-09-17 A | 100% | 2014-03-05 | 2014-09-17 | 141d? | finish no earlier than 2014-09-17 | S1 | 1128h | 1128h | IMS_Corp2 | 32 | Alcatel-Lucent | betsy.covell@alcatel-lucent.com | Rel-12 | 63 | Alain |  | S1-143300 |
| 5550 | 1954.2 | CT1 part of Transfer of ETSI business trunking specifications | 200d? | 2014-03-05 A | 2014-12-09 A | 100% | 2014-03-05 | 2014-09-12 | 138d? | finish no earlier than 2014-12-09 | C1 | 1600h | 1600h | IMS_Corp2 | 32 | Alcatel-Lucent | keith.drage@alcatel-lucent.com, Youssef Chadli | Rel-12 | 63 | Frederic |  | CP-140619 |
| 5551 | 1955 | **Support of ALT-C attribute** | 284.38d? | 2014-03-10 A | 2014-12-09 A | 100% | 2014-03-05 | 2014-09-12 | 138d? |  | C4; C1; C3 | 9600h | 9600h | ALTC | 32 | Orange | lionel.morand@orange.com | Rel-12 | 63 | Kimmo | ALTC |  |
| 5552 | 1955.1 | CT4 part of Support of ALT-C attribute | 200d? | 2014-03-10 A | 2014-12-09 A | 100% | 2014-03-05 | 2014-09-12 | 138d? | finish no earlier than 2014-12-09 | C4 | 1600h | 1600h | ALTC | 32 | Orange | lionel.morand@orange.com | Rel-12 | 63 | Kimmo |  | CP-140485 |
| 5553 | 1955.2 | CT1 part of Support of ALT-C attribute | 200d? | 2014-03-10 A | 2014-12-09 A | 100% | 2014-03-05 | 2014-09-12 | 138d? | finish no earlier than 2014-12-09 | C1 | 1600h | 1600h | ALTC | 32 | Orange | lionel.morand@orange.com | Rel-12 | 63 | Frederic |  | CP-140611 |
| 5554 | 1955.3 | CT3 part of Support of ALT-C attribute | 200d? | 2014-03-10 A | 2014-12-09 A | 100% | 2014-03-05 | 2014-06-13 | 73d? | finish no earlier than 2014-12-09 | C3 | 1600h | 1600h | ALTC | 32 | Orange | lionel.morand@orange.com | Rel-12 | 63 | Adrian |  | CP-140563 |
| 5555 | 1956 | **Diameter Overload Control Mechanisms** | 186.12d? | 2014-06-13 A | 2014-12-09 A | 100% | 2014-06-13 | 2014-12-05 | 126d? |  | C4; IETF | 4144h | 4144h | DOCME | 33 | Orange | lionel.morand@orange.com | Rel-12 | 64 |  | DOCME |  |
| 5556 | 1956.1 | CT4 part of Diameter Overload Control Mechanisms | 128d? | 2014-06-13 A | 2014-12-09 A | 100% | 2014-06-13 | 2014-09-12 | 66d? | finish no earlier than 2014-12-09 | C4 | 1024h | 1024h | DOCME | 33 | Orange | lionel.morand@orange.com | Rel-12 | 64 |  |  | CP-140486 |
| 5557 | 1956.2 | (IETF) Diameter Overload Control Mechanisms (draft-ietf-dime-ovli) | 128d? | 2014-06-13 A | 2014-12-09 A | 100% | 2014-06-13 | 2014-12-05 | 126d? | finish no earlier than 2014-12-09 | C4-IETF | 1024h | 1024h | DOCME | 33 | christer.holmberg@ericsson.com | christer.holmberg@ericsson.com | Rel-12 | 64 |  |  |  |
| 5558 | 1957 | **Impacts of RFC7044 for introduction of the new History-Info header field** | 186.12d? | 2014-06-13 A | 2014-12-09 A | 100% | 2014-06-13 | 2014-09-12 | 66d? |  | C1; C3 | 3648h | 3648h | HISTORY_CT | 33 | Deutsche Telekom | Roland Jesske (r.jesske@telekom.de) | Rel-12 | 64 |  | HISTORY_CT |  |
| 5559 | 1957.1 | CT1 part of Impacts of RFC7044 for introduction of the new History-Info header field | 128d? | 2014-06-13 A | 2014-12-09 A | 100% | 2014-06-13 | 2014-09-12 | 66d? | finish no earlier than 2014-12-09 | C1 | 1024h | 1024h | HISTORY_CT | 33 | Deutsche Telekom | Roland Jesske (r.jesske@telekom.de) | Rel-12 | 64 |  |  | CP-140609 |
| 5560 | 1957.2 | CT3 part of Impacts of RFC7044 for introduction of the new History-Info header field | 66d? | 2014-06-13 A | 2014-09-11 A | 100% | 2014-06-13 | 2014-09-12 | 66d? | finish no earlier than 2014-09-12 | C3 | 528h | 528h | HISTORY_CT | 33 | Deutsche Telekom | Roland Jesske (r.jesske@telekom.de) | Rel-12 | 64 |  |  |  |

Notes:
- 5535: Stage 3. Review the references related to RFC 3265 in the 3GPP IMS specifications and determine the impact of the RFC 6665 changes / Impacted TSs and TRs: Stage 3
- 5536: CP#65 completion 09/14=>12/14. Exception in CP-140620. 3/3/15: 100% cpltd. / Impacted TSs and TRs: 23.218; 24.141; 24.147; 24.229; 24.237; 24.292; 24.337; 24.341; 24.604; 24.606; 24.623; 24.628; 24.629; 24.642
- 5537: CP#62 completed / Impacted TSs and TRs: 29.163; 29.165
- 5538: Added as per CT chair indications on 12th March 2015, no WID, no end date; 9/4/21: RFC 7647 added; / Impacted TSs and TRs: draft-ietf-sipcore-refer-clarification; RFC 7647
- 5539: Added as per CT chair indications on 12th March 2015, no WID, no end date¦14/09/15: 50%->100; 9/4/21: RFC 7614 added; / Impacted TSs and TRs: draft-ietf-sipcore-refer-explicit-subscription; RFC 7614
- 5540: Added as per CT chair indications on 12th March 2015, no WID, no end date¦14/09/15: 50%->100 / Impacted TSs and TRs: draft-roach-sipcore-6665-clarification
- 5541: Handling of premium rate numbers remained OPEN in Rel-11 (shifted to Rel-12). CP-130384 LS_out sent to SA1 / GSMA informing this TSG CP#60 decision / Impacted TSs and TRs: Stage 3
- 5542: CP#64 completed / Impacted TSs and TRs: 24.229; 24.315
- 5543: CP#65 completed / Impacted TSs and TRs: 29.165
- 5544: CP#65 completion 09/14=>12/14. Exception in CP-140617.Dec.14: 80->85%. 3/3/15: 100% cpltd. / Impacted TSs and TRs: 24.008; 24.301
- 5545: Add optional ICE support as defined in Rel-8 TS (23.228, 24.229) to Iq, Ix, Mn, Mp, Mc interfaces. SA2 Rel-12 TS 23.228 requires support for ICE in eP-CSCF, eIMS-AGW for WebRTC / Impacted TSs and TRs: Stage 2/3
- 5546: CP#65 completed / Impacted TSs and TRs: 23.333; 23.334; 29.232; 29.238; 29.332; 29.333; 29.334
- 5547: CP#64 completed / Impacted TSs and TRs: 29.162; 29.163; 29.292
- 5548: Rel-12 enhancements to business trunking (BusTI). ETSI E2NA(14)000019 asked 3GPP to take responsibility of business communications over IMS: TS 181 019, TS 182 023, TS 182 024, TS 182 025, TR 183 060
- 5549: SP#65 completed. TS 22.519v200 for Approval / Impacted TSs and TRs: New 22.519 (ETSI 181 019)
- 5550: CP#65 TS 24.525v200 for Approval. TR 24.969v100 for Information. Completion 09/14=>12/14. Exception in CP-140619. Dec.14: 90->100 / Impacted TSs and TRs: New TSs [24.523 (182 023); 24.524 (182 024); 24.525 (182 025)]; New 24.969 (183 069)
- 5551: SA2 TS 23.228 requires UEs supporting IPv4, IPv6 or both IPv4 and IPv6 IP address formats shall be supported by IMS. Specify procedures to support altc SDP attribute within IMS for terminating communications destined to an enterprise network.
- 5552: CP#65 completion 09/14=>12/14. Exception in CP-140485. Dec.14: 0->100 / Impacted TSs and TRs: 23.334; 29.238; 29.334
- 5553: CP#65 completion 09/14=>12/14. Exception in CP-140611. Dec.14: 0->100 / Impacted TSs and TRs: 24.229
- 5554: CP#65 completion 09/14=>12/14. Exception in CP-140563. Dec.14: 0->100 / Impacted TSs and TRs: 29.162
- 5555: Triggered by TR 29.809 Study on Diameter overload control mechanism (FS_DOCME)
- 5556: CP#65 completion 09/14=>12/14. Exception in CP-140486. Dec.14: 70->100 / Impacted TSs and TRs: 29.228; 29.229; 29.272; 29.273; 29.328; 29.329; 29.336; 29.337; 29.344; 29.345
- 5557: Mar15: In WGLC¦7/3/16: 50%->100; 9/4/21: RFC 7683 added; / Impacted TSs and TRs: draft-ietf-dime-ovli; RFC 7683
- 5558: IETF updated RFC4244 for History-Info header field to RFC7044. IETF introduced new features which could be useful for 3GPP use cases.
- 5559: CP#65 completion 09/14=>12/14. Exception in CP-140609. Dec.14: 85->100 / Impacted TSs and TRs: 24.229; 24.259; 24.604
- 5560: CP#65 completed / Impacted TSs and TRs: 29.163; 29.165; 29.292

| ID | WBS | Task | Duration | Start | Finish | Complete | Remaining | Baseline start | Baseline finish | Baseline duration | Total slack | Constraint | Resources | Work | Actual work | Acronym | PCG approved | WI rapporteur name | Release | TSG approved | Acronym_3GU_Export | Status Report | MCC resp |
| --- | --- | --- | --- | --- | --- | --- | --- | --- | --- | --- | --- | --- | --- | --- | --- | --- | --- | --- | --- | --- | --- | --- | --- |
| 5561 | 1958 | **Indication of NNI Routeing scenarios in SIP requests** | 186.12d? | 2014-06-13 A | 2014-12-09 A | 100% |  | 2014-06-13 | 2014-12-05 | 126d? |  |  | C1; C3; IETF | 4408h | 4408h | NNI_RS | 33 | Ericsson | Rel-12 | 64 | NNI_RS |  |  |
| 5562 | 1958.1 | CT1 part of Indication of NNI Routeing scenarios in SIP requests | 128d? | 2014-06-13 A | 2014-12-09 A | 100% |  | 2014-06-13 | 2014-09-12 | 66d? |  | finish no earlier than 2014-12-09 | C1 | 1024h | 1024h | NNI_RS | 33 | Ericsson | Rel-12 | 64 |  | CP-140613 |  |
| 5563 | 1958.2 | (IETF) CT1 part of Indication of NNI Routeing scenarios in SIP requests (draft-holmberg-dispatch-iotl) | 95d? | 2014-06-13 A | 2014-12-09 A | 100% |  | 2014-06-13 | 2014-12-05 | 93d? |  | finish no earlier than 2014-12-09 | C1-IETF | 760h | 760h | NNI_RS | 33 | christer.holmberg@ericsson.com | Rel-12 | 64 |  |  |  |
| 5564 | 1958.3 | CT3 part of Indication of NNI Routeing scenarios in SIP requests | 66d? | 2014-06-13 A | 2014-09-11 A | 100% |  | 2014-06-13 | 2014-09-12 | 66d? |  | finish no earlier than 2014-09-12 | C3 | 528h | 528h | NNI_RS | 33 | Ericsson | Rel-12 | 64 |  |  |  |
| 5565 | 1959 | Unstructured Supplementary Service Data (USSD) method selection (Stage 3) | 3d? | 2014-06-11 A | 2014-06-13 A | 100% |  | 2014-06-11 | 2014-06-13 | 3d? |  | finish no earlier than 2014-06-13 | C1 | 24h | 24h | USSD_MS | 33 | Ericsson | Rel-12 | 64 | USSD_MS |  |  |
| 5566 | 1960 | Representational State Transfer (REST) reference point between Application Function (AF) and Protocol Converter (PC) | 128d? | 2014-06-13 A | 2014-12-09 A | 100% |  | 2014-06-13 | 2014-09-12 | 66d? |  | finish no earlier than 2014-12-09 | C3 | 1024h | 1024h | REST_AF_PC | 33 | Alcatel-Lucent | Rel-12 | 64 | REST_AF_PC | CP-140561 |  |
| 5567 | 1961 | **Overload Control for PCC based Diameter applications** | 186.12d? | 2014-06-13 A | 2014-12-09 A | 100% |  | 2014-06-13 | 2014-12-05 | 126d? |  |  | C3; IETF | 3648h | 3648h | DOCME-PCC | 33 | Huawei | Rel-12 | 64 | DOCME-PCC |  |  |
| 5568 | 1961.1 | CT3 part of Overload Control for PCC based Diameter applications | 66d? | 2014-06-13 A | 2014-09-11 A | 100% |  | 2014-06-13 | 2014-09-12 | 66d? |  | finish no earlier than 2014-09-12 | C3 | 528h | 528h | DOCME-PCC | 33 | Huawei | Rel-12 | 64 |  |  |  |
| 5569 | 1961.2 | (IETF) Overload Control for PCC based Diameter applications | 128d? | 2014-06-13 A | 2014-12-09 A | 100% |  | 2014-06-13 | 2014-12-05 | 126d? |  | finish no earlier than 2014-12-09 | C3-IETF | 1024h | 1024h | DOCME-PCC | 33 | christer.holmberg@ericsson.com | Rel-12 | 64 |  |  |  |
| 5570 | 1962 | Network Initiated USSD Simulation Services in IMS | 63d? | 2014-09-12 A | 2014-12-09 A | 100% |  |  |  |  |  | finish no earlier than 2014-12-09 | C1 | 504h | 504h | USSI-NET | 33 | AT&T | Rel-12 | 65 | USSI-NET | CP-140610 |  |
| 5571 | 1963 | **Introduction of ER-GSM band for GSM-R** | 927.75d? | 2011-09-16 A | 2014-02-28 A | 100% |  | 2011-09-16 | 2014-02-28 | 651d? |  |  | G1; C1; G3new | 26496h | 26496h | RT_ERGSM | 27 | Kapsch Carriercom, Sierra Wireless | Rel-12 | 51 | RT_ERGSM |  | Paolo |
| 5572 | 1963.1 | GERAN1 part of Introduction of ER-GSM band for GSM-R | 647d? | 2011-09-16 A | 2014-02-28 A | 100% |  | 2011-09-16 | 2014-02-28 | 647d? |  | finish no earlier than 2014-02-28 | G1 | 5168h | 5168h | RT_ERGSM | 27 | Kapsch Carriercom, Sierra Wireless | Rel-12 | 51 |  |  | Paolo |
| 5573 | 1963.2 | Test part: Introduction of ER-GSM band for GSM-R | 131d? | 2013-09-02 A | 2014-02-28 A | 100% |  | 2013-09-02 | 2014-02-28 | 131d? |  | finish no earlier than 2014-02-28 | G3new | 1048h | 1048h | RT_ERGSM | 31 | Kapsch Carriercom, Sierra Wireless | Rel-12 | 59 |  |  | Ingbert |
| 5574 | 1963.3 | CT1 part of Introduction of ER-GSM band for GSM-R | 582d? | 2011-09-28 A | 2013-12-06 A | 100% |  | 2011-09-28 | 2013-12-06 | 582d? |  | finish no earlier than 2013-12-06 | C1 | 4656h | 4656h | RT_ERGSM | 27 | Kapsch Carriercom, Sierra Wireless | Rel-12 | 53 |  |  | Frederic |
| 5575 | 1964 | **Downlink Multi Carrier GERAN** | 889.88d? | 2012-09-10 A | 2015-01-18 | 91% | 82.74d? | 2012-09-10 | 2014-09-12 | 533d? | 41951d |  | G2; G1; C1; G3new | 33600h | 31495.3h | DMCG | 29 | Ericsson | Rel-12 | 55 | DMCG |  | Gert |
| 5576 | 1964.1 | Core part: Downlink Multi Carrier GERAN | 229d? | 2013-07-22 A | 2014-05-30 A | 100% |  | 2013-07-22 | 2014-05-30 | 229d? |  | finish no earlier than 2014-05-30 | G2; G1 | 3664h | 3664h | DMCG | 29 | Ericsson | Rel-12 | 55 |  |  | Gert |
| 5577 | 1964.2 | CT part: Downlink Multi Carrier GERAN | 533d? | 2012-09-10 A | 2014-09-11 A | 100% |  | 2012-09-10 | 2014-09-12 | 533d? |  | finish no earlier than 2014-09-12 | C1 | 4264h | 4264h | DMCG | 29 | Ericsson | Rel-12 | 55 |  |  | Frederic |
| 5578 | 1964.3 | Test part: Downlink Multi Carrier GERAN | 662d? | 2012-09-10 A | 2015-01-18 | 80% | 132.4d? | 2012-09-10 | 2014-08-29 | 522d? | 41951d | finish no earlier than 2015-03-13 | G3new | 5296h | 4236.8h | DMCG-MStest | 29 | ST-Ericsson | Rel-12 | 55 | DMCG-MStest |  | Ingbert |
| 5579 | 1965 | **Mobile Station Receive Diversity (MSRD) for Voice Services over Adaptive Multi-user channels on One Slot (VAMOS)** | 652.5d? | 2013-03-01 A | 2014-11-21 A | 100% |  | 2013-03-01 | 2014-08-29 | 396d? |  |  | G1; G2; C1; G3new | 24064h | 24064h | MSRD_VAMOS | 30 | Nokia Networks, Microsoft | Rel-12 | 57 | MSRD_VAMOS | GP-140579 | Paolo |
| 5580 | 1965.1 | CT1 introduction of MS capability support for MS supporting MSRD for VAMOS | 205d? | 2013-03-01 A | 2013-12-06 A | 100% |  | 2013-03-01 | 2013-12-06 | 205d? |  | finish no earlier than 2013-12-06 | C1 | 1640h | 1640h | MSRD_VAMOS | 30 | Nokia Networks, Microsoft | Rel-12 | 57 |  |  | Frederic |
| 5581 | 1965.2 | MSRD for VAMOS - Performance Requirements | 257.5d? | 2013-11-28 A | 2014-11-21 A | 100% |  | 2013-11-28 | 2014-08-29 | 197.5d? |  | finish no earlier than 2014-11-21 | G1; G2 | 4120h | 4120h | MSRD_VAMOS-PerfReq | 30 | Nokia Networks, Microsoft | Rel-12 | 57 | MSRD_VAMOS-PerfReq | GP-140579 | Paolo |
| 5582 | 1965.3 | MSRD for VAMOS - MS Conformance Test | 453d? | 2013-03-06 A | 2014-11-21 A | 100% |  | 2013-03-06 | 2014-08-29 | 393d? |  | finish no earlier than 2014-11-21 | G3new | 3616h | 3616h | MSRD_VAMOS-Test | 30 | Nokia Networks, Microsoft | Rel-12 | 57 | MSRD_VAMOS-Test | GP-140579 | Ingbert |
| 5583 | 1966 | **New Training Sequence Codes (TSC) for GERAN** | 396.25d? | 2013-11-22 A | 2014-12-09 | 93% | 26.01d? | 2013-11-22 | 2014-08-29 | 202d? | 41992d |  | G1; G2; C1 | 11184h | 10449.7h | NewToN | 32 | Ericsson | Rel-12 | 60 | NewToN | GP-140542 | Paolo |
| 5584 | 1966.1 | GERAN1 part of New Training Sequence Codes (TSC) for GERAN | 261d? | 2013-11-22 A | 2014-11-21 A | 100% |  | 2013-11-22 | 2014-08-29 | 201d? |  | finish no earlier than 2014-11-21 | G1 | 2088h | 2088h | NewToN | 32 | Ericsson | Rel-12 | 60 |  | GP-140542 | Paolo |
| 5585 | 1966.2 | GERAN2 part of New Training Sequence Codes (TSC) for GERAN | 261d? | 2013-11-22 A | 2014-10-31 | 80% | 52.2d? | 2013-11-22 | 2014-08-29 | 201d? | 42033d | finish no earlier than 2014-11-21 | G2 | 2088h | 1670.4h | NewToN | 32 | Ericsson | Rel-12 | 60 |  | GP-140542 | Gert |
| 5586 | 1966.3 | CT1 part of New Training Sequence Codes (TSC) for GERAN (Stage 3) | 273d? | 2013-11-22 A | 2014-12-09 A | 100% |  | 2013-11-22 | 2014-08-29 | 201d? |  | finish no earlier than 2014-12-09 | C1 | 2184h | 2184h | NewToN | 32 | Ericsson | Rel-12 | 60 |  | CP-140604 | Frederic |

Notes:
- 5561: Triggered by TR 24.802 Study on Indication of Network to Network Interface (NNI) Routeing scenarios in SIP requests UID_580025 / WI rapporteur e-mail: Jan.Holm@ericsson.com
- 5562: CP#65 completion 09/14=>12/14. Exception in CP-140613. Dec.14: 95->100 / Impacted TSs and TRs: 24.229 / WI rapporteur e-mail: Jan.Holm@ericsson.com
- 5563: Publication requested¦7/3/16: 50%->100 / Impacted TSs and TRs: draft-holmberg-dispatch-iotl / WI rapporteur e-mail: christer.holmberg@ericsson.com
- 5564: CP#65 completed / Impacted TSs and TRs: 29.079; 29.165 / WI rapporteur e-mail: Jan.Holm@ericsson.com
- 5565: CP#64 approved WID & completed. Related to R11 USSD simulation service in IMS (delivery of UE originating USSD request using IMS, I.e. introduce 2nd method for delivery of UE originating USSD request to network (additional to USSD using CS domain) / Impacted TSs and TRs: 24.173; 24.390; New 24.391 / WI rapporteur e-mail: ivo.sedlacek@ericsson.com
- 5566: CP#65 completion 09/14=>12/14. TS 29.201v200 for Approval. Exception in CP-140561. Dec.14: 80->100 / Impacted TSs and TRs: 29.213; 29.214; new 29.201 / WI rapporteur e-mail: horst.brinkmann@alcatel-lucent.com
- 5567: Triggered by TR 29.809 Study on Diameter overload control mechanism (FS_DOCME) / WI rapporteur e-mail: Xia Haitao (xiahaitao@huawei.com)
- 5568: CP#65 completed / Impacted TSs and TRs: 29.212; 29.213; 29.214 / WI rapporteur e-mail: Xia Haitao (xiahaitao@huawei.com)
- 5569: work in progress¦7/3/16: 50%->100 / Impacted TSs and TRs: draft-ietf-dime-ovli / WI rapporteur e-mail: christer.holmberg@ericsson.com
- 5570: CP#65 exception in CP-140610. Dec.14: 75->100 / Impacted TSs and TRs: 24.390 / WI rapporteur e-mail: Martin Dolly (md3135@att.com)
- 5571: Use of band 870-876/915-921 MHz for land mobile service on national possibilities/market demand - as per ECC/DEC/(04)06. Introduction of ERGSM band, Performance requirements and Deployment scenarios. / Impacted TSs and TRs: GERAN / WI rapporteur e-mail: thomas.chatelet@kapsch.net, Rémi Lascoux (rlascoux@sierrawireless.com)
- 5572: GP#61 completed. GP#51 approved WID / Impacted TSs and TRs: 45.001; 45.005; 45.008; 45.050 / WI rapporteur e-mail: thomas.chatelet@kapsch.net, Rémi Lascoux (rlascoux@sierrawireless.com)
- 5573: GP#61 completed / Impacted TSs and TRs: 51.010; 51.021 / WI rapporteur e-mail: thomas.chatelet@kapsch.net, Rémi Lascoux (rlascoux@sierrawireless.com)
- 5574: CP#62 completed. Added ERGSM capability indication (24.008 CR#2469R1) / Impacted TSs and TRs: 24.008 / WI rapporteur e-mail: thomas.chatelet@kapsch.net, Rémi Lascoux (rlascoux@sierrawireless.com)
- 5575: Linked to Rel-7 Downlink Dual Carrier UID_50579 (Previous work on multiple carriers on the downlink was limited to two). Ref: TR 45.912 Feasibility study for evolved GERAN, TS 43.064 GPRS Stage 2 / Impacted TSs and TRs: GERAN / WI rapporteur e-mail: paul.schliwa-bertling@ericsson.com
- 5576: GP#62 completed. GP#55 approved WID / Impacted TSs and TRs: 43.064; 44.004; 44.018; 44.060; 45.002; 45.003; 45.005; 45.008; 48.018 / WI rapporteur e-mail: paul.schliwa-bertling@ericsson.com
- 5577: CP#65 completed / Impacted TSs and TRs: 24.008 / WI rapporteur e-mail: paul.schliwa-bertling@ericsson.com
- 5578: GP#63 completion 08/14=>11/14. Dec.14: 35->80%, CD:11/14->03/15 / Impacted TSs and TRs: 51.010-1; 51.010-2 / WI rapporteur e-mail: hakan.e.grunditz@stericsson.com
- 5579: GP#63 completion 08/14=>11/14. Exception in GP-140579. Linked to Rel-7 Mobile Station Receive Diversity (DARP Phase II) UID_50569, Rel-9 Voice Services over Adaptive Multiuser channels on One Slot (VAMOS) UID_420002 / Impacted TSs and TRs: GERAN / WI rapporteur e-mail: Khairul Hasan (Nokia Networks), Markku Tarkiainen (Nokia=>Microsoft)
- 5580: CP#62 completed / Impacted TSs and TRs: 24.008 / WI rapporteur e-mail: Khairul Hasan (Nokia Networks), Markku Tarkiainen (Nokia=>Microsoft)
- 5581: GP#63 completion 08/14=>11/14. Exception in GP-140579. Dec.14: 95->100 / Impacted TSs and TRs: 44.018; 45.001; 45.002; 45.005; 45.008; 45.009 / WI rapporteur e-mail: Khairul Hasan (Nokia Networks), Markku Tarkiainen (Nokia=>Microsoft)
- 5582: GP#63 completion 08/14=>11/14. Exception in GP-140579. Dec.14: 85->100 / Impacted TSs and TRs: 51.010-1; 51.010-2 / WI rapporteur e-mail: Khairul Hasan (Nokia Networks), Markku Tarkiainen (Nokia=>Microsoft)
- 5583: GP#63 completion 08/14=>11/14. Exception in GP-140542. GP#60 approved WID. Triggered by GP-131041, GP#40 GP-081949 (WID VAMOS). Linked to Rel-9 VAMOS (Previous work where new TSCs were defined for GMSK modulation) UID_420002 / Impacted TSs and TRs: GERAN / WI rapporteur e-mail: Mårten Sundberg
- 5584: GP#63 completion 08/14=>11/14. Exception in GP-140542. Dec.14: 80->100% / Impacted TSs and TRs: 45.001; 45.002; 45.008; 45.009; 45.050 / WI rapporteur e-mail: Mårten Sundberg
- 5585: GP#63 completion 08/14=>11/14. Exception in GP-140542. / Impacted TSs and TRs: 44.018; 44.060 / WI rapporteur e-mail: Mårten Sundberg
- 5586: CP#65 completion 09/14=>12/14. CP#65 exception in CP-140604. 3/3/15: 100% cpltd. / Impacted TSs and TRs: 24.008 / WI rapporteur e-mail: Mårten Sundberg

| ID | WBS | Task | Duration | Start | Finish | Complete | Remaining | Baseline start | Baseline finish | Baseline duration | Total slack | Constraint | Resources | Work | Actual work | Acronym | PCG approved | WI rapporteur name | Release | TSG approved | MCC resp | Acronym_3GU_Export | Status Report | Special Focus Doc | PCG stopped | TSG stopped |
| --- | --- | --- | --- | --- | --- | --- | --- | --- | --- | --- | --- | --- | --- | --- | --- | --- | --- | --- | --- | --- | --- | --- | --- | --- | --- | --- |
| 5587 | 1967 | **Verification of radiated multi-antenna reception performance of UEs in LTE/UMTS** | 663.62d? | 2012-03-05 A | 2013-12-06 A | 100% |  | 2012-03-05 | 2013-12-06 | 469d? |  |  | R4 | 7464h | 7464h | HSPA_LTE_measRP_MIMO | 28 | Vodafone | Rel-12 | 55 | Issam | HSPA_LTE_measRP_MIMO |  |  |  |  |
| 5588 | 1967.1 | Perf. Part: Verification of radiated multi-antenna reception performance of UEs in LTE/UMTS | 464d? | 2012-03-05 A | 2013-12-06 A | 100% |  | 2012-03-05 | 2013-12-06 | 464d? |  | finish no earlier than 2013-12-06 | R4 | 3712h | 3712h | HSPA_LTE_measRP_MIMO-Perf | 28 | Vodafone | Rel-12 | 55 | Issam | HSPA_LTE_measRP_MIMO-Perf | RP-131507 |  |  |  |
| 5589 | 1968 | **Further enhancements to H(e)NB mobility - Part 3 (Stage 2/3)** | 466.12d? | 2012-09-12 A | 2013-12-06 A | 100% |  | 2012-09-12 | 2013-12-06 | 330d? |  |  | R3; R2 | 10560h | 10560h | EHNB_enh3 | 29 | Alcatel-Lucent | Rel-12 | 57 | Juha | EHNB_enh3 |  | HNB |  |  |
| 5590 | 1968.1 | Core part: Further enhancements to H(e)NB mobility - Part 3 | 330d? | 2012-09-12 A | 2013-12-06 A | 100% |  | 2012-09-12 | 2013-12-06 | 330d? |  | finish no earlier than 2013-12-06 | R3; R2 | 5280h | 5280h | EHNB_enh3-Core | 29 | Alcatel-Lucent | Rel-12 | 57 | Juha | EHNB_enh3-Core | RP-131508 | HNB |  |  |
| 5591 | 1969 | **Support for BeiDou Navigation Satellite System (BDS) for UTRA and LTE** | 862.75d? | 2013-03-04 A | 2015-06-15 A | 100% |  | 2013-03-04 | 2015-06-12 | 600d? |  |  | R2; R3; R4; R5 | 31680h | 31680h | LCS_BDS | 30 | CATR | Rel-12 | 59 | Yong-Jun | LCS_BDS |  |  |  |  |
| 5592 | 1969.1 | Core part: Support for BeiDou Navigation Satellite System (BDS) for UTRA | 204d? | 2013-06-02 A | 2014-03-06 A | 100% |  | 2013-06-02 | 2014-03-06 | 204d? |  | finish no earlier than 2014-03-06 | R2; R3 | 3264h | 3264h | LCS_BDS-UTRA-Core | 30 | ZTE | Rel-12 | 59 | Yong-Jun | LCS_BDS-UTRA-Core | RP-131500 |  |  |  |
| 5593 | 1969.2 | Perf. part: Support for BeiDou Navigation Satellite System (BDS) for UTRA | 336d? | 2013-03-07 A | 2014-06-13 A | 100% |  | 2013-03-07 | 2014-06-13 | 336d? |  | finish no earlier than 2014-06-13 | R4 | 2688h | 2688h | LCS_BDS-UTRA-Perf | 30 | ZTE | Rel-12 | 59 | Issam | LCS_BDS-UTRA-Perf | RP-140714 |  |  |  |
| 5594 | 1969.3 | Core part: Support for BeiDou Navigation Satellite System (BDS) for LTE | 202d? | 2013-03-04 A | 2013-12-06 A | 100% |  | 2013-03-04 | 2013-12-06 | 202d? |  | finish no earlier than 2013-12-06 | R2 | 1616h | 1616h | LCS_BDS-LTE-Core | 30 | CATR | Rel-12 | 59 | Yong-Jun | LCS_BDS-LTE-Core | RP-131525 |  |  |  |
| 5595 | 1969.4 | Perf. part: Support for BeiDou Navigation Satellite System (BDS) for LTE | 336d? | 2013-03-07 A | 2014-06-13 A | 100% |  | 2013-03-07 | 2014-06-13 | 336d? |  | finish no earlier than 2014-06-13 | R4 | 2688h | 2688h | LCS_BDS-LTE-Perf | 30 | ZTE | Rel-12 | 59 | Issam | LCS_BDS-LTE-Perf | RP-140713 |  |  |  |
| 5596 | 1969.5 | Test part: BeiDou Navigation Satellite System (BDS) Positioning Support for LTE and UMTS | 262d? | 2014-06-15 A | 2015-06-15 A | 100% |  | 2014-06-13 | 2015-06-12 | 261d? |  | finish no earlier than 2015-06-15 | R5 | 2096h | 2096h | LCS_BDS-UEConTest | 33 | CATT | Rel-12 | 64 |  | LCS_BDS-UEConTest | RP-150656 |  |  |  |
| 5597 | 1970 | **Support for BeiDou Navigation Satellite System (BDS) for LCS in GERAN** | 471d? | 2013-11-22 A | 2015-02-20 | 93% | 34.39d? | 2013-11-22 | 2014-11-21 | 262d? | 41917.2d |  | G2; G1; G3new | 14213.2h | 5848.39h | LCS_BDS_GERAN | 32 | ZTE | Rel-12 | 60 | Gert | LCS_BDS_GERAN |  |  |  |  |
| 5598 | 1970.1 | GERAN2 part of Support for BeiDou Navigation Satellite System (BDS) for LCS in GERAN | 201d? | 2013-11-22 A | 2014-08-29 A | 100% |  | 2013-11-22 | 2014-08-29 | 201d? |  | finish no earlier than 2014-08-29 | G2 | 1608h | 1608h | LCS_BDS_GERAN | 32 | ZTE | Rel-12 | 60 | Gert |  |  |  |  |  |
| 5599 | 1970.2 | GERAN1 part of Support for BeiDou Navigation Satellite System (BDS) for LCS in GERAN | 201d? | 2013-11-22 A | 2014-08-29 A | 100% |  | 2013-11-22 | 2014-08-29 | 201d? |  | finish no earlier than 2014-08-29 | G1 | 1608h | 1608h | LCS_BDS_GERAN | 32 | ZTE | Rel-12 | 60 | Paolo |  |  |  |  |  |
| 5600 | 1970.3 | Support for BeiDou Navigation Satellite System (BDS) for LCS in GERAN3new | 272d? | 2014-03-01 A | 2015-02-20 | 80% | 54.4d? | 2014-02-28 | 2014-11-21 | 192d? | 41917.2d | finish no earlier than 2015-03-13 | G3new | 2176h | 1740.8h | LCS_BDS_GERAN-GERAN3new | 32 | CATR | Rel-12 | 61 | Ingbert | LCS_BDS_GERAN-GERAN3new |  |  |  |  |
| 5601 | 1970.4 | Deleted - Test part: Support for BeiDou Navigation Satellite System (BDS) for LCS in GERAN | 71d? | 2013-11-22 A | 2014-02-28 A | 100% |  | 2013-11-22 | 2014-02-28 | 71d? |  | finish no earlier than 2014-08-29 | G3new | 565.19h | 565.19h | LCS_BDS_GERAN-MStest | 32 | ZTE | Rel-12 | 60 | Ingbert | LCS_BDS_GERAN-MStest |  |  | PCG-32 | GP-61 |
| 5602 | 1971 | **Deleted - New Base Station specification structure** | 177.62d? | 2013-06-18 A | 2013-12-06 A | 100% |  | 2013-06-18 | 2013-12-06 | 127d? |  |  | R4 | 3024h | 3024h | BSspec_struc | 31 | Ericsson | Rel-12 | 60 | Issam | BSspec_struc |  |  | PCG-32 | RP-62 |
| 5603 | 1971.1 | Deleted - Core part: New Base Station specification structure | 126d? | 2013-06-18 A | 2013-12-06 A | 100% |  | 2013-06-18 | 2013-12-06 | 126d? |  | finish no earlier than 2013-12-06 | R4 | 1008h | 1008h | BSspec_struc-Core | 31 | Ericsson | Rel-12 | 60 | Issam | BSspec_struc-Core | RP-131513 |  | PCG-32 | RP-62 |
| 5604 | 1971.2 | Deleted - Perf. part: New Base Station specification structure | 125d? | 2013-06-20 A | 2013-12-06 A | 100% |  | 2013-06-20 | 2013-12-06 | 125d? |  | finish no earlier than 2013-12-06 | R4 | 1000h | 1000h | BSspec_struc-Perf | 31 | Ericsson | Rel-12 | 60 | Issam | BSspec_struc-Perf | RP-131514 |  | PCG-32 | RP-62 |
| 5605 | 1972 | **L-band for Supplemental Downlink in E-UTRA and UTRA** | 943.62d? | 2013-06-17 A | 2015-12-15 A | 100% |  | 2013-06-17 | 2014-06-13 | 264d? |  |  | R4; R2; R3 | 21600h | 21600h | LTE_UTRA_SDL_BandL | 31 | Orange | Rel-12 | 60 | Issam | LTE_UTRA_SDL_BandL |  |  |  |  |
| 5606 | 1972.1 | Core part: L-band for Supplemental Downlink in E-UTRA and UTRA | 87.33d? | 2014-02-13 A | 2014-06-13 A | 100% |  | 2014-02-13 | 2014-06-13 | 87.33d? |  | finish no earlier than 2014-06-13 | R4; R2; R3 | 2096h | 2096h | LTE_UTRA_SDL_BandL-Core | 31 | Orange | Rel-12 | 60 | Issam | LTE_UTRA_SDL_BandL-Core | RP-140633 |  |  |  |
| 5607 | 1972.2 | Perf. part: L-band for Supplemental Downlink in E-UTRA and UTRA | 264d? | 2013-06-17 A | 2014-06-13 A | 100% |  | 2013-06-17 | 2014-06-13 | 264d? |  | finish no earlier than 2014-06-13 | R4 | 2112h | 2112h | LTE_UTRA_SDL_BandL-Perf | 31 | Orange | Rel-12 | 60 | Issam | LTE_UTRA_SDL_BandL-Perf | RP-140633 |  |  |  |
| 5608 | 1972.3 | UE Conformance Test Aspects - L-band for Supplemental Downlink in E-UTRA and UTRA | 197d? | 2015-03-16 A | 2015-12-15 A | 100% |  |  |  |  |  | finish no earlier than 2015-12-15 | R5 | 1576h | 1576h | LTE_UTRA_SDL_BandL-UEConTest | 34 | Ericsson | Rel-12 | 67 |  |  | RP-151163 |  |  |  |
| 5609 | 1973 | **LTE-HRPD (High Rate Packet Data in 3GPP2) inter-RAT SON** | 373.25d? | 2013-06-18 A | 2014-06-13 A | 100% |  | 2013-06-18 | 2014-06-13 | 263d? |  |  | R3; S2; C4; G2 | 11096h | 11096h | LTE_HRPD_SON | 31 | China Telecom | Rel-12 | 60 | Juha | LTE_HRPD_SON |  | SON |  |  |
| 5610 | 1973.1 | Stage 2 for LTE-HRPD (High Rate Packet Data in 3GPP2) inter-RAT SON | 67d? | 2013-09-11 A | 2013-12-11 A | 100% |  | 2013-09-11 | 2013-12-11 | 67d? |  | finish no earlier than 2013-09-11 | S2 | 528h | 528h | LTE_HRPD_SON | 31 | Huawei | Rel-12 | 61 | Maurice |  |  |  |  |  |
| 5611 | 1973.2 | Core part: LTE-HRPD (High Rate Packet Data in 3GPP2) inter-RAT SON | 263d? | 2013-06-18 A | 2014-06-13 A | 100% |  | 2013-06-18 | 2014-06-13 | 263d? |  | finish no earlier than 2014-06-13 | R3 | 2088h | 2088h | LTE_HRPD_SON-Core | 31 | China Telecom | Rel-12 | 60 | Juha | LTE_HRPD_SON-Core | RP-140745 |  |  |  |
| 5612 | 1973.3 | CT aspects for LTE-HRPD (High Rate Packet Data in 3GPP2) inter-RAT SON (Stage 3) | 3d? | 2013-09-04 A | 2013-09-06 A | 100% |  | 2013-09-04 | 2013-09-06 | 3d? |  | finish no earlier than 2013-09-06 | C4 | 24h | 24h | LTE_HRPD_SON-CT | 31 | Huawei | Rel-12 | 61 | Kimmo | LTE_HRPD_SON-CT |  |  |  |  |
| 5613 | 1973.4 | GERAN aspects for LTE-HRPD inter-RAT SON, RAN Information Management (RIM) - Stage 3 | 5d? | 2013-08-26 A | 2013-08-30 A | 100% |  | 2013-08-26 | 2013-08-30 | 5d? |  | finish no earlier than 2013-09-06 | G2 | 40h | 40h | LTE_HRPD_SON-RIM | 31 | Alcatel-Lucent | Rel-12 | 59 | Gert | LTE_HRPD_SON-RIM |  |  |  |  |

Notes:
- 5587: RP#59 moved to Rel-12. Triggered by FS_HSPA_LTE_measRP_MIMO_multi-antenna. Core functionality exists since Rel-6 & Rel-7 (MIMO). Adds a very generic test method to test UEs with 2 or more Rx antennas / Impacted TSs and TRs: UTRA; LTE / WI rapporteur e-mail: Luis Anaya
- 5588: RP#62 completed. Rx diversity (defined as Rel-6 HSDPA RAN4 enhanced type 1 req.) & MIMO (defined as Rel-7 HSDPA MIMO for HSPA). Rx diversity & MIMO (defined as part of Rel-8 basic LTE WI) / Impacted TSs and TRs: new 37.977 / WI rapporteur e-mail: luis.anaya@vodafone.com
- 5589: Triggered by FS_EHNB_enh (TR 37.803) / Impacted TSs and TRs: UTRA; LTE / WI rapporteur e-mail: Martin.Warner@alcatel-lucent.com
- 5590: RP#62 completed / Impacted TSs and TRs: 25.304; 25.331; 25.367; 25.467; 25.469; 36.300; 36.331 / WI rapporteur e-mail: Martin.Warner@alcatel-lucent.com
- 5591: BeiDou = Chinese Navigation Satellite System. Location Services (LCS) TS 22.071 Stage 1, TS 23.271 Stage 2 / Impacted TSs and TRs: UTRA; LTE / WI rapporteur e-mail: Ying Du (duying1@catr.cn)
- 5592: RP#62 completed / Impacted TSs and TRs: 25.305; 25.306; 25.331; 25.453; 25.413; 25.423; 25.433 / WI rapporteur e-mail: Huang He (huang.he4@zte.com.cn)
- 5593: RP#64 completed. TS 25.173v100 for 1-step Approval / Impacted TSs and TRs: 25.172 (FDD); new 25.173 (TDD) / WI rapporteur e-mail: Ling Soonleh (soonleh.ling@zte.com.cn)
- 5594: RP#62 completed / Impacted TSs and TRs: 36.305; 36.355 / WI rapporteur e-mail: Ying Du (duying1@catr.cn)
- 5595: RP#64 completed / Impacted TSs and TRs: 36.171 / WI rapporteur e-mail: Ling Soonleh (soonleh.ling@zte.com.cn)
- 5596: ¦Stat Rep: RP-141350->RP-141950 1st Apr 15: Compl:80%->90% 1st Apr 15: Stat Rep: RP-141950->RP-150357 03/07/15: Compl:90%->100% 03/07/15: Stat Rep: RP-150357->RP-150656 / Impacted TSs and TRs: 34.108; 36.508; 37.571-1; 37.571-2; 37.571-3; 37.571-4; 37.571-5 / WI rapporteur e-mail: Chen Xiaiozhong (chenxiaozhong@catt.cn)
- 5597: GP#60 approved WID. Based on the same framework used in Rel-8 Support for Additional Navigation Satellite Systems (ANSS) for LCS UID_38001 / Impacted TSs and TRs: GERAN / WI rapporteur e-mail: Wang Xinhui (wangxinhui@zte.com.cn)
- 5598: GP#63 completed / Impacted TSs and TRs: 44.031; 49.031; 44.071; 48.031 / WI rapporteur e-mail: Wang Xinhui (wangxinhui@zte.com.cn)
- 5599: GP#63 completed / Impacted TSs and TRs: 43.059; 45.005 / WI rapporteur e-mail: Wang Xinhui (wangxinhui@zte.com.cn)
- 5600: Dec.14: 25->80%, CD: 11/14->03/15 / Impacted TSs and TRs: 51010-1; 51.010-2; 51.010-7 / WI rapporteur e-mail: Zhou DaiWei, China Academy of Telecommunication Research, zhoudaiwei@catr.cn
- 5601: GP#61 stopped / Impacted TSs and TRs: 51.010-1 / WI rapporteur e-mail: Wang Xinhui (wangxinhui@zte.com.cn)
- 5602: Triggered by Rel-12 TR 37.810 Study on Base Station specification structure (FS_BSspec_struc) / Impacted TSs and TRs: UTRA; LTE; MSR / WI rapporteur e-mail: johan.skold@ericsson.com
- 5603: RP#62 stopped (at 20% completion) / Impacted TSs and TRs: 25.104; 25.105; 36.104; 37.104; 37.810; New 37.811 (New BS specification structure); New 37.xya (New RF core specification) / WI rapporteur e-mail: johan.skold@ericsson.com
- 5604: RP#62 stopped (at 0% completion) / Impacted TSs and TRs: 25.113; 25.141; 25.142; 36.113; 36.141; 37.113; 37.141; 37.810; New 37.xyz (New RF test specification; New 37.xyw (ew EMC specification) / WI rapporteur e-mail: johan.skold@ericsson.com
- 5605: ECC(12)052 CEPT decision to harmonize 1452-1492 MHz (L-band) for mobile communications Supplemental Downlink (SDL) => standardize L-band and corresponding E-UTRA and UTRA requirements for SDL operation in Region 1 / Impacted TSs and TRs: UTRA; LTE / WI rapporteur e-mail: olfa.benhaddada@orange.com
- 5606: RP#64 completed. RP#65 forgotten TR 37.814 v100 for 1-step Approval / Impacted TSs and TRs: 25.101; 25.104; 25.113; 25.133; 25.307; 25.327; 25.461; 25.466; 34.124; 36.101; 36.104; 36.113; 36.124; 36.133; 36.307; 36.331; 37.104; 37.113; new 37.814 / WI rapporteur e-mail: olfa.benhaddada@orange.com
- 5607: RP#64 completed / Impacted TSs and TRs: 25.133; 25.141; 25.307; 25.327; 36.133; 36.141; 36.307; 37.141 / WI rapporteur e-mail: olfa.benhaddada@orange.com
- 5608: 03/07/15: Compl:0%->85% 03/07/15: CD:Mon 15/06/15->Tue 15/09/15 03/07/15: WID: RP-150134->RP-150835 03/07/15: Stat Rep: ->RP-150830 29/09/15: Compl:85%->90% 29/09/15: CD:Tue 15/09/15->Tue 15/12/15 29/09/15: Stat Rep: RP-150830->RP-151163¦1/1/16
- 5609: Triggered by Rel-12 TR 37.813 (FS_LTE_HRPD_SON). SA2 should verify the architecture solution in TR 37.813 for inter-RAT load balancing between LTE-HRPD. CT4 should specify the RIM extension to support the feature. / Impacted TSs and TRs: UTRA; LTE / WI rapporteur e-mail: Jinlian_wu@189.cn
- 5610: SP#62 completed / Impacted TSs and TRs: 23.402 / WI rapporteur e-mail: Huan Li (ivy.lihuan@huawei.com)
- 5611: RP#64 completed / Impacted TSs and TRs: 36.300; 36.413 / WI rapporteur e-mail: Jinlian_wu@189.cn
- 5612: CP#61 WID approved & Completed / Impacted TSs and TRs: 29.274; 29.276; 29.280 / WI rapporteur e-mail: Xiaoyan SHI (sean.shixiaoyan@huawei.com
- 5613: GP#59 WID approved & Completed / Impacted TSs and TRs: 48.018 / WI rapporteur e-mail: marguerite.woch@alcatel-lucent.com

| ID | WBS | Task | Duration | Start | Finish | Complete | Remaining | Baseline start | Baseline finish | Baseline duration | Total slack | Constraint | Resources | Work | Actual work | Acronym | PCG approved | Impacted TSs and TRs | WI rapporteur name | WI rapporteur e-mail | Release | TSG approved | MCC resp | Acronym_3GU_Export | Status Report | Special Focus Doc | PCG stopped | TSG stopped |
| --- | --- | --- | --- | --- | --- | --- | --- | --- | --- | --- | --- | --- | --- | --- | --- | --- | --- | --- | --- | --- | --- | --- | --- | --- | --- | --- | --- | --- |
| 5614 | 1974 | **Increasing the minimum number of carriers for UE monitoring in UTRA and E-UTRA** | 1796.25d? | 2013-12-15 A | 2018-09-14 | 99% | 0d? | 2013-12-09 | 2015-03-13 | 331d? | 0d |  | R4; R2 | 20724.4h | 20724.4h | LTE_UTRA_IncMon | 32 | UTRA; LTE | Ericsson | christopher.callender@ericsson.com | Rel-12 | 62 | Issam | LTE_UTRA_IncMon |  |  |  |  |
| 5615 | 1974.1 | Core part: Increasing the minimum number of carriers for UE monitoring in UTRA and E-UTRA | 201d? | 2013-12-15 A | 2014-12-15 A | 100% |  | 2014-01-06 | 2014-09-12 | 133d? |  | finish no earlier than 2014-12-15 | R4; R2 | 1844.4h | 1844.4h | LTE_UTRA_IncMon-Core | 32 | 25.133; 25.331; 36.133 | Ericsson | christopher.callender@ericsson.com | Rel-12 | 62 | Issam | LTE_UTRA_IncMon-Core | RP-141787 |  |  |  |
| 5616 | 1974.2 | Perf. part: Increasing the minimum number of carriers for UE monitoring in UTRA and E-UTRA | 395d? | 2013-12-15 A | 2015-06-15 A | 100% |  | 2013-12-09 | 2015-03-13 | 331d? |  | finish no earlier than 2015-06-15 | R4 | 3160h | 3160h | LTE_UTRA_IncMon-Perf | 32 | 25.133; 36.133 | Ericsson | christopher.callender@ericsson.com | Rel-12 | 62 | Issam | LTE_UTRA_IncMon-Perf | RP-150596 |  |  |  |
| 5617 | 1974.3 | UE Conformance Test Aspects - Increasing the minimum number of carriers for UE monitoring in UTRA and E-UTRA | 720d? | 2015-12-15 A | 2018-09-14 A | 100% |  |  |  |  |  | finish no earlier than 2018-09-15 | R5 | 5760h | 5760h | LTE_UTRA_IncMon-UEConTest | 36 |  | Ericsson |  | Rel-12 | 70 |  |  |  |  |  |  |
| 5618 | 1975 | **WLAN/3GPP Radio Interworking** | 381.75d? | 2013-12-06 A | 2014-12-09 A | 100% |  | 2013-12-06 | 2014-09-17 | 205d? |  |  | R2; S2; C1; C4 | 11021h | 11021h | UTRA_LTE_WLAN_interw | 32 | UTRA; LTE | Intel | sasha.sirotkin@intel.com | Rel-12 | 62 | Yong-Jun | UTRA_LTE_WLAN_interw |  | WLAN |  |  |
| 5619 | 1975.1 | Core part: WLAN/3GPP Radio Interworking | 202d? | 2013-12-06 A | 2014-09-12 A | 100% |  | 2013-12-06 | 2014-09-12 | 202d? |  | finish no earlier than 2014-09-12 | R2 | 1616h | 1616h | UTRA_LTE_WLAN_interw-Core | 32 | 25.304; 25.306; 25.331; 36.304; 36.306; 36.331 | Intel | sasha.sirotkin@intel.com | Rel-12 | 62 | Yong-Jun | UTRA_LTE_WLAN_interw-Core | RP-141310 | WLAN |  |  |
| 5620 | 1975.2 | SA2 aspects of WLAN/3GPP Radio Interworking | 140d? | 2014-03-07 A | 2014-09-17 A | 100% |  | 2014-03-07 | 2014-09-17 | 139d? |  | finish no earlier than 2014-09-17 | S2 | 1120h | 1120h | UTRA_LTE_WLAN_interw-SA2 | 32 | 23.402; 23.401; 23.060; 23.251 | Alcatel-Lucent | nicolas.drevon@alcatel-lucent.com | Rel-12 | 63 | Maurice | UTRA_LTE_WLAN_interw-SA2 |  | WLAN |  |  |
| 5621 | 1975.3 | **CT aspects of WLAN/3GPP Radio Interworking (Stage 2/3)** | 95d? | 2014-09-09 A | 2014-12-09 A | 100% |  | 2014-06-13 | 2014-09-12 | 66d? |  |  | C1; C4 | 1665.6h | 1665.6h | UTRA_LTE_WLAN_interw-CT | 33 | Stage 2/3 | Alcatel-Lucent | jennifer.liu@alcatel-lucent.com | Rel-12 | 64 |  | UTRA_LTE_WLAN_interw-CT |  | WLAN |  |  |
| 5622 | 1975.3.1 | CT1 part of CT aspects of WLAN/3GPP Radio Interworking (Stage 3) | 95d? | 2014-09-09 A | 2014-12-09 A | 100% |  | 2014-06-13 | 2014-09-12 | 66d? |  | finish no earlier than 2014-12-09 | C1 | 528h | 528h | UTRA_LTE_WLAN_interw-CT | 33 | 24.008; 24.301; 24.302; 24.312 | Alcatel-Lucent | jennifer.liu@alcatel-lucent.com | Rel-12 | 64 |  |  | CP-140720 | WLAN |  |  |
| 5623 | 1975.3.2 | CT4 part of CT aspects of WLAN/3GPP Radio Interworking (Stage 2/3) | 63d? | 2014-09-12 A | 2014-12-09 A | 100% |  |  |  |  |  | finish no earlier than 2014-12-09 | C4 | 504h | 504h | UTRA_LTE_WLAN_interw-CT | 33 | 23.008; 29.002; 29.272; 29.274; 29.305 | Alcatel-Lucent | jennifer.liu@alcatel-lucent.com | Rel-12 | 65 |  |  | CP-140482 | WLAN |  |  |
| 5624 | 1976 | UE Conformance Test Aspects – WLAN/3GPP Radio Interworking | 327d? | 2014-12-15 A | 2016-03-15 A | 100% |  |  |  |  |  | finish no earlier than 2016-03-15 | R5 | 2616h | 2616h | UTRA_LTE_WLAN_interw-UEConTest | 34 |  | Intel | Intel | Rel-12 | 66 |  |  | RP-151264 |  |  |  |
| 5625 | 1977 | **Rel-12 LTE Carrier Aggregation** | 1981.38d? | 2011-09-19 A | 2016-12-15 A | 100% |  | 2011-09-19 | 2014-12-11 | 855d? |  |  | R4 | 567982h | 567982h | LTE_CA_Rel-12 | 30 | LTE |  |  | Rel-12 | 58 | Issam | LTE_CA_Rel-12 |  | CA |  |  |
| 5626 | 1977.1 | **LTE Advanced inter-band Carrier Aggregation of Band 1 and Band 7** | 1127.25d? | 2011-09-19 A | 2014-09-12 A | 100% |  | 2011-09-19 | 2014-09-12 | 791d? |  |  | R4 | 18896h | 18896h | LTE_CA_B1_B7 | 27 | LTE | Ericsson | christian.bergljung@ericsson.com | Rel-12 | 53 | Issam | LTE_CA_B1_B7 |  | CA |  |  |
| 5627 | 1977.1.1 | Core part:LTE Advanced inter-band Carrier Aggregation of Band 1 and Band 7 | 790d? | 2011-09-19 A | 2014-09-12 A | 100% |  | 2011-09-19 | 2014-09-12 | 790d? |  | finish no earlier than 2014-09-12 | R4 | 6312h | 6312h | LTE_CA_B1_B7-Core | 27 | 36.101; 36.104; new generic 36.851 | Ericsson | christian.bergljung@ericsson.com | Rel-12 | 53 | Issam | LTE_CA_B1_B7-Core | RP-141084 | CA |  |  |
| 5628 | 1977.1.2 | Perf. part:LTE Advanced inter-band Carrier Aggregation of Band 1 and Band 7 | 781d? | 2011-10-03 A | 2014-09-12 A | 100% |  | 2011-09-30 | 2014-09-12 | 781d? |  | finish no earlier than 2014-09-12 | R4 | 6248h | 6248h | LTE_CA_B1_B7-Perf | 27 | 36.141; 36.307 | Ericsson | christian.bergljung@ericsson.com | Rel-12 | 53 | Issam | LTE_CA_B1_B7-Perf | RP-141084 | CA |  |  |
| 5629 | 1977.2 | **LTE Advanced intra-band non-contiguous Carrier Aggregation in Band 25** | 656.62d? | 2011-09-19 A | 2013-06-14 A | 100% |  | 2011-09-19 | 2013-06-14 | 462d? |  |  | R4 | 11056h | 11056h | LTE_CA_NC_B25 | 27 | LTE | Sprint | George.Cummings@sprint.com | Rel-12 | 53 | Issam | LTE_CA_NC_B25 |  | CA |  |  |
| 5630 | 1977.2.1 | Core part:LTE Advanced intra-band non-contiguous Carrier Aggregation in Band 25 | 459d? | 2011-09-19 A | 2013-06-14 A | 100% |  | 2011-09-19 | 2013-06-14 | 459d? |  | finish no earlier than 2013-06-14 | R4 | 3672h | 3672h | LTE_CA_NC_B25-Core | 27 | 36.101; 36.104; 36.133; new 36.833-2-25 | Sprint | George.Cummings@sprint.com | Rel-12 | 53 | Issam | LTE_CA_NC_B25-Core | RP-130563 | CA |  |  |
| 5631 | 1977.2.2 | Perf. part:LTE Advanced intra-band non-contiguous Carrier Aggregation in Band 25 | 461d? | 2011-09-19 A | 2013-06-14 A | 100% |  | 2011-09-19 | 2013-06-14 | 461d? |  | finish no earlier than 2013-06-14 | R4 | 3688h | 3688h | LTE_CA_NC_B25-Perf | 27 | 36.141; 36.307 | Sprint | George.Cummings@sprint.com | Rel-12 | 53 | Issam | LTE_CA_NC_B25-Perf | RP-130759 | CA |  |  |
| 5632 | 1977.3 | **Deleted -LTE Advanced inter-band Carrier Aggregation of Band 3 and Band 5 with 2UL** | 374.12d? | 2012-03-05 A | 2013-03-01 A | 100% |  | 2012-03-05 | 2013-03-01 | 265d? |  |  | R4 | 6296h | 6296h | LTE_CA_B3_B5_2UL | 28 | LTE | SK Telecom | Seungpyo Hong | Rel-12 | 55 | Issam | LTE_CA_B3_B5_2UL |  | CA | PCG-30 | RP-59 |
| 5633 | 1977.3.1 | Deleted - Core part:LTE Advanced inter-band Carrier Aggregation of Band 3 and Band 5 with 2UL | 262d? | 2012-03-05 A | 2013-03-01 A | 100% |  | 2012-03-05 | 2013-03-01 | 262d? |  | finish no earlier than 2013-03-01 | R4 | 2096h | 2096h | LTE_CA_B3_B5_2UL-Core | 28 | 36.101; 36.104; 36.133; 36.307; new generic 36.851 | SK Telecom | Seungpyo Hong | Rel-12 | 55 | Issam | LTE_CA_B3_B5_2UL-Core | RP-130098 | CA | PCG-30 | RP-59 |
| 5634 | 1977.3.2 | Deleted - Perf. part:LTE Advanced inter-band Carrier Aggregation of Band 3 and Band 5 with 2UL | 260d? | 2012-03-12 A | 2013-03-01 A | 100% |  | 2012-03-12 | 2013-03-01 | 260d? |  | finish no earlier than 2013-03-01 | R4 | 2080h | 2080h | LTE_CA_B3_B5_2UL-Perf | 28 | 36.133; 36.141 | SK Telecom | Seungpyo Hong | Rel-12 | 55 | Issam | LTE_CA_B3_B5_2UL-Perf | RP-130099 | CA | PCG-30 | RP-59 |
| 5635 | 1977.4 | UE Conformance Test Aspects - Further Rel-12 configurations for LTE Advanced Carrier Aggregation with 2UL | 460d? | 2015-03-16 A | 2016-12-15 A | 100% |  |  |  |  |  | finish no earlier than 2016-12-15 | R5 | 3680h | 3680h | LTE_CA_Rel12_2UL-UEConTest | 34 |  | Ericsson | NA | Rel-12 | 67 |  |  |  |  |  |  |
| 5636 | 1977.5 | **LTE Advanced intra-band non-contiguous Carrier Aggregation in Band 3** | 663.62d? | 2012-03-05 A | 2013-12-06 A | 100% |  | 2012-03-05 | 2013-12-06 | 469d? |  |  | R4 | 11136h | 11136h | LTE_CA_NC_B3 | 28 | LTE | SK Telecom | haesung.park@sk.com | Rel-12 | 55 | Issam | LTE_CA_NC_B3 |  | CA |  |  |
| 5637 | 1977.5.1 | Core part:LTE Advanced intra-band non-contiguous Carrier Aggregation in Band 3 | 462d? | 2012-03-05 A | 2013-12-06 A | 100% |  | 2012-03-05 | 2013-12-06 | 462d? |  | finish no earlier than 2013-12-06 | R4 | 3696h | 3696h | LTE_CA_NC_B3-Core | 28 | 36.101; 36.104; 36.133; new 36.833-2-03 | SK Telecom | haesung.park@sk.com | Rel-12 | 55 | Issam | LTE_CA_NC_B3-Core | RP-131573 | CA |  |  |
| 5638 | 1977.5.2 | Perf. part:LTE Advanced intra-band non-contiguous Carrier Aggregation in Band 3 | 461d? | 2012-03-15 A | 2013-12-06 A | 100% |  | 2012-03-15 | 2013-12-06 | 461d? |  | finish no earlier than 2013-12-06 | R4 | 3688h | 3688h | LTE_CA_NC_B3-Perf | 28 | 36.101; 36.104; 36.133; 36.141; 36.307 | SK Telecom | haesung.park@sk.com | Rel-12 | 55 | Issam | LTE_CA_NC_B3-Perf | RP-131574 | CA |  |  |

Notes:
- 5614: -
- 5615: ¦CD:Thu 18/12/14->Mon 15/12/14¦WID: RP-141966->RP-142235¦Stat Rep: RP-141600->RP-141787
- 5616: ¦CD:Fri 12/06/15->Mon 15/06/15¦WID: RP-141966->RP-142235¦Stat Rep: RP-141600->RP-141787 1st Apr 15: Compl:5%->40% 1st Apr 15: Stat Rep: RP-141787->RP-150063 03/07/15: Compl:40%->100% 03/07/15: Stat Rep: RP-150063->RP-150596
- 5617: 22/3/16: Compl:0%->4%1/7/16: CD:Thu 15/09/16->Thu 15/12/16¦26/9/16: Com 21/3/17: Compl ¦2 ;; 11/10/20: 35%->100
- 5618: Triggered by Rel-12 TR 37.834 Study on WLAN/3GPP Radio Interworking (FS_UTRA_LTE_WLAN_interw)
- 5619: SP#65 completed
- 5620: SP#65 completed
- 5621: CP#65 revised WID CP-140287=>CP-140623 (added CT4 part)
- 5622: CP#65 completion 09/14=>12/14. Exception in CP-140720. 78%->95%. 12/12: 95->78%. 3/3/15: 100% cpltd.
- 5623: CP#65 revised WID CP-140287=>CP-140623 (added CT4 part). Exception in CP-140482. Dec.14: 50->100
- 5624: Rel13->Rel-12¦Moved at appropriate place 1st Apr 15: Compl:0%->5% 1st Apr 15: Stat Rep: ->RP-150098 03/07/15: Compl:5%->20% 03/07/15: Stat Rep: RP-150098->RP-150929 29/09/15: Compl:20%->60% 29/09/15: WID: RP-141879->RP-151270 29/09/15: Stat Rep: RP-15
- 5625: LTE_CA_Rel-12
- 5626: Inter-band CA 2DL
- 5627: RP#65 completed. Updated WID RP-132042=>RP-141487
- 5628: RP#65 completed
- 5629: Intra-band NC
- 5630: RP#60 completed. TR 36.841 for 1-step Approval
- 5631: RP#60 completed
- 5632: Inter-band 2UL
- 5633: RP#59 stopped (covered by new WI LTE_CA_2UL-A4)
- 5634: RP#59 stopped (covered by new WI LTE_CA_2UL-A4)
- 5635: 03/07/15: Compl:0%->29% 03/07/15: Stat Rep: ->RP-150834 29/09/15: Compl:29%->55% 29/09/15: Stat Rep: RP-150834->RP-151166 1/1/16: Compl:55%->70% 1/1/16: CD:Tue 15/12/15->Tue 15/03/16 1/1/16: WID: RP-1¦
- 5636: Intra-band NC
- 5637: RP#62 completed
- 5638: RP#62 completed

| ID | WBS | Task | Duration | Start | Finish | Complete | Baseline start | Baseline finish | Baseline duration | Constraint | Resources | Work | Actual work | Acronym | PCG approved | Impacted TSs and TRs | WI rapporteur name | WI rapporteur e-mail | Release | TSG approved | MCC resp | PCG stopped | TSG stopped | Special Focus Doc | Acronym_3GU_Export | Status Report |
| --- | --- | --- | --- | --- | --- | --- | --- | --- | --- | --- | --- | --- | --- | --- | --- | --- | --- | --- | --- | --- | --- | --- | --- | --- | --- | --- |
| 5639 | 1977.6 | **Deleted - LTE Advanced intra-band contiguous Carrier Aggregation in Band 1** | 374.12d? | 2012-06-18 A | 2013-06-14 A | 100% | 2012-06-18 | 2013-06-14 | 265d? |  | R4 | 6328h | 6328h | LTE_CA_C_B1 | 29 | LTE | KDDI | Masaaki Obara (ms-obara@kddi.com) | Rel-12 | 56 | Issam | PCG-31 | RP-60 | CA | LTE_CA_C_B1 |  |
| 5640 | 1977.6.1 | Deleted - Core part: LTE Advanced intra-band contiguous Carrier Aggregation in Band 1 | 265d? | 2012-06-18 A | 2013-06-14 A | 100% | 2012-06-18 | 2013-06-14 | 265d? | finish no earlier than 2013-06-14 | R4 | 2120h | 2120h | LTE_CA_C_B1-Core | 29 | 36.101; 36.104; 36.133; 36.141; 36.307; new 36.835 | KDDI | Masaaki Obara (ms-obara@kddi.com) | Rel-12 | 56 | Issam | PCG-31 | RP-60 | CA | LTE_CA_C_B1-Core | RP-130549 |
| 5641 | 1977.6.2 | Deleted - Perf. part: LTE Advanced intra-band contiguous Carrier Aggregation in Band 1 | 261d? | 2012-06-22 A | 2013-06-14 A | 100% | 2012-06-22 | 2013-06-14 | 261d? | finish no earlier than 2013-06-14 | R4 | 2088h | 2088h | LTE_CA_C_B1-Perf | 29 | 36.101; 36.104; 36.133; 36.141; 36.307 | KDDI | Masaaki Obara (ms-obara@kddi.com) | Rel-12 | 56 | Issam | PCG-31 | RP-60 | CA | LTE_CA_C_B1-Perf | RP-130550 |
| 5642 | 1977.7 | **LTE Advanced intra-band non-contiguous Carrier Aggregation in Band 4** | 460.88d? | 2012-06-18 A | 2013-09-06 A | 100% | 2012-06-18 | 2013-09-06 | 327d? |  | R4 | 7752h | 7752h | LTE_CA_NC_B4 | 29 | LTE | T-Mobile USA | nelson.ueng@t-mobile.com | Rel-12 | 56 | Issam |  |  | CA | LTE_CA_NC_B4 |  |
| 5643 | 1977.7.1 | Core part:LTE Advanced intra-band non-contiguous Carrier Aggregation in Band 4 | 323d? | 2012-06-18 A | 2013-09-06 A | 100% | 2012-06-18 | 2013-09-06 | 323d? | finish no earlier than 2013-09-06 | R4 | 2568h | 2568h | LTE_CA_NC_B4-Core | 29 | 36.101; 36.104; 36.133; new 36.833-2-04 | T-Mobile USA | nelson.ueng@t-mobile.com | Rel-12 | 56 | Issam |  |  | CA | LTE_CA_NC_B4-Core | RP-131039 |
| 5644 | 1977.7.2 | Perf. part:LTE Advanced intra-band non-contiguous Carrier Aggregation in Band 4 | 323d? | 2012-06-22 A | 2013-09-06 A | 100% | 2012-06-22 | 2013-09-06 | 323d? | finish no earlier than 2013-09-06 | R4 | 2568h | 2568h | LTE_CA_NC_B4-Perf | 29 | 36.101; 36.104; 36.133; 36.141; 36.307 | T-Mobile USA | nelson.ueng@t-mobile.com | Rel-12 | 56 | Issam |  |  | CA | LTE_CA_NC_B4-Perf | RP-131040 |
| 5645 | 1977.8 | **LTE Advanced inter-band Carrier Aggregation of Band 2 and Band 4** | 460.88d? | 2012-06-18 A | 2013-09-06 A | 100% | 2012-06-18 | 2013-09-06 | 327d? |  | R4 | 7752h | 7752h | LTE_CA_B2_B4 | 29 | LTE | T-Mobile USA | nelson.ueng@t-mobile.com | Rel-12 | 56 | Issam |  |  | CA | LTE_CA_B2_B4 |  |
| 5646 | 1977.8.1 | Core part:LTE Advanced inter-band Carrier Aggregation of Band 2 and Band 4 | 321d? | 2012-06-18 A | 2013-09-06 A | 100% | 2012-06-18 | 2013-09-06 | 321d? | finish no earlier than 2013-09-06 | R4 | 2568h | 2568h | LTE_CA_B2_B4-Core | 29 | 36.101; 36.104; 36.133; new generic 36.851 | T-Mobile USA | nelson.ueng@t-mobile.com | Rel-12 | 56 | Issam |  |  | CA | LTE_CA_B2_B4-Core | RP-131007 |
| 5647 | 1977.8.2 | Perf. part:LTE Advanced inter-band Carrier Aggregation of Band 2 and Band 4 | 321d? | 2012-06-22 A | 2013-09-06 A | 100% | 2012-06-22 | 2013-09-06 | 321d? | finish no earlier than 2013-09-06 | R4 | 2568h | 2568h | LTE_CA_B2_B4-Perf | 29 | 36.101; 36.104; 36.133; 36.141; 36.307 | T-Mobile USA | nelson.ueng@t-mobile.com | Rel-12 | 56 | Issam |  |  | CA | LTE_CA_B2_B4-Perf | RP-131376 |
| 5648 | 1977.9 | **LTE Advanced inter-band Carrier Aggregation of Band 23 and Band 29** | 285.25d? | 2012-09-12 A | 2013-06-14 A | 100% | 2012-09-12 | 2013-06-14 | 202d? |  | R4 | 4832h | 4832h | LTE_CA_B23_B29 | 29 | LTE | DISH Network | mariam.sorond@dish.com, johny.kim@dish.com | Rel-12 | 57 | Issam |  |  | CA | LTE_CA_B23_B29 |  |
| 5649 | 1977.9.1 | Core part:LTE Advanced inter-band Carrier Aggregation of Band 23 and Band 29 | 201d? | 2012-09-12 A | 2013-06-14 A | 100% | 2012-09-12 | 2013-06-14 | 201d? | finish no earlier than 2013-06-14 | R4 | 1608h | 1608h | LTE_CA_B23_B29-Core | 29 | 36.101; 36.104; 36.133; new generic 36.851 | DISH Network | mariam.sorond@dish.com, johny.kim@dish.com | Rel-12 | 57 | Issam |  |  | CA | LTE_CA_B23_B29-Core | RP-130535 |
| 5650 | 1977.9.2 | Perf. part:LTE Advanced inter-band Carrier Aggregation of Band 23 and Band 29 | 201d? | 2012-09-12 A | 2013-06-14 A | 100% | 2012-09-12 | 2013-06-14 | 201d? | finish no earlier than 2013-06-14 | R4 | 1608h | 1608h | LTE_CA_B23_B29-Perf | 29 | 36.141; 36.307 | DISH Network | mariam.sorond@dish.com, johny.kim@dish.com | Rel-12 | 57 | Issam |  |  | CA | LTE_CA_B23_B29-Perf | RP-130536 |
| 5651 | 1977.10 | **LTE Advanced inter-band Carrier Aggregation of Band 3 and Band 26** | 286.25d? | 2012-09-11 A | 2013-06-14 A | 100% | 2012-09-11 | 2013-06-14 | 203d? |  | R4 | 4840h | 4840h | LTE_CA_B3_B26 | 29 | LTE | KT | Chungwoo HWANG (cwhwang@kt.com) | Rel-12 | 57 | Issam |  |  | CA | LTE_CA_B3_B26 |  |
| 5652 | 1977.10.1 | Core part:LTE Advanced inter-band Carrier Aggregation of Band 3 and Band 26 | 202d? | 2012-09-11 A | 2013-06-14 A | 100% | 2012-09-11 | 2013-06-14 | 202d? | finish no earlier than 2013-06-14 | R4 | 1608h | 1608h | LTE_CA_B3_B26-Core | 29 | 36.101; 36.104; 36.133; 36.307; new generic 36.851 | KT | Chungwoo HWANG (cwhwang@kt.com) | Rel-12 | 57 | Issam |  |  | CA | LTE_CA_B3_B26-Core | RP-130527 |
| 5653 | 1977.10.2 | Perf. part:LTE Advanced inter-band Carrier Aggregation of Band 3 and Band 26 | 202d? | 2012-09-11 A | 2013-06-14 A | 100% | 2012-09-11 | 2013-06-14 | 202d? | finish no earlier than 2013-06-14 | R4 | 1608h | 1608h | LTE_CA_B3_B26-Perf | 29 | 36.101; 36.104; 36.133; 36.141; 36.307 | KT | Chungwoo HWANG (cwhwang@kt.com) | Rel-12 | 57 | Issam |  |  | CA | LTE_CA_B3_B26-Perf | RP-130528 |
| 5654 | 1977.11 | **LTE Advanced inter-band Carrier Aggregation of Band 3 and Band 19** | 286.25d? | 2012-09-11 A | 2013-06-14 A | 100% | 2012-09-11 | 2013-06-14 | 203d? |  | R4 | 4840h | 4840h | LTE_CA_B3_B19 | 29 | LTE | NTT DOCOMO | Kei ANDO | Rel-12 | 57 | Issam |  |  | CA | LTE_CA_B3_B19 |  |
| 5655 | 1977.11.1 | Core part:LTE Advanced inter-band Carrier Aggregation of Band 3 and Band 19 | 201d? | 2012-09-11 A | 2013-06-14 A | 100% | 2012-09-11 | 2013-06-14 | 201d? | finish no earlier than 2013-06-14 | R4 | 1608h | 1608h | LTE_CA_B3_B19-Core | 29 | 36.101; 36.104; 36.133; new generic 36.851 | NTT DOCOMO | Kei ANDO | Rel-12 | 57 | Issam |  |  | CA | LTE_CA_B3_B19-Core | RP-130525 |
| 5656 | 1977.11.2 | Perf. part:LTE Advanced inter-band Carrier Aggregation of Band 3 and Band 19 | 201d? | 2012-09-13 A | 2013-06-14 A | 100% | 2012-09-13 | 2013-06-14 | 201d? | finish no earlier than 2013-06-14 | R4 | 1608h | 1608h | LTE_CA_B3_B19-Perf | 29 | 36.141; 36.307 | NTT DOCOMO | Kei ANDO | Rel-12 | 57 | Issam |  |  | CA | LTE_CA_B3_B19-Perf | RP-130526 |
| 5657 | 1977.12 | **Deleted -LTE Advanced inter-band Carrier Aggregation of Band 38 and Band 39** | 90.75d? | 2012-09-11 A | 2012-12-07 A | 100% | 2012-09-11 | 2012-12-07 | 66d? |  | R4 | 1584h | 1584h | LTE_CA_B38_B39 | 29 | LTE | China Mobile | Pan Qun (panqun@chinamobile.com) | Rel-12 | 57 | Issam | PCG-30 | RP-58 | CA | LTE_CA_B38_B39 |  |
| 5658 | 1977.12.1 | Deleted - Core part:LTE Advanced inter-band Carrier Aggregation of Band 38 and Band 39 | 66d? | 2012-09-11 A | 2012-12-07 A | 100% | 2012-09-11 | 2012-12-07 | 66d? | finish no earlier than 2012-12-07 | R4 | 528h | 528h | LTE_CA_B38_B39-Core | 29 | 36.101; 36.104; 36.307; new generic 36.851 | China Mobile | Pan Qun (panqun@chinamobile.com) | Rel-12 | 57 | Issam | PCG-30 | RP-58 | CA | LTE_CA_B38_B39-Core | RP-121624 |
| 5659 | 1977.12.2 | Deleted - Perf. part:LTE Advanced inter-band Carrier Aggregation of Band 38 and Band 39 | 66d? | 2012-09-11 A | 2012-12-07 A | 100% | 2012-09-11 | 2012-12-07 | 66d? | finish no earlier than 2012-12-07 | R4 | 528h | 528h | LTE_CA_B38_B39-Perf | 29 | 36.133; 36.141 | China Mobile | Pan Qun (panqun@chinamobile.com) | Rel-12 | 57 | Issam | PCG-30 | RP-58 | CA | LTE_CA_B38_B39-Perf | RP-121625 |
| 5660 | 1977.13 | **LTE Advanced intra-band contiguous Carrier Aggregation in Band 3** | 373d? | 2012-09-11 A | 2013-09-06 A | 100% | 2012-09-11 | 2013-09-06 | 265d? |  | R4 | 6312h | 6312h | LTE_CA_C_B3 | 29 | LTE | China Unicom | Fei CUI (cuifei1@chinaunicom.cn) | Rel-12 | 57 | Issam |  |  | CA | LTE_CA_C_B3 |  |
| 5661 | 1977.13.1 | Core part: LTE Advanced intra-band contiguous Carrier Aggregation in Band 3 | 263d? | 2012-09-11 A | 2013-09-06 A | 100% | 2012-09-11 | 2013-09-06 | 263d? | finish no earlier than 2013-09-06 | R4 | 2096h | 2096h | LTE_CA_C_B3-Core | 29 | 36.101; 36.104; 36.133; new 36.833-1-03 | China Unicom | Fei CUI (cuifei1@chinaunicom.cn) | Rel-12 | 57 | Issam |  |  | CA | LTE_CA_C_B3-Core | RP-131029 |
| 5662 | 1977.13.2 | Perf. part: LTE Advanced intra-band contiguous Carrier Aggregation in Band 3 | 263d? | 2012-09-11 A | 2013-09-06 A | 100% | 2012-09-11 | 2013-09-06 | 263d? | finish no earlier than 2013-09-06 | R4 | 2096h | 2096h | LTE_CA_C_B3-Perf | 29 | 36.141; 36.307 | China Unicom | Fei CUI (cuifei1@chinaunicom.cn) | Rel-12 | 57 | Issam |  |  | CA | LTE_CA_C_B3-Perf | RP-131030 |

Notes:
- 5639: Intra-band C
- 5640: RP#60 stopped at 10% completion (rationale in RP-130670)
- 5641: RP#60 stopped at 0% completion
- 5642: Intra-band NC
- 5643: RP#61 completed. Updated WID RP-130842=>RP-131135
- 5644: RP#61 completed. Updated WID RP-130842=>RP-131135
- 5645: Inter-band 1 UL
- 5646: RP#61 completed
- 5647: RP#61 completed
- 5648: Inter-band 1 UL
- 5649: RP#60 completed
- 5650: RP#60 completed
- 5651: Inter-band 1 UL
- 5652: RP#60 completed. Updated WID RP-130199=>RP-130658
- 5653: RP#60 completed. Updated WID RP-130199=>RP-130658
- 5654: Inter-band 1 UL
- 5655: RP#60 completed
- 5656: RP#60 completed
- 5657: Inter-band 1 UL
- 5658: RP#58 stopped at 10% completion following regulatory decisions (see instead new WI LTE_CA_B39_B41)
- 5659: RP#58 stopped at 0% completion following regulatory decisions (see instead new WI LTE_CA_B39_B41)
- 5660: Intra-band NC
- 5661: RP#61 completed. Updated WID RP-130294=>RP-131184 (impacted specs)
- 5662: RP#61 completed

| ID | WBS | Task | Duration | Start | Finish | Complete | Baseline start | Baseline finish | Baseline duration | Constraint | Resources | Work | Actual work | Acronym | PCG approved | Impacted TSs and TRs | WI rapporteur name | WI rapporteur e-mail | Release | TSG approved | MCC resp | Special Focus Doc | Acronym_3GU_Export | Status Report |
| --- | --- | --- | --- | --- | --- | --- | --- | --- | --- | --- | --- | --- | --- | --- | --- | --- | --- | --- | --- | --- | --- | --- | --- | --- |
| 5663 | 1977.14 | **LTE Advanced inter-band Carrier Aggregation of Band 1 and Band 8** | 515.8d? | 2012-02-02 A | 2013-06-14 A | 100% | 2012-02-02 | 2013-06-14 | 362.8d? |  | R4 | 6118.4h | 6118.4h | LTE_CA_B1_B8 | 29 | LTE | Softbank Mobile | Kenichi Kihara | Rel-12 | 57 | Issam | CA | LTE_CA_B1_B8 |  |
| 5664 | 1977.14.1 | Core part:LTE Advanced inter-band Carrier Aggregation of Band 1 and Band 8 | 201d? | 2012-02-02 A | 2013-06-14 A | 100% | 2012-02-02 | 2013-06-14 | 201d? | finish no earlier than 2013-06-14 | R4 | 1608h | 1608h | LTE_CA_B1_B8-Core | 29 | 36.101; 36.104; new generic 36.851 | Softbank Mobile | Kenichi Kihara | Rel-12 | 57 | Issam | CA | LTE_CA_B1_B8-Core | RP-130515 |
| 5665 | 1977.14.2 | Perf. part:LTE Advanced inter-band Carrier Aggregation of Band 1 and Band 8 | 202d? | 2012-09-11 A | 2013-06-14 A | 100% | 2012-09-11 | 2013-06-14 | 202d? | finish no earlier than 2013-06-14 | R4 | 1608h | 1608h | LTE_CA_B1_B8-Perf | 29 | 36.141; 36.307 | Softbank Mobile | Kenichi Kihara | Rel-12 | 57 | Issam | CA | LTE_CA_B1_B8-Perf | RP-130516 |
| 5666 | 1977.15 | **LTE Advanced inter-band Carrier Aggregation of Band 3 and Band 28** | 286.25d? | 2012-09-11 A | 2013-06-14 A | 100% | 2012-09-11 | 2013-06-14 | 203d? |  | R4 | 4840h | 4840h | LTE_CA_B3_B28 | 29 | LTE | eAccess | FukumotoShiro@eaccess.net | Rel-12 | 57 | Issam | CA | LTE_CA_B3_B28 |  |
| 5667 | 1977.15.1 | Core part:LTE Advanced inter-band Carrier Aggregation of Band 3 and Band 28 | 202d? | 2012-09-11 A | 2013-06-14 A | 100% | 2012-09-11 | 2013-06-14 | 202d? | finish no earlier than 2013-06-14 | R4 | 1608h | 1608h | LTE_CA_B3_B28-Core | 29 | 36.101; 36.104; new generic 36.851 | eAccess | FukumotoShiro@eaccess.net | Rel-12 | 57 | Issam | CA | LTE_CA_B3_B28-Core | RP-130529 |
| 5668 | 1977.15.2 | Perf. part:LTE Advanced inter-band Carrier Aggregation of Band 3 and Band 28 | 201d? | 2012-09-12 A | 2013-06-14 A | 100% | 2012-09-12 | 2013-06-14 | 201d? | finish no earlier than 2013-06-14 | R4 | 1608h | 1608h | LTE_CA_B3_B28-Perf | 29 | 36.141; 36.307 | eAccess | FukumotoShiro@eaccess.net | Rel-12 | 57 | Issam | CA | LTE_CA_B3_B28-Perf | RP-130530 |
| 5669 | 1977.16 | **LTE Advanced inter-band Carrier Aggregation of Band 1 and Band 26** | 283.25d? | 2012-12-07 A | 2013-09-06 A | 100% | 2012-12-07 | 2013-09-06 | 200d? |  | R4 | 4768h | 4768h | LTE_CA_B1_B26 | 30 | LTE | KDDI | Masaaki Obara (ms-obara@kddi.com) | Rel-12 | 58 | Issam | CA | LTE_CA_B1_B26 |  |
| 5670 | 1977.16.1 | Core part:LTE Advanced inter-band Carrier Aggregation of Band 1 and Band 26 | 200d? | 2012-12-07 A | 2013-09-06 A | 100% | 2012-12-07 | 2013-09-06 | 200d? | finish no earlier than 2013-09-06 | R4 | 1576h | 1576h | LTE_CA_B1_B26-Core | 30 | 36.101; 36.104; 36.133; new generic 36.851 | KDDI | Masaaki Obara (ms-obara@kddi.com) | Rel-12 | 58 | Issam | CA | LTE_CA_B1_B26-Core | RP-131005 |
| 5671 | 1977.16.2 | Perf. part:LTE Advanced inter-band Carrier Aggregation of Band 1 and Band 26 | 200d? | 2012-12-07 A | 2013-09-06 A | 100% | 2012-12-07 | 2013-09-06 | 200d? | finish no earlier than 2013-09-06 | R4 | 1600h | 1600h | LTE_CA_B1_B26-Perf | 30 | 36.141; 36.307 | KDDI | Masaaki Obara (ms-obara@kddi.com) | Rel-12 | 58 | Issam | CA | LTE_CA_B1_B26-Perf | RP-131006 |
| 5672 | 1977.17 | **LTE Advanced inter-band Carrier Aggregation of Band 39 and Band 41** | 467.25d? | 2012-12-10 A | 2014-03-06 A | 100% | 2012-12-10 | 2014-03-06 | 330d? |  | R4 | 7848h | 7848h | LTE_CA_B39_B41 | 30 | LTE | China Mobile | Pan Qun (panqun@chinamobile.com) | Rel-12 | 58 | Issam | CA | LTE_CA_B39_B41 | RP-140428 |
| 5673 | 1977.17.1 | Core part:LTE Advanced inter-band Carrier Aggregation of Band 39 and Band 41 | 326d? | 2012-12-10 A | 2014-03-06 A | 100% | 2012-12-10 | 2014-03-06 | 326d? | finish no earlier than 2014-03-06 | R4 | 2608h | 2608h | LTE_CA_B39_B41-Core | 30 | 36.101; 36.104; 36.307; new generic 36.851 | China Mobile | Pan Qun (panqun@chinamobile.com) | Rel-12 | 58 | Issam | CA | LTE_CA_B39_B41-Core | RP-140428 |
| 5674 | 1977.17.2 | Perf. part:LTE Advanced inter-band Carrier Aggregation of Band 39 and Band 41 | 325d? | 2012-12-14 A | 2014-03-06 A | 100% | 2012-12-14 | 2014-03-06 | 325d? | finish no earlier than 2014-03-06 | R4 | 2600h | 2600h | LTE_CA_B39_B41-Perf | 30 | 36.133; 36.141 | China Mobile | Pan Qun (panqun@chinamobile.com) | Rel-12 | 58 | Issam | CA | LTE_CA_B39_B41-Perf | RP-140428 |
| 5675 | 1977.18 | **LTE Advanced inter-band Carrier Aggregation of Band 2 and Band 12** | 663.88d? | 2012-12-10 A | 2014-09-12 A | 100% | 2012-12-10 | 2014-09-12 | 466d? |  | R4 | 10040h | 10040h | LTE_CA_B2_B12 | 30 | LTE | US Cellular | sebastian.thalanany@uscellular.com | Rel-12 | 58 | Issam | CA | LTE_CA_B2_B12 |  |
| 5676 | 1977.18.1 | Core part:LTE Advanced inter-band Carrier Aggregation of Band 2 and Band 12 | 464d? | 2012-12-10 A | 2014-09-12 A | 100% | 2012-12-10 | 2014-09-12 | 464d? | finish no earlier than 2014-09-12 | R4 | 3704h | 3704h | LTE_CA_B2_B12-Core | 30 | 36.101; 36.104; 36.133; 36.141; 36.307; new generic 36.851 | US Cellular | sebastian.thalanany@uscellular.com | Rel-12 | 58 | Issam | CA | LTE_CA_B2_B12-Core | RP-141084 |
| 5677 | 1977.18.2 | Perf. part:LTE Advanced inter-band Carrier Aggregation of Band 2 and Band 12 | 325d? | 2012-12-14 A | 2014-03-06 A | 100% | 2012-12-14 | 2014-03-06 | 325d? | finish no earlier than 2014-06-13 | R4 | 2600h | 2600h | LTE_CA_B2_B12-Perf | 30 | 36.101; 36.104; 36.133; 36.141; 36.307 | US Cellular | sebastian.thalanany@uscellular.com | Rel-12 | 58 | Issam | CA | LTE_CA_B2_B12-Perf | RP-140428 |
| 5678 | 1977.19 | **LTE Advanced intra-band non-contiguous Carrier Aggregation in Band 7** | 374.12d? | 2012-12-10 A | 2013-12-06 A | 100% | 2012-12-10 | 2013-12-06 | 265d? |  | R4 | 6296h | 6296h | LTE_CA_NC_B7 | 30 | LTE | Ericsson | christian.bergljung@ericsson.com | Rel-12 | 58 | Issam | CA | LTE_CA_NC_B7 |  |
| 5679 | 1977.19.1 | Core part:LTE Advanced intra-band non-contiguous Carrier Aggregation in Band 7 | 261d? | 2012-12-10 A | 2013-12-06 A | 100% | 2012-12-10 | 2013-12-06 | 261d? | finish no earlier than 2013-12-06 | R4 | 2088h | 2088h | LTE_CA_NC_B7-Core | 30 | 36.101; 36.104; 36.133; new 36.833-2-07 | Ericsson | christian.bergljung@ericsson.com | Rel-12 | 58 | Issam | CA | LTE_CA_NC_B7-Core | RP-131575 |
| 5680 | 1977.19.2 | Perf. part:LTE Advanced intra-band non-contiguous Carrier Aggregation in Band 7 | 261d? | 2012-12-14 A | 2013-12-06 A | 100% | 2012-12-14 | 2013-12-06 | 261d? | finish no earlier than 2013-12-06 | R4 | 2088h | 2088h | LTE_CA_NC_B7-Perf | 30 | 36.141; 36.307 | Ericsson | christian.bergljung@ericsson.com | Rel-12 | 58 | Issam | CA | LTE_CA_NC_B7-Perf | RP-131576 |
| 5681 | 1977.20 | **LTE Advanced intra-band contiguous Carrier Aggregation in Band 27** | 569.75d? | 2012-12-10 A | 2014-06-13 A | 100% | 2012-12-10 | 2014-06-13 | 401d? |  | R4 | 8472h | 8472h | LTE_CA_C_B27 | 30 | LTE | NII Holdings | bill.shvodian@nii.com | Rel-12 | 58 | Issam | CA | LTE_CA_C_B27 |  |
| 5682 | 1977.20.1 | Core part: LTE Advanced intra-band contiguous Carrier Aggregation in Band 27 | 261d? | 2012-12-10 A | 2013-12-06 A | 100% | 2012-12-10 | 2013-12-06 | 261d? | finish no earlier than 2013-12-06 | R4 | 2088h | 2088h | LTE_CA_C_B27-Core | 30 | 36.101; 36.104; new 36.833-1-27 | NII Holdings | bill.shvodian@nii.com | Rel-12 | 58 | Issam | CA | LTE_CA_C_B27-Core | RP-131567 |
| 5683 | 1977.20.2 | Perf part: LTE Advanced intra-band contiguous Carrier Aggregation in Band 27 | 397d? | 2012-12-14 A | 2014-06-13 A | 100% | 2012-12-14 | 2014-06-13 | 397d? | finish no earlier than 2014-06-13 | R4 | 3176h | 3176h | LTE_CA_C_B27-Perf | 30 | 36.101; 36.133; 36.141; 36.307; new 36.833-1-27 | NII Holdings | bill.shvodian@nii.com | Rel-12 | 58 | Issam | CA | LTE_CA_C_B27-Perf | RP-140569 |
| 5684 | 1977.21 | **LTE Advanced inter-band Carrier Aggregation of Band 2 and Band 13** | 106.38d? | 2013-03-04 A | 2013-06-14 A | 100% | 2013-03-04 | 2013-06-14 | 76d? |  | R4 | 1824h | 1824h | LTE_CA_B2_B13 | 30 | LTE | Ericsson | christian.bergljung@ericsson.com | Rel-12 | 59 | Issam | CA | LTE_CA_B2_B13 |  |
| 5685 | 1977.21.1 | Core part:LTE Advanced inter-band Carrier Aggregation of Band 2 and Band 13 | 76d? | 2013-03-04 A | 2013-06-14 A | 100% | 2013-03-04 | 2013-06-14 | 76d? | finish no earlier than 2013-06-14 | R4 | 608h | 608h | LTE_CA_B2_B13-Core | 30 | 36.101; 36.104; 36.133; new generic 36.851 | Ericsson | christian.bergljung@ericsson.com | Rel-12 | 59 | Issam | CA | LTE_CA_B2_B13-Core | RP-130523 |
| 5686 | 1977.21.2 | Perf. part:LTE Advanced inter-band Carrier Aggregation of Band 2 and Band 13 | 76d? | 2013-03-04 A | 2013-06-14 A | 100% | 2013-03-04 | 2013-06-14 | 76d? | finish no earlier than 2013-06-14 | R4 | 608h | 608h | LTE_CA_B2_B13-Perf | 30 | 36.101; 36.104; 36.133; 36.141; 36.307 | Ericsson | christian.bergljung@ericsson.com | Rel-12 | 59 | Issam | CA | LTE_CA_B2_B13-Perf | RP-130524 |

Notes:
- 5663: Inter-band 1 UL
- 5664: RP#60 completed
- 5665: RP#60 completed
- 5666: Inter-band 1 UL
- 5667: RP#60 completed
- 5668: RP#60 completed
- 5669: Inter-band 1UL/2DL
- 5670: RP#61 completed
- 5671: RP#61 completed
- 5672: Inter-band 2DL
- 5673: RP#63 completed. Replaces the Stopped WI - LTE Advanced inter-band Carrier Aggregation of Band 38 and Band 39 (LTE_CA_B38_B39) UID_570015
- 5674: RP#63 completed
- 5675: Inter-band CA 2DL
- 5676: RP#65 completed
- 5677: RP#63 completed
- 5678: Intra-band NC
- 5679: RP#62 completed
- 5680: RP#62 completed
- 5681: Intra-band contig. CA 2DL/1UL
- 5682: RP#62 completed
- 5683: RP#64 completed. TR 36.833-1-27v200 for Approval
- 5684: Inter-band 1 UL
- 5685: RP#60 completed
- 5686: RP#60 completed

| ID | WBS | Task | Duration | Start | Finish | Complete | Baseline start | Baseline finish | Baseline duration | Constraint | Resources | Work | Actual work | Acronym | PCG approved | Impacted TSs and TRs | WI rapporteur name | WI rapporteur e-mail | Release | TSG approved | MCC resp | Special Focus Doc | Acronym_3GU_Export | Status Report | PCG stopped | TSG stopped |
| --- | --- | --- | --- | --- | --- | --- | --- | --- | --- | --- | --- | --- | --- | --- | --- | --- | --- | --- | --- | --- | --- | --- | --- | --- | --- | --- |
| 5687 | 1977.22 | **LTE Advanced inter-band Carrier Aggregation of Band 19 and Band 21** | 106.38d? | 2013-03-04 A | 2013-06-14 A | 100% | 2013-03-04 | 2013-06-14 | 76d? |  | R4 | 1824h | 1824h | LTE_CA_B19_B21 | 30 | LTE | NTT DOCOMO | Kei ANDO | Rel-12 | 59 | Issam | CA | LTE_CA_B19_B21 |  |  |  |
| 5688 | 1977.22.1 | Core part:LTE Advanced inter-band Carrier Aggregation of Band 19 and Band 21 | 76d? | 2013-03-04 A | 2013-06-14 A | 100% | 2013-03-04 | 2013-06-14 | 76d? | finish no earlier than 2013-06-14 | R4 | 608h | 608h | LTE_CA_B19_B21-Core | 30 | 36.101; 36.104; 36.133; new generic 36.851 | NTT DOCOMO | Kei ANDO | Rel-12 | 59 | Issam | CA | LTE_CA_B19_B21-Core | RP-130533 |  |  |
| 5689 | 1977.22.2 | Perf. part:LTE Advanced inter-band Carrier Aggregation of Band 19 and Band 21 | 76d? | 2013-03-04 A | 2013-06-14 A | 100% | 2013-03-04 | 2013-06-14 | 76d? | finish no earlier than 2013-06-14 | R4 | 608h | 608h | LTE_CA_B19_B21-Perf | 30 | 36.141; 36.307 | NTT DOCOMO | Kei ANDO | Rel-12 | 59 | Issam | CA | LTE_CA_B19_B21-Perf | RP-130534 |  |  |
| 5690 | 1977.23 | **Deleted -LTE Advanced inter-band Carrier Aggregation of Band 8 and Band 26** | 287.25d? | 2013-03-04 A | 2013-12-06 A | 100% | 2013-03-04 | 2013-12-06 | 204d? |  | R4 | 4848h | 4848h | LTE_CA_B8_B26 | 30 | LTE | KT | Chungwoo HWANG (cwhwang@kt.com) | Rel-12 | 59 | Issam | CA | LTE_CA_B8_B26 |  | PCG-32 | RP-62 |
| 5691 | 1977.23.1 | Deleted - Core part:LTE Advanced inter-band Carrier Aggregation of Band 8 and Band 26 | 201d? | 2013-03-04 A | 2013-12-06 A | 100% | 2013-03-04 | 2013-12-06 | 201d? | finish no earlier than 2013-12-06 | R4 | 1608h | 1608h | LTE_CA_B8_B26-Core | 30 | 36.101; 36.104; 36.133; new generic 36.851 | KT | Chungwoo HWANG (cwhwang@kt.com) | Rel-12 | 59 | Issam | CA | LTE_CA_B8_B26-Core | RP-131549 | PCG-32 | RP-62 |
| 5692 | 1977.23.2 | Deleted - Perf. part:LTE Advanced inter-band Carrier Aggregation of Band 8 and Band 26 | 201d? | 2013-03-04 A | 2013-12-06 A | 100% | 2013-03-04 | 2013-12-06 | 201d? | finish no earlier than 2013-12-06 | R4 | 1608h | 1608h | LTE_CA_B8_B26-Perf | 30 | 36.141; 36.307 | KT | Chungwoo HWANG (cwhwang@kt.com) | Rel-12 | 59 | Issam | CA | LTE_CA_B8_B26-Perf | RP-131550 | PCG-32 | RP-62 |
| 5693 | 1977.24 | **LTE Advanced dual uplink inter-band Carrier Aggregation Class A1** | 674.25d? | 2013-03-04 A | 2014-12-15 A | 100% | 2013-03-04 | 2014-09-12 | 405d? |  | R4 | 11272h | 11272h | LTE_CA_2UL-A1 | 30 | LTE | Huawei | Liu Ye (leo.liuye@huawei.com) | Rel-12 | 59 | Issam | CA | LTE_CA_2UL-A1 |  |  |  |
| 5694 | 1977.24.1 | Core part:LTE Advanced dual uplink inter-band Carrier Aggregation Class A1 | 468d? | 2013-03-04 A | 2014-12-15 A | 100% | 2013-03-04 | 2014-09-12 | 402d? | finish no earlier than 2014-12-15 | R4 | 3744h | 3744h | LTE_CA_2UL-A1-Core | 30 | 36.101; 36.104; New generic 36.860 | Huawei | Liu Ye (leo.liuye@huawei.com) | Rel-12 | 59 | Issam | CA | LTE_CA_2UL-A1-Core | RP-141732 |  |  |
| 5695 | 1977.24.2 | Perf. part:LTE Advanced dual uplink inter-band Carrier Aggregation Class A1 | 467d? | 2013-03-13 A | 2014-12-15 A | 100% | 2013-03-08 | 2014-09-12 | 401d? | finish no earlier than 2014-12-15 | R4 | 3736h | 3736h | LTE_CA_2UL-A1-Perf | 30 | 36.133 | Huawei | Liu Ye (leo.liuye@huawei.com) | Rel-12 | 59 | Issam | CA | LTE_CA_2UL-A1-Perf | RP-141732 |  |  |
| 5696 | 1977.25 | **LTE Advanced dual uplink inter-band Carrier Aggregation Class A2** | 674.25d? | 2013-03-04 A | 2014-12-15 A | 100% | 2013-03-04 | 2014-09-12 | 405d? |  | R4 | 11272h | 11272h | LTE_CA_2UL-A2 | 30 | LTE | Qualcomm | Gene Fong (gfong@qti.qualcomm.com) | Rel-12 | 59 | Issam | CA | LTE_CA_2UL-A2 |  |  |  |
| 5697 | 1977.25.1 | Core part:LTE Advanced dual uplink inter-band Carrier Aggregation Class A2 | 468d? | 2013-03-04 A | 2014-12-15 A | 100% | 2013-03-04 | 2014-09-12 | 402d? | finish no earlier than 2014-12-15 | R4 | 3744h | 3744h | LTE_CA_2UL-A2-Core | 30 | 36.101; 36.104; 36.133; New generic 36.860 | Qualcomm | Gene Fong (gfong@qti.qualcomm.com) | Rel-12 | 59 | Issam | CA | LTE_CA_2UL-A2-Core | RP-141732 |  |  |
| 5698 | 1977.25.2 | Perf. part:LTE Advanced dual uplink inter-band Carrier Aggregation Class A2 | 467d? | 2013-03-13 A | 2014-12-15 A | 100% | 2013-03-08 | 2014-09-12 | 401d? | finish no earlier than 2014-12-15 | R4 | 3736h | 3736h | LTE_CA_2UL-A2-Perf | 30 | 36.141; 36.307 | Qualcomm | Gene Fong (gfong@qti.qualcomm.com) | Rel-12 | 59 | Issam | CA | LTE_CA_2UL-A2-Perf | RP-141732 |  |  |
| 5699 | 1977.26 | **LTE Advanced dual uplink inter-band Carrier Aggregation Class A3** | 674.25d? | 2013-03-04 A | 2014-12-15 A | 100% | 2013-03-04 | 2014-09-12 | 405d? |  | R4 | 11264h | 11264h | LTE_CA_2UL-A3 | 30 | LTE | Ericsson | christian.bergljung@ericsson.com | Rel-12 | 59 | Issam | CA | LTE_CA_2UL-A3 |  |  |  |
| 5700 | 1977.26.1 | Core part:LTE Advanced dual uplink inter-band Carrier Aggregation Class A3 | 467d? | 2013-03-04 A | 2014-12-15 A | 100% | 2013-03-04 | 2014-09-12 | 401d? | finish no earlier than 2014-12-15 | R4 | 3736h | 3736h | LTE_CA_2UL-A3-Core | 30 | 36.101; 36.104; 36.133; New generic 36.860 | Ericsson | christian.bergljung@ericsson.com | Rel-12 | 59 | Issam | CA | LTE_CA_2UL-A3-Core | RP-141732 |  |  |
| 5701 | 1977.26.2 | Perf. part:LTE Advanced dual uplink inter-band Carrier Aggregation Class A3 | 467d? | 2013-03-13 A | 2014-12-15 A | 100% | 2013-03-08 | 2014-09-12 | 401d? | finish no earlier than 2014-12-15 | R4 | 3736h | 3736h | LTE_CA_2UL-A3-Perf | 30 | 36.141; 36.307 | Ericsson | christian.bergljung@ericsson.com | Rel-12 | 59 | Issam | CA | LTE_CA_2UL-A3-Perf | RP-141732 |  |  |
| 5702 | 1977.27 | **LTE Advanced dual uplink inter-band Carrier Aggregation Class A4** | 674.25d? | 2013-03-04 A | 2014-12-15 A | 100% | 2013-03-04 | 2014-09-12 | 405d? |  | R4 | 11272h | 11272h | LTE_CA_2UL-A4 | 30 | LTE | Nokia | petri.j.vasenkari@nokia.com | Rel-12 | 59 | Issam | CA | LTE_CA_2UL-A4 |  |  |  |
| 5703 | 1977.27.1 | Core part:LTE Advanced dual uplink inter-band Carrier Aggregation Class A4 | 468d? | 2013-03-04 A | 2014-12-15 A | 100% | 2013-03-04 | 2014-09-12 | 402d? | finish no earlier than 2014-12-15 | R4 | 3744h | 3744h | LTE_CA_2UL-A4-Core | 30 | 36.101; 36.104; 36.133; New generic 36.860 | Nokia | petri.j.vasenkari@nokia.com | Rel-12 | 59 | Issam | CA | LTE_CA_2UL-A4-Core | RP-141732 |  |  |
| 5704 | 1977.27.2 | Perf. part:LTE Advanced dual uplink inter-band Carrier Aggregation Class A4 | 467d? | 2013-03-13 A | 2014-12-15 A | 100% | 2013-03-08 | 2014-09-12 | 401d? | finish no earlier than 2014-12-15 | R4 | 3736h | 3736h | LTE_CA_2UL-A4-Perf | 30 | 36.141; 36.307 | Nokia | petri.j.vasenkari@nokia.com | Rel-12 | 59 | Issam | CA | LTE_CA_2UL-A4-Perf | RP-141732 |  |  |
| 5705 | 1977.28 | **LTE Advanced dual uplink inter-band Carrier Aggregation Class A5** | 674.25d? | 2013-03-04 A | 2014-12-15 A | 100% | 2013-03-04 | 2014-09-12 | 405d? |  | R4 | 11264h | 11264h | LTE_CA_2UL-A5 | 30 | LTE | NTT DOCOMO | kei.andou.ye@nttdocomo.com | Rel-12 | 59 | Issam | CA | LTE_CA_2UL-A5 |  |  |  |
| 5706 | 1977.28.1 | Core part:LTE Advanced dual uplink inter-band Carrier Aggregation Class A5 | 467d? | 2013-03-04 A | 2014-12-15 A | 100% | 2013-03-04 | 2014-09-12 | 401d? | finish no earlier than 2014-12-15 | R4 | 3736h | 3736h | LTE_CA_2UL-A5-Core | 30 | 36.101; 36.104; 36.133; New generic 36.860 | NTT DOCOMO | kei.andou.ye@nttdocomo.com | Rel-12 | 59 | Issam | CA | LTE_CA_2UL-A5-Core | RP-141732 |  |  |
| 5707 | 1977.28.2 | Perf. part:LTE Advanced dual uplink inter-band Carrier Aggregation Class A5 | 467d? | 2013-03-13 A | 2014-12-15 A | 100% | 2013-03-08 | 2014-09-12 | 401d? | finish no earlier than 2014-12-15 | R4 | 3736h | 3736h | LTE_CA_2UL-A5-Perf | 30 | 36.141; 36.307 | NTT DOCOMO | kei.andou.ye@nttdocomo.com | Rel-12 | 59 | Issam | CA | LTE_CA_2UL-A5-Perf | RP-141732 |  |  |
| 5708 | 1977.29 | **LTE Advanced intra-band contiguous Carrier Aggregation in Band 39** | 380.38d? | 2013-03-04 A | 2014-03-06 A | 100% | 2013-03-04 | 2014-03-06 | 269d? |  | R4 | 6400h | 6400h | LTE_CA_C_B39 | 30 | LTE | China Mobile | Li Nan (linan@chinamobile.com) | Rel-12 | 59 | Issam | CA | LTE_CA_C_B39 |  |  |  |
| 5709 | 1977.29.1 | Core part: LTE Advanced intra-band contiguous Carrier Aggregation in Band 39 | 266d? | 2013-03-04 A | 2014-03-06 A | 100% | 2013-03-04 | 2014-03-06 | 266d? | finish no earlier than 2014-03-06 | R4 | 2128h | 2128h | LTE_CA_C_B39-Core | 30 | 36.101; 36.104; 36.133; New 36.833-1-39 [instead of 36.845] | China Mobile | Li Nan (linan@chinamobile.com) | Rel-12 | 59 | Issam | CA | LTE_CA_C_B39-Core | RP-140428 |  |  |
| 5710 | 1977.29.2 | Perf. part: LTE Advanced intra-band contiguous Carrier Aggregation in Band 39 | 265d? | 2013-03-07 A | 2014-03-06 A | 100% | 2013-03-07 | 2014-03-06 | 265d? | finish no earlier than 2014-03-06 | R4 | 2120h | 2120h | LTE_CA_C_B39-Perf | 30 | 36.141; 36.307 | China Mobile | Li Nan (linan@chinamobile.com) | Rel-12 | 59 | Issam | CA | LTE_CA_C_B39-Perf | RP-140428 |  |  |

Notes:
- 5687: Inter-band 1 UL
- 5688: RP#60 completed
- 5689: RP#60 completed
- 5690: Inter-band 1 UL
- 5691: RP#62 stopped (at 20%)
- 5692: RP#62 stopped (at 20%)
- 5693: Inter-band CA 2UL
- 5694: ¦WID: RP-142043->RP-141941¦Stat Rep: RP-141084->RP-141732
- 5695: ¦WID: RP-142043->RP-141941¦Stat Rep: RP-141084->RP-141732
- 5696: Inter-band CA 2UL
- 5697: ¦Stat Rep: RP-141084->RP-141732
- 5698: ¦Stat Rep: RP-141084->RP-141732
- 5699: Inter-band CA 2UL
- 5700: ¦Stat Rep: RP-141084->RP-141732
- 5701: ¦Stat Rep: RP-141084->RP-141732
- 5702: Inter-band CA 2UL. RP#65 updated WID RP-140476=>RP-141160.
- 5703: ¦WID: RP-142043->RP-141967¦Stat Rep: RP-141084->RP-141732
- 5704: ¦WID: RP-142043->RP-141967¦Stat Rep: RP-141084->RP-141732
- 5705: Inter-band CA 2UL. RP#65 updated WID RP-131146=>RP-141195. Changed Rapp Renesas=>Broadcom=>NTT DOCOMO
- 5706: ¦Stat Rep: RP-141084->RP-141732
- 5707: ¦Stat Rep: RP-141084->RP-141732
- 5708: Intra-band C 2DL/2UL
- 5709: RP#63 completed
- 5710: RP#63 completed

| ID | WBS | Task | Duration | Start | Finish | Complete | Baseline start | Baseline finish | Baseline duration | Constraint | Resources | Work | Actual work | Acronym | PCG approved | WI rapporteur name | WI rapporteur e-mail | Release | TSG approved | MCC resp | Special Focus Doc | Acronym_3GU_Export | Status Report | PCG stopped | TSG stopped |
| --- | --- | --- | --- | --- | --- | --- | --- | --- | --- | --- | --- | --- | --- | --- | --- | --- | --- | --- | --- | --- | --- | --- | --- | --- | --- |
| 5711 | 1977.30 | **LTE Advanced intra-band non-contiguous Carrier Aggregation: framework requirements for 2UL** | 564.62d? | 2013-06-18 A | 2014-12-15 A | 100% | 2013-06-18 | 2014-09-12 | 328d? |  | R4 | 6328h | 6328h | LTE_CA_NC_2UL | 31 | Nokia | petri.j.vasenkari@nokia.com | Rel-12 | 60 | Issam | CA | LTE_CA_NC_2UL |  |  |  |
| 5712 | 1977.30.1 | Core part:LTE Advanced intra-band non-contiguous Carrier Aggregation: framework requirements for 2UL | 394d? | 2013-06-18 A | 2014-12-15 A | 100% | 2013-06-18 | 2014-09-12 | 328d? | finish no earlier than 2014-12-15 | R4 | 3152h | 3152h | LTE_CA_NC_2UL-Core | 31 | Nokia | petri.j.vasenkari@nokia.com | Rel-12 | 60 | Issam | CA | LTE_CA_NC_2UL-Core | RP-141732 |  |  |
| 5713 | 1977.31 | **Deleted -LTE Advanced intra-band non-contiguous Carrier Aggregation in Band 41 for 2UL** | 269.75d? | 2013-06-19 A | 2014-03-06 A | 100% | 2013-06-19 | 2014-03-06 | 191d? |  | R4 | 4576h | 4576h | LTE_CA_NC_B41_2UL | 31 | Sprint | yang.xu@clearwire.com | Rel-12 | 60 | Issam | CA | LTE_CA_NC_B41_2UL | RP-140428 | PCG-32 | RP-63 |
| 5714 | 1977.31.1 | Deleted - Core part:LTE Advanced intra-band non-contiguous Carrier Aggregation in Band 41 for 2UL | 191d? | 2013-06-19 A | 2014-03-06 A | 100% | 2013-06-19 | 2014-03-06 | 191d? | finish no earlier than 2014-03-06 | R4 | 1528h | 1528h | LTE_CA_NC_B41_2UL-Core | 31 | Sprint | yang.xu@clearwire.com | Rel-12 | 60 | Issam | CA | LTE_CA_NC_B41_2UL-Core | RP-140428 | PCG-32 | RP-63 |
| 5715 | 1977.31.2 | Deleted - Perf. part:LTE Advanced intra-band non-contiguous Carrier Aggregation in Band 41 for 2UL | 190d? | 2013-06-20 A | 2014-03-06 A | 100% | 2013-06-20 | 2014-03-06 | 190d? | finish no earlier than 2014-03-06 | R4 | 1520h | 1520h | LTE_CA_NC_B41_2UL-Perf | 31 | Sprint | yang.xu@clearwire.com | Rel-12 | 60 | Issam | CA | LTE_CA_NC_B41_2UL-Perf | RP-140428 | PCG-32 | RP-63 |
| 5716 | 1977.32 | **LTE Advanced intra-band non-contiguous Carrier Aggregation in Band 4 for 2UL** | 563.62d? | 2013-06-19 A | 2014-12-15 A | 100% | 2013-06-19 | 2014-09-12 | 327d? |  | R4 | 9448h | 9448h | LTE_CA_NC_B4_2UL | 31 | T-Mobile USA | nelson.ueng@t-mobile.com | Rel-12 | 60 | Issam | CA | LTE_CA_NC_B4_2UL |  |  |  |
| 5717 | 1977.32.1 | Core part:LTE Advanced intra-band non-contiguous Carrier Aggregation in Band 4 for 2UL | 393d? | 2013-06-19 A | 2014-12-15 A | 100% | 2013-06-19 | 2014-09-12 | 327d? | finish no earlier than 2014-12-15 | R4 | 3144h | 3144h | LTE_CA_NC_B4_2UL-Core | 31 | T-Mobile USA | nelson.ueng@t-mobile.com | Rel-12 | 60 | Issam | CA | LTE_CA_NC_B4_2UL-Core | RP-141732 |  |  |
| 5718 | 1977.32.2 | Perf. part:LTE Advanced intra-band non-contiguous Carrier Aggregation in Band 4 for 2UL | 392d? | 2013-06-25 A | 2014-12-15 A | 100% | 2013-06-20 | 2014-09-12 | 326d? | finish no earlier than 2014-12-15 | R4 | 3136h | 3136h | LTE_CA_NC_B4_2UL-Perf | 31 | T-Mobile USA | nelson.ueng@t-mobile.com | Rel-12 | 60 | Issam | CA | LTE_CA_NC_B4_2UL-Perf | RP-141732 |  |  |
| 5719 | 1977.33 | **LTE Advanced intra-band contiguous Carrier Aggregation in Band 23** | 177.62d? | 2013-06-18 A | 2013-12-06 A | 100% | 2013-06-18 | 2013-12-06 | 127d? |  | R4 | 3032h | 3032h | LTE_CA_C_B23 | 31 | Dish Network | mariam.sorond@dish.com, johny.kim@dish.com | Rel-12 | 60 | Issam | CA | LTE_CA_C_B23 |  |  |  |
| 5720 | 1977.33.1 | Core part: LTE Advanced intra-band contiguous Carrier Aggregation in Band 23 | 126d? | 2013-06-18 A | 2013-12-06 A | 100% | 2013-06-18 | 2013-12-06 | 126d? | finish no earlier than 2013-12-06 | R4 | 1008h | 1008h | LTE_CA_C_B23-Core | 31 | Dish Network | mariam.sorond@dish.com, johny.kim@dish.com | Rel-12 | 60 | Issam | CA | LTE_CA_C_B23-Core | RP-131565 |  |  |
| 5721 | 1977.33.2 | Perf. part: LTE Advanced intra-band contiguous Carrier Aggregation in Band 23 | 126d? | 2013-06-18 A | 2013-12-06 A | 100% | 2013-06-18 | 2013-12-06 | 126d? | finish no earlier than 2013-12-06 | R4 | 1008h | 1008h | LTE_CA_C_B23-Perf | 31 | Dish Network | mariam.sorond@dish.com, johny.kim@dish.com | Rel-12 | 60 | Issam | CA | LTE_CA_C_B23-Perf | RP-131566 |  |  |
| 5722 | 1977.34 | **LTE Advanced intra-band non-contiguous Carrier Aggregation in Band 23** | 373.25d? | 2013-06-18 A | 2014-06-13 A | 100% | 2013-06-18 | 2014-06-13 | 263d? |  | R4 | 5216h | 5216h | LTE_CA_NC_B23 | 31 | Dish Network | mariam.sorond@dish.com, johny.kim@dish.com | Rel-12 | 60 | Issam | CA | LTE_CA_NC_B23 |  |  |  |
| 5723 | 1977.34.1 | Core part:LTE Advanced intra-band non-contiguous Carrier Aggregation in Band 23 | 126d? | 2013-06-18 A | 2013-12-06 A | 100% | 2013-06-18 | 2013-12-06 | 126d? | finish no earlier than 2013-12-06 | R4 | 1008h | 1008h | LTE_CA_NC_B23-Core | 31 | Dish Network | mariam.sorond@dish.com, johny.kim@dish.com | Rel-12 | 60 | Issam | CA | LTE_CA_NC_B23-Core | RP-131577 |  |  |
| 5724 | 1977.34.2 | Perf. part:LTE Advanced intra-band non-contiguous Carrier Aggregation in Band 23 | 263d? | 2013-06-18 A | 2014-06-13 A | 100% | 2013-06-18 | 2014-06-13 | 263d? | finish no earlier than 2014-06-13 | R4 | 2104h | 2104h | LTE_CA_NC_B23-Perf | 31 | Dish Network | mariam.sorond@dish.com, johny.kim@dish.com | Rel-12 | 60 | Issam | CA | LTE_CA_NC_B23-Perf | RP-140569 |  |  |
| 5725 | 1977.35 | **LTE Advanced inter-band Carrier Aggregation of Band 12 and Band 25** | 177.62d? | 2013-06-18 A | 2013-12-06 A | 100% | 2013-06-18 | 2013-12-06 | 127d? |  | R4 | 3032h | 3032h | LTE_CA_B12_B25 | 31 | US Cellular | sebastian.thalanany@uscellular.com | Rel-12 | 60 | Issam | CA | LTE_CA_B12_B25 |  |  |  |
| 5726 | 1977.35.1 | Core part:LTE Advanced inter-band Carrier Aggregation of Band 12 and Band 25 | 126d? | 2013-06-18 A | 2013-12-06 A | 100% | 2013-06-18 | 2013-12-06 | 126d? | finish no earlier than 2013-12-06 | R4 | 1008h | 1008h | LTE_CA_B12_B25-Core | 31 | US Cellular | sebastian.thalanany@uscellular.com | Rel-12 | 60 | Issam | CA | LTE_CA_B12_B25-Core | RP-131705 |  |  |
| 5727 | 1977.35.2 | Perf. part:LTE Advanced inter-band Carrier Aggregation of Band 12 and Band 25 | 126d? | 2013-06-19 A | 2013-12-06 A | 100% | 2013-06-19 | 2013-12-06 | 126d? | finish no earlier than 2013-12-06 | R4 | 1008h | 1008h | LTE_CA_B12_B25-Perf | 31 | US Cellular | sebastian.thalanany@uscellular.com | Rel-12 | 60 | Issam | CA | LTE_CA_B12_B25-Perf | RP-131706 |  |  |
| 5728 | 1977.36 | **LTE Advanced inter-band Carrier Aggregation of Band 1 and Band 18 - Additional bandwidth combination set** | 83.5d? | 2013-06-18 A | 2013-09-06 A | 100% | 2013-06-18 | 2013-09-06 | 61d? |  | R4 | 1464h | 1464h | LTE_CA_B1_B18_BWset | 31 | KDDI | Masaaki Obara (ms-obara@kddi.com) | Rel-12 | 60 | Issam | CA | LTE_CA_B1_B18_BWset |  |  |  |
| 5729 | 1977.36.1 | Core part:LTE Advanced inter-band Carrier Aggregation of Band 1 and Band 18 - Additional bandwidth combination set | 61d? | 2013-06-18 A | 2013-09-06 A | 100% | 2013-06-18 | 2013-09-06 | 61d? | finish no earlier than 2013-09-06 | R4 | 488h | 488h | LTE_CA_B1_B18_BWset-Core | 31 | KDDI | Masaaki Obara (ms-obara@kddi.com) | Rel-12 | 60 | Issam | CA | LTE_CA_B1_B18_BWset-Core | RP-131003 |  |  |
| 5730 | 1977.36.2 | Perf. part:LTE Advanced inter-band Carrier Aggregation of Band 1 and Band 18 - Additional bandwidth combination set | 61d? | 2013-06-18 A | 2013-09-06 A | 100% | 2013-06-18 | 2013-09-06 | 61d? | finish no earlier than 2013-09-06 | R4 | 488h | 488h | LTE_CA_B1_B18_BWset-Perf | 31 | KDDI | Masaaki Obara (ms-obara@kddi.com) | Rel-12 | 60 | Issam | CA | LTE_CA_B1_B18_BWset-Perf | RP-131004 |  |  |
| 5731 | 1977.37 | **LTE Advanced inter-band Carrier Aggregation of Band 2 and Band 5** | 83.5d? | 2013-06-18 A | 2013-09-06 A | 100% | 2013-06-18 | 2013-09-06 | 61d? |  | R4 | 1464h | 1464h | LTE_CA_B2_B5 | 31 | AT&T | marc.grant@att.com | Rel-12 | 60 | Issam | CA | LTE_CA_B2_B5 |  |  |  |
| 5732 | 1977.37.1 | Core part:LTE Advanced inter-band Carrier Aggregation of Band 2 and Band 5 | 61d? | 2013-06-18 A | 2013-09-06 A | 100% | 2013-06-18 | 2013-09-06 | 61d? | finish no earlier than 2013-09-06 | R4 | 488h | 488h | LTE_CA_B2_B5-Core | 31 | AT&T | marc.grant@att.com | Rel-12 | 60 | Issam | CA | LTE_CA_B2_B5-Core | RP-131009 |  |  |
| 5733 | 1977.37.2 | Perf. part:LTE Advanced inter-band Carrier Aggregation of Band 2 and Band 5 | 61d? | 2013-06-18 A | 2013-09-06 A | 100% | 2013-06-18 | 2013-09-06 | 61d? | finish no earlier than 2013-12-06 | R4 | 488h | 488h | LTE_CA_B2_B5-Perf | 31 | AT&T | marc.grant@att.com | Rel-12 | 60 | Issam | CA | LTE_CA_B2_B5-Perf | RP-131010 |  |  |
| 5734 | 1977.38 | **LTE Advanced 3 Band Carrier Aggregation (3DL/1UL) of Band 2, Band 5 and Band 30** | 467.38d? | 2013-06-18 A | 2014-09-12 A | 100% | 2013-06-18 | 2014-09-12 | 328d? |  | R4 | 7872h | 7872h | LTE_CA_B2_B5_B30 | 31 | AT&T | marc.grant@att.com | Rel-12 | 60 | Issam | CA | LTE_CA_B2_B5_B30 |  |  |  |
| 5735 | 1977.38.1 | Core part:LTE Advanced 3 Band Carrier Aggregation (3DL/1UL) of Band 2, Band 5 and Band 30 | 328d? | 2013-06-18 A | 2014-09-12 A | 100% | 2013-06-18 | 2014-09-12 | 328d? | finish no earlier than 2014-09-12 | R4 | 2624h | 2624h | LTE_CA_B2_B5_B30-Core | 31 | AT&T | marc.grant@att.com | Rel-12 | 60 | Issam | CA | LTE_CA_B2_B5_B30-Core | RP-141084 |  |  |
| 5736 | 1977.38.2 | Perf. part:LTE Advanced 3 Band Carrier Aggregation (3DL/1UL) of Band 2, Band 5 and Band 30 | 327d? | 2013-06-18 A | 2014-09-12 A | 100% | 2013-06-18 | 2014-09-12 | 327d? | finish no earlier than 2014-09-12 | R4 | 2616h | 2616h | LTE_CA_B2_B5_B30-Perf | 31 | AT&T | marc.grant@att.com | Rel-12 | 60 | Issam | CA | LTE_CA_B2_B5_B30-Perf | RP-141084 |  |  |

Notes:
- 5711: Intra-band non-contig. CA 2DL / Impacted TSs and TRs: LTE
- 5712: ¦WID: RP-142043->RP-141962¦Stat Rep: RP-141084->RP-141732 / Impacted TSs and TRs: 36.101; 36.104; 36.133; 36.306; 36.331; New 36.833-4
- 5713: Intra-band NC 2UL / Impacted TSs and TRs: LTE
- 5714: RP#63 stopped (5% complete). Reason: Market conditions have eliminated the need for this feature, at least for the foreseeable future / Impacted TSs and TRs: 36.101; 36.104; 36.133; new 36.833-3-41
- 5715: RP#63 stopped (0% complete). / Impacted TSs and TRs: 36.101; 36.104; 36.133; 36.141; 36.307
- 5716: Intra-band non-contig. CA 2DL / Impacted TSs and TRs: LTE
- 5717: ¦WID: RP-142043->RP-141784¦Stat Rep: RP-141084->RP-141732 / Impacted TSs and TRs: 36.101; 36.104; 36.133; new 36.833-4-04
- 5718: ¦WID: RP-142043->RP-141784¦Stat Rep: RP-141084->RP-141732 / Impacted TSs and TRs: 36.101; 36.104; 36.133; 36.141; 36.307
- 5719: Intra-band C CA / Impacted TSs and TRs: LTE
- 5720: RP#62 completed / Impacted TSs and TRs: 36.101; 36.104; 36.133; new 36.833-1-23 [instead of 36.864]
- 5721: RP#62 completed / Impacted TSs and TRs: 36.141; 36.307
- 5722: Intra-band non-contig. CA 2DL / Impacted TSs and TRs: LTE
- 5723: RP#62 completed / Impacted TSs and TRs: 36.101; 36.104; 36.133; new 36.833-2-23
- 5724: RP#64 completed. TR 36.833-2-23v200 for Approval / Impacted TSs and TRs: 36.101; 36.133; 36.141; 36.307; new 36.833-2-23
- 5725: Inter-band 1UL/2DL / Impacted TSs and TRs: LTE
- 5726: RP#62 completed / Impacted TSs and TRs: 36.101; 36.104; 36.133; new generic 36.851
- 5727: RP#62 completed / Impacted TSs and TRs: 36.141; 36.307
- 5728: Inter-band 1UL/2DL / Impacted TSs and TRs: LTE
- 5729: RP#61 completed / Impacted TSs and TRs: 36.101; new generic 36.851
- 5730: RP#61 completed / Impacted TSs and TRs: 36.307
- 5731: Inter-band 2DL / Impacted TSs and TRs: LTE
- 5732: RP#61 completed / Impacted TSs and TRs: 36.101; 36.104; 36.307
- 5733: RP#61 completed / Impacted TSs and TRs: 36.101; 36.104; 36.133; 36.141; 36.307
- 5734: Inter-band 3DL / Impacted TSs and TRs: LTE
- 5735: RP#65 completed. TR 36.853v200 for Approval / Impacted TSs and TRs: 36.101; 36.104; 36.133; 36.141; 36.307; new generic 36.853 (3 Band CA with 1UL)
- 5736: RP#65 completed / Impacted TSs and TRs: 36.101; 36.104; 36.133; 36.141; 36.307

| ID | WBS | Task | Duration | Start | Finish | Complete | Baseline start | Baseline finish | Baseline duration | Constraint | Resources | Work | Actual work | Acronym | PCG approved | WI rapporteur name | WI rapporteur e-mail | Release | TSG approved | MCC resp | PCG stopped | TSG stopped | Special Focus Doc | Acronym_3GU_Export | Status Report |
| --- | --- | --- | --- | --- | --- | --- | --- | --- | --- | --- | --- | --- | --- | --- | --- | --- | --- | --- | --- | --- | --- | --- | --- | --- | --- |
| 5737 | 1977.39 | **Deleted -LTE Advanced 3 Band Carrier Aggregation (3DL/1UL) of Band 2, Band 17 and Band 30** | 177.62d? | 2013-06-18 A | 2013-12-06 A | 100% | 2013-06-18 | 2013-12-06 | 127d? |  | R4 | 3024h | 3024h | LTE_CA_B2_B17_B30 | 31 | AT&T | marc.grant@att.com | Rel-12 | 60 | Issam | PCG-32 | RP-62 | CA | LTE_CA_B2_B17_B30 |  |
| 5738 | 1977.39.1 | Deleted - Core part:LTE Advanced 3 Band Carrier Aggregation (3DL/1UL) of Band 2, Band 17 and Band 30 | 126d? | 2013-06-18 A | 2013-12-06 A | 100% | 2013-06-18 | 2013-12-06 | 126d? | finish no earlier than 2014-06-13 | R4 | 1008h | 1008h | LTE_CA_B2_B17_B30-Core | 31 | AT&T | marc.grant@att.com | Rel-12 | 60 | Issam | PCG-32 | RP-62 | CA | LTE_CA_B2_B17_B30-Core | RP-131590 |
| 5739 | 1977.39.2 | Deleted - Perf. part:LTE Advanced 3 Band Carrier Aggregation (3DL/1UL) of Band 2, Band 17 and Band 30 | 125d? | 2013-06-19 A | 2013-12-06 A | 100% | 2013-06-19 | 2013-12-06 | 125d? | finish no earlier than 2014-09-12 | R4 | 1000h | 1000h | LTE_CA_B2_B17_B30-Perf | 31 | AT&T | marc.grant@att.com | Rel-12 | 60 | Issam | PCG-32 | RP-62 | CA | LTE_CA_B2_B17_B30-Perf | RP-131591 |
| 5740 | 1977.40 | **LTE Advanced 3 Band Carrier Aggregation (3DL/1UL) of Band 2, Band 29 and Band 30** | 466.38d? | 2013-06-19 A | 2014-09-12 A | 100% | 2013-06-19 | 2014-09-12 | 327d? |  | R4 | 7856h | 7856h | LTE_CA_B2_B29_B30 | 31 | AT&T | marc.grant@att.com | Rel-12 | 60 | Issam |  |  | CA | LTE_CA_B2_B29_B30 |  |
| 5741 | 1977.40.1 | Core part:LTE Advanced 3 Band Carrier Aggregation (3DL/1UL) of Band 2, Band 29 and Band 30 | 327d? | 2013-06-19 A | 2014-09-12 A | 100% | 2013-06-19 | 2014-06-13 | 262d? | finish no earlier than 2014-09-12 | R4 | 2616h | 2616h | LTE_CA_B2_B29_B30-Core | 31 | AT&T | marc.grant@att.com | Rel-12 | 60 | Issam |  |  | CA | LTE_CA_B2_B29_B30-Core | RP-141084 |
| 5742 | 1977.40.2 | Perf. part:LTE Advanced 3 Band Carrier Aggregation (3DL/1UL) of Band 2, Band 29 and Band 30 | 327d? | 2013-06-19 A | 2014-09-12 A | 100% | 2013-06-19 | 2014-09-12 | 327d? | finish no earlier than 2014-09-12 | R4 | 2616h | 2616h | LTE_CA_B2_B29_B30-Perf | 31 | AT&T | marc.grant@att.com | Rel-12 | 60 | Issam |  |  | CA | LTE_CA_B2_B29_B30-Perf | RP-141084 |
| 5743 | 1977.41 | **LTE Advanced 3 Band Carrier Aggregation (3DL/1UL) of Band 4, Band 5 and Band 30** | 471.62d? | 2013-06-14 A | 2014-09-12 A | 100% | 2013-06-14 | 2014-09-12 | 330d? |  | R4 | 7904h | 7904h | LTE_CA_B4_B5_B30 | 31 | AT&T | marc.grant@att.com | Rel-12 | 60 | Issam |  |  | CA | LTE_CA_B4_B5_B30 |  |
| 5744 | 1977.41.1 | Core part:LTE Advanced 3 Band Carrier Aggregation (3DL/1UL) of Band 4, Band 5 and Band 30 | 330d? | 2013-06-14 A | 2014-09-12 A | 100% | 2013-06-14 | 2014-09-12 | 330d? | finish no earlier than 2014-09-12 | R4 | 2640h | 2640h | LTE_CA_B4_B5_B30-Core | 31 | AT&T | marc.grant@att.com | Rel-12 | 60 | Issam |  |  | CA | LTE_CA_B4_B5_B30-Core | RP-141084 |
| 5745 | 1977.41.2 | Perf. part:LTE Advanced 3 Band Carrier Aggregation (3DL/1UL) of Band 4, Band 5 and Band 30 | 327d? | 2013-06-19 A | 2014-09-12 A | 100% | 2013-06-19 | 2014-09-12 | 327d? | finish no earlier than 2014-09-12 | R4 | 2616h | 2616h | LTE_CA_B4_B5_B30-Perf | 31 | AT&T | marc.grant@att.com | Rel-12 | 60 | Issam |  |  | CA | LTE_CA_B4_B5_B30-Perf | RP-141084 |
| 5746 | 1977.42 | **Deleted -LTE Advanced 3 Band Carrier Aggregation (3DL/1UL) of Band 4, Band 17 and Band 30** | 177.62d? | 2013-06-18 A | 2013-12-06 A | 100% | 2013-06-18 | 2013-12-06 | 127d? |  | R4 | 3040h | 3040h | LTE_CA_B4_B17_B30 | 31 | AT&T | marc.grant@att.com | Rel-12 | 60 | Issam | PCG-32 | RP-62 | CA | LTE_CA_B4_B17_B30 |  |
| 5747 | 1977.42.1 | Deleted - Core part:LTE Advanced 3 Band Carrier Aggregation (3DL/1UL) of Band 4, Band 17 and Band 30 | 127d? | 2013-06-18 A | 2013-12-06 A | 100% | 2013-06-18 | 2013-12-06 | 127d? | finish no earlier than 2013-12-06 | R4 | 1016h | 1016h | LTE_CA_B4_B17_B30-Core | 31 | AT&T | marc.grant@att.com | Rel-12 | 60 | Issam | PCG-32 | RP-62 | CA | LTE_CA_B4_B17_B30-Core | RP-131598 |
| 5748 | 1977.42.2 | Deleted - Perf. part:LTE Advanced 3 Band Carrier Aggregation (3DL/1UL) of Band 4, Band 17 and Band 30 | 126d? | 2013-06-19 A | 2013-12-06 A | 100% | 2013-06-19 | 2013-12-06 | 126d? | finish no earlier than 2013-12-06 | R4 | 1008h | 1008h | LTE_CA_B4_B17_B30-Perf | 31 | AT&T | marc.grant@att.com | Rel-12 | 60 | Issam | PCG-32 | RP-62 | CA | LTE_CA_B4_B17_B30-Perf | RP-131599 |
| 5749 | 1977.43 | **LTE Advanced 3 Band Carrier Aggregation (3DL/1UL) of Band 4, Band 29 and Band 30** | 471.62d? | 2013-06-14 A | 2014-09-12 A | 100% | 2013-06-14 | 2014-09-12 | 330d? |  | R4 | 7904h | 7904h | LTE_CA_B4_B29_B30 | 31 | AT&T | marc.grant@att.com | Rel-12 | 60 | Issam |  |  | CA | LTE_CA_B4_B29_B30 |  |
| 5750 | 1977.43.1 | Core part:LTE Advanced 3 Band Carrier Aggregation (3DL/1UL) of Band 4, Band 29 and Band 30 | 330d? | 2013-06-14 A | 2014-09-12 A | 100% | 2013-06-14 | 2014-09-12 | 330d? | finish no earlier than 2014-09-12 | R4 | 2640h | 2640h | LTE_CA_B4_B29_B30-Core | 31 | AT&T | marc.grant@att.com | Rel-12 | 60 | Issam |  |  | CA | LTE_CA_B4_B29_B30-Core | RP-141084 |
| 5751 | 1977.43.2 | Perf. part:LTE Advanced 3 Band Carrier Aggregation (3DL/1UL) of Band 4, Band 29 and Band 30 | 327d? | 2013-06-19 A | 2014-09-12 A | 100% | 2013-06-19 | 2014-09-12 | 327d? | finish no earlier than 2014-09-12 | R4 | 2616h | 2616h | LTE_CA_B4_B29_B30-Perf | 31 | AT&T | marc.grant@att.com | Rel-12 | 60 | Issam |  |  | CA | LTE_CA_B4_B29_B30-Perf | RP-141084 |
| 5752 | 1977.44 | **LTE Advanced 3 Band Carrier Aggregation (3DL/1UL) of Band 2, Band 4 and Band 13** | 471.62d? | 2013-06-14 A | 2014-09-12 A | 100% | 2013-06-14 | 2014-09-12 | 330d? |  | R4 | 7904h | 7904h | LTE_CA_B2_B4_B13 | 31 | Verizon | zheng.zhao@verizonwireless.com | Rel-12 | 60 | Issam |  |  | CA | LTE_CA_B2_B4_B13 |  |
| 5753 | 1977.44.1 | Core part:LTE Advanced 3 Band Carrier Aggregation (3DL/1UL) of Band 2, Band 4 and Band 13 | 330d? | 2013-06-14 A | 2014-09-12 A | 100% | 2013-06-14 | 2014-09-12 | 330d? | finish no earlier than 2014-09-12 | R4 | 2640h | 2640h | LTE_CA_B2_B4_B13-Core | 31 | Verizon | zheng.zhao@verizonwireless.com | Rel-12 | 60 | Issam |  |  | CA | LTE_CA_B2_B4_B13-Core | RP-141084 |
| 5754 | 1977.44.2 | Perf. part:LTE Advanced 3 Band Carrier Aggregation (3DL/1UL) of Band 2, Band 4 and Band 13 | 327d? | 2013-06-19 A | 2014-09-12 A | 100% | 2013-06-19 | 2014-09-12 | 327d? | finish no earlier than 2014-09-12 | R4 | 2616h | 2616h | LTE_CA_B2_B4_B13-Perf | 31 | Verizon | zheng.zhao@verizonwireless.com | Rel-12 | 60 | Issam |  |  | CA | LTE_CA_B2_B4_B13-Perf | RP-141084 |
| 5755 | 1977.45 | **LTE Advanced 3 Band Carrier Aggregation (3DL/1UL) of Band 2, Band 2 and Band 13** | 467.38d? | 2013-06-18 A | 2014-09-12 A | 100% | 2013-06-18 | 2014-09-12 | 328d? |  | R4 | 7864h | 7864h | LTE_CA_B2_B2_B13 | 31 | Verizon | zheng.zhao@verizonwireless.com | Rel-12 | 60 | Issam |  |  | CA | LTE_CA_B2_B2_B13 |  |
| 5756 | 1977.45.1 | Core part:LTE Advanced 3 Band Carrier Aggregation (3DL/1UL) of Band 2, Band 2 and Band 13 | 327d? | 2013-06-18 A | 2014-09-12 A | 100% | 2013-06-18 | 2014-09-12 | 327d? | finish no earlier than 2014-09-12 | R4 | 2616h | 2616h | LTE_CA_B2_B2_B13-Core | 31 | Verizon | zheng.zhao@verizonwireless.com | Rel-12 | 60 | Issam |  |  | CA | LTE_CA_B2_B2_B13-Core | RP-141084 |
| 5757 | 1977.45.2 | Perf. part:LTE Advanced 3 Band Carrier Aggregation (3DL/1UL) of Band 2, Band 2 and Band 13 | 327d? | 2013-06-19 A | 2014-09-12 A | 100% | 2013-06-19 | 2014-09-12 | 327d? | finish no earlier than 2014-09-12 | R4 | 2616h | 2616h | LTE_CA_B2_B2_B13-Perf | 31 | Verizon | zheng.zhao@verizonwireless.com | Rel-12 | 60 | Issam |  |  | CA | LTE_CA_B2_B2_B13-Perf | RP-141084 |
| 5758 | 1977.46 | **LTE Advanced 3 Band Carrier Aggregation (3DL/1UL) of Band 4, Band 4 and Band 13** | 471.62d? | 2013-06-14 A | 2014-09-12 A | 100% | 2013-06-14 | 2014-09-12 | 330d? |  | R4 | 7928h | 7928h | LTE_CA_B4_B4_B13 | 31 | Verizon | zheng.zhao@verizonwireless.com | Rel-12 | 60 | Issam |  |  | CA | LTE_CA_B4_B4_B13 |  |
| 5759 | 1977.46.1 | Core part:LTE Advanced 3 Band Carrier Aggregation (3DL/1UL) of Band 4, Band 4 and Band 13 | 330d? | 2013-06-14 A | 2014-09-12 A | 100% | 2013-06-14 | 2014-09-12 | 330d? | finish no earlier than 2014-09-12 | R4 | 2640h | 2640h | LTE_CA_B4_B4_B13-Core | 31 | Verizon | zheng.zhao@verizonwireless.com | Rel-12 | 60 | Issam |  |  | CA | LTE_CA_B4_B4_B13-Core | RP-141084 |
| 5760 | 1977.46.2 | Perf. part:LTE Advanced 3 Band Carrier Aggregation (3DL/1UL) of Band 4, Band 4 and Band 13 | 330d? | 2013-06-14 A | 2014-09-12 A | 100% | 2013-06-14 | 2014-09-12 | 330d? | finish no earlier than 2014-09-12 | R4 | 2640h | 2640h | LTE_CA_B4_B4_B13-Perf | 31 | Verizon | zheng.zhao@verizonwireless.com | Rel-12 | 60 | Issam |  |  | CA | LTE_CA_B4_B4_B13-Perf | RP-141084 |

Notes:
- 5737: Inter-band 3DL / Impacted TSs and TRs: LTE
- 5738: RP#62 stopped (25% complete) following RP-131652 discussion / Impacted TSs and TRs: 36.101; 36.104; 36.133; 36.141; 36.307; new generic 36.853 (3 Band CA with 1UL)
- 5739: RP#62 stopped (25% complete) following RP-131652 discussion / Impacted TSs and TRs: 36.101; 36.104; 36.133; 36.141; 36.307
- 5740: Inter-band 3DL / Impacted TSs and TRs: LTE
- 5741: RP#65 completed. Updated WID RP-131697=>RP-141212 / Impacted TSs and TRs: 36.101; 36.104; 36.133; 36.141; 36.307; new generic 36.853 (3 Band CA with 1UL)
- 5742: RP#65 completed / Impacted TSs and TRs: 36.101; 36.104; 36.133; 36.141; 36.307
- 5743: Inter-band CA 3DL / Impacted TSs and TRs: LTE
- 5744: RP#65 completed. Updated WID RP-131698=>RP-141213 / Impacted TSs and TRs: 36.101; 36.104; 36.133; 36.141; 36.307; new generic 36.853 (3 Band CA with 1UL)
- 5745: RP#65 completed / Impacted TSs and TRs: 36.101; 36.104; 36.133; 36.141; 36.307
- 5746: Inter-band 3DL / Impacted TSs and TRs: LTE
- 5747: RP#62 stopped (25% complete) following RP-131653 discussion / Impacted TSs and TRs: 36.101; 36.104; 36.133; 36.141; 36.307; new generic 36.853 (3 Band CA with 1UL)
- 5748: RP#62 stopped (25% complete) following RP-131653 discussion / Impacted TSs and TRs: 36.101; 36.104; 36.133; 36.141; 36.307
- 5749: Inter-band CA 3DL / Impacted TSs and TRs: LTE
- 5750: RP#65 completed. Updated WID RP-131699=>RP- 141215 / Impacted TSs and TRs: 36.101; 36.104; 36.133; 36.141; 36.307; new generic 36.853 (3 Band CA with 1UL)
- 5751: RP#65 completed / Impacted TSs and TRs: 36.101; 36.104; 36.133; 36.141; 36.307
- 5752: Inter-band CA 3DL / Impacted TSs and TRs: LTE
- 5753: RP#65 completed. Updated RP-131684=>RP-141434 / Impacted TSs and TRs: 36.101; 36.104; 36.133; new generic 36.853 (3 Band CA with 1UL)
- 5754: RP#65 completed / Impacted TSs and TRs: 36.101; 36.133; 36.141; 36.307
- 5755: Inter-band CA 3DL / Impacted TSs and TRs: LTE
- 5756: RP#65 completed. Updated WID RP-131682=>RP-141435 / Impacted TSs and TRs: 36.101; 36.104; 36.133; new generic 36.853 (3 Band CA with 1UL)
- 5757: RP#65 completed / Impacted TSs and TRs: 36.101; 36.133; 36.141; 36.307
- 5758: Inter-band CA 3DL / Impacted TSs and TRs: LTE
- 5759: RP#65 completed. Updated WID RP-131683=>RP-141433 / Impacted TSs and TRs: 36.101; 36.104; 36.133; new generic 36.853 (3 Band CA with 1UL)
- 5760: RP#65 completed / Impacted TSs and TRs: 36.101; 36.133; 36.141; 36.307

| ID | WBS | Task | Duration | Start | Finish | Complete | Baseline start | Baseline finish | Baseline duration | Constraint | Resources | Work | Actual work | Acronym | PCG approved | Impacted TSs and TRs | WI rapporteur name | WI rapporteur e-mail | Release | TSG approved | MCC resp | Special Focus Doc | Acronym_3GU_Export | Status Report |
| --- | --- | --- | --- | --- | --- | --- | --- | --- | --- | --- | --- | --- | --- | --- | --- | --- | --- | --- | --- | --- | --- | --- | --- | --- |
| 5761 | 1977.47 | **LTE Advanced inter-band Carrier Aggregation of Band 7 and Band 28** | 91.88d? | 2013-09-09 A | 2013-12-06 A | 100% | 2013-09-09 | 2013-12-06 | 66d? |  | R4 | 1584h | 1584h | LTE_CA_B7_B28 | 31 | LTE | Huawei | Liehai Liu (liuliehai@huawei.com) | Rel-12 | 61 | Issam | CA | LTE_CA_B7_B28 |  |
| 5762 | 1977.47.1 | Core part:LTE Advanced inter-band Carrier Aggregation of Band 7 and Band 28 | 66d? | 2013-09-09 A | 2013-12-06 A | 100% | 2013-09-09 | 2013-12-06 | 66d? | finish no earlier than 2013-12-06 | R4 | 528h | 528h | LTE_CA_B7_B28-Core | 31 | 36.101; 36.104; 36.307 | Huawei | Liehai Liu (liuliehai@huawei.com) | Rel-12 | 61 | Issam | CA | LTE_CA_B7_B28-Core | RP-131545 |
| 5763 | 1977.47.2 | Perf. part:LTE Advanced inter-band Carrier Aggregation of Band 7 and Band 28 | 66d? | 2013-09-09 A | 2013-12-06 A | 100% | 2013-09-09 | 2013-12-06 | 66d? | finish no earlier than 2013-12-06 | R4 | 528h | 528h | LTE_CA_B7_B28-Perf | 31 | 36.141 | Huawei | Liehai Liu (liuliehai@huawei.com) | Rel-12 | 61 | Issam | CA | LTE_CA_B7_B28-Perf | RP-131546 |
| 5764 | 1977.48 | **LTE Advanced inter-band Carrier Aggregation of Band 5 and Band 25** | 91.88d? | 2013-09-09 A | 2013-12-06 A | 100% | 2013-09-09 | 2013-12-06 | 66d? |  | R4 | 1584h | 1584h | LTE_CA_B5_B25 | 31 | LTE | U.S. Cellular | sebastian.thalanany@uscellular.com | Rel-12 | 61 | Issam | CA | LTE_CA_B5_B25 |  |
| 5765 | 1977.48.1 | Core part:LTE Advanced inter-band Carrier Aggregation of Band 5 and Band 25 | 66d? | 2013-09-09 A | 2013-12-06 A | 100% | 2013-09-09 | 2013-12-06 | 66d? | finish no earlier than 2013-12-06 | R4 | 528h | 528h | LTE_CA_B5_B25-Core | 31 | 36.101; 36.104; 36.133; new generic 36.851 | U.S. Cellular | sebastian.thalanany@uscellular.com | Rel-12 | 61 | Issam | CA | LTE_CA_B5_B25-Core | RP-131543 |
| 5766 | 1977.48.2 | Perf. part:LTE Advanced inter-band Carrier Aggregation of Band 5 and Band 25 | 66d? | 2013-09-09 A | 2013-12-06 A | 100% | 2013-09-09 | 2013-12-06 | 66d? | finish no earlier than 2013-12-06 | R4 | 528h | 528h | LTE_CA_B5_B25-Perf | 31 | 36.141; 36.307 | U.S. Cellular | sebastian.thalanany@uscellular.com | Rel-12 | 61 | Issam | CA | LTE_CA_B5_B25-Perf | RP-131705 |
| 5767 | 1977.49 | **LTE Advanced inter-band Carrier Aggregation of Band 1 and Band 11** | 287.5d? | 2013-09-09 A | 2014-06-13 A | 100% | 2013-09-09 | 2014-06-13 | 202d? |  | R4 | 4848h | 4848h | LTE_CA_B1_B11 | 31 | LTE | SoftBank Mobile | kenichi.kihara@g.softbank.co.jp | Rel-12 | 61 | Issam | CA | LTE_CA_B1_B11 |  |
| 5768 | 1977.49.1 | Core part:LTE Advanced inter-band Carrier Aggregation of Band 1 and Band 11 | 202d? | 2013-09-09 A | 2014-06-13 A | 100% | 2013-09-09 | 2014-06-13 | 202d? | finish no earlier than 2014-06-13 | R4 | 1616h | 1616h | LTE_CA_B1_B11-Core | 31 | 36.101; 36.104; new generic 36.851 | SoftBank Mobile | kenichi.kihara@g.softbank.co.jp | Rel-12 | 61 | Issam | CA | LTE_CA_B1_B11-Core | RP-140569 |
| 5769 | 1977.49.2 | Perf. part:LTE Advanced inter-band Carrier Aggregation of Band 1 and Band 11 | 202d? | 2013-09-09 A | 2014-06-13 A | 100% | 2013-09-09 | 2014-06-13 | 202d? | finish no earlier than 2014-06-13 | R4 | 1616h | 1616h | LTE_CA_B1_B11-Perf | 31 | 36.141; 36.307 | SoftBank Mobile | kenichi.kihara@g.softbank.co.jp | Rel-12 | 61 | Issam | CA | LTE_CA_B1_B11-Perf | RP-140569 |
| 5770 | 1977.50 | **LTE Advanced inter-band Carrier Aggregation of Band 8 and Band 11** | 381.62d? | 2013-09-09 A | 2014-09-12 A | 100% | 2013-09-09 | 2014-09-12 | 267d? |  | R4 | 6416h | 6416h | LTE_CA_B8_B11 | 31 | LTE | SoftBank Mobile | kenichi.kihara@g.softbank.co.jp | Rel-12 | 61 | Issam | CA | LTE_CA_B8_B11 |  |
| 5771 | 1977.50.1 | Core part:LTE Advanced inter-band Carrier Aggregation of Band 8 and Band 11 | 267d? | 2013-09-09 A | 2014-09-12 A | 100% | 2013-09-09 | 2014-09-12 | 267d? | finish no earlier than 2014-09-12 | R4 | 2136h | 2136h | LTE_CA_B8_B11-Core | 31 | 36.101; 36.104; new generic 36.851 | SoftBank Mobile | kenichi.kihara@g.softbank.co.jp | Rel-12 | 61 | Issam | CA | LTE_CA_B8_B11-Core | RP-141084 |
| 5772 | 1977.50.2 | Perf. part:LTE Advanced inter-band Carrier Aggregation of Band 8 and Band 11 | 267d? | 2013-09-09 A | 2014-09-12 A | 100% | 2013-09-09 | 2014-09-12 | 267d? | finish no earlier than 2014-09-12 | R4 | 2136h | 2136h | LTE_CA_B8_B11-Perf | 31 | 36.141; 36.307 | SoftBank Mobile | kenichi.kihara@g.softbank.co.jp | Rel-12 | 61 | Issam | CA | LTE_CA_B8_B11-Perf | RP-141084 |
| 5773 | 1977.51 | **LTE Advanced inter-band Carrier Aggregation of Band 5 and Band 7** | 87.88d? | 2013-09-09 A | 2013-12-02 A | 100% | 2013-09-09 | 2013-12-02 | 62d? |  | R4 | 1488h | 1488h | LTE_CA_B5_B7 | 31 | LTE | LG Uplus | Yeonsang KOO (yskoo@lguplus.co.kr) | Rel-12 | 61 | Issam | CA | LTE_CA_B5_B7 |  |
| 5774 | 1977.51.1 | Core part:LTE Advanced inter-band Carrier Aggregation of Band 5 and Band 7 | 62d? | 2013-09-09 A | 2013-12-02 A | 100% | 2013-09-09 | 2013-12-02 | 62d? | finish no earlier than 2013-12-02 | R4 | 496h | 496h | LTE_CA_B5_B7-Core | 31 | 36.101; 36.104; 36.133; new generic 36.851 | LG Uplus | Yeonsang KOO (yskoo@lguplus.co.kr) | Rel-12 | 61 | Issam | CA | LTE_CA_B5_B7-Core | RP-131541 |
| 5775 | 1977.51.2 | Perf. part:LTE Advanced inter-band Carrier Aggregation of Band 5 and Band 7 | 62d? | 2013-09-09 A | 2013-12-02 A | 100% | 2013-09-09 | 2013-12-02 | 62d? | finish no earlier than 2013-12-02 | R4 | 496h | 496h | LTE_CA_B5_B7-Perf | 31 | 36.141; 36.307 | LG Uplus | Yeonsang KOO (yskoo@lguplus.co.kr) | Rel-12 | 61 | Issam | CA | LTE_CA_B5_B7-Perf | RP-131542 |
| 5776 | 1977.52 | **LTE Advanced intra-band contiguous Carrier Aggregation in Band 41 for 3DL** | 569.88d? | 2013-09-09 A | 2015-03-13 A | 100% | 2013-09-09 | 2014-09-12 | 267d? |  | R4 | 8512h | 8512h | LTE_CA_C_B41_3DL | 31 | LTE | Alcatel-Lucent | man-hung.ng@alcatel-lucent.com | Rel-12 | 61 | Issam | CA | LTE_CA_C_B41_3DL |  |
| 5777 | 1977.52.1 | Core part: LTE Advanced intra-band contiguous Carrier Aggregation in Band 41 for 3DL | 267d? | 2013-09-09 A | 2014-09-12 A | 100% | 2013-09-09 | 2014-09-12 | 267d? | finish no earlier than 2014-09-12 | R4 | 2136h | 2136h | LTE_CA_C_B41_3DL-Core | 31 | 36.101; 36.104; 36.133; 36.307; New 36.833-5-41 | Alcatel-Lucent | man-hung.ng@alcatel-lucent.com | Rel-12 | 61 | Issam | CA | LTE_CA_C_B41_3DL-Core | RP-141084 |
| 5778 | 1977.52.2 | Perf. part: LTE Advanced intra-band contiguous Carrier Aggregation in Band 41 for 3DL | 397d? | 2013-09-09 A | 2015-03-13 A | 100% | 2013-09-09 | 2014-09-12 | 267d? | finish no earlier than 2015-03-15 | R4 | 3176h | 3176h | LTE_CA_C_B41_3DL-Perf | 31 | 36.141 | Alcatel-Lucent | man-hung.ng@alcatel-lucent.com | Rel-12 | 61 | Issam | CA | LTE_CA_C_B41_3DL-Perf | RP-150013 |
| 5779 | 1977.53 | **LTE Advanced intra-band non-contiguous Carrier Aggregation in Band 2** | 287.5d? | 2013-09-09 A | 2014-06-13 A | 100% | 2013-09-09 | 2014-06-13 | 202d? |  | R4 | 4840h | 4840h | LTE_CA_NC_B2 | 31 | LTE | Ericsson | imadur.rahman@ericsson.com | Rel-12 | 61 | Issam | CA | LTE_CA_NC_B2 |  |
| 5780 | 1977.53.1 | Core part:LTE Advanced intra-band non-contiguous Carrier Aggregation in Band 2 | 202d? | 2013-09-09 A | 2014-06-13 A | 100% | 2013-09-09 | 2014-06-13 | 202d? | finish no earlier than 2014-06-13 | R4 | 1616h | 1616h | LTE_CA_NC_B2-Core | 31 | 36.101; 36.104; 36.133; New 36.833-2-02 | Ericsson | imadur.rahman@ericsson.com | Rel-12 | 61 | Issam | CA | LTE_CA_NC_B2-Core | RP-140569 |
| 5781 | 1977.53.2 | Perf. part:LTE Advanced intra-band non-contiguous Carrier Aggregation in Band 2 | 201d? | 2013-09-10 A | 2014-06-13 A | 100% | 2013-09-10 | 2014-06-13 | 201d? | finish no earlier than 2014-06-13 | R4 | 1608h | 1608h | LTE_CA_NC_B2-Perf | 31 | 36.141; 36.307 | Ericsson | imadur.rahman@ericsson.com | Rel-12 | 61 | Issam | CA | LTE_CA_NC_B2-Perf | RP-140569 |
| 5782 | 1977.54 | **LTE Advanced inter-band Carrier Aggregation of Band 1 and Band 3** | 287.5d? | 2013-12-09 A | 2014-09-12 A | 100% | 2013-12-09 | 2014-09-12 | 201d? |  | R4 | 4832h | 4832h | LTE_CA_B1_B3 | 32 | LTE | China Unicom | Hao Chen (chenhao49@chinaunicom.cn) | Rel-12 | 62 | Issam | CA | LTE_CA_B1_B3 |  |
| 5783 | 1977.54.1 | Core part:LTE Advanced inter-band Carrier Aggregation of Band 1 and Band 3 | 201d? | 2013-12-09 A | 2014-09-12 A | 100% | 2013-12-09 | 2014-09-12 | 201d? | finish no earlier than 2014-09-12 | R4 | 1608h | 1608h | LTE_CA_B1_B3-Core | 32 | 36.101; 36.104; 36.133; new generic 36.851 | China Unicom | Hao Chen (chenhao49@chinaunicom.cn) | Rel-12 | 62 | Issam | CA | LTE_CA_B1_B3-Core | RP-141084 |
| 5784 | 1977.54.2 | Perf. part:LTE Advanced inter-band Carrier Aggregation of Band 1 and Band 3 | 201d? | 2013-12-09 A | 2014-09-12 A | 100% | 2013-12-09 | 2014-09-12 | 201d? | finish no earlier than 2014-09-12 | R4 | 1608h | 1608h | LTE_CA_B1_B3-Perf | 32 | 36.141; 36.307 | China Unicom | Hao Chen (chenhao49@chinaunicom.cn) | Rel-12 | 62 | Issam | CA | LTE_CA_B1_B3-Perf | RP-141084 |

Notes:
- 5761: Inter-band 1UL/2DL
- 5762: RP#62 completed
- 5763: RP#62 completed
- 5764: Inter-band 1UL/2DL
- 5765: RP#62 completed
- 5766: RP#62 completed
- 5767: Inter-band CA 2DL
- 5768: RP#64 completed
- 5769: RP#64 completed
- 5770: Inter-band CA 2DL
- 5771: RP#65 completed
- 5772: RP#65 completed
- 5773: Inter-band 1UL/2DL
- 5774: RP#62 completed
- 5775: RP#62 completed
- 5776: Intra-band contig. CA 3DL
- 5777: RP#65 completed
- 5778: ¦WID: RP-142043->RP-142017¦Stat Rep: RP-141084->RP-141732 1st Apr 15: Compl:70%->100% 1st Apr 15: Stat Rep: RP-141732->RP-150013
- 5779: Intra-band non-contig. CA 2DL
- 5780: RP#64 completed. TR 36.833-2-02v100 for 1-step Approval
- 5781: RP#64 completed
- 5782: Inter-band CA 2DL
- 5783: RP#65 completed
- 5784: RP#65 completed

| ID | WBS | Task | Duration | Start | Finish | Complete | Baseline start | Baseline finish | Baseline duration | Constraint | Resources | Work | Actual work | Acronym | PCG approved | WI rapporteur name | WI rapporteur e-mail | Release | TSG approved | MCC resp | Special Focus Doc | Acronym_3GU_Export | Status Report |
| --- | --- | --- | --- | --- | --- | --- | --- | --- | --- | --- | --- | --- | --- | --- | --- | --- | --- | --- | --- | --- | --- | --- | --- |
| 5785 | 1977.55 | **LTE Advanced inter-band Carrier Aggregation of Band 1 and Band 28** | 384.75d? | 2013-12-09 A | 2014-12-15 A | 100% | 2013-12-09 | 2014-09-12 | 201d? |  | R4 | 6432h | 6432h | LTE_CA_B1_B28 | 32 | KDDI | Masaaki Obara (ms-obara@kddi.com) | Rel-12 | 62 | Issam | CA | LTE_CA_B1_B28 |  |
| 5786 | 1977.55.1 | Core part:LTE Advanced inter-band Carrier Aggregation of Band 1 and Band 28 | 267d? | 2013-12-09 A | 2014-12-15 A | 100% | 2013-12-09 | 2014-09-12 | 201d? | finish no earlier than 2014-12-15 | R4 | 2136h | 2136h | LTE_CA_B1_B28-Core | 32 | KDDI | Masaaki Obara (ms-obara@kddi.com) | Rel-12 | 62 | Issam | CA | LTE_CA_B1_B28-Core | RP-141732 |
| 5787 | 1977.55.2 | Perf. part:LTE Advanced inter-band Carrier Aggregation of Band 1 and Band 28 | 267d? | 2013-12-12 A | 2014-12-15 A | 100% | 2013-12-09 | 2014-09-12 | 201d? | finish no earlier than 2014-12-15 | R4 | 2136h | 2136h | LTE_CA_B1_B28-Perf | 32 | KDDI | Masaaki Obara (ms-obara@kddi.com) | Rel-12 | 62 | Issam | CA | LTE_CA_B1_B28-Perf | RP-141732 |
| 5788 | 1977.56 | **LTE Advanced inter-band Carrier Aggregation of Band 2 and Band 4 - Additional bandwidth combination set** | 90.88d? | 2013-12-09 A | 2014-03-06 A | 100% | 2013-12-09 | 2014-03-06 | 65d? |  | R4 | 1560h | 1560h | LTE_CA_B2_B4_BWset | 32 | T-Mobile USA | nelson.ueng@t-mobile.com | Rel-12 | 62 | Issam | CA | LTE_CA_B2_B4_BWset |  |
| 5789 | 1977.56.1 | Core part:LTE Advanced inter-band Carrier Aggregation of Band 2 and Band 4 - Additional bandwidth combination set | 65d? | 2013-12-09 A | 2014-03-06 A | 100% | 2013-12-09 | 2014-03-06 | 65d? | finish no earlier than 2014-03-06 | R4 | 520h | 520h | LTE_CA_B2_B4_BWset-Core | 32 | T-Mobile USA | nelson.ueng@t-mobile.com | Rel-12 | 62 | Issam | CA | LTE_CA_B2_B4_BWset-Core | RP-140428 |
| 5790 | 1977.56.2 | Perf. part:LTE Advanced inter-band Carrier Aggregation of Band 2 and Band 4 - Additional bandwidth combination set | 65d? | 2013-12-09 A | 2014-03-06 A | 100% | 2013-12-09 | 2014-03-06 | 65d? | finish no earlier than 2014-03-06 | R4 | 520h | 520h | LTE_CA_B2_B4_BWset-Perf | 32 | T-Mobile USA | nelson.ueng@t-mobile.com | Rel-12 | 62 | Issam | CA | LTE_CA_B2_B4_BWset-Perf | RP-140428 |
| 5791 | 1977.57 | **LTE Advanced inter-band Carrier Aggregation of Band 4 and Band 27** | 193.38d? | 2013-12-09 A | 2014-06-13 A | 100% | 2013-12-09 | 2014-06-13 | 136d? |  | R4 | 3264h | 3264h | LTE_CA_B4_B27 | 32 | NII Holdings | bill.shvodian@nii.com | Rel-12 | 62 | Issam | CA | LTE_CA_B4_B27 |  |
| 5792 | 1977.57.1 | Core part:LTE Advanced inter-band Carrier Aggregation of Band 4 and Band 27 | 136d? | 2013-12-09 A | 2014-06-13 A | 100% | 2013-12-09 | 2014-06-13 | 136d? | finish no earlier than 2014-06-13 | R4 | 1088h | 1088h | LTE_CA_B4_B27-Core | 32 | NII Holdings | bill.shvodian@nii.com | Rel-12 | 62 | Issam | CA | LTE_CA_B4_B27-Core | RP-140569 |
| 5793 | 1977.57.2 | Perf. part:LTE Advanced inter-band Carrier Aggregation of Band 4 and Band 27 | 136d? | 2013-12-09 A | 2014-06-13 A | 100% | 2013-12-09 | 2014-06-13 | 136d? | finish no earlier than 2014-06-13 | R4 | 1088h | 1088h | LTE_CA_B4_B27-Perf | 32 | NII Holdings | bill.shvodian@nii.com | Rel-12 | 62 | Issam | CA | LTE_CA_B4_B27-Perf | RP-140569 |
| 5794 | 1977.58 | **LTE Advanced inter-band Carrier Aggregation of Band 3 and Band 27** | 90.88d? | 2013-12-09 A | 2014-03-06 A | 100% | 2013-12-09 | 2014-03-06 | 65d? |  | R4 | 1560h | 1560h | LTE_CA_B3_B27 | 32 | KT | Chungwoo HWANG (cwhwang@kt.com) | Rel-12 | 62 | Issam | CA | LTE_CA_B3_B27 | RP-140428 |
| 5795 | 1977.58.1 | Core part:LTE Advanced inter-band Carrier Aggregation of Band 3 and Band 27 | 65d? | 2013-12-09 A | 2014-03-06 A | 100% | 2013-12-09 | 2014-03-06 | 65d? | finish no earlier than 2014-03-06 | R4 | 520h | 520h | LTE_CA_B3_B27-Core | 32 | KT | Chungwoo HWANG (cwhwang@kt.com) | Rel-12 | 62 | Issam | CA | LTE_CA_B3_B27-Core | RP-140428 |
| 5796 | 1977.58.2 | Perf. part:LTE Advanced inter-band Carrier Aggregation of Band 3 and Band 27 | 65d? | 2013-12-09 A | 2014-03-06 A | 100% | 2013-12-09 | 2014-03-06 | 65d? | finish no earlier than 2014-03-06 | R4 | 520h | 520h | LTE_CA_B3_B27-Perf | 32 | KT | Chungwoo HWANG (cwhwang@kt.com) | Rel-12 | 62 | Issam | CA | LTE_CA_B3_B27-Perf | RP-140428 |
| 5797 | 1977.59 | **LTE Advanced inter-band Carrier Aggregation in Band 8 and Band 20 - Additional channel bandwidth** | 90.88d? | 2013-12-09 A | 2014-03-06 A | 100% | 2013-12-09 | 2014-03-06 | 65d? |  | R4 | 1560h | 1560h | LTE_CA_B8_B20_BW | 32 | Vodafone | luis.anaya@vodafone.com | Rel-12 | 62 | Issam | CA | LTE_CA_B8_B20_BW | RP-140428 |
| 5798 | 1977.59.1 | Core part:LTE Advanced inter-band Carrier Aggregation in Band 8 and Band 20 - Additional channel bandwidth | 65d? | 2013-12-09 A | 2014-03-06 A | 100% | 2013-12-09 | 2014-03-06 | 65d? | finish no earlier than 2014-03-06 | R4 | 520h | 520h | LTE_CA_B8_B20_BW-Core | 32 | Vodafone | luis.anaya@vodafone.com | Rel-12 | 62 | Issam | CA | LTE_CA_B8_B20_BW-Core | RP-140428 |
| 5799 | 1977.59.2 | Perf. part:LTE Advanced inter-band Carrier Aggregation in Band 8 and Band 20 - Additional channel bandwidth | 65d? | 2013-12-09 A | 2014-03-06 A | 100% | 2013-12-09 | 2014-03-06 | 65d? | finish no earlier than 2014-03-06 | R4 | 520h | 520h | LTE_CA_B8_B20_BW-Perf | 32 | Vodafone | luis.anaya@vodafone.com | Rel-12 | 62 | Issam | CA | LTE_CA_B8_B20_BW-Perf | RP-140428 |
| 5800 | 1977.60 | **LTE Advanced 3 Band Carrier Aggregation (3DL/1UL) for Band 1, Band 3 and Band 8** | 287.5d? | 2013-12-09 A | 2014-09-12 A | 100% | 2013-12-09 | 2014-09-12 | 201d? |  | R4 | 4832h | 4832h | LTE_CA_B1_B3_B8 | 32 | KT | Ilwhan Kim (ilwhan.kim@kt.com) | Rel-12 | 62 | Issam | CA | LTE_CA_B1_B3_B8 |  |
| 5801 | 1977.60.1 | Core part:LTE Advanced 3 Band Carrier Aggregation (3DL/1UL) for Band 1, Band 3 and Band 8 | 201d? | 2013-12-09 A | 2014-09-12 A | 100% | 2013-12-09 | 2014-09-12 | 201d? | finish no earlier than 2014-09-12 | R4 | 1608h | 1608h | LTE_CA_B1_B3_B8-Core | 32 | KT | Ilwhan Kim (ilwhan.kim@kt.com) | Rel-12 | 62 | Issam | CA | LTE_CA_B1_B3_B8-Core | RP-141084 |
| 5802 | 1977.60.2 | Perf. part:LTE Advanced 3 Band Carrier Aggregation (3DL/1UL) for Band 1, Band 3 and Band 8 | 201d? | 2013-12-09 A | 2014-09-12 A | 100% | 2013-12-09 | 2014-09-12 | 201d? | finish no earlier than 2014-09-12 | R4 | 1608h | 1608h | LTE_CA_B1_B3_B8-Perf | 32 | KT | Ilwhan Kim (ilwhan.kim@kt.com) | Rel-12 | 62 | Issam | CA | LTE_CA_B1_B3_B8-Perf | RP-141084 |
| 5803 | 1977.61 | **LTE Advanced 3 Band Carrier Aggregation (3DL/1UL) for Band 1, Band 5 and Band 7** | 287.5d? | 2013-12-09 A | 2014-09-12 A | 100% | 2013-12-09 | 2014-09-12 | 201d? |  | R4 | 4832h | 4832h | LTE_CA_B1_B5_B7 | 32 | LG Uplus | Yeonsang KOO (yskoo@lguplus.co.kr) | Rel-12 | 62 | Issam | CA | LTE_CA_B1_B5_B7 |  |
| 5804 | 1977.61.1 | Core part:LTE Advanced 3 Band Carrier Aggregation (3DL/1UL) for Band 1, Band 5 and Band 7 | 201d? | 2013-12-09 A | 2014-09-12 A | 100% | 2013-12-09 | 2014-09-12 | 201d? | finish no earlier than 2014-09-12 | R4 | 1608h | 1608h | LTE_CA_B1_B5_B7-Core | 32 | LG Uplus | Yeonsang KOO (yskoo@lguplus.co.kr) | Rel-12 | 62 | Issam | CA | LTE_CA_B1_B5_B7-Core | RP-141084 |
| 5805 | 1977.61.2 | Perf. part:LTE Advanced 3 Band Carrier Aggregation (3DL/1UL) for Band 1, Band 5 and Band 7 | 201d? | 2013-12-09 A | 2014-09-12 A | 100% | 2013-12-09 | 2014-09-12 | 201d? | finish no earlier than 2014-09-12 | R4 | 1608h | 1608h | LTE_CA_B1_B5_B7-Perf | 32 | LG Uplus | Yeonsang KOO (yskoo@lguplus.co.kr) | Rel-12 | 62 | Issam | CA | LTE_CA_B1_B5_B7-Perf | RP-141084 |
| 5806 | 1977.62 | **LTE Advanced 3 Band Carrier Aggregation (3DL/1UL) for Band 2, Band 4 and Band 5** | 287.5d? | 2013-12-09 A | 2014-09-12 A | 100% | 2013-12-09 | 2014-09-12 | 201d? |  | R4 | 4832h | 4832h | LTE_CA_B2_B4_B5 | 32 | U.S. Cellular | sebastian.thalanany@uscellular.com | Rel-12 | 62 | Issam | CA | LTE_CA_B2_B4_B5 |  |
| 5807 | 1977.62.1 | Core part:LTE Advanced 3 Band Carrier Aggregation (3DL/1UL) for Band 2, Band 4 and Band 5 | 201d? | 2013-12-09 A | 2014-09-12 A | 100% | 2013-12-09 | 2014-09-12 | 201d? | finish no earlier than 2014-09-12 | R4 | 1608h | 1608h | LTE_CA_B2_B4_B5-Core | 32 | U.S. Cellular | sebastian.thalanany@uscellular.com | Rel-12 | 62 | Issam | CA | LTE_CA_B2_B4_B5-Core | RP-141084 |
| 5808 | 1977.62.2 | Perf. part:LTE Advanced 3 Band Carrier Aggregation (3DL/1UL) for Band 2, Band 4 and Band 5 | 201d? | 2013-12-09 A | 2014-09-12 A | 100% | 2013-12-09 | 2014-09-12 | 201d? | finish no earlier than 2014-09-12 | R4 | 1608h | 1608h | LTE_CA_B2_B4_B5-Perf | 32 | U.S. Cellular | sebastian.thalanany@uscellular.com | Rel-12 | 62 | Issam | CA | LTE_CA_B2_B4_B5-Perf | RP-141084 |

Notes:
- 5785: Inter-band CA 2DL / Impacted TSs and TRs: LTE
- 5786: ¦WID: RP-142043->RP-141803¦Stat Rep: RP-141084->RP-141732 / Impacted TSs and TRs: 36.101; 36.104; 36.133; 36.307; new generic 36.851
- 5787: ¦WID: RP-142043->RP-141803¦Stat Rep: RP-141084->RP-141732 / Impacted TSs and TRs: 36.133; 36.141
- 5788: Inter-band 2DL / Impacted TSs and TRs: LTE
- 5789: RP#63 completed / Impacted TSs and TRs: 36.101; new generic 36.851
- 5790: RP#63 completed / Impacted TSs and TRs: 36.307
- 5791: Inter-band CA 2DL / Impacted TSs and TRs: LTE
- 5792: RP#64 completed / Impacted TSs and TRs: 36.101; 36.104; 36.133; new generic 36.851
- 5793: RP#64 completed / Impacted TSs and TRs: 36.141; 36.307
- 5794: Inter-band CA 2DL/1UL / Impacted TSs and TRs: LTE
- 5795: RP#63 completed. Updated WID RP-131752=>RP-140119 / Impacted TSs and TRs: 36.101; 36.104; 36.133; 36.307; New generic 36.851
- 5796: RP#63 completed. Updated WID RP-131752=>RP-140119 / Impacted TSs and TRs: 36.101; 36.104; 36.133; 36.141
- 5797: Inter-band 2DL / Impacted TSs and TRs: LTE
- 5798: RP#63 completed / Impacted TSs and TRs: 36.101; 36.104; 36.307
- 5799: RP#63 completed / Impacted TSs and TRs: 36.141
- 5800: Inter-band CA 3DL / Impacted TSs and TRs: LTE
- 5801: RP#65 completed. Updated WID RP-131753=>RP-141654 / Impacted TSs and TRs: 36.101; 36.104; 36.133; 36.141; 36.307; new generic 36.853 (3 Band CA with 1UL)
- 5802: RP#65 completed / Impacted TSs and TRs: 36.101; 36.104; 36.133; 36.141; 36.307
- 5803: Inter-band CA 3DL / Impacted TSs and TRs: LTE
- 5804: RP#65 completed. Updated WID RP-140209=>RP-141462 / Impacted TSs and TRs: 36.101; 36.104; 36.133; new generic 36.853 (3 Band CA with 1UL)
- 5805: RP#65 completed / Impacted TSs and TRs: 36.141; 36.307
- 5806: Inter-band CA 3DL / Impacted TSs and TRs: LTE
- 5807: RP#65 completed / Impacted TSs and TRs: 36.101; 36.104; 36.133; new generic 36.853 (3 Band CA with 1UL)
- 5808: RP#65 completed / Impacted TSs and TRs: 36.141; 36.307

| ID | WBS | Task | Duration | Start | Finish | Complete | Baseline start | Baseline finish | Baseline duration | Constraint | Resources | Work | Actual work | Acronym | PCG approved | WI rapporteur name | WI rapporteur e-mail | Release | TSG approved | MCC resp | Special Focus Doc | Acronym_3GU_Export | Status Report |
| --- | --- | --- | --- | --- | --- | --- | --- | --- | --- | --- | --- | --- | --- | --- | --- | --- | --- | --- | --- | --- | --- | --- | --- |
| 5809 | 1977.63 | **LTE Advanced 3 Band Carrier Aggregation (3DL/1UL) for Band 2, Band 4 and Band 12** | 380.5d? | 2013-12-09 A | 2014-12-11 A | 100% | 2013-12-09 | 2014-09-12 | 201d? |  | R4 | 5872h | 5872h | LTE_CA_B2_B4_B12 | 32 | U.S. Cellular | sebastian.thalanany@uscellular.com | Rel-12 | 62 | Issam | CA | LTE_CA_B2_B4_B12 |  |
| 5810 | 1977.63.1 | Core part:LTE Advanced 3 Band Carrier Aggregation (3DL/1UL) for Band 2, Band 4 and Band 12 | 201d? | 2013-12-09 A | 2014-09-12 A | 100% | 2013-12-09 | 2014-09-12 | 201d? | finish no earlier than 2014-09-12 | R4 | 1608h | 1608h | LTE_CA_B2_B4_B12-Core | 32 | U.S. Cellular | sebastian.thalanany@uscellular.com | Rel-12 | 62 | Issam | CA | LTE_CA_B2_B4_B12-Core | RP-141084 |
| 5811 | 1977.63.2 | Perf. part:LTE Advanced 3 Band Carrier Aggregation (3DL/1UL) for Band 2, Band 4 and Band 12 | 265d? | 2013-12-09 A | 2014-12-11 A | 100% | 2013-12-09 | 2014-09-12 | 201d? | finish no earlier than 2014-12-11 | R4 | 2120h | 2120h | LTE_CA_B2_B4_B12-Perf | 32 | U.S. Cellular | sebastian.thalanany@uscellular.com | Rel-12 | 62 | Issam | CA | LTE_CA_B2_B4_B12-Perf | RP-141084 |
| 5812 | 1977.64 | **LTE Advanced 3 Band Carrier Aggregation (3DL/1UL) for Band 2, Band 5 and Band 12** | 287.5d? | 2013-12-09 A | 2014-09-12 A | 100% | 2013-12-09 | 2014-09-12 | 201d? |  | R4 | 4832h | 4832h | LTE_CA_B2_B5_B12 | 32 | U.S. Cellular | sebastian.thalanany@uscellular.com | Rel-12 | 62 | Issam | CA | LTE_CA_B2_B5_B12 |  |
| 5813 | 1977.64.1 | Core part:LTE Advanced 3 Band Carrier Aggregation (3DL/1UL) for Band 2, Band 5 and Band 12 | 201d? | 2013-12-09 A | 2014-09-12 A | 100% | 2013-12-09 | 2014-09-12 | 201d? | finish no earlier than 2014-09-12 | R4 | 1608h | 1608h | LTE_CA_B2_B5_B12-Core | 32 | U.S. Cellular | sebastian.thalanany@uscellular.com | Rel-12 | 62 | Issam | CA | LTE_CA_B2_B5_B12-Core | RP-141084 |
| 5814 | 1977.64.2 | Perf. part:LTE Advanced 3 Band Carrier Aggregation (3DL/1UL) for Band 2, Band 5 and Band 12 | 201d? | 2013-12-10 A | 2014-09-12 A | 100% | 2013-12-09 | 2014-09-12 | 201d? | finish no earlier than 2014-09-12 | R4 | 1608h | 1608h | LTE_CA_B2_B5_B12-Perf | 32 | U.S. Cellular | sebastian.thalanany@uscellular.com | Rel-12 | 62 | Issam | CA | LTE_CA_B2_B5_B12-Perf | RP-141084 |
| 5815 | 1977.65 | **LTE Advanced 3 Band Carrier Aggregation (3DL/1UL) for Band 2, Band 12 and Band 12** | 287.5d? | 2013-12-09 A | 2014-09-12 A | 100% | 2013-12-09 | 2014-09-12 | 201d? |  | R4 | 4832h | 4832h | LTE_CA_B2_B12_B12 | 32 | AT&T | marc.grant@att.com | Rel-12 | 62 | Issam | CA | LTE_CA_B2_B12_B12 |  |
| 5816 | 1977.65.1 | Core part:LTE Advanced 3 Band Carrier Aggregation (3DL/1UL) for Band 2, Band 12 and Band 12 | 201d? | 2013-12-09 A | 2014-09-12 A | 100% | 2013-12-09 | 2014-09-12 | 201d? | finish no earlier than 2014-09-12 | R4 | 1608h | 1608h | LTE_CA_B2_B12_B12-Core | 32 | AT&T | marc.grant@att.com | Rel-12 | 62 | Issam | CA | LTE_CA_B2_B12_B12-Core | RP-141084 |
| 5817 | 1977.65.2 | Perf. part:LTE Advanced 3 Band Carrier Aggregation (3DL/1UL) for Band 2, Band 12 and Band 12 | 201d? | 2013-12-09 A | 2014-09-12 A | 100% | 2013-12-09 | 2014-09-12 | 201d? | finish no earlier than 2014-09-12 | R4 | 1608h | 1608h | LTE_CA_B2_B12_B12-Perf | 32 | AT&T | marc.grant@att.com | Rel-12 | 62 | Issam | CA | LTE_CA_B2_B12_B12-Perf | RP-141084 |
| 5818 | 1977.66 | **LTE Advanced 3 Band Carrier Aggregation (3DL/1UL) for Band 2, Band 12 and Band 30** | 287.5d? | 2013-12-09 A | 2014-09-12 A | 100% | 2013-12-09 | 2014-09-12 | 201d? |  | R4 | 4832h | 4832h | LTE_CA_B2_B12_B30 | 32 | AT&T | marc.grant@att.com | Rel-12 | 62 | Issam | CA | LTE_CA_B2_B12_B30 |  |
| 5819 | 1977.66.1 | Core part:LTE Advanced 3 Band Carrier Aggregation (3DL/1UL) for Band 2, Band 12 and Band 30 | 201d? | 2013-12-09 A | 2014-09-12 A | 100% | 2013-12-09 | 2014-09-12 | 201d? | finish no earlier than 2014-09-12 | R4 | 1608h | 1608h | LTE_CA_B2_B12_B30-Core | 32 | AT&T | marc.grant@att.com | Rel-12 | 62 | Issam | CA | LTE_CA_B2_B12_B30-Core | RP-141084 |
| 5820 | 1977.66.2 | Perf. part:LTE Advanced 3 Band Carrier Aggregation (3DL/1UL) for Band 2, Band 12 and Band 30 | 201d? | 2013-12-09 A | 2014-09-12 A | 100% | 2013-12-09 | 2014-09-12 | 201d? | finish no earlier than 2014-09-12 | R4 | 1608h | 1608h | LTE_CA_B2_B12_B30-Perf | 32 | AT&T | marc.grant@att.com | Rel-12 | 62 | Issam | CA | LTE_CA_B2_B12_B30-Perf | RP-141084 |
| 5821 | 1977.67 | **LTE Advanced 3 Band Carrier Aggregation (3DL/1UL) for Band 3, Band 7 and Band 20** | 287.5d? | 2013-12-09 A | 2014-09-12 A | 100% | 2013-12-09 | 2014-09-12 | 201d? |  | R4 | 4832h | 4832h | LTE_CA_B3_B7_B20 | 32 | Vodafone | luis.anaya@vodafone.com | Rel-12 | 62 | Issam | CA | LTE_CA_B3_B7_B20 |  |
| 5822 | 1977.67.1 | Core part:LTE Advanced 3 Band Carrier Aggregation (3DL/1UL) for Band 3, Band 7 and Band 20 | 201d? | 2013-12-09 A | 2014-09-12 A | 100% | 2013-12-09 | 2014-09-12 | 201d? | finish no earlier than 2014-09-12 | R4 | 1608h | 1608h | LTE_CA_B3_B7_B20-Core | 32 | Vodafone | luis.anaya@vodafone.com | Rel-12 | 62 | Issam | CA | LTE_CA_B3_B7_B20-Core | RP-141084 |
| 5823 | 1977.67.2 | Perf. part:LTE Advanced 3 Band Carrier Aggregation (3DL/1UL) for Band 3, Band 7 and Band 20 | 201d? | 2013-12-10 A | 2014-09-12 A | 100% | 2013-12-09 | 2014-09-12 | 201d? | finish no earlier than 2014-09-12 | R4 | 1608h | 1608h | LTE_CA_B3_B7_B20-Perf | 32 | Vodafone | luis.anaya@vodafone.com | Rel-12 | 62 | Issam | CA | LTE_CA_B3_B7_B20-Perf | RP-141084 |
| 5824 | 1977.68 | **LTE Advanced 3 Band Carrier Aggregation (3DL/1UL) for Band 4, Band 5 and Band 12** | 287.5d? | 2013-12-09 A | 2014-09-12 A | 100% | 2013-12-09 | 2014-09-12 | 201d? |  | R4 | 4832h | 4832h | LTE_CA_B4_B5_B12 | 32 | U.S. Cellular | sebastian.thalanany@uscellular.com | Rel-12 | 62 | Issam | CA | LTE_CA_B4_B5_B12 |  |
| 5825 | 1977.68.1 | Core part:LTE Advanced 3 Band Carrier Aggregation (3DL/1UL) for Band 4, Band 5 and Band 12 | 201d? | 2013-12-09 A | 2014-09-12 A | 100% | 2013-12-09 | 2014-09-12 | 201d? | finish no earlier than 2014-09-12 | R4 | 1608h | 1608h | LTE_CA_B4_B5_B12-Core | 32 | U.S. Cellular | sebastian.thalanany@uscellular.com | Rel-12 | 62 | Issam | CA | LTE_CA_B4_B5_B12-Core | RP-141084 |
| 5826 | 1977.68.2 | Perf. part:LTE Advanced 3 Band Carrier Aggregation (3DL/1UL) for Band 4, Band 5 and Band 12 | 201d? | 2013-12-09 A | 2014-09-12 A | 100% | 2013-12-09 | 2014-09-12 | 201d? | finish no earlier than 2014-09-12 | R4 | 1608h | 1608h | LTE_CA_B4_B5_B12-Perf | 32 | U.S. Cellular | sebastian.thalanany@uscellular.com | Rel-12 | 62 | Issam | CA | LTE_CA_B4_B5_B12-Perf | RP-141084 |
| 5827 | 1977.69 | **LTE Advanced 3 Band Carrier Aggregation (3DL/1UL) for Band 4, Band 12 and Band 12** | 287.5d? | 2013-12-09 A | 2014-09-12 A | 100% | 2013-12-09 | 2014-09-12 | 201d? |  | R4 | 4832h | 4832h | LTE_CA_B4_B12_B12 | 32 | AT&T | marc.grant@att.com | Rel-12 | 62 | Issam | CA | LTE_CA_B4_B12_B12 |  |
| 5828 | 1977.69.1 | Core part:LTE Advanced 3 Band Carrier Aggregation (3DL/1UL) for Band 4, Band 12 and Band 12 | 201d? | 2013-12-09 A | 2014-09-12 A | 100% | 2013-12-09 | 2014-09-12 | 201d? | finish no earlier than 2014-09-12 | R4 | 1608h | 1608h | LTE_CA_B4_B12_B12-Core | 32 | AT&T | marc.grant@att.com | Rel-12 | 62 | Issam | CA | LTE_CA_B4_B12_B12-Core | RP-141084 |
| 5829 | 1977.69.2 | Perf. part:LTE Advanced 3 Band Carrier Aggregation (3DL/1UL) for Band 4, Band 12 and Band 12 | 201d? | 2013-12-09 A | 2014-09-12 A | 100% | 2013-12-09 | 2014-09-12 | 201d? | finish no earlier than 2014-09-12 | R4 | 1608h | 1608h | LTE_CA_B4_B12_B12-Perf | 32 | AT&T | marc.grant@att.com | Rel-12 | 62 | Issam | CA | LTE_CA_B4_B12_B12-Perf | RP-141084 |
| 5830 | 1977.70 | **LTE Advanced 3 Band Carrier Aggregation (3DL/1UL) for Band 4, Band 12 and Band 30** | 287.5d? | 2013-12-09 A | 2014-09-12 A | 100% | 2013-12-09 | 2014-09-12 | 201d? |  | R4 | 4832h | 4832h | LTE_CA_B4_B12_B30 | 32 | AT&T | marc.grant@att.com | Rel-12 | 62 | Issam | CA | LTE_CA_B4_B12_B30 |  |
| 5831 | 1977.70.1 | Core part:LTE Advanced 3 Band Carrier Aggregation (3DL/1UL) for Band 4, Band 12 and Band 30 | 201d? | 2013-12-09 A | 2014-09-12 A | 100% | 2013-12-09 | 2014-09-12 | 201d? | finish no earlier than 2014-09-12 | R4 | 1608h | 1608h | LTE_CA_B4_B12_B30-Core | 32 | AT&T | marc.grant@att.com | Rel-12 | 62 | Issam | CA | LTE_CA_B4_B12_B30-Core | RP-141084 |
| 5832 | 1977.70.2 | Perf. part:LTE Advanced 3 Band Carrier Aggregation (3DL/1UL) for Band 4, Band 12 and Band 30 | 201d? | 2013-12-09 A | 2014-09-12 A | 100% | 2013-12-09 | 2014-09-12 | 201d? | finish no earlier than 2014-09-12 | R4 | 1608h | 1608h | LTE_CA_B4_B12_B30-Perf | 32 | AT&T | marc.grant@att.com | Rel-12 | 62 | Issam | CA | LTE_CA_B4_B12_B30-Perf | RP-141084 |

Notes:
- 5809: Inter-band CA 3DL / Impacted TSs and TRs: LTE
- 5810: RP#65 completed / Impacted TSs and TRs: 36.101; 36.104; 36.133; new generic 36.853 (3 Band CA with 1UL)
- 5811: RP#65 completion 09/14=>12/14 / Impacted TSs and TRs: 36.141; 36.307
- 5812: Inter-band CA 3DL / Impacted TSs and TRs: LTE
- 5813: RP#65 completed / Impacted TSs and TRs: 36.101; 36.104; 36.133; new generic 36.853 (3 Band CA with 1UL)
- 5814: RP#65 completed / Impacted TSs and TRs: 36.141; 36.307
- 5815: Inter-band CA 3DL / Impacted TSs and TRs: LTE
- 5816: RP#65 completed / Impacted TSs and TRs: 36.101; 36.104; 36.133; 36.141; 36.307; new generic 36.853
- 5817: RP#65 completed / Impacted TSs and TRs: 36.101; 36.104; 36.133; 36.141; 36.307
- 5818: Inter-band CA 3DL / Impacted TSs and TRs: LTE
- 5819: RP#65 completed. Updated WID RP-131652=>RP-141211. / Impacted TSs and TRs: 36.101; 36.104; 36.133; 36.141; 36.307; new generic 36.853 (3 Band CA with 1UL)
- 5820: RP#65 completed / Impacted TSs and TRs: 36.101; 36.104; 36.133; 36.141; 36.307
- 5821: Inter-band CA 3DL / Impacted TSs and TRs: LTE
- 5822: RP#65 completed. Updated WID RP-140244=>RP-141224 / Impacted TSs and TRs: 36.101; 36.104; 36.133; new generic 36.853 (3 Band CA with 1UL)
- 5823: RP#65 completed / Impacted TSs and TRs: 36.101; 36.133; 36.141; 36.307
- 5824: Inter-band CA 3DL / Impacted TSs and TRs: LTE
- 5825: RP#65 completed / Impacted TSs and TRs: 36.101; 36.104; 36.133; new generic 36.853 (3 Band CA with 1UL)
- 5826: RP#65 completed / Impacted TSs and TRs: 36.141; 36.307
- 5827: Inter-band CA 3DL / Impacted TSs and TRs: LTE
- 5828: RP#65 completed / Impacted TSs and TRs: 36.101; 36.104; 36.133; 36.141; 36.307; new generic 36.853 (3 Band CA with 1UL)
- 5829: RP#65 completed / Impacted TSs and TRs: 36.101; 36.104; 36.133; 36.141; 36.307
- 5830: Inter-band CA 3DL / Impacted TSs and TRs: LTE
- 5831: RP#65 completed. Updated WID RP-131653=>RP-141214 / Impacted TSs and TRs: 36.101; 36.104; 36.133; 36.141; 36.307; new generic 36.853 (3 Band CA with 1UL)
- 5832: RP#65 completed / Impacted TSs and TRs: 36.101; 36.104; 36.133; 36.141; 36.307

| ID | WBS | Task | Duration | Start | Finish | Complete | Baseline start | Baseline finish | Baseline duration | Constraint | Resources | Work | Actual work | Acronym | PCG approved | WI rapporteur name | WI rapporteur e-mail | Release | TSG approved | MCC resp | Special Focus Doc | Acronym_3GU_Export | Status Report |
| --- | --- | --- | --- | --- | --- | --- | --- | --- | --- | --- | --- | --- | --- | --- | --- | --- | --- | --- | --- | --- | --- | --- | --- |
| 5833 | 1977.71 | **LTE Advanced intra-band contiguous Carrier Aggregation in Band 42** | 193.38d? | 2013-12-09 A | 2014-06-13 A | 100% | 2013-12-09 | 2014-06-13 | 136d? |  | R4 | 3264h | 3264h | LTE_CA_C_B42 | 32 | CATT | Yuexia Song (songyuexia@catt.cn) | Rel-12 | 62 | Issam | CA | LTE_CA_C_B42 |  |
| 5834 | 1977.71.1 | Core part: LTE Advanced intra-band contiguous Carrier Aggregation in Band 42 | 136d? | 2013-12-09 A | 2014-06-13 A | 100% | 2013-12-09 | 2014-06-13 | 136d? | finish no earlier than 2014-06-13 | R4 | 1088h | 1088h | LTE_CA_C_B42-Core | 32 | CATT | Yuexia Song (songyuexia@catt.cn) | Rel-12 | 62 | Issam | CA | LTE_CA_C_B42-Core | RP-140569 |
| 5835 | 1977.71.2 | Perf. part: LTE Advanced intra-band contiguous Carrier Aggregation in Band 42 | 136d? | 2013-12-09 A | 2014-06-13 A | 100% | 2013-12-09 | 2014-06-13 | 136d? | finish no earlier than 2014-06-13 | R4 | 1088h | 1088h | LTE_CA_C_B42-Perf | 32 | CATT | Yuexia Song (songyuexia@catt.cn) | Rel-12 | 62 | Issam | CA | LTE_CA_C_B42-Perf | RP-140569 |
| 5836 | 1977.72 | **LTE Advanced intra-band contiguous Carrier Aggregation in Band 7 - Additional bandwidth combinations** | 193.38d? | 2013-12-09 A | 2014-06-13 A | 100% | 2013-12-09 | 2014-06-13 | 136d? |  | R4 | 3264h | 3264h | LTE_CA_C_B7_BW | 32 | Orange | Olfa BEN HADDADA | Rel-12 | 62 | Issam | CA | LTE_CA_C_B7_BW |  |
| 5837 | 1977.72.1 | Core part: LTE Advanced intra-band contiguous Carrier Aggregation in Band 7 - Additional bandwidth combinations | 136d? | 2013-12-09 A | 2014-06-13 A | 100% | 2013-12-09 | 2014-06-13 | 136d? | finish no earlier than 2014-06-13 | R4 | 1088h | 1088h | LTE_CA_C_B7_BW-Core | 32 | Orange | Olfa BEN HADDADA | Rel-12 | 62 | Issam | CA | LTE_CA_C_B7_BW-Core | RP-140569 |
| 5838 | 1977.72.2 | Perf. part: LTE Advanced intra-band contiguous Carrier Aggregation in Band 7 - Additional bandwidth combinations | 136d? | 2013-12-09 A | 2014-06-13 A | 100% | 2013-12-09 | 2014-06-13 | 136d? | finish no earlier than 2014-06-13 | R4 | 1088h | 1088h | LTE_CA_C_B7_BW-Perf | 32 | Orange | Olfa BEN HADDADA | Rel-12 | 62 | Issam | CA | LTE_CA_C_B7_BW-Perf | RP-140569 |
| 5839 | 1977.73 | **LTE Advanced intra-band non-contiguous Carrier Aggregation in Band 41 for 3 DL** | 475.75d? | 2013-12-09 A | 2015-03-13 A | 100% | 2013-12-09 | 2014-09-12 | 200d? |  | R4 | 6920h | 6920h | LTE_CA_NC_B41_3DL | 32 | Sprint, Alcatel-Lucent | man-hung.ng@alcatel-lucent.com | Rel-12 | 62 | Issam | CA | LTE_CA_NC_B41_3DL |  |
| 5840 | 1977.73.1 | Core part:LTE Advanced intra-band non-contiguous Carrier Aggregation in Band 41 for 3 DL | 200d? | 2013-12-09 A | 2014-09-11 A | 100% | 2013-12-09 | 2014-09-12 | 200d? | finish no earlier than 2014-09-12 | R4 | 1600h | 1600h | LTE_CA_NC_B41_3DL-Core | 32 | Sprint, Alcatel-Lucent | man-hung.ng@alcatel-lucent.com | Rel-12 | 62 | Issam | CA | LTE_CA_NC_B41_3DL-Core | RP-141084 |
| 5841 | 1977.73.2 | Perf. part:LTE Advanced intra-band non-contiguous Carrier Aggregation in Band 41 for 3 DL | 331d? | 2013-12-09 A | 2015-03-13 A | 100% | 2013-12-09 | 2014-09-12 | 200d? | finish no earlier than 2015-03-15 | R4 | 2648h | 2648h | LTE_CA_NC_B41_3DL-Perf | 32 | Sprint, Alcatel-Lucent | man-hung.ng@alcatel-lucent.com | Rel-12 | 62 | Issam | CA | LTE_CA_NC_B41_3DL-Perf | RP-150013 |
| 5842 | 1977.74 | **LTE Advanced intra-band non-contiguous Carrier Aggregation in Band 42** | 193.38d? | 2013-12-09 A | 2014-06-13 A | 100% | 2013-12-09 | 2014-06-13 | 136d? |  | R4 | 3264h | 3264h | LTE_CA_NC_B42 | 32 | Huawei | Liu Liehai (liuliehai@huawei.com) | Rel-12 | 62 | Issam | CA | LTE_CA_NC_B42 |  |
| 5843 | 1977.74.1 | Core part:LTE Advanced intra-band non-contiguous Carrier Aggregation in Band 42 | 136d? | 2013-12-09 A | 2014-06-13 A | 100% | 2013-12-09 | 2014-06-13 | 136d? | finish no earlier than 2014-06-13 | R4 | 1088h | 1088h | LTE_CA_NC_B42-Core | 32 | Huawei | Liu Liehai (liuliehai@huawei.com) | Rel-12 | 62 | Issam | CA | LTE_CA_NC_B42-Core | RP-140569 |
| 5844 | 1977.74.2 | Perf. part:LTE Advanced intra-band non-contiguous Carrier Aggregation in Band 42 | 136d? | 2013-12-09 A | 2014-06-13 A | 100% | 2013-12-09 | 2014-06-13 | 136d? | finish no earlier than 2014-06-13 | R4 | 1088h | 1088h | LTE_CA_NC_B42-Perf | 32 | Huawei | Liu Liehai (liuliehai@huawei.com) | Rel-12 | 62 | Issam | CA | LTE_CA_NC_B42-Perf | RP-140569 |
| 5845 | 1977.75 | **LTE Advanced 3 Band Carrier Aggregation (3DL/1UL) for Band 1, Band 3 and Band 5** | 290.75d? | 2013-12-06 A | 2014-09-12 A | 100% | 2013-12-06 | 2014-09-12 | 202d? |  | R4 | 4856h | 4856h | LTE_CA_B1_B3_B5 | 32 | SK Telecom | haesung.park@sk.com | Rel-12 | 62 | Issam | CA | LTE_CA_B1_B3_B5 |  |
| 5846 | 1977.75.1 | Core part:LTE Advanced 3 Band Carrier Aggregation(3DL/1UL) for Band 1, Band 3 and Band 5 | 202d? | 2013-12-06 A | 2014-09-12 A | 100% | 2013-12-06 | 2014-09-12 | 202d? | finish no earlier than 2014-09-12 | R4 | 1616h | 1616h | LTE_CA_B1_B3_B5-Core | 32 | SK Telecom | haesung.park@sk.com | Rel-12 | 62 | Issam | CA | LTE_CA_B1_B3_B5-Core | RP-141084 |
| 5847 | 1977.75.2 | Perf. part:LTE Advanced 3 Band Carrier Aggregation(3DL/1UL) for Band 1, Band 3 and Band 5 | 202d? | 2013-12-06 A | 2014-09-12 A | 100% | 2013-12-06 | 2014-09-12 | 202d? | finish no earlier than 2014-09-12 | R4 | 1616h | 1616h | LTE_CA_B1_B3_B5-Perf | 32 | SK Telecom | haesung.park@sk.com | Rel-12 | 62 | Issam | CA | LTE_CA_B1_B3_B5-Perf | RP-141084 |
| 5848 | 1977.76 | **LTE Advanced 3 Band Carrier Aggregation (3DL/1UL) for Band 1, Band 3 and Band 20** | 287.5d? | 2013-12-09 A | 2014-09-12 A | 100% | 2013-12-09 | 2014-09-12 | 201d? |  | R4 | 4832h | 4832h | LTE_CA_B1_B3_B20 | 32 | Vodafone | luis.anaya@vodafone.com | Rel-12 | 62 | Issam | CA | LTE_CA_B1_B3_B20 |  |
| 5849 | 1977.76.1 | Core part:LTE Advanced 3 Band Carrier Aggregation (3DL/1UL) for Band 1, Band 3 and Band 20 | 201d? | 2013-12-09 A | 2014-09-12 A | 100% | 2013-12-09 | 2014-09-12 | 201d? | finish no earlier than 2014-09-12 | R4 | 1608h | 1608h | LTE_CA_B1_B3_B20-Core | 32 | Vodafone | luis.anaya@vodafone.com | Rel-12 | 62 | Issam | CA | LTE_CA_B1_B3_B20-Core | RP-141084 |
| 5850 | 1977.76.2 | Perf. part:LTE Advanced 3 Band Carrier Aggregation (3DL/1UL) for Band 1, Band 3 and Band 20 | 201d? | 2013-12-10 A | 2014-09-12 A | 100% | 2013-12-09 | 2014-09-12 | 201d? | finish no earlier than 2014-09-12 | R4 | 1608h | 1608h | LTE_CA_B1_B3_B20-Perf | 32 | Vodafone | luis.anaya@vodafone.com | Rel-12 | 62 | Issam | CA | LTE_CA_B1_B3_B20-Perf | RP-141084 |
| 5851 | 1977.77 | **LTE Advanced 3 Band Carrier Aggregation (3DL/1UL) for Band 1, Band 7 and Band 20** | 287.5d? | 2013-12-09 A | 2014-09-12 A | 100% | 2013-12-09 | 2014-09-12 | 201d? |  | R4 | 4832h | 4832h | LTE_CA_B1_B7_B20 | 32 | Vodafone | luis.anaya@vodafone.com | Rel-12 | 62 | Issam | CA | LTE_CA_B1_B7_B20 |  |
| 5852 | 1977.77.1 | Core part:LTE Advanced 3 Band Carrier Aggregation (3DL/1UL) for Band 1, Band 7 and Band 20 | 201d? | 2013-12-09 A | 2014-09-12 A | 100% | 2013-12-09 | 2014-09-12 | 201d? | finish no earlier than 2014-09-12 | R4 | 1608h | 1608h | LTE_CA_B1_B7_B20-Core | 32 | Vodafone | luis.anaya@vodafone.com | Rel-12 | 62 | Issam | CA | LTE_CA_B1_B7_B20-Core | RP-141084 |
| 5853 | 1977.77.2 | Perf. part:LTE Advanced 3 Band Carrier Aggregation (3DL/1UL) for Band 1, Band 7 and Band 20 | 201d? | 2013-12-10 A | 2014-09-12 A | 100% | 2013-12-09 | 2014-09-12 | 201d? | finish no earlier than 2014-09-12 | R4 | 1608h | 1608h | LTE_CA_B1_B7_B20-Perf | 32 | Vodafone | luis.anaya@vodafone.com | Rel-12 | 62 | Issam | CA | LTE_CA_B1_B7_B20-Perf | RP-141084 |
| 5854 | 1977.78 | **LTE Advanced 3 Band Carrier Aggregation (3DL/1UL) for Band 7, Band 8 and Band 20** | 384.75d? | 2013-12-09 A | 2014-12-15 A | 100% | 2013-12-09 | 2014-09-12 | 201d? |  | R4 | 6432h | 6432h | LTE_CA_B7_B8_B20 | 32 | Vodafone | luis.anaya@vodafone.com | Rel-12 | 62 | Issam | CA | LTE_CA_B7_B8_B20 |  |
| 5855 | 1977.78.1 | Core part:LTE Advanced 3 Band Carrier Aggregation (3DL/1UL) for Band 7, Band 8 and Band 20 | 267d? | 2013-12-09 A | 2014-12-15 A | 100% | 2013-12-09 | 2014-09-12 | 201d? | finish no earlier than 2014-12-15 | R4 | 2136h | 2136h | LTE_CA_B7_B8_B20-Core | 32 | Vodafone | luis.anaya@vodafone.com | Rel-12 | 62 | Issam | CA | LTE_CA_B7_B8_B20-Core | RP-141732 |
| 5856 | 1977.78.2 | Perf. part:LTE Advanced 3 Band Carrier Aggregation (3DL/1UL) for Band 7, Band 8 and Band 20 | 267d? | 2013-12-12 A | 2014-12-15 A | 100% | 2013-12-09 | 2014-09-12 | 201d? | finish no earlier than 2014-12-15 | R4 | 2136h | 2136h | LTE_CA_B7_B8_B20-Perf | 32 | Vodafone | luis.anaya@vodafone.com | Rel-12 | 62 | Issam | CA | LTE_CA_B7_B8_B20-Perf | RP-141732 |

Notes:
- 5833: Intra-band contig. CA 2DL/2UL / Impacted TSs and TRs: LTE
- 5834: RP#64 completed. TR 36.833-1-42v100 for 1-step Approval. Updated WID RP-132029=>RP-140728 / Impacted TSs and TRs: 36.101; 36.104; 36.133; new 36.833-1-42
- 5835: RP#64 completed. TR 36.833-1-42v100 for 1-step Approval. Updated WID RP-132029=>RP-140728 / Impacted TSs and TRs: 36.141; 36.307
- 5836: Intra-band contig. CA 2DL/2UL / Impacted TSs and TRs: LTE
- 5837: RP#64 completed / Impacted TSs and TRs: 36.101; 36.307
- 5838: RP#64 completed / Impacted TSs and TRs: 36.307
- 5839: Intra-band non-contig. CA 3DL / Impacted TSs and TRs: LTE
- 5840: RP#65 completed / Impacted TSs and TRs: 36.101; 36.104; 36.133; 36.307; new 36.833-6-xy
- 5841: CD:Thu 12/03/15->Sun 15/03/15¦Compl:60%->70%¦Stat Rep: RP-141084->RP-141732 1st Apr 15: Compl:70%->100% 1st Apr 15: Stat Rep: RP-141732->RP-150013 / Impacted TSs and TRs: 36.141
- 5842: Intra-band non-contig. CA 2DL / Impacted TSs and TRs: LTE
- 5843: RP#64 completed. Updated WID RP-140404=>RP-140671. TR 36.833-2-42v100 for 1-step Approval / Impacted TSs and TRs: 36.101; 36.104; 36.133; new 36.833-2-42
- 5844: RP#64 completed / Impacted TSs and TRs: 36.141; 36.307
- 5845: Inter-band CA 3DL / Impacted TSs and TRs: LTE
- 5846: RP#65 completed. Updated WID RP-132121=>RP-141454 / Impacted TSs and TRs: 36.101; 36.104; 36.133; new generic 36.853 (3 Band CA with 1UL)
- 5847: RP#65 completed. Updated WID RP-132121=>RP-141454 / Impacted TSs and TRs: 36.141; 36.307
- 5848: Inter-band CA 3DL / Impacted TSs and TRs: LTE
- 5849: RP#65 completed. Updated WID RP-141017=>RP-141222 / Impacted TSs and TRs: 36.101; 36.104; 36.133; new generic 36.851 (2 Band CA with 1UL); 36.853 (3 Band CA with 1UL)
- 5850: RP#65 completed / Impacted TSs and TRs: 36.101; 36.133; 36.141; 36.307
- 5851: Inter-band CA 3DL / Impacted TSs and TRs: LTE
- 5852: RP#65 completed. Updated WID RP-140243=>RP-141223 / Impacted TSs and TRs: 36.101; 36.104; 36.133; new generic 36.853 (3 Band CA with 1UL); 36.851 (2 Band CA with 1UL)
- 5853: RP#65 completed / Impacted TSs and TRs: 36.101; 36.133; 36.141; 36.307
- 5854: Inter-band CA 3DL / Impacted TSs and TRs: LTE
- 5855: CD:Thu 11/12/14->Mon 15/12/14¦Compl:85%->100%¦Stat Rep: RP-141084->RP-141732 / Impacted TSs and TRs: 36.101; 36.104; 36.133; new generic 36.853 (3 Band CA with 1UL); 36.851 (2 Band CA with 1UL)
- 5856: CD:Thu 11/12/14->Mon 15/12/14¦Compl:0%->100%¦Stat Rep: RP-141084->RP-141732 / Impacted TSs and TRs: 36.101; 36.133; 36.141; 36.307

| ID | WBS | Task | Duration | Start | Finish | Complete | Baseline start | Baseline finish | Baseline duration | Constraint | Resources | Work | Actual work | Acronym | PCG approved | WI rapporteur name | WI rapporteur e-mail | Release | TSG approved | MCC resp | Special Focus Doc | Acronym_3GU_Export | Status Report | PCG stopped | TSG stopped |
| --- | --- | --- | --- | --- | --- | --- | --- | --- | --- | --- | --- | --- | --- | --- | --- | --- | --- | --- | --- | --- | --- | --- | --- | --- | --- |
| 5857 | 1977.79 | **Additional bandwidth combinations for LTE Advanced inter-band Carrier Aggregation of Band 2 and Band 29 and of Band 4 and Band 29** | 4d? | 2014-03-03 A | 2014-03-06 A | 100% | 2014-03-03 | 2014-03-06 | 4d? |  | R4 | 64h | 64h | LTE_DL_FDD700_B29_Bwset | 32 | AT&T | marc.grant@att.com | Rel-12 | 63 | Issam | CA | LTE_DL_FDD700_B29_Bwset |  |  |  |
| 5858 | 1977.79.1 | Core part: Additional bandwidth combinations for LTE Advanced inter-band Carrier Aggregation of Band 2 and Band 29 and of Band 4 and Band 29 | 4d? | 2014-03-03 A | 2014-03-06 A | 100% | 2014-03-03 | 2014-03-06 | 4d? | finish no earlier than 2014-03-06 | R4 | 32h | 32h | LTE_DL_FDD700_B29_BWset-Core | 32 | AT&T | marc.grant@att.com | Rel-12 | 63 | Issam | CA | LTE_DL_FDD700_B29_BWset-Core | RP-140428 |  |  |
| 5859 | 1977.80 | **Additional bandwidth combination set for LTE Advanced inter-band Carrier Aggregation of Band 3 and Band 20** | 103.5d? | 2014-03-06 A | 2014-06-13 A | 100% | 2014-03-06 | 2014-06-13 | 72d? |  | R4 | 1152h | 1152h | LTE_CA_B3_B20_BWset | 32 | NSN | iwajlo.angelow@nsn.com | Rel-12 | 63 | Issam | CA | LTE_CA_B3_B20_BWset |  |  |  |
| 5860 | 1977.80.1 | Core part: Additional bandwidth combination set for LTE Advanced inter-band Carrier Aggregation of Band 3 and Band 20 | 72d? | 2014-03-06 A | 2014-06-13 A | 100% | 2014-03-06 | 2014-06-13 | 72d? | finish no earlier than 2014-06-13 | R4 | 576h | 576h | LTE_CA_B3_B20_BWset-Core | 32 | NSN | iwajlo.angelow@nsn.com | Rel-12 | 63 | Issam | CA | LTE_CA_B3_B20_BWset-Core | RP-140569 |  |  |
| 5861 | 1977.81 | **Additional bandwidth combination set for LTE Advanced inter-band Carrier Aggregation of Band 7 and Band 20** | 103.5d? | 2014-03-06 A | 2014-06-13 A | 100% | 2014-03-06 | 2014-06-13 | 72d? |  | R4 | 1152h | 1152h | LTE_CA_B7_B20_BWset | 32 | NSN | iwajlo.angelow@nsn.com | Rel-12 | 63 | Issam | CA | LTE_CA_B7_B20_BWset |  |  |  |
| 5862 | 1977.81.1 | Core part: Additional bandwidth combination set for LTE Advanced inter-band Carrier Aggregation of Band 7 and Band 20 | 72d? | 2014-03-06 A | 2014-06-13 A | 100% | 2014-03-06 | 2014-06-13 | 72d? | finish no earlier than 2014-06-13 | R4 | 576h | 576h | LTE_CA_B7_B20_BWset-Core | 32 | NSN | iwajlo.angelow@nsn.com | Rel-12 | 63 | Issam | CA | LTE_CA_B7_B20_BWset-Core | RP-140569 |  |  |
| 5863 | 1977.82 | **Additional bandwidth combinations for LTE Advanced inter-band Carrier Aggregation to support 3DL fallback** | 103.5d? | 2014-03-06 A | 2014-06-13 A | 100% | 2014-03-06 | 2014-06-13 | 72d? |  | R4 | 1152h | 1152h | LTE_CA_3DL_FB_BW | 32 | Qualcomm | Fong Gene (gfong@qti.qualcomm.com) | Rel-12 | 63 | Issam | CA | LTE_CA_3DL_FB_BW |  |  |  |
| 5864 | 1977.82.1 | Core part: Additional bandwidth combinations for LTE Advanced inter-band Carrier Aggregation to support 3DL fallback | 72d? | 2014-03-06 A | 2014-06-13 A | 100% | 2014-03-06 | 2014-06-13 | 72d? | finish no earlier than 2014-06-13 | R4 | 576h | 576h | LTE_CA_3DL_FB_BW-Core | 32 | Qualcomm | Fong Gene (gfong@qti.qualcomm.com) | Rel-12 | 63 | Issam | CA | LTE_CA_3DL_FB_BW-Core | RP-140569 |  |  |
| 5865 | 1977.83 | **LTE Advanced 3 Band Carrier Aggregation (3DL/1UL) of Band 3, Band 7 and Band 7** | 197.62d? | 2014-03-06 A | 2014-09-12 A | 100% | 2014-03-06 | 2014-09-12 | 137d? |  | R4 | 3296h | 3296h | LTE_CA_B3_B7_B7 | 32 | Nokia Networks | iwajlo.angelow@nsn.com | Rel-12 | 63 | Issam | CA | LTE_CA_B3_B7_B7 |  |  |  |
| 5866 | 1977.83.1 | Core part:LTE Advanced 3 Band Carrier Aggregation (3DL/1UL) of Band 3, Band 7 and Band 7 | 137d? | 2014-03-06 A | 2014-09-12 A | 100% | 2014-03-06 | 2014-09-12 | 137d? | finish no earlier than 2014-09-12 | R4 | 1096h | 1096h | LTE_CA_B3_B7_B7-Core | 32 | Nokia Networks | iwajlo.angelow@nsn.com | Rel-12 | 63 | Issam | CA | LTE_CA_B3_B7_B7-Core | RP-141084 |  |  |
| 5867 | 1977.83.2 | Perf. part:LTE Advanced 3 Band Carrier Aggregation (3DL/1UL) of Band 3, Band 7 and Band 7 | 137d? | 2014-03-06 A | 2014-09-12 A | 100% | 2014-03-06 | 2014-09-12 | 137d? | finish no earlier than 2014-09-12 | R4 | 1096h | 1096h | LTE_CA_B3_B7_B7-Perf | 32 | Nokia Networks | iwajlo.angelow@nsn.com | Rel-12 | 63 | Issam | CA | LTE_CA_B3_B7_B7-Perf | RP-141084 |  |  |
| 5868 | 1977.84 | **LTE Advanced 3 Band Carrier Aggregation (3DL/1UL) of Band 1, Band 19 and Band 21** | 197.62d? | 2014-03-06 A | 2014-09-12 A | 100% | 2014-03-06 | 2014-09-12 | 137d? |  | R4 | 3296h | 3296h | LTE_CA_B1_B19_B21 | 32 | NTT DOCOMO | teruaki.toeda.zf@nttdocomo.com | Rel-12 | 63 | Issam | CA | LTE_CA_B1_B19_B21 |  |  |  |
| 5869 | 1977.84.1 | Core part:LTE Advanced 3 Band Carrier Aggregation (3DL/1UL) of Band 1, Band 19 and Band 21 | 137d? | 2014-03-06 A | 2014-09-12 A | 100% | 2014-03-06 | 2014-09-12 | 137d? | finish no earlier than 2014-09-12 | R4 | 1096h | 1096h | LTE_CA_B1_B19_B21-Core | 32 | NTT DOCOMO | teruaki.toeda.zf@nttdocomo.com | Rel-12 | 63 | Issam | CA | LTE_CA_B1_B19_B21-Core | RP-141084 |  |  |
| 5870 | 1977.84.2 | Perf. part:LTE Advanced 3 Band Carrier Aggregation (3DL/1UL) of Band 1, Band 19 and Band 21 | 137d? | 2014-03-06 A | 2014-09-12 A | 100% | 2014-03-06 | 2014-09-12 | 137d? | finish no earlier than 2014-09-12 | R4 | 1096h | 1096h | LTE_CA_B1_B19_B21-Perf | 32 | NTT DOCOMO | teruaki.toeda.zf@nttdocomo.com | Rel-12 | 63 | Issam | CA | LTE_CA_B1_B19_B21-Perf | RP-141084 |  |  |
| 5871 | 1977.85 | **LTE Advanced 3 Band Carrier Aggregation (3DL/1UL) of Band 3, Band 3 and Band 7** | 197.62d? | 2014-03-06 A | 2014-09-12 A | 100% | 2014-03-06 | 2014-09-12 | 137d? |  | R4 | 3296h | 3296h | LTE_CA_B3_B3_B7 | 32 | TeliaSonera | Ralf.Schuh@TeliaSonera.com | Rel-12 | 63 | Issam | CA | LTE_CA_B3_B3_B7 |  |  |  |
| 5872 | 1977.85.1 | Core part: LTE-Advanced 3 Band Carrier Aggregation (3DL/1UL) of Band 3, Band 3 and Band 7 | 137d? | 2014-03-06 A | 2014-09-12 A | 100% | 2014-03-06 | 2014-09-12 | 137d? | finish no earlier than 2014-09-12 | R4 | 1096h | 1096h | LTE_CA_B3_B3_B7-Core | 32 | TeliaSonera | Ralf.Schuh@TeliaSonera.com | Rel-12 | 63 | Issam | CA | LTE_CA_B3_B3_B7-Core | RP-141084 |  |  |
| 5873 | 1977.85.2 | Perf. part: LTE-Advanced 3 Band Carrier Aggregation (3DL/1UL) of Band 3, Band 3 and Band 7 | 137d? | 2014-03-06 A | 2014-09-12 A | 100% | 2014-03-06 | 2014-09-12 | 137d? | finish no earlier than 2014-09-12 | R4 | 1096h | 1096h | LTE_CA_B3_B3_B7-Perf | 32 | TeliaSonera | Ralf.Schuh@TeliaSonera.com | Rel-12 | 63 | Issam | CA | LTE_CA_B3_B3_B7-Perf | RP-141084 |  |  |
| 5874 | 1977.86 | **LTE Advanced intra-band contiguous Carrier Aggregation in Band 40 for 3DL** | 103.5d? | 2014-03-06 A | 2014-06-13 A | 100% | 2014-03-06 | 2014-06-13 | 72d? |  | R4 | 1728h | 1728h | LTE_CA_C_B40_3DL | 32 | China Mobile | Pan Qun (panqun@chinamobile.com) | Rel-12 | 63 | Issam | CA | LTE_CA_C_B40_3DL |  |  |  |
| 5875 | 1977.86.1 | Core part: LTE Advanced intra-band contiguous Carrier Aggregation in Band 40 for 3DL | 72d? | 2014-03-06 A | 2014-06-13 A | 100% | 2014-03-06 | 2014-06-13 | 72d? | finish no earlier than 2014-06-13 | R4 | 576h | 576h | LTE_CA_C_B40_3DL-Core | 32 | China Mobile | Pan Qun (panqun@chinamobile.com) | Rel-12 | 63 | Issam | CA | LTE_CA_C_B40_3DL-Core | RP-140569 |  |  |
| 5876 | 1977.86.2 | Perf. part: LTE Advanced intra-band contiguous Carrier Aggregation in Band 40 for 3DL | 72d? | 2014-03-06 A | 2014-06-13 A | 100% | 2014-03-06 | 2014-06-13 | 72d? | finish no earlier than 2014-06-13 | R4 | 576h | 576h | LTE_CA_C_B40_3DL-Perf | 32 | China Mobile | Pan Qun (panqun@chinamobile.com) | Rel-12 | 63 | Issam | CA | LTE_CA_C_B40_3DL-Perf | RP-140569 |  |  |
| 5877 | 1977.87 | **Additional bandwidth combination set for LTE Advanced inter-band Carrier Aggregation of Band 4 and Band 12** | 196.62d? | 2014-03-07 A | 2014-09-12 A | 100% | 2014-03-06 | 2014-12-05 | 197d? |  | R4 | 3288h | 3288h | LTE_CA_B4_B12_BWset | 32 | T-Mobile USA | nelson.ueng@t-mobile.com | Rel-12 | 63 | Issam | CA | LTE_CA_B4_B12_BWset |  |  |  |
| 5878 | 1977.87.1 | Core part: Additional bandwidth combination set for LTE Advanced inter-band Carrier Aggregation of Band 4 and Band 12 | 137d? | 2014-03-07 A | 2014-09-12 A | 100% | 2014-03-06 | 2014-12-05 | 197d? | finish no earlier than 2014-09-12 | R4 | 1096h | 1096h | LTE_CA_B4_B12_BWset-Core | 32 | T-Mobile USA | nelson.ueng@t-mobile.com | Rel-12 | 63 | Issam | CA | LTE_CA_B4_B12_BWset-Core | RP-141084 |  |  |
| 5879 | 1977.87.2 | Deleted - Perf. part: Additional bandwidth combination set for LTE Advanced inter-band Carrier Aggregation of Band 4 and Band 12 | 137d? | 2014-03-07 A | 2014-09-12 A | 100% | 2014-03-06 | 2014-12-05 | 197d? | finish no earlier than 2014-09-12 | R4 | 1096h | 1096h | LTE_CA_B4_B12_BWset-Perf | 32 | T-Mobile USA | nelson.ueng@t-mobile.com | Rel-12 | 63 | Issam | CA | LTE_CA_B4_B12_BWset-Perf | RP-141084 | PCG-33 | RP-65 |
| 5880 | 1977.88 | **LTE Advanced inter-band Carrier Aggregation of Band 41 and Band 42** | 197.62d? | 2014-03-06 A | 2014-09-12 A | 100% | 2014-03-06 | 2014-09-12 | 137d? |  | R4 | 2776h | 2776h | LTE_CA_B41_B42 | 32 | Huawei | leo.liuye@huawei.com | Rel-12 | 63 | Issam | CA | LTE_CA_B41_B42 |  |  |  |
| 5881 | 1977.88.1 | Core part:LTE Advanced inter-band Carrier Aggregation of Band 41 and Band 42 | 72d? | 2014-03-06 A | 2014-09-12 A | 100% | 2014-03-06 | 2014-09-12 | 72d? | finish no earlier than 2014-09-12 | R4 | 576h | 576h | LTE_CA_B41_B42-Core | 32 | Huawei | leo.liuye@huawei.com | Rel-12 | 63 | Issam | CA | LTE_CA_B41_B42-Core | RP-141084 |  |  |
| 5882 | 1977.88.2 | Perf. Part:LTE Advanced inter-band Carrier Aggregation of Band 41 and Band 42 | 137d? | 2014-03-07 A | 2014-09-12 A | 100% | 2014-03-06 | 2014-09-12 | 137d? | finish no earlier than 2014-09-12 | R4 | 1096h | 1096h | LTE_CA_B41_B42-Perf | 32 | Huawei | leo.liuye@huawei.com | Rel-12 | 63 | Issam | CA | LTE_CA_B41_B42-Perf | RP-141084 |  |  |

Notes:
- 5857: Inter-band 2DL/1UL / Impacted TSs and TRs: LTE
- 5858: RP#63 approved WI (no Perf. Part) & completed. Rel-10 and Rel-11 versions of 36.307 affected / Impacted TSs and TRs: 36.101; 36.307
- 5859: Inter-band CA 2DL / Impacted TSs and TRs: LTE
- 5860: RP#64 completed / Impacted TSs and TRs: 36.101; 36.851
- 5861: Inter-band CA 2DL / Impacted TSs and TRs: LTE
- 5862: RP#64 completed / Impacted TSs and TRs: 36.101; 36.851
- 5863: Inter-band CA 2DL / Impacted TSs and TRs: LTE
- 5864: RP#64 completed, Additional BW combinations added for 6 Wis: 3 open Rel-12 Wis (B1_B5_B7, B2_B29_B30, B4_B29_B30) and 3 completed Rel-11 Wis (B3_B5, B4_B5, B4_B12) / Impacted TSs and TRs: 36.101; 36.307
- 5865: Inter-band CA 3DL. Mar15: acronym reverted to LTE_CA_B3_B7_B7_ / Impacted TSs and TRs: LTE
- 5866: RP#65 completed. Updated WID RP-140095=>RP-141196. Mar15: acronym reverted to LTE_CA_B3_B7_B7-Core_ / Impacted TSs and TRs: 36.101; 36.104; 36.133; new generic 36.853 (3 Band CA with 1UL)
- 5867: RP#65 completed. Updated WID RP-140095=>RP-141196. Mar15: acronym reverted from LTE_CA_B3_B7_B7-Perf_ / Impacted TSs and TRs: 36.141; 36.307
- 5868: Inter-band CA 3DL / Impacted TSs and TRs: LTE
- 5869: RP#65 completed. Updated WID RP-140106=>RP-141193 / Impacted TSs and TRs: 36.101; 36.104; 36.133; new generic 36.853 (3 Band CA with 1UL)
- 5870: RP#65 completed. Updated WID RP-140106=>RP-141193 / Impacted TSs and TRs: 36.141; 36.307
- 5871: Inter-band CA 3DL / Impacted TSs and TRs: LTE
- 5872: RP#65 completed. Updated RP-140390=>RP-141126 / Impacted TSs and TRs: 36.101; 36.104; 36.133; new generic 36.853 (3 Band CA with 1UL)
- 5873: RP#65 completed. Updated RP-140390=>RP-141126 / Impacted TSs and TRs: 36.141; 36.307
- 5874: Intra-band contig. CA 3DL / Impacted TSs and TRs: LTE
- 5875: RP#64 completed. Updated WID RP-140453=>RP-140948 / Impacted TSs and TRs: 36.101; 36.104; 36.133; New 36.833-5-40
- 5876: RP#64 completed. Updated WID RP-140453=>RP-140948 / Impacted TSs and TRs: 36.141; 36.307
- 5877: Inter-band CA 2DL / Impacted TSs and TRs: LTE
- 5878: RP#65 completed. Updated WID RP-140987=>RP-141235 (removed Perf. Part) / Impacted TSs and TRs: 36.101; generic 36.850
- 5879: RP#65 stopped. Updated WID RP-140987=>RP-141235 (removed Perf. Part) / Impacted TSs and TRs: 36.307
- 5880: Inter-band CA 2DL / Impacted TSs and TRs: LTE
- 5881: RP#65 completed / Impacted TSs and TRs: 36.101; 36.104; 36.851
- 5882: RP#65 completed / Impacted TSs and TRs: 36.141

| ID | WBS | Task | Duration | Start | Finish | Complete | Baseline start | Baseline finish | Baseline duration | Constraint | Resources | Work | Actual work | Acronym | PCG approved | WI rapporteur name | WI rapporteur e-mail | Release | TSG approved | MCC resp | Special Focus Doc | Acronym_3GU_Export | Status Report |
| --- | --- | --- | --- | --- | --- | --- | --- | --- | --- | --- | --- | --- | --- | --- | --- | --- | --- | --- | --- | --- | --- | --- | --- |
| 5883 | 1977.89 | **LTE Advanced 3 Band Carrier Aggregation (3DL/1UL) of Band 4, Band 4, and Band 12** | 197.62d? | 2014-03-06 A | 2014-09-12 A | 100% | 2014-03-06 | 2014-12-05 | 197d? |  | R4 | 3296h | 3296h | LTE_CA_B4_B4_B12 | 32 | T-Mobile USA | nelson.ueng@t-mobile.com | Rel-12 | 63 | Issam | CA | LTE_CA_B4_B4_B12 |  |
| 5884 | 1977.89.1 | Core part:LTE Advanced 3 Band Carrier Aggregation (3DL/1UL) of Band 4, Band 4, and Band 12 | 137d? | 2014-03-06 A | 2014-09-12 A | 100% | 2014-03-06 | 2014-12-05 | 197d? | finish no earlier than 2014-09-12 | R4 | 1096h | 1096h | LTE_CA_B4_B4_B12-Core | 32 | T-Mobile USA | nelson.ueng@t-mobile.com | Rel-12 | 63 | Issam | CA | LTE_CA_B4_B4_B12-Core | RP-141084 |
| 5885 | 1977.89.2 | Perf. part:LTE Advanced 3 Band Carrier Aggregation (3DL/1UL) of Band 4, Band 4, and Band 12 | 137d? | 2014-03-07 A | 2014-09-12 A | 100% | 2014-03-06 | 2014-12-05 | 197d? | finish no earlier than 2014-09-12 | R4 | 1096h | 1096h | LTE_CA_B4_B4_B12-Perf | 32 | T-Mobile USA | nelson.ueng@t-mobile.com | Rel-12 | 63 | Issam | CA | LTE_CA_B4_B4_B12-Perf | RP-141084 |
| 5886 | 1977.90 | **LTE Advanced 3 Band Carrier Aggregation (3DL/1UL) of Band 2, Band 4, and Band 4** | 197.62d? | 2014-03-06 A | 2014-09-12 A | 100% | 2014-03-06 | 2014-12-05 | 197d? |  | R4 | 3296h | 3296h | LTE_CA_B2_B4_B4 | 32 | T-Mobile USA | nelson.ueng@T-Mobile.com | Rel-12 | 63 | Issam | CA | LTE_CA_B2_B4_B4 |  |
| 5887 | 1977.90.1 | Core part:LTE Advanced 3 Band Carrier Aggregation (3DL/1UL) of Band 2, Band 4, and Band 4 | 137d? | 2014-03-06 A | 2014-09-12 A | 100% | 2014-03-06 | 2014-12-05 | 197d? | finish no earlier than 2014-09-12 | R4 | 1096h | 1096h | LTE_CA_B2_B4_B4-Core | 32 | T-Mobile USA | nelson.ueng@T-Mobile.com | Rel-12 | 63 | Issam | CA | LTE_CA_B2_B4_B4-Core | RP-141084 |
| 5888 | 1977.90.2 | Perf. part:LTE Advanced 3 Band Carrier Aggregation (3DL/1UL) of Band 2, Band 4, and Band 4 | 137d? | 2014-03-07 A | 2014-09-12 A | 100% | 2014-03-06 | 2014-12-05 | 197d? | finish no earlier than 2014-09-12 | R4 | 1096h | 1096h | LTE_CA_B2_B4_B4-Perf | 32 | T-Mobile USA | nelson.ueng@T-Mobile.com | Rel-12 | 63 | Issam | CA | LTE_CA_B2_B4_B4-Perf | RP-141084 |
| 5889 | 1977.91 | **Additional bandwidth combinations for LTE Advanced intra-band non-contiguous Carrier Aggregation in Band 25** | 197.62d? | 2014-03-06 A | 2014-09-12 A | 100% | 2014-03-06 | 2014-09-12 | 137d? |  | R4 | 3296h | 3296h | LTE_CA_NC_B25_BWset | 32 | Huawei | Liu Liehai (liuliehai@huawei.com) | Rel-12 | 63 | Issam | CA | LTE_CA_NC_B25_BWset |  |
| 5890 | 1977.91.1 | Core part: Additional bandwidth combinations for LTE Advanced intra-band non-contiguous Carrier Aggregation in Band 25 | 137d? | 2014-03-06 A | 2014-09-12 A | 100% | 2014-03-06 | 2014-09-12 | 137d? | finish no earlier than 2014-09-12 | R4 | 1096h | 1096h | LTE_CA_NC_B25_BWset-Core | 32 | Huawei | Liu Liehai (liuliehai@huawei.com) | Rel-12 | 63 | Issam | CA | LTE_CA_NC_B25_BWset-Core | RP-141084 |
| 5891 | 1977.91.2 | Perf. part: Additional bandwidth combinations for LTE Advanced intra-band non-contiguous Carrier Aggregation in Band 25 | 137d? | 2014-03-07 A | 2014-09-12 A | 100% | 2014-03-06 | 2014-09-12 | 137d? | finish no earlier than 2014-09-12 | R4 | 1096h | 1096h | LTE_CA_NC_B25_BWset-Perf | 32 | Huawei | Liu Liehai (liuliehai@huawei.com) | Rel-12 | 63 | Issam | CA | LTE_CA_NC_B25_BWset-Perf | RP-141084 |
| 5892 | 1977.92 | **Additional bandwidth combination set for LTE Advanced inter-band Carrier Aggregation of Band 2 and Band 4** | 93d? | 2014-06-15 A | 2014-09-12 A | 100% | 2014-06-13 | 2014-09-12 | 66d? |  | R4 | 1056h | 1056h | LTE_CA_B2_B4_Bwset2 | 33 | T-Mobile USA | nelson.ueng@T-Mobile.com | Rel-12 | 64 |  | CA | LTE_CA_B2_B4_BWset |  |
| 5893 | 1977.92.1 | Core part: Additional bandwidth combination set 2 for LTE Advanced inter-band Carrier Aggregation of Band 2 and Band 4 | 66d? | 2014-06-15 A | 2014-09-12 A | 100% | 2014-06-13 | 2014-09-12 | 66d? | finish no earlier than 2014-09-15 | R4 | 528h | 528h | LTE_CA_B2_B4_BWset2-Core | 33 | T-Mobile USA | nelson.ueng@T-Mobile.com | Rel-12 | 64 |  | CA | LTE_CA_B2_B4_BWset-Core | RP-141084 |
| 5894 | 1977.93 | **Additional bandwidth combination set for LTE Advanced inter-band Carrier Aggregation of Band 2 and Band 5** | 187.12d? | 2014-06-18 A | 2014-12-15 A | 100% | 2014-06-13 | 2014-09-12 | 66d? |  | R4 | 3168h | 3168h | LTE_CA_B2_B5_BWset | 33 | AT&T | marc.grant@att.com | Rel-12 | 64 |  | CA | LTE_CA_B2_B5_BWset |  |
| 5895 | 1977.93.1 | Core part: Additional bandwidth combination set for LTE Advanced inter-band Carrier Aggregation of Band 2 and Band 5 | 132d? | 2014-06-18 A | 2014-12-15 A | 100% | 2014-06-13 | 2014-09-12 | 66d? | finish no earlier than 2014-12-15 | R4 | 1056h | 1056h | LTE_CA_B2_B5_Bwset-Core | 33 | AT&T | marc.grant@att.com | Rel-12 | 64 |  | CA | LTE_CA_B2_B5_Bwset-Core | RP-141732 |
| 5896 | 1977.93.2 | Perf. Part: Additional bandwidth combination set for LTE Advanced inter-band Carrier Aggregation of Band 2 and Band 5 | 132d? | 2014-06-18 A | 2014-12-15 A | 100% | 2014-06-13 | 2014-09-12 | 66d? | finish no earlier than 2014-12-15 | R4 | 1056h | 1056h | LTE_CA_B2_B5_BWset-Perf | 33 | AT&T | marc.grant@att.com | Rel-12 | 64 |  | CA | LTE_CA_B2_B5_BWset-Perf | RP-141732 |
| 5897 | 1977.94 | **E-UTRA UE demodulation/Channel State Information (CSI) performance requirements for multiple Carrier Aggregation configurations** | 280.12d? | 2014-06-16 A | 2015-03-13 A | 100% | 2014-06-13 | 2015-03-13 | 196d? |  | R4 | 3152h | 3152h | LTE_CA_Mult | 33 | China Mobile | Zhang Xiaoran (zhangxiaoran@chinamobile.com) | Rel-12 | 64 |  | CA | LTE_CA_Mult |  |
| 5898 | 1977.94.1 | Perf. Part: E-UTRA UE demodulation/Channel State Information (CSI) performance requirements for multiple Carrier Aggregation configurations | 196d? | 2014-06-16 A | 2015-03-13 A | 100% | 2014-06-13 | 2015-03-13 | 196d? | finish no earlier than 2015-03-15 | R4 | 1568h | 1568h | LTE_CA_Mult-Perf | 33 | China Mobile | Zhang Xiaoran (zhangxiaoran@chinamobile.com) | Rel-12 | 64 |  | CA | LTE_CA_Mult-Perf | RP-150188 |
| 5899 | 1977.95 | **LTE Advanced 3 Band Carrier Aggregation (3DL/1UL) of Band 1, Band 3 and Band 19** | 91.88d? | 2014-06-16 A | 2014-09-12 A | 100% | 2014-06-13 | 2014-09-12 | 66d? |  | R4 | 1584h | 1584h | LTE_CA_B1_B3_B19 | 33 | NTT DOCOMO | teruaki.toeda.zf@nttdocomo.com | Rel-12 | 64 |  | CA | LTE_CA_B1_B3_B19 |  |
| 5900 | 1977.95.1 | Core part:LTE Advanced 3 Band Carrier Aggregation (3DL/1UL) of Band 1, Band 3 and Band 19 | 66d? | 2014-06-16 A | 2014-09-12 A | 100% | 2014-06-13 | 2014-09-12 | 66d? | finish no earlier than 2014-09-12 | R4 | 528h | 528h | LTE_CA_B1_B3_B19-Core | 33 | NTT DOCOMO | teruaki.toeda.zf@nttdocomo.com | Rel-12 | 64 |  | CA | LTE_CA_B1_B3_B19-Core | RP-141084 |
| 5901 | 1977.95.2 | Perf. Part:LTE Advanced 3 Band Carrier Aggregation (3DL/1UL) of Band 1, Band 3 and Band 19 | 66d? | 2014-06-16 A | 2014-09-12 A | 100% | 2014-06-13 | 2014-09-12 | 66d? | finish no earlier than 2014-09-12 | R4 | 528h | 528h | LTE_CA_B1_B3_B19-Perf | 33 | NTT DOCOMO | teruaki.toeda.zf@nttdocomo.com | Rel-12 | 64 |  | CA | LTE_CA_B1_B3_B19-Perf | RP-141084 |
| 5902 | 1977.96 | **LTE Advanced 3 Band Carrier Aggregation (3DL/1UL) of Band 19, Band 42 and Band 42** | 91.88d? | 2014-06-16 A | 2014-09-12 A | 100% | 2014-06-13 | 2014-09-12 | 66d? |  | R4 | 1584h | 1584h | LTE_CA_B19_B42_B42 | 33 | NTT DOCOMO | teruaki.toeda.zf@nttdocomo.com | Rel-12 | 64 |  | CA | LTE_CA_B19_B42_B42 |  |
| 5903 | 1977.96.1 | Core part:LTE Advanced 3 Band Carrier Aggregation (3DL/1UL) of Band 19, Band 42 and Band 42 | 66d? | 2014-06-16 A | 2014-09-12 A | 100% | 2014-06-13 | 2014-09-12 | 66d? | finish no earlier than 2014-09-12 | R4 | 528h | 528h | LTE_CA_B19_B42_B42-Core | 33 | NTT DOCOMO | teruaki.toeda.zf@nttdocomo.com | Rel-12 | 64 |  | CA | LTE_CA_B19_B42_B42-Core | RP-141084 |
| 5904 | 1977.96.2 | Perf. Part:LTE Advanced 3 Band Carrier Aggregation (3DL/1UL) of Band 19, Band 42 and Band 42 | 66d? | 2014-06-16 A | 2014-09-12 A | 100% | 2014-06-13 | 2014-09-12 | 66d? | finish no earlier than 2014-09-12 | R4 | 528h | 528h | LTE_CA_B19_B42_B42-Perf | 33 | NTT DOCOMO | teruaki.toeda.zf@nttdocomo.com | Rel-12 | 64 |  | CA | LTE_CA_B19_B42_B42-Perf | RP-141084 |
| 5905 | 1977.97 | **LTE Advanced 3 Band Carrier Aggregation (3DL/1UL) of Band 3, Band 42 and Band 42** | 280.12d? | 2014-06-16 A | 2015-03-13 A | 100% | 2014-06-13 | 2014-09-12 | 66d? |  | R4 | 4720h | 4720h | LTE_CA_B3_B42_B42 | 33 | NTT DOCOMO | ANDO Kei (kei.andou.ye@nttdocomo.com) | Rel-12 | 64 |  | CA | LTE_CA_B3_B42_B42 |  |
| 5906 | 1977.97.1 | Core part:LTE Advanced 3 Band Carrier Aggregation (3DL/1UL) of Band 3, Band 42 and Band 42 | 196d? | 2014-06-16 A | 2015-03-13 A | 100% | 2014-06-13 | 2014-09-12 | 66d? | finish no earlier than 2015-03-15 | R4 | 1568h | 1568h | LTE_CA_B3_B42_B42-Core | 33 | NTT DOCOMO | ANDO Kei (kei.andou.ye@nttdocomo.com) | Rel-12 | 64 |  | CA | LTE_CA_B3_B42_B42-Core | RP-150013 |
| 5907 | 1977.97.2 | Perf. Part:LTE Advanced 3 Band Carrier Aggregation (3DL/1UL) of Band 3, Band 42 and Band 42 | 196d? | 2014-06-16 A | 2015-03-13 A | 100% | 2014-06-13 | 2014-09-12 | 66d? | finish no earlier than 2016-03-15 | R4 | 1568h | 1568h | LTE_CA_B3_B42_B42-Perf | 33 | NTT DOCOMO | ANDO Kei (kei.andou.ye@nttdocomo.com) | Rel-12 | 64 |  | CA | LTE_CA_B3_B42_B42-Perf | RP-150013 |

Notes:
- 5883: Inter-band CA 3DL / Impacted TSs and TRs: LTE
- 5884: RP#65 completed. Updated WID RP-140116=>RP-141709 / Impacted TSs and TRs: 36.101; 36.104; 36.133; 36.141; 36.307; generic 36.853 (3 Band CA with 1UL)
- 5885: RP#65 completed / Impacted TSs and TRs: 36.101; 36.104; 36.133; 36.141; 36.307
- 5886: Inter-band CA 3DL / Impacted TSs and TRs: LTE
- 5887: RP#65 completed. Updated WID RP-140117=>RP-141236 / Impacted TSs and TRs: 36.101; 36.104; 36.133; 36.141; 36.307; generic 36.853 (3 Band CA with 1UL)
- 5888: RP#65 completed / Impacted TSs and TRs: 36.101; 36.104; 36.133; 36.141; 36.307
- 5889: Intra-band non-contig. CA 2DL / Impacted TSs and TRs: LTE
- 5890: RP#65 completed / Impacted TSs and TRs: 36.101; 36.307; 36.833-2-25
- 5891: RP#65 completed / Impacted TSs and TRs: 36.307
- 5892: Inter-band CA 2DL. Mar 15: acronym changed from LTE_CA_B2_B4_Bwset_ / Impacted TSs and TRs: LTE
- 5893: Dec 14: Prev CD:Fri 12/09/14¦Prev %:100%, title changed. Mar 15: Acronym changed to LTE_CA_B2_B4_BWset2-Core_ / Impacted TSs and TRs: 36.101; 36.851
- 5894: 2DL/1UL / Impacted TSs and TRs: LTE
- 5895: ¦WID: RP-142043->RP-141803¦Stat Rep: RP-141084->RP-141732 / Impacted TSs and TRs: 36.101; 36.851
- 5896: CD:Thu 11/12/14->Mon 15/12/14¦Compl:0%->0%¦Stat Rep: RP-141084->RP-141732 / Impacted TSs and TRs: 36.307
- 5897: LTE / Impacted TSs and TRs: LTE
- 5898: CD:Thu 12/03/15->Sun 15/03/15¦Compl:10%->90%¦Stat Rep: RP-141303->RP-141839 1st Apr 15: Compl:90%->100% 1st Apr 15: Stat Rep: RP-141839->RP-150188 / Impacted TSs and TRs: 36.101
- 5899: Inter-band CA 3DL / Impacted TSs and TRs: LTE
- 5900: RP#65 completed / Impacted TSs and TRs: 36.101; 36.104; 36.133; generic 36.853 (3 Band CA with 1UL)
- 5901: RP#65 completed / Impacted TSs and TRs: 36.141; 36.307
- 5902: Inter-band CA 3DL / Impacted TSs and TRs: LTE
- 5903: RP#65 completed / Impacted TSs and TRs: 36.101; 36.104; 36.133; generic 36.853 (3 Band CA with 1UL)
- 5904: RP#65 completed / Impacted TSs and TRs: 36.141; 36.307
- 5905: 3DL/1UL / Impacted TSs and TRs: LTE
- 5906: CD:Thu 11/12/14->Sun 15/03/15¦Compl:50%->70%¦Stat Rep: RP-141084->RP-141732 1st Apr 15: Compl:70%->100% 1st Apr 15: Stat Rep: RP-141732->RP-150013 / Impacted TSs and TRs: 36.101; 36.104; 36.133; generic 36.853 (3 Band CA with 1UL)
- 5907: CD:Thu 11/12/14->Tue 15/03/16¦Compl:50%->70%¦Stat Rep: RP-141084->RP-141732 1st Apr 15: Compl:70%->100% 1st Apr 15: CD:Tue 15/03/16->Sun 15/03/15 1st Apr 15: Stat Rep: RP-141732->RP-150013 / Impacted TSs and TRs: 36.141; 36.307

| ID | WBS | Task | Duration | Start | Finish | Complete | Baseline start | Baseline finish | Baseline duration | Constraint | Resources | Work | Actual work | Acronym | PCG approved | Impacted TSs and TRs | WI rapporteur name | WI rapporteur e-mail | Release | TSG approved | Special Focus Doc | Acronym_3GU_Export | Status Report | MCC resp |
| --- | --- | --- | --- | --- | --- | --- | --- | --- | --- | --- | --- | --- | --- | --- | --- | --- | --- | --- | --- | --- | --- | --- | --- | --- |
| 5908 | 1977.98 | **LTE Advanced 3 Band Carrier Aggregation (3DL/1UL) of Band 1, Band 42 and Band 42** | 91.88d? | 2014-06-16 A | 2014-09-12 A | 100% | 2014-06-13 | 2014-09-12 | 66d? |  | R4 | 1584h | 1584h | LTE_CA_B1_B42_B42 | 33 | LTE | NTT DOCOMO | ANDO Kei (kei.andou.ye@nttdocomo.com) | Rel-12 | 64 | CA | LTE_CA_B1_B42_B42 |  |  |
| 5909 | 1977.98.1 | Core part:LTE Advanced 3 Band Carrier Aggregation (3DL/1UL) of Band 1, Band 42 and Band 42 | 66d? | 2014-06-16 A | 2014-09-12 A | 100% | 2014-06-13 | 2014-09-12 | 66d? | finish no earlier than 2014-09-12 | R4 | 528h | 528h | LTE_CA_B1_B42_B42-Core | 33 | 36.101; 36.104; 36.133; generic 36.853 (3 Band CA with 1UL) | NTT DOCOMO | ANDO Kei (kei.andou.ye@nttdocomo.com) | Rel-12 | 64 | CA | LTE_CA_B1_B42_B42-Core | RP-141084 |  |
| 5910 | 1977.98.2 | Perf. Part:LTE Advanced 3 Band Carrier Aggregation (3DL/1UL) of Band 1, Band 42 and Band 42 | 66d? | 2014-06-16 A | 2014-09-12 A | 100% | 2014-06-13 | 2014-09-12 | 66d? | finish no earlier than 2014-09-12 | R4 | 528h | 528h | LTE_CA_B1_B42_B42-Perf | 33 | 36.141; 36.307 | NTT DOCOMO | ANDO Kei (kei.andou.ye@nttdocomo.com) | Rel-12 | 64 | CA | LTE_CA_B1_B42_B42-Perf | RP-141084 |  |
| 5911 | 1977.99 | **Additional bandwidth combination set for LTE Advanced intra-band contiguous Carrier Aggregation in Band 40 for 3DL** | 91.88d? | 2014-06-16 A | 2014-09-12 A | 100% | 2014-06-13 | 2014-09-12 | 66d? |  | R4 | 1096h | 1096h | LTE_CA_C_B40_3DL_BW | 33 | LTE | TeliaSonera | Ralf.Schuh@TeliaSonera.com | Rel-12 | 64 | CA | LTE_CA_C_B40_3DL_BW |  |  |
| 5912 | 1977.99.1 | Core part: Additional bandwidth combination set for LTE Advanced intra-band contiguous Carrier Aggregation in Band 40 for 3DL | 66d? | 2014-06-16 A | 2014-09-12 A | 100% | 2014-06-13 | 2014-09-12 | 66d? | finish no earlier than 2014-09-12 | R4 | 528h | 528h | LTE_CA_C_B40_3DL_BW-Core | 33 | 36.101 | TeliaSonera | Ralf.Schuh@TeliaSonera.com | Rel-12 | 64 | CA | LTE_CA_C_B40_3DL_BW-Core | RP-141084 |  |
| 5913 | 1977.99.2 | Perf. part: Additional bandwidth combination set for LTE Advanced intra-band contiguous Carrier Aggregation in Band 40 for 3DL | 5d? | 2014-09-08 A | 2014-09-12 A | 100% |  |  |  | finish no earlier than 2014-09-12 | R4 | 40h | 40h | LTE_CA_C_B40_3DL_BW-Perf | 33 | 36.307 | TeliaSonera | Ralf.Schuh@TeliaSonera.com | Rel-12 | 65 |  | LTE_CA_C_B40_3DL_BW-Perf | RP-141084 |  |
| 5914 | 1977.100 | **LTE Advanced inter-band Carrier Aggregation of Band 18 and Band 28** | 3d? | 2014-09-10 A | 2014-09-12 A | 100% | 2014-03-06 | 2015-03-13 | 267d? |  | R4 | 72h | 72h | LTE_CA_B18_B28 | 33 | LTE | KDDI | Masaaki Obara (ms-obara@kddi.com) | Rel-12 | 65 | CA | LTE_CA_B18_B28 |  | Issam |
| 5915 | 1977.100.1 | Core part:LTE Advanced inter-band Carrier Aggregation of Band 18 and Band 28 | 3d? | 2014-09-10 A | 2014-09-12 A | 100% | 2014-03-06 | 2015-03-13 | 267d? | finish no earlier than 2014-09-12 | R4 | 24h | 24h | LTE_CA_B18_B28-Core | 33 | 36.101; 36.104; 36.133 | KDDI | Masaaki Obara (ms-obara@kddi.com) | Rel-12 | 65 | CA | LTE_CA_B18_B28-Core |  | Issam |
| 5916 | 1977.100.2 | Perf. Part:LTE Advanced inter-band Carrier Aggregation of Band 18 and Band 28 | 3d? | 2014-09-10 A | 2014-09-12 A | 100% | 2014-03-06 | 2015-03-13 | 267d? | finish no earlier than 2014-09-12 | R4 | 24h | 24h | LTE_CA_B18_B28-Perf | 33 | 36.141; 36.307 | KDDI | Masaaki Obara (ms-obara@kddi.com) | Rel-12 | 65 | CA | LTE_CA_B18_B28-Perf |  | Issam |
| 5917 | 1977.101 | **LTE Advanced inter-band Carrier Aggregation of Band 5 and Band 13** | 294.88d? | 2014-03-06 A | 2014-12-15 A | 100% | 2014-03-06 | 2014-12-05 | 197d? |  | R4 | 4896h | 4896h | LTE_CA_B5_B13 | 32 | LTE | Intel | xinrong.wang@intel.com | Rel-12 | 63 | CA | LTE_CA_B5_B13 |  | Issam |
| 5918 | 1977.101.1 | Core part:LTE Advanced inter-band Carrier Aggregation of Band 5 and Band 13 | 203d? | 2014-03-06 A | 2014-12-15 A | 100% | 2014-03-06 | 2014-12-05 | 197d? | finish no earlier than 2014-12-15 | R4 | 1624h | 1624h | LTE_CA_B5_B13-Core | 32 | 36.101; 36.104; 36.133; generic 36.851 (2 Band CA with 1UL) | Intel | xinrong.wang@intel.com | Rel-12 | 63 | CA | LTE_CA_B5_B13-Core | RP-141732 | Issam |
| 5919 | 1977.101.2 | Perf. part:LTE Advanced inter-band Carrier Aggregation of Band 5 and Band 13 | 203d? | 2014-03-06 A | 2014-12-15 A | 100% | 2014-03-06 | 2014-12-05 | 197d? | finish no earlier than 2014-12-15 | R4 | 1624h | 1624h | LTE_CA_B5_B13-Perf | 32 | 36.101; 36.133; 36.141; 36.307 | Intel | xinrong.wang@intel.com | Rel-12 | 63 | CA | LTE_CA_B5_B13-Perf | RP-141732 | Issam |
| 5920 | 1977.102 | **LTE Advanced 3 Band Carrier Aggregation (3DL/1UL) of Band 2, Band 2 and Band 5** | 294.88d? | 2014-03-06 A | 2014-12-15 A | 100% | 2014-03-06 | 2014-12-05 | 197d? |  | R4 | 4912h | 4912h | LTE_CA_B2_B2_B5 | 32 | LTE | Intel | peiling.zhang@intel.com | Rel-12 | 63 | CA | LTE_CA_B2_B2_B5 |  | Issam |
| 5921 | 1977.102.1 | Core part:LTE Advanced 3 Band Carrier Aggregation (3DL/1UL) of Band 2, Band 2 and Band 5 | 205d? | 2014-03-06 A | 2014-12-15 A | 100% | 2014-03-06 | 2014-12-05 | 197d? | finish no earlier than 2014-12-15 | R4 | 1640h | 1640h | LTE_CA_B2_B2_B5-Core | 32 | 36.101; 36.104; 36.133; generic 36.853 (3 Band CA with 1UL) | Intel | peiling.zhang@intel.com | Rel-12 | 63 | CA | LTE_CA_B2_B2_B5-Core | RP-141732 | Issam |
| 5922 | 1977.102.2 | Perf. part:LTE Advanced 3 Band Carrier Aggregation (3DL/1UL) of Band 2, Band 2 and Band 5 | 203d? | 2014-03-06 A | 2014-12-15 A | 100% | 2014-03-06 | 2014-12-05 | 197d? | finish no earlier than 2014-12-15 | R4 | 1624h | 1624h | LTE_CA_B2_B2_B5-Perf | 32 | 36.101; 36.133; 36.141; 36.307 | Intel | peiling.zhang@intel.com | Rel-12 | 63 | CA | LTE_CA_B2_B2_B5-Perf | RP-141732 | Issam |
| 5923 | 1977.103 | **LTE Advanced 3 Band Carrier Aggregation (3DL/1UL) of Band 4, Band 4 and Band 5** | 294.88d? | 2014-03-06 A | 2014-12-15 A | 100% | 2014-03-06 | 2014-12-05 | 197d? |  | R4 | 4912h | 4912h | LTE_CA_B4_B4_B5 | 32 | LTE | Intel | peiling.zhang@intel.com | Rel-12 | 63 | CA | LTE_CA_B4_B4_B5 |  | Issam |
| 5924 | 1977.103.1 | Core part:LTE Advanced 3 Band Carrier Aggregation (3DL/1UL) of Band 4, Band 4 and Band 5 | 205d? | 2014-03-06 A | 2014-12-15 A | 100% | 2014-03-06 | 2014-12-05 | 197d? | finish no earlier than 2014-12-15 | R4 | 1640h | 1640h | LTE_CA_B4_B4_B5-Core | 32 | 36.101; 36.104; 36.133; generic 36.853 (3 Band CA with 1UL) | Intel | peiling.zhang@intel.com | Rel-12 | 63 | CA | LTE_CA_B4_B4_B5-Core | RP-141732 | Issam |
| 5925 | 1977.103.2 | Perf. part:LTE Advanced 3 Band Carrier Aggregation (3DL/1UL) of Band 4, Band 4 and Band 5 | 203d? | 2014-03-06 A | 2014-12-15 A | 100% | 2014-03-06 | 2014-12-05 | 197d? | finish no earlier than 2014-12-15 | R4 | 1624h | 1624h | LTE_CA_B4_B4_B5-Perf | 32 | 36.101; 36.133; 36.141; 36.307 | Intel | peiling.zhang@intel.com | Rel-12 | 63 | CA | LTE_CA_B4_B4_B5-Perf | RP-141732 | Issam |
| 5926 | 1977.104 | **LTE Advanced 3 Band Carrier Aggregation (3DL/1UL) of Band 2, Band 5 and Band 13** | 294.88d? | 2014-03-06 A | 2014-12-15 A | 100% | 2014-03-06 | 2014-12-05 | 197d? |  | R4 | 4896h | 4896h | LTE_CA_B2_B5_B13 | 32 | LTE | Intel | xinrong.wang@intel.com | Rel-12 | 63 | CA | LTE_CA_B2_B5_B13 |  | Issam |
| 5927 | 1977.104.1 | Core part:LTE Advanced 3 Band Carrier Aggregation (3DL/1UL) of Band 2, Band 5 and Band 13 | 203d? | 2014-03-06 A | 2014-12-15 A | 100% | 2014-03-06 | 2014-12-05 | 197d? | finish no earlier than 2014-12-15 | R4 | 1624h | 1624h | LTE_CA_B2_B5_B13-Core | 32 | 36.101; 36.104; 36.133; generic 36.853 (3 Band CA with 1UL) | Intel | xinrong.wang@intel.com | Rel-12 | 63 | CA | LTE_CA_B2_B5_B13-Core | RP-141732 | Issam |
| 5928 | 1977.104.2 | Perf. part:LTE Advanced 3 Band Carrier Aggregation (3DL/1UL) of Band 2, Band 5 and Band 13 | 203d? | 2014-03-06 A | 2014-12-15 A | 100% | 2014-03-06 | 2014-12-05 | 197d? | finish no earlier than 2014-12-15 | R4 | 1624h | 1624h | LTE_CA_B2_B5_B13-Perf | 32 | 36.101; 36.133; 36.141; 36.307 | Intel | xinrong.wang@intel.com | Rel-12 | 63 | CA | LTE_CA_B2_B5_B13-Perf | RP-141732 | Issam |
| 5929 | 1977.105 | **LTE Advanced 3 Band Carrier Aggregation (3DL/1UL) of Band 4, Band 5 and Band 13** | 294.88d? | 2014-03-06 A | 2014-12-15 A | 100% | 2014-03-06 | 2014-12-05 | 197d? |  | R4 | 4896h | 4896h | LTE_CA_B4_B5_B13 | 32 | LTE | Intel | xinrong.wang@intel.com | Rel-12 | 63 | CA | LTE_CA_B4_B5_B13 |  | Issam |
| 5930 | 1977.105.1 | Core part:LTE Advanced 3 Band Carrier Aggregation (3DL/1UL) of Band 4, Band 5 and Band 13 | 203d? | 2014-03-06 A | 2014-12-15 A | 100% | 2014-03-06 | 2014-12-05 | 197d? | finish no earlier than 2014-12-15 | R4 | 1624h | 1624h | LTE_CA_B4_B5_B13-Core | 32 | 36.101; 36.104; 36.133; generic 36.853 (3 Band CA with 1UL) | Intel | xinrong.wang@intel.com | Rel-12 | 63 | CA | LTE_CA_B4_B5_B13-Core | RP-141732 | Issam |
| 5931 | 1977.105.2 | Perf. part:LTE Advanced 3 Band Carrier Aggregation (3DL/1UL) of Band 4, Band 5 and Band 13 | 203d? | 2014-03-06 A | 2014-12-15 A | 100% | 2014-03-06 | 2014-12-05 | 197d? | finish no earlier than 2014-12-15 | R4 | 1624h | 1624h | LTE_CA_B4_B5_B13-Perf | 32 | 36.101; 36.133; 36.141; 36.307 | Intel | xinrong.wang@intel.com | Rel-12 | 63 | CA | LTE_CA_B4_B5_B13-Perf | RP-141732 | Issam |

Notes:
- 5908: Inter-band CA 3DL
- 5909: RP#65 completed
- 5910: RP#65 completed
- 5911: Inter-band CA 3DL
- 5912: RP#65 completed. Updated WID RP-140950=>RP-141127
- 5913: RP#65 updated WID RP-140950=>RP-141127 (added Perf. Part). Completed.
- 5914: Inter-band CA 2DL
- 5915: RP#65 WID approved & completed. Triggered by revised Rel-13 WID RP-140451=>RP-141610 (take out B18_B28 for Rel-12 from the Rel-13 B1_B18_B28)
- 5916: -
- 5917: Inter-band CA 2DL
- 5918: CD:Thu 12/03/15->Mon 15/12/14¦Compl:50%->100%¦Stat Rep: RP-141084->RP-141732¦Release: Rel-13->Rel-12
- 5919: CD:Thu 12/03/15->Mon 15/12/14¦Compl:10%->100%¦Stat Rep: RP-141084->RP-141732¦Release: Rel-13->Rel-12
- 5920: Inter-band CA 3DL
- 5921: CD:Thu 12/03/15->Mon 15/12/14¦Compl:90%->100%¦Stat Rep: RP-141084->RP-141732¦Release: Rel-13->Rel-12
- 5922: CD:Thu 12/03/15->Mon 15/12/14¦Compl:10%->100%¦Stat Rep: RP-141084->RP-141732¦Release: Rel-13->Rel-12
- 5923: Inter-band CA 3DL
- 5924: CD:Thu 12/03/15->Mon 15/12/14¦Compl:90%->100%¦Stat Rep: RP-141084->RP-141732¦Release: Rel-13->Rel-12
- 5925: CD:Thu 12/03/15->Mon 15/12/14¦Compl:10%->100%¦Stat Rep: RP-141084->RP-141732¦Release: Rel-13->Rel-12
- 5926: Inter-band CA 3DL
- 5927: CD:Thu 12/03/15->Mon 15/12/14¦Compl:50%->100%¦Stat Rep: RP-141084->RP-141732¦Release: Rel-13->Rel-12
- 5928: CD:Thu 12/03/15->Mon 15/12/14¦Compl:10%->100%¦Stat Rep: RP-141084->RP-141732¦Release: Rel-13->Rel-12
- 5929: Inter-band CA 3DL
- 5930: CD:Thu 12/03/15->Mon 15/12/14¦Compl:50%->100%¦Stat Rep: RP-141084->RP-141732¦Release: Rel-13->Rel-12
- 5931: CD:Thu 12/03/15->Mon 15/12/14¦Compl:10%->100%¦Stat Rep: RP-141084->RP-141732¦Release: Rel-13->Rel-12

| ID | WBS | Task | Duration | Start | Finish | Complete | Baseline start | Baseline finish | Baseline duration | Constraint | Resources | Work | Actual work | Acronym | PCG approved | WI rapporteur name | WI rapporteur e-mail | Release | TSG approved | MCC resp | Special Focus Doc | Acronym_3GU_Export | Status Report |
| --- | --- | --- | --- | --- | --- | --- | --- | --- | --- | --- | --- | --- | --- | --- | --- | --- | --- | --- | --- | --- | --- | --- | --- |
| 5932 | 1977.106 | **LTE Advanced 3 Band Carrier Aggregation (3DL/1UL) of Band 1, Band 3 and Band 26** | 294.88d? | 2014-03-06 A | 2014-12-15 A | 100% | 2014-03-06 | 2014-12-05 | 197d? |  | R4 | 4896h | 4896h | LTE_CA_B1_B3_B26 | 32 | China Telecom | Zhao Dong (zhaodong@ctbri.com.cn) | Rel-12 | 63 | Issam | CA | LTE_CA_B1_B3_B26 |  |
| 5933 | 1977.106.1 | Core part:LTE Advanced 3 Band Carrier Aggregation (3DL/1UL) of Band 1, Band 3 and Band 26 | 203d? | 2014-03-06 A | 2014-12-15 A | 100% | 2014-03-06 | 2014-12-05 | 197d? | finish no earlier than 2014-12-15 | R4 | 1624h | 1624h | LTE_CA_B1_B3_B26-Core | 32 | China Telecom | Zhao Dong (zhaodong@ctbri.com.cn) | Rel-12 | 63 | Issam | CA | LTE_CA_B1_B3_B26-Core | RP-141732 |
| 5934 | 1977.106.2 | Perf. part:LTE Advanced 3 Band Carrier Aggregation (3DL/1UL) of Band 1, Band 3 and Band 26 | 203d? | 2014-03-06 A | 2014-12-15 A | 100% | 2014-03-06 | 2014-12-05 | 197d? | finish no earlier than 2014-12-15 | R4 | 1624h | 1624h | LTE_CA_B1_B3_B26-Perf | 32 | China Telecom | Zhao Dong (zhaodong@ctbri.com.cn) | Rel-12 | 63 | Issam | CA | LTE_CA_B1_B3_B26-Perf | RP-141732 |
| 5935 | 1977.107 | **LTE Advanced 3 Band Carrier Aggregation (3DL/1UL) of Band 1, Band 18 and Band 28** | 294.88d? | 2014-03-06 A | 2014-12-15 A | 100% | 2014-03-06 | 2015-03-13 | 267d? |  | R4 | 4896h | 4896h | LTE_CA_B1_B18_B28 | 32 | KDDI | Masaaki Obara (ms-obara@kddi.com) | Rel-12 | 63 | Issam | CA | LTE_CA_B1_B18_B28 |  |
| 5936 | 1977.107.1 | Core part:LTE Advanced 3 Band Carrier Aggregation (3DL/1UL) of Band 1, Band 18 and Band 28 | 203d? | 2014-03-06 A | 2014-12-15 A | 100% | 2014-03-06 | 2015-03-13 | 267d? | finish no earlier than 2014-12-15 | R4 | 1624h | 1624h | LTE_CA_B1_B18_B28-Core | 32 | KDDI | Masaaki Obara (ms-obara@kddi.com) | Rel-12 | 63 | Issam | CA | LTE_CA_B1_B18_B28-Core | RP-141732 |
| 5937 | 1977.107.2 | Perf. part:LTE Advanced 3 Band Carrier Aggregation (3DL/1UL) of Band 1, Band 18 and Band 28 | 203d? | 2014-03-11 A | 2014-12-15 A | 100% | 2014-03-06 | 2015-03-13 | 267d? | finish no earlier than 2014-12-15 | R4 | 1624h | 1624h | LTE_CA_B1_B18_B28-Perf | 32 | KDDI | Masaaki Obara (ms-obara@kddi.com) | Rel-12 | 63 | Issam | CA | LTE_CA_B1_B18_B28-Perf | RP-141732 |
| 5938 | 1977.108 | **LTE Advanced 3 Band Carrier Aggregation (3DL/1UL) of Band 4, Band 7 and Band 12** | 187.12d? | 2014-06-18 A | 2014-12-15 A | 100% | 2014-06-13 | 2015-03-13 | 196d? |  | R4 | 3168h | 3168h | LTE_CA_B4_B7_B12 | 33 | Rogers Wireless | pavlo.nebesny@rci.rogers.com | Rel-12 | 64 |  | CA | LTE_CA_B4_B7_B12 |  |
| 5939 | 1977.108.1 | Core part:LTE Advanced 3 Band Carrier Aggregation (3DL/1UL) of Band 4, Band 7 and Band 12 | 132d? | 2014-06-18 A | 2014-12-15 A | 100% | 2014-06-13 | 2015-03-13 | 196d? | finish no earlier than 2014-12-15 | R4 | 1056h | 1056h | LTE_CA_B4_B7_B12-Core | 33 | Rogers Wireless | pavlo.nebesny@rci.rogers.com | Rel-12 | 64 |  | CA | LTE_CA_B4_B7_B12-Core | RP-141732 |
| 5940 | 1977.108.2 | Perf. Part:LTE Advanced 3 Band Carrier Aggregation (3DL/1UL) of Band 4, Band 7 and Band 12 | 132d? | 2014-06-18 A | 2014-12-15 A | 100% | 2014-06-13 | 2015-03-13 | 196d? | finish no earlier than 2014-12-15 | R4 | 1056h | 1056h | LTE_CA_B4_B7_B12-Perf | 33 | Rogers Wireless | pavlo.nebesny@rci.rogers.com | Rel-12 | 64 |  | CA | LTE_CA_B4_B7_B12-Perf | RP-141732 |
| 5941 | 1977.109 | **LTE Advanced 3 Band Carrier Aggregation (3DL/1UL) of Band 4, Band 4 and Band 7** | 187.12d? | 2014-06-18 A | 2014-12-15 A | 100% | 2014-06-13 | 2015-03-13 | 196d? |  | R4 | 3168h | 3168h | LTE_CA_B4_B4_B7 | 33 | Rogers Wireless | pavlo.nebesny@rci.rogers.com | Rel-12 | 64 |  | CA | LTE_CA_B4_B4_B7 |  |
| 5942 | 1977.109.1 | Core part:LTE Advanced 3 Band Carrier Aggregation (3DL/1UL) of Band 4, Band 4 and Band 7 | 132d? | 2014-06-18 A | 2014-12-15 A | 100% | 2014-06-13 | 2015-03-13 | 196d? | finish no earlier than 2014-12-15 | R4 | 1056h | 1056h | LTE_CA_B4_B4_B7-Core | 33 | Rogers Wireless | pavlo.nebesny@rci.rogers.com | Rel-12 | 64 |  | CA | LTE_CA_B4_B4_B7-Core | RP-141732 |
| 5943 | 1977.109.2 | Perf. Part:LTE Advanced 3 Band Carrier Aggregation (3DL/1UL) of Band 4, Band 4 and Band 7 | 132d? | 2014-06-18 A | 2014-12-15 A | 100% | 2014-06-13 | 2015-03-13 | 196d? | finish no earlier than 2014-12-15 | R4 | 1056h | 1056h | LTE_CA_B4_B4_B7-Perf | 33 | Rogers Wireless | pavlo.nebesny@rci.rogers.com | Rel-12 | 64 |  | CA | LTE_CA_B4_B4_B7-Perf | RP-141732 |
| 5944 | 1977.110 | **LTE Advanced 3 Band Carrier Aggregation (3DL/1UL) of Band 39, Band 41 and Band 41** | 189.12d? | 2014-06-16 A | 2014-12-15 A | 100% | 2014-06-13 | 2014-12-05 | 126d? |  | R4 | 3184h | 3184h | LTE_CA_B39_B41_B41 | 33 | China Mobile | PAN Qun (panqun@chinamobile.com) | Rel-12 | 64 |  | CA | LTE_CA_B39_B41_B41 |  |
| 5945 | 1977.110.1 | Core part:LTE Advanced 3 Band Carrier Aggregation (3DL/1UL) of Band 39, Band 41 and Band 41 | 132d? | 2014-06-16 A | 2014-12-15 A | 100% | 2014-06-13 | 2014-12-05 | 126d? | finish no earlier than 2014-12-15 | R4 | 1056h | 1056h | LTE_CA_B39_B41_B41-Core | 33 | China Mobile | PAN Qun (panqun@chinamobile.com) | Rel-12 | 64 |  | CA | LTE_CA_B39_B41_B41-Core | RP-141732 |
| 5946 | 1977.110.2 | Perf. Part:LTE Advanced 3 Band Carrier Aggregation (3DL/1UL) of Band 39, Band 41 and Band 41 | 132d? | 2014-06-18 A | 2014-12-15 A | 100% | 2014-06-13 | 2014-12-05 | 126d? | finish no earlier than 2014-12-15 | R4 | 1056h | 1056h | LTE_CA_B39_B41_B41-Perf | 33 | China Mobile | PAN Qun (panqun@chinamobile.com) | Rel-12 | 64 |  | CA | LTE_CA_B39_B41_B41-Perf | RP-141732 |
| 5947 | 1977.111 | **LTE Advanced 3 Band Carrier Aggregation (3DL/1UL) of Band 1, Band 41 and Band 41** | 187.12d? | 2014-06-18 A | 2014-12-15 A | 100% | 2014-06-13 | 2015-03-13 | 196d? |  | R4 | 3168h | 3168h | LTE_CA_B1_B41_B41 | 33 | KDDI | Masaaki Obara (ms-obara@kddi.com) | Rel-12 | 64 |  | CA | LTE_CA_B1_B41_B41 |  |
| 5948 | 1977.111.1 | Core part:LTE Advanced 3 Band Carrier Aggregation (3DL/1UL) of Band 1, Band 41 and Band 41 | 132d? | 2014-06-18 A | 2014-12-15 A | 100% | 2014-06-13 | 2015-03-13 | 196d? | finish no earlier than 2014-12-15 | R4 | 1056h | 1056h | LTE_CA_B1_B41_B41-Core | 33 | KDDI | Masaaki Obara (ms-obara@kddi.com) | Rel-12 | 64 |  | CA | LTE_CA_B1_B41_B41-Core | RP-141732 |
| 5949 | 1977.111.2 | Perf. Part:LTE Advanced 3 Band Carrier Aggregation (3DL/1UL) of Band 1, Band 41 and Band 41 | 132d? | 2014-06-18 A | 2014-12-15 A | 100% | 2014-06-13 | 2015-03-13 | 196d? | finish no earlier than 2014-12-15 | R4 | 1056h | 1056h | LTE_CA_B1_B41_B41-Perf | 33 | KDDI | Masaaki Obara (ms-obara@kddi.com) | Rel-12 | 64 |  | CA | LTE_CA_B1_B41_B41-Perf | RP-141732 |
| 5950 | 1977.112 | **LTE Advanced 3 Band Carrier Aggregation (3DL/1UL) of Band 26, Band 41 and Band 41** | 187.12d? | 2014-06-18 A | 2014-12-15 A | 100% | 2014-06-13 | 2015-03-13 | 196d? |  | R4 | 3168h | 3168h | LTE_CA_B26_B41_B41 | 33 | KDDI | Masaaki Obara (ms-obara@kddi.com) | Rel-12 | 64 |  | CA | LTE_CA_B26_B41_B41 |  |
| 5951 | 1977.112.1 | Core part:LTE Advanced 3 Band Carrier Aggregation (3DL/1UL) of Band 26, Band 41 and Band 41 | 132d? | 2014-06-18 A | 2014-12-15 A | 100% | 2014-06-13 | 2015-03-13 | 196d? | finish no earlier than 2014-12-15 | R4 | 1056h | 1056h | LTE_CA_B26_B41_B41-Core | 33 | KDDI | Masaaki Obara (ms-obara@kddi.com) | Rel-12 | 64 |  | CA | LTE_CA_B26_B41_B41-Core | RP-141732 |
| 5952 | 1977.112.2 | Perf. Part:LTE Advanced 3 Band Carrier Aggregation (3DL/1UL) of Band 26, Band 41 and Band 41 | 132d? | 2014-06-18 A | 2014-12-15 A | 100% | 2014-06-13 | 2015-03-13 | 196d? | finish no earlier than 2014-12-15 | R4 | 1056h | 1056h | LTE_CA_B26_B41_B41-Perf | 33 | KDDI | Masaaki Obara (ms-obara@kddi.com) | Rel-12 | 64 |  | CA | LTE_CA_B26_B41_B41-Perf | RP-141732 |
| 5953 | 1977.113 | **LTE Advanced 3 Band Carrier Aggregation (3DL/1UL) of Band 25, Band 41 and Band 41** | 95d? | 2014-09-15 A | 2014-12-15 A | 100% | 2014-06-13 | 2015-03-13 | 196d? |  | R4 | 1632h | 1632h | LTE_CA_B25_B41_B41 | 33 | Alcatel-Lucent | Ng, Man Hung (man-hung.ng@alcatel-lucent.com) | Rel-12 | 65 |  | CA | LTE_CA_B25_B41_B41 |  |
| 5954 | 1977.113.1 | Core part:LTE Advanced 3 Band Carrier Aggregation (3DL/1UL) of Band 25, Band 41 and Band 41 | 68d? | 2014-09-15 A | 2014-12-15 A | 100% | 2014-06-13 | 2015-03-13 | 196d? | finish no earlier than 2014-12-15 | R4 | 544h | 544h | LTE_CA_B25_B41_B41-Core | 33 | Alcatel-Lucent | Ng, Man Hung (man-hung.ng@alcatel-lucent.com) | Rel-12 | 65 |  | CA | LTE_CA_B25_B41_B41-Core | RP-141732 |
| 5955 | 1977.113.2 | Perf. Part:LTE Advanced 3 Band Carrier Aggregation (3DL/1UL) of Band 25, Band 41 and Band 41 | 68d? | 2014-09-15 A | 2014-12-15 A | 100% | 2014-06-13 | 2015-03-13 | 196d? | finish no earlier than 2014-12-15 | R4 | 544h | 544h | LTE_CA_B25_B41_B41-Perf | 33 | Alcatel-Lucent | Ng, Man Hung (man-hung.ng@alcatel-lucent.com) | Rel-12 | 65 |  | CA | LTE_CA_B25_B41_B41-Perf | RP-141732 |

Notes:
- 5932: Inter-band CA 3DL / Impacted TSs and TRs: LTE
- 5933: CD:Thu 11/12/14->Mon 15/12/14¦Compl:90%->100%¦Stat Rep: RP-141084->RP-141732¦Release: Rel-13->Rel-12 / Impacted TSs and TRs: 36.101; 36.104; 36.133; generic 36.853 (3 Band CA with 1UL)
- 5934: CD:Thu 11/12/14->Mon 15/12/14¦Compl:90%->100%¦Stat Rep: RP-141084->RP-141732¦Release: Rel-13->Rel-12 / Impacted TSs and TRs: 36.141; 36.307
- 5935: Inter-band CA 3DL / Impacted TSs and TRs: LTE
- 5936: ¦WID: RP-142043->RP-141788¦Stat Rep: RP-141084->RP-141732¦Release: Rel-13->Rel-12 / Impacted TSs and TRs: 36.101; 36.104; 36.133; generic 36.853 (3 Band CA with 1UL)
- 5937: ¦WID: RP-142043->RP-141788¦Stat Rep: RP-141084->RP-141732¦Release: Rel-13->Rel-12 / Impacted TSs and TRs: 36.141; 36.307
- 5938: Inter-band CA 3DL/1UL / Impacted TSs and TRs: LTE
- 5939: CD:Thu 12/03/15->Mon 15/12/14¦Compl:0%->100%¦Stat Rep: RP-141084->RP-141732¦Release: Rel-13->Rel-12 / Impacted TSs and TRs: 36.101; 36.104; 36.133; 36.307; generic 36.851 (2 Band CA with 1UL); generic 36.853 (3 Band CA with 1UL)
- 5940: CD:Thu 12/03/15->Mon 15/12/14¦Compl:0%->100%¦Stat Rep: RP-141084->RP-141732¦Release: Rel-13->Rel-12 / Impacted TSs and TRs: 36.133; 36.141
- 5941: Inter-band CA 3DL/1UL / Impacted TSs and TRs: LTE
- 5942: CD:Thu 12/03/15->Mon 15/12/14¦Compl:0%->100%¦Stat Rep: RP-141084->RP-141732¦Release: Rel-13->Rel-12 / Impacted TSs and TRs: 36.101; 36.104; 36.133; 36.307; generic 36.853 (3 Band CA with 1UL)
- 5943: CD:Thu 12/03/15->Mon 15/12/14¦Compl:0%->100%¦Stat Rep: RP-141084->RP-141732¦Release: Rel-13->Rel-12 / Impacted TSs and TRs: 36.133; 36.141
- 5944: Inter-band CA 3DL/1UL / Impacted TSs and TRs: LTE
- 5945: ¦WID: RP-140708->RP-142301¦Stat Rep: RP-141084->RP-141732¦Release: Rel-13->Rel-12 / Impacted TSs and TRs: 36.101; 36.104; 36.133; generic 36.853 (3 Band CA with 1UL)
- 5946: ¦WID: RP-140708->RP-142301¦Stat Rep: RP-141084->RP-141732¦Release: Rel-13->Rel-12 / Impacted TSs and TRs: 36.141; 36.307
- 5947: Inter-band CA 3DL/1UL / Impacted TSs and TRs: LTE
- 5948: ¦WID: RP-142043->RP-142297¦Stat Rep: RP-141084->RP-141732¦Release: Rel-13->Rel-12 / Impacted TSs and TRs: 36.101; 36.104; 36.133; generic 36.853 (3 Band CA with 1UL)
- 5949: Compl:100%->0%¦WID: RP-142043->RP-142297¦Stat Rep: RP-141084->RP-141732¦Release: Rel-13->Rel-12 / Impacted TSs and TRs: 36.141; 36.307
- 5950: Inter-band CA 3DL/1UL / Impacted TSs and TRs: LTE
- 5951: ¦WID: RP-142043->RP-142298¦Stat Rep: RP-141084->RP-141732¦Release: Rel-13->Rel-12 / Impacted TSs and TRs: 36.101; 36.104; 36.133; generic 36.853 (3 Band CA with 1UL)
- 5952: Compl:100%->0%¦WID: RP-142043->RP-142298¦Stat Rep: RP-141084->RP-141732¦Release: Rel-13->Rel-12 / Impacted TSs and TRs: 36.141; 36.307
- 5953: Inter-band CA 3DL/1UL / Impacted TSs and TRs: LTE
- 5954: ¦WID: RP-142043->RP-142018¦Stat Rep: -->RP-141732¦Release: Rel-13->Rel-12 / Impacted TSs and TRs: 36.101; 36.104; 36.307; New 36.833-x-yz
- 5955: ¦WID: RP-142043->RP-142018¦Stat Rep: -->RP-141732¦Release: Rel-13->Rel-12 / Impacted TSs and TRs: 36.141

| ID | WBS | Task | Duration | Start | Finish | Complete | Baseline start | Baseline finish | Baseline duration | Constraint | Resources | Work | Actual work | Acronym | PCG approved | WI rapporteur name | WI rapporteur e-mail | Release | TSG approved | Special Focus Doc | Acronym_3GU_Export | Status Report | MCC resp | PCG stopped | TSG stopped |
| --- | --- | --- | --- | --- | --- | --- | --- | --- | --- | --- | --- | --- | --- | --- | --- | --- | --- | --- | --- | --- | --- | --- | --- | --- | --- |
| 5956 | 1977.114 | **LTE Advanced 3 Band Carrier Aggregation (3DL/1UL) of Band 39, Band 39 and Band 41** | 95d? | 2014-09-15 A | 2014-12-15 A | 100% | 2014-06-13 | 2015-03-13 | 196d? |  | R4 | 1632h | 1632h | LTE_CA_B39_B39_B41 | 33 | China Mobile | PAN, Qun (panqun@chinamobile.com) | Rel-12 | 65 | CA | LTE_CA_B39_B39_B41 |  |  |  |  |
| 5957 | 1977.114.1 | Core part:LTE Advanced 3 Band Carrier Aggregation (3DL/1UL) of Band 39, Band 39 and Band 41 | 68d? | 2014-09-15 A | 2014-12-15 A | 100% | 2014-06-13 | 2015-03-13 | 196d? | finish no earlier than 2014-12-15 | R4 | 544h | 544h | LTE_CA_B39_B39_B41-Core | 33 | China Mobile | PAN, Qun (panqun@chinamobile.com) | Rel-12 | 65 | CA | LTE_CA_B39_B39_B41-Core | RP-141732 |  |  |  |
| 5958 | 1977.114.2 | Perf. Part:LTE Advanced 3 Band Carrier Aggregation (3DL/1UL) of Band 39, Band 39 and Band 41 | 68d? | 2014-09-15 A | 2014-12-15 A | 100% | 2014-06-13 | 2015-03-13 | 196d? | finish no earlier than 2014-12-15 | R4 | 544h | 544h | LTE_CA_B39_B39_B41-Perf | 33 | China Mobile | PAN, Qun (panqun@chinamobile.com) | Rel-12 | 65 | CA | LTE_CA_B39_B39_B41-Perf | RP-141732 |  |  |  |
| 5959 | 1977.115 | **LTE Advanced 3 Band Carrier Aggregation (3DL/1UL) of Band 2, Band 2 and Band 29** | 95d? | 2014-09-15 A | 2014-12-15 A | 100% | 2014-06-13 | 2015-03-13 | 196d? |  | R4 | 1632h | 1632h | LTE_CA_B2_B2_B29 | 33 | AT&T | marc.grant@att.com | Rel-12 | 65 | CA | LTE_CA_B2_B2_B29 |  |  |  |  |
| 5960 | 1977.115.1 | Core part:LTE Advanced 3 Band Carrier Aggregation (3DL/1UL) of Band 2, Band 2 and Band 29 | 68d? | 2014-09-15 A | 2014-12-15 A | 100% | 2014-06-13 | 2015-03-13 | 196d? | finish no earlier than 2014-12-15 | R4 | 544h | 544h | LTE_CA_B2_B2_B29-Core | 33 | AT&T | marc.grant@att.com | Rel-12 | 65 | CA | LTE_CA_B2_B2_B29-Core | RP-141732 |  |  |  |
| 5961 | 1977.115.2 | Perf. Part:LTE Advanced 3 Band Carrier Aggregation (3DL/1UL) of Band 2, Band 2 and Band 29 | 68d? | 2014-09-15 A | 2014-12-15 A | 100% | 2014-06-13 | 2015-03-13 | 196d? | finish no earlier than 2014-12-15 | R4 | 544h | 544h | LTE_CA_B2_B2_B29-Perf | 33 | AT&T | marc.grant@att.com | Rel-12 | 65 | CA | LTE_CA_B2_B2_B29-Perf | RP-141732 |  |  |  |
| 5962 | 1977.116 | **LTE Advanced 3 Band Carrier Aggregation (3DL/1UL) of Band 2, Band 4 and Band 29** | 95d? | 2014-09-15 A | 2014-12-15 A | 100% | 2014-06-13 | 2015-03-13 | 196d? |  | R4 | 1632h | 1632h | LTE_CA_B2_B4_B29 | 33 | Huawei | SHAN Huiping (shanhuiping@huawei.com) | Rel-12 | 65 | CA | LTE_CA_B2_B4_B29 |  |  |  |  |
| 5963 | 1977.116.1 | Core part:LTE Advanced 3 Band Carrier Aggregation (3DL/1UL) of Band 2, Band 4 and Band 29 | 68d? | 2014-09-15 A | 2014-12-15 A | 100% | 2014-06-13 | 2015-03-13 | 196d? | finish no earlier than 2014-12-15 | R4 | 544h | 544h | LTE_CA_B2_B4_B29-Core | 33 | Huawei | SHAN Huiping (shanhuiping@huawei.com) | Rel-12 | 65 | CA | LTE_CA_B2_B4_B29-Core | RP-141732 |  |  |  |
| 5964 | 1977.116.2 | Perf. Part:LTE Advanced 3 Band Carrier Aggregation (3DL/1UL) of Band 2, Band 4 and Band 29 | 68d? | 2014-09-15 A | 2014-12-15 A | 100% | 2014-06-13 | 2015-03-13 | 196d? | finish no earlier than 2014-12-15 | R4 | 544h | 544h | LTE_CA_B2_B4_B29-Perf | 33 | Huawei | SHAN Huiping (shanhuiping@huawei.com) | Rel-12 | 65 | CA | LTE_CA_B2_B4_B29-Perf | RP-141732 |  |  |  |
| 5965 | 1978 | UE Conformance Test Aspects – Further Rel-12 configurations for LTE Advanced Carrier Aggregation | 393d? | 2013-09-15 A | 2015-03-13 A | 100% | 2013-09-09 | 2014-12-05 | 327d? | finish no earlier than 2015-03-15 | R5 | 3144h | 3144h | LTE_CA_Rel12-UEConTest | 31 | Microsoft | jussi.kuusisto@microsoft.com | Rel-12 | 61 | CA | LTE_CA_Rel12-UEConTest | RP-150076 | Ingbert |  |  |
| 5966 | 1979 | UE Conformance Test Aspects – Further Rel-12 configurations for LTE Advanced Carrier Aggregation with 3DL | 394d? | 2014-09-15 A | 2016-03-15 A | 100% |  |  |  | finish no earlier than 2016-03-15 | R5 | 3152h | 3152h | LTE_CA_Rel12_3DL-UEConTest | 33 | Microsoft | jussi.kuusisto@microsoft.com | Rel-12 | 65 | CA | LTE_CA_Rel12_3DL-UEConTest | RP-151464 |  |  |  |
| 5967 | 1980 | **Deleted - Carrier based HetNet ICIC for LTE** | 848.12d? | 2011-03-18 A | 2013-06-14 A | 100% | 2011-03-18 | 2013-06-14 | 595d? |  | R3; R1; R2 | 28560h | 28560h | LTE_CA_HetNet_ICIC | 26 | Nokia Siemens Networks | krzysztof.kordybach@nsn.com | Rel-12 | 51 |  | LTE_CA_HetNet_ICIC |  | Juha | PCG-31 | RP-60 |
| 5968 | 1980.1 | Deleted - Core part: Carrier based HetNet ICIC for LTE | 595d? | 2011-03-18 A | 2013-06-14 A | 100% | 2011-03-18 | 2013-06-14 | 595d? | finish no earlier than 2013-06-14 | R3; R1; R2 | 14280h | 14280h | LTE_CA_HetNet_ICIC-Core | 26 | Nokia Siemens Networks | krzysztof.kordybach@nsn.com | Rel-12 | 51 |  | LTE_CA_HetNet_ICIC-Core | RP-130500 | Juha | PCG-31 | RP-60 |
| 5969 | 1981 | **LTE in the US Wireless Communications Service (WCS) Band 30** | 853.12d? | 2012-09-12 A | 2014-12-15 A | 100% | 2012-09-12 | 2014-12-05 | 591d? |  | R4; R2; R5 | 20312h | 20312h | LTE_WCS_band | 29 | AT&T | marc.grant@att.com | Rel-12 | 57 |  | LTE_WCS_band |  | Issam |  |  |
| 5970 | 1981.1 | Core part: LTE in the US Wireless Communications Service (WCS) Band 30 | 202d? | 2012-09-12 A | 2013-06-14 A | 100% | 2012-09-12 | 2013-06-14 | 202d? | finish no earlier than 2013-06-14 | R4; R2 | 3232h | 3232h | LTE_WCS_band-Core | 29 | AT&T | marc.grant@att.com | Rel-12 | 57 |  | LTE_WCS_band-Core | RP-130569 | Issam |  |  |
| 5971 | 1981.2 | Perf. Part: LTE in the US Wireless Communications Service (WCS) Band 30 | 201d? | 2012-09-13 A | 2013-06-14 A | 100% | 2012-09-13 | 2013-06-14 | 201d? | finish no earlier than 2013-06-14 | R4 | 1608h | 1608h | LTE_WCS_band-Perf | 29 | AT&T | marc.grant@att.com | Rel-12 | 57 |  | LTE_WCS_band-Perf | RP-130570 | Issam |  |  |
| 5972 | 1981.3 | Test Part: LTE in the US Wireless Communications Service (WCS) Band 30 | 134d? | 2014-06-15 A | 2014-12-15 A | 100% | 2014-06-13 | 2014-12-05 | 126d? | finish no earlier than 2014-12-15 | R5 | 1072h | 1072h | LTE_WCS_band-UEConTest | 33 | Ericsson | fredrik.sundstrom@ericsson.com | Rel-12 | 64 |  | LTE_WCS_band-UEConTest | RP-141773 |  |  |  |
| 5973 | 1982 | **Introduction of LTE 450 MHz band in Brazil** | 467.12d? | 2012-09-11 A | 2013-12-06 A | 100% | 2012-09-11 | 2013-12-06 | 331d? |  | R4; R5 | 10000h | 10000h | LTE450_Brazil | 29 | Huawei | Liehai Liu (liuliehai@huawei.com) | Rel-12 | 57 |  | LTE450_Brazil |  | Issam |  |  |
| 5974 | 1982.1 | Core part: Introduction of LTE 450 MHz band in Brazil | 201d? | 2012-09-11 A | 2013-06-14 A | 100% | 2012-09-11 | 2013-06-14 | 201d? | finish no earlier than 2013-06-14 | R4 | 1608h | 1608h | LTE450_Brazil-Core | 29 | Huawei | Liehai Liu (liuliehai@huawei.com) | Rel-12 | 57 |  | LTE450_Brazil-Core | RP-130567 | Issam |  |  |
| 5975 | 1982.2 | Perf. part: Introduction of LTE 450 MHz band in Brazil | 261d? | 2012-09-13 A | 2013-09-06 A | 100% | 2012-09-13 | 2013-09-06 | 261d? | finish no earlier than 2013-09-06 | R4 | 2088h | 2088h | LTE450_Brazil-Perf | 29 | Huawei | Liehai Liu (liuliehai@huawei.com) | Rel-12 | 57 |  | LTE450_Brazil-Perf | RP-131070 | Issam |  |  |
| 5976 | 1982.3 | Test part: Introduction of LTE 450 MHz band in Brazil | 126d? | 2013-06-18 A | 2013-12-06 A | 100% | 2013-06-18 | 2013-12-06 | 126d? | finish no earlier than 2013-12-06 | R5 | 1008h | 1008h | LTE450_Brazil-UEConTest | 31 | Huawei | Xiang Li (tricia.li@huawei.com) | Rel-12 | 60 |  | LTE450_Brazil-UEConTest | RP-131457 | Ingbert |  |  |
| 5977 | 1983 | **Further Downlink MIMO Enhancement for LTE Advanced** | 1326.38d? | 2012-09-11 A | 2016-03-15 A | 100% | 2012-09-11 | 2014-09-12 | 532d? |  | R1; R4 | 25384.8h | 25384.8h | LTE_eDL_MIMO_enh | 29 | Alcatel-Lucent | Min Zhang (min.hs.zhang@alcatel-lucent.com) | Rel-12 | 57 |  | LTE_eDL_MIMO_enh |  | Patrick |  |  |
| 5978 | 1983.1 | Core part: Further Downlink MIMO Enhancement for LTE Advanced | 464d? | 2012-09-11 A | 2014-06-13 A | 100% | 2012-09-11 | 2014-06-13 | 464d? | finish no earlier than 2014-06-13 | R1 | 3696.76h | 3696.76h | LTE_eDL_MIMO_enh-Core | 29 | Alcatel-Lucent | Min Zhang (min.hs.zhang@alcatel-lucent.com) | Rel-12 | 57 |  | LTE_eDL_MIMO_enh-Core | RP-140652 | Patrick |  |  |
| 5979 | 1983.2 | Perf. part: Further Downlink MIMO Enhancement for LTE Advanced | 595d? | 2012-09-15 A | 2014-12-15 A | 100% | 2012-09-18 | 2014-09-12 | 526d? | finish no earlier than 2014-12-15 | R4 | 4760h | 4760h | LTE_eDL_MIMO_enh-Perf | 29 | Alcatel-Lucent | ren.da@alcatel-lucent.com | Rel-12 | 57 |  | LTE_eDL_MIMO_enh-Perf | RP-142042 | Issam |  |  |
| 5980 | 1983.3 | UE Conformance Test Aspects - Further DL MIMO Enhancement for LTE-Advanced | 262d? | 2015-03-16 A | 2016-03-15 A | 100% |  |  |  | finish no earlier than 2016-03-15 | R5 | 2096h | 2096h | LTE_eDL_MIMO_enh-UEConTest | 34 | ZTE |  | Rel-12 | 67 |  |  | RP-151189 |  |  |  |

Notes:
- 5956: Inter-band CA 3DL/1UL / Impacted TSs and TRs: LTE
- 5957: ¦WID: RP-141288->RP-142302¦Stat Rep: -->RP-141732¦Release: Rel-13->Rel-12 / Impacted TSs and TRs: 36.101; 36.104; 36.133; New 36.8xx
- 5958: ¦WID: RP-141288->RP-142302¦Stat Rep: -->RP-141732¦Release: Rel-13->Rel-12 / Impacted TSs and TRs: 36.141; 36.307
- 5959: Inter-band CA 3DL/1UL / Impacted TSs and TRs: LTE
- 5960: CD:Thu 11/12/14->Mon 15/12/14¦Compl:0%->100%¦Stat Rep: -->RP-141732¦Release: Rel-13->Rel-12 / Impacted TSs and TRs: 36.101; 36.104; 36.133; New 36.8xx
- 5961: CD:Thu 11/12/14->Mon 15/12/14¦Compl:0%->100%¦Stat Rep: -->RP-141732¦Release: Rel-13->Rel-12 / Impacted TSs and TRs: 36.141; 36.307
- 5962: Inter-band CA 3DL/1UL / Impacted TSs and TRs: LTE
- 5963: CD:Fri 11/12/15->Mon 15/12/14¦Compl:0%->100%¦Stat Rep: -->RP-141732¦Release: Rel-13->Rel-12 / Impacted TSs and TRs: 36.101; 36.104; 36.133; New 36.8xx
- 5964: CD:Thu 11/12/14->Mon 15/12/14¦Compl:0%->100%¦Stat Rep: -->RP-141732¦Release: Rel-13->Rel-12 / Impacted TSs and TRs: 36.141; 36.307
- 5965: ¦Stat Rep: RP-141444->RP-141774 1st Apr 15: Compl:75%->100% 1st Apr 15: WID: RP-140621->RP-150077 1st Apr 15: Stat Rep: RP-141774->RP-150076 / Impacted TSs and TRs: 36.508; 36.521-1; 36.521-2; 36.521-3; 36.523-1; 36.523-2; 36.523-3; 37.571-1; 37.571-3; 37.571-5
- 5966: ¦Stat Rep: -->RP-141775 1st Apr 15: Compl:6%->12% 1st Apr 15: CD:Tue 15/09/15->Tue 15/12/15 1st Apr 15: WID: RP-142231->RP-150079 1st Apr 15: Stat Rep: RP-141775->RP-150078 03/07/15: Compl:12%->35% 03/07/15: WID: RP-150079->RP-150594 03/07/15: Stat Re / Impacted TSs and TRs: 36.508; 36.521-1; 36.521-2; 36.521-3; 36.523-1; 36.523-2; 36.523-3; 37.571-1; 37.571-3; 37.571-5
- 5967: RP#60 stopped. RP#58 on hold til June 2013 / Impacted TSs and TRs: LTE
- 5968: RP#60 stopped at 40% completion. RP#58 on hold til June 2013 / Impacted TSs and TRs: 36.300; 36.413; 36.420; 36.423
- 5969: RP#58 RP-121701 work can start based on FCC Order (FCC-12-130) http://hraunfoss.fcc.gov/edocs_public/attachmatch/FCC-12-130A1.pdf / Impacted TSs and TRs: LTE
- 5970: RP#60 completed. Updated WID RP-121419=>RP-130843 / Impacted TSs and TRs: 36.101; 36.104; 36.113; 36.124; 36.133; 36.307; 36.331; new 36.846
- 5971: RP#60 completed. Updated WID RP-121419=>RP-130843 / Impacted TSs and TRs: 36.101; 36.133; 36.141
- 5972: ¦Stat Rep: RP-141166->RP-141773 / Impacted TSs and TRs: 36.508; 36.521-1; 36.521-2; 36.521-3; 36.523-2; 36.523-3; 37.571-1
- 5973: - / Impacted TSs and TRs: LTE
- 5974: RP#60 completed. TR 36.840 v100 for 1-step Approval / Impacted TSs and TRs: 36.101; 36.104; 36.113; 36.124; 36.133; 37.104; 37.113; 36.307; new 36.840
- 5975: RP#61 completed / Impacted TSs and TRs: 36.133; 36.141; 37.141
- 5976: RP#62 completed / Impacted TSs and TRs: 36.508; 36.521-1; 36.521-2; 36.521-3
- 5977: Stage 3 / Impacted TSs and TRs: LTE
- 5978: RP#64 completed / Impacted TSs and TRs: 36.211; 36.212; 36.213; 36.331
- 5979: ¦CD:Fri 12/06/15->Mon 15/06/15¦WID: RP-141966->RP-142235¦Stat Rep: RP-141378->RP-142042 / Impacted TSs and TRs: 36.101
- 5980: 03/07/15: Compl:0%->10% 03/07/15: Stat Rep: ->RP-150606 29/09/15: Compl:10%->70% 29/09/15: Stat Rep: RP-150606->RP-1511891/1/16: Compl:70%->75%

| ID | WBS | Task | Duration | Start | Finish | Complete | Remaining | Baseline start | Baseline finish | Baseline duration | Total slack | Constraint | Resources | Work | Actual work | Acronym | PCG approved | WI rapporteur name | Release | TSG approved | MCC resp | PCG stopped | TSG stopped | Acronym_3GU_Export | Status Report | Special Focus Doc |
| --- | --- | --- | --- | --- | --- | --- | --- | --- | --- | --- | --- | --- | --- | --- | --- | --- | --- | --- | --- | --- | --- | --- | --- | --- | --- | --- |
| 5981 | 1984 | **Deleted - New Carrier Type for LTE** | 373d? | 2012-09-11 A | 2013-09-06 A | 100% |  | 2012-09-11 | 2013-09-06 | 265d? |  |  | R1; R2; R4 | 14808h | 14808h | LTE_NCT | 29 | Ericsson | Rel-12 | 57 | Patrick | PCG-31 | RP-61 | LTE_NCT |  |  |
| 5982 | 1984.1 | Deleted - Core part: New Carrier Type for LTE | 265d? | 2012-09-11 A | 2013-09-06 A | 100% |  | 2012-09-11 | 2013-09-06 | 265d? |  | finish no earlier than 2013-09-06 | R1; R2; R4 | 6360h | 6360h | LTE_NCT-Core | 29 | Ericsson | Rel-12 | 57 | Patrick | PCG-31 | RP-61 | LTE_NCT-Core | RP-130984 |  |
| 5983 | 1984.2 | Deleted - Perf. part: New Carrier Type for LTE | 261d? | 2012-09-17 A | 2013-09-06 A | 100% |  | 2012-09-17 | 2013-09-06 | 261d? |  | finish no earlier than 2013-09-06 | R4 | 2088h | 2088h | LTE_NCT-Perf | 29 | Ericsson | Rel-12 | 57 | Issam | PCG-31 | RP-61 | LTE_NCT-Perf | RP-130985 |  |
| 5984 | 1985 | **Further Enhancements to LTE TDD for DL-UL Interference Management and Traffic Adaptation** | 1992.5d? | 2012-12-07 A | 2018-03-15 A | 100% |  | 2012-12-07 | 2014-12-05 | 527d? |  |  | R1; R2; R3; R4 | 56138.6h | 56138.6h | LTE_TDD_eIMTA | 30 | CATT | Rel-12 | 58 | Patrick |  |  | LTE_TDD_eIMTA |  | Small cell |
| 5985 | 1985.1 | Core part: Further Enhancements to LTE TDD for DL-UL Interference Management and Traffic Adaptation | 24.58d? | 2012-12-07 A | 2014-06-13 A | 100% |  | 2012-12-07 | 2014-06-13 | 24.58d? |  | finish no earlier than 2014-06-13 | R1; R2; R3; R4 | 786.56h | 786.56h | LTE_TDD_eIMTA-Core | 30 | CATT | Rel-12 | 58 | Patrick |  |  | LTE_TDD_eIMTA-Core | RP-140724 | Small cell |
| 5986 | 1985.2 | Perf. part: Further Enhancements to LTE TDD for DL-UL Interference Management and Traffic Adaptation | 725d? | 2012-12-15 A | 2015-09-15 A | 100% |  | 2012-12-07 | 2014-12-05 | 527d? |  | finish no earlier than 2015-09-15 | R4 | 5800h | 5800h | LTE_TDD_eIMTA-Perf | 30 | CATT | Rel-12 | 58 | Patrick |  |  | LTE_TDD_eIMTA-Perf | RP-151447 | Small cell |
| 5987 | 1985.3 | UE Conformance Test Aspects - Further Enhancements to LTE TDD for DL-UL Interference Management and Traffic Adaptation | 654d? | 2015-09-15 A | 2018-03-15 A | 100% |  |  |  |  |  | finish no earlier than 2018-03-15 | R5 | 5232h | 5232h | LTE_TDD_eIMTA-UEConTest | 35 | CATT | Rel-12 | 69 |  |  |  |  |  |  |
| 5988 | 1986 | **HetNet Mobility enhancements for LTE** | 912.77d? | 2012-04-13 A | 2014-09-12 A | 100% |  | 2012-04-13 | 2014-09-12 | 640.65d? |  |  | R2; R4 | 11624h | 11624h | HetNet_eMOB_LTE | 30 | Alcatel-Lucent | Rel-12 | 58 | Yong-Jun |  |  | HetNet_eMOB_LTE |  |  |
| 5989 | 1986.1 | Core part: HetNet Mobility enhancements for LTE | 263.5d? | 2012-04-13 A | 2014-09-12 A | 100% |  | 2012-04-13 | 2014-09-12 | 263.5d? |  | finish no earlier than 2014-09-12 | R2; R4 | 4216h | 4216h | HetNet_eMOB_LTE-Core | 30 | Alcatel-Lucent | Rel-12 | 58 | Yong-Jun |  |  | HetNet_eMOB_LTE-Core | RP-141413 |  |
| 5990 | 1987 | **Further enhancements for HeNB mobility-X2-GW** | 569.75d? | 2012-12-10 A | 2014-06-13 A | 100% |  | 2012-12-10 | 2014-06-13 | 401d? |  |  | R3 | 6408h | 6408h | EHNB_enh2_X2GW | 30 | Alcatel-Lucent | Rel-12 | 58 | Juha |  |  | EHNB_enh2_X2GW |  | HNB |
| 5991 | 1987.1 | Core part: Further enhancements for HeNB mobility-X2-GW | 400d? | 2012-12-10 A | 2014-06-13 A | 100% |  | 2012-12-10 | 2014-06-13 | 400d? |  | finish no earlier than 2014-06-13 | R3 | 3200h | 3200h | EHNB_enh2_X2GW-Core | 30 | Alcatel-Lucent | Rel-12 | 58 | Juha |  |  | EHNB_enh2_X2GW-Core | RP-140592 | HNB |
| 5992 | 1988 | **8 Rx Antennas for LTE UL** | 374.12d? | 2012-12-10 A | 2013-12-06 A | 100% |  | 2012-12-10 | 2013-12-06 | 265d? |  |  | R4 | 4208h | 4208h | LTE_UL_8Rx | 30 | China Telecom | Rel-12 | 58 | Issam |  |  | LTE_UL_8Rx |  |  |
| 5993 | 1988.1 | Perf. part: 8 Rx Antennas for LTE UL | 261d? | 2012-12-10 A | 2013-12-06 A | 100% |  | 2012-12-10 | 2013-12-06 | 261d? |  | finish no earlier than 2013-12-06 | R4 | 2088h | 2088h | LTE_UL_8Rx-Perf | 30 | China Telecom | Rel-12 | 58 | Issam |  |  | LTE_UL_8Rx-Perf | RP-131523 |  |
| 5994 | 1989 | **LTE TDD-FDD joint operation including Carrier Aggregation** | 633.03d? | 2013-04-12 A | 2014-12-15 A | 100% |  | 2013-04-12 | 2014-12-05 | 435.03d? |  |  | R1; R2; R4 | 14776h | 14776h | LTE_CA_TDD_FDD | 31 | Nokia | Rel-12 | 60 | Patrick |  |  | LTE_CA_TDD_FDD |  |  |
| 5995 | 1989.1 | Core part: LTE TDD-FDD joint operation including Carrier Aggregation | 87.33d? | 2013-04-12 A | 2014-06-13 A | 100% |  | 2013-04-12 | 2014-06-13 | 87.33d? |  | finish no earlier than 2014-06-13 | R1; R2; R4 | 2096h | 2096h | LTE_CA_TDD_FDD-Core | 31 | Nokia, China Mobile (for TR) | Rel-12 | 60 | Patrick |  |  | LTE_CA_TDD_FDD-Core | RP-140982 |  |
| 5996 | 1989.2 | Perf. part: LTE TDD-FDD joint operation including Carrier Aggregation | 397d? | 2013-06-15 A | 2014-12-15 A | 100% |  | 2013-06-20 | 2014-12-05 | 386d? |  | finish no earlier than 2014-12-15 | R4 | 3176h | 3176h | LTE_CA_TDD_FDD-Perf | 31 | Nokia | Rel-12 | 60 | Issam |  |  | LTE_CA_TDD_FDD-Perf | RP-141972 |  |
| 5997 | 1990 | **LTE Coverage Enhancements** | 865.17d? | 2013-03-01 A | 2015-06-15 A | 100% |  | 2013-03-01 | 2014-12-05 | 465.17d? |  |  | R1; R2; R4; R5 | 21348.1h | 21348.1h | Cov_Enh_LTE | 31 | China Telecom | Rel-12 | 60 | Patrick |  |  | Cov_Enh_LTE |  |  |
| 5998 | 1990.1 | Core part: LTE Coverage Enhancements | 87d? | 2013-03-01 A | 2014-06-13 A | 100% |  | 2013-03-01 | 2014-06-13 | 87d? |  | finish no earlier than 2014-06-13 | R1; R2; R4 | 2088h | 2088h | Cov_Enh_LTE-Core | 31 | China Telecom | Rel-12 | 60 | Patrick |  |  | Cov_Enh_LTE-Core | RP-140683 |  |
| 5999 | 1990.2 | Perf. part: LTE Coverage Enhancements | 397d? | 2013-06-15 A | 2014-12-15 A | 100% |  | 2013-06-20 | 2014-12-05 | 386d? |  | finish no earlier than 2014-12-15 | R4 | 3176h | 3176h | Cov_Enh_LTE-Perf | 31 | China Telecom | Rel-12 | 60 | Issam |  |  | Cov_Enh_LTE-Perf | RP-141833 |  |
| 6000 | 1990.3 | Test part: LTE Coverage Enhancements | 198d? | 2014-09-15 A | 2015-06-15 A | 100% |  |  |  |  |  | finish no earlier than 2015-09-15 | R5 | 1584h | 1584h | Cov_Enh_LTE-UEConTest | 33 | China Telecom | Rel-12 | 65 |  |  |  | Cov_Enh_LTE-UEConTest | RP-150631 |  |
| 6001 | 1991 | **Further MBMS operations support for E-UTRAN** | 472.88d? | 2013-09-15 A | 2014-12-15 A | 100% |  | 2013-12-09 | 2014-09-12 | 201d? |  |  | R2; R1; R3; R4 | 21280h | 21280h | MBMS_LTE_OS | 31 | Verizon | Rel-12 | 61 | Yong-Jun |  |  | MBMS_LTE_OS |  |  |
| 6002 | 1991.1 | Core part: Further MBMS operations support for E-UTRAN | 329d? | 2013-09-15 A | 2014-12-15 A | 100% |  | 2014-04-04 | 2014-09-12 | 115.25d? |  | finish no earlier than 2014-12-15 | R2; R1; R3; R4 | 10528h | 10528h | MBMS_LTE_OS-Core | 31 | Verizon | Rel-12 | 61 | Yong-Jun |  |  | MBMS_LTE_OS-Core | RP-141821 |  |
| 6003 | 1991.2 | Perf. part: Further MBMS operations support for E-UTRAN | 264d? | 2013-12-15 A | 2014-12-15 A | 100% |  | 2013-12-09 | 2014-09-12 | 201d? |  | finish no earlier than 2014-12-15 | R4 | 2112h | 2112h | MBMS_LTE_OS-Perf | 32 | Verizon | Rel-12 | 62 | Issam |  |  | MBMS_LTE_OS-Perf | RP-141821 |  |
| 6004 | 1992 | **Dual connectivity for LTE** | 1419.25d? | 2013-12-15 A | 2017-09-15 | 99% | 0d? | 2013-12-09 | 2014-12-05 | 261d? | 0d |  | R2; R1; R3; R4; S2; C4 | 49408h | 49408h | LTE_SC_enh_dualC | 32 | NTT DOCOMO | Rel-12 | 62 | Yong-Jun |  |  | LTE_SC_enh_dualC |  | Small cell |
| 6005 | 1992.1 | Core part: Dual connectivity for LTE | 264d? | 2013-12-15 A | 2014-12-15 A | 100% |  | 2014-04-29 | 2014-09-12 | 99d? |  | finish no earlier than 2014-12-15 | R2; R1; R3; R4 | 8448h | 8448h | LTE_SC_enh_dualC-Core | 32 | NTT DOCOMO, NEC | Rel-12 | 62 | Yong-Jun |  |  | LTE_SC_enh_dualC-Core | RP-141796 | Small cell |
| 6006 | 1992.2 | Perf. part: Dual Connectivity for LTE | 395d? | 2013-12-15 A | 2015-06-15 A | 100% |  | 2013-12-09 | 2014-12-05 | 261d? |  | finish no earlier than 2015-06-15 | R4 | 3160h | 3160h | LTE_SC_enh_dualC-Perf | 32 | NTT DOCOMO | Rel-12 | 62 | Issam |  |  | LTE_SC_enh_dualC-Perf | RP-150791 | Small cell |
| 6007 | 1992.3 | SA2 part of Dual connectivity for LTE | 131d? | 2014-03-19 A | 2014-09-17 A | 100% |  | 2014-03-19 | 2014-09-17 | 131d? |  | finish no earlier than 2014-09-17 | S2 | 1048h | 1048h | LTE_SC_enh_dualC-S2 | 32 |  | Rel-12 | 63 |  |  |  |  |  | Small cell |
| 6008 | 1992.4 | CT aspects of Dual connectivity for LTE | 63d? | 2014-09-12 A | 2014-12-09 A | 100% |  |  |  |  |  | finish no earlier than 2014-12-09 | C4 | 504h | 504h | LTE_SC_enh_dualC-CT | 33 | Huawei | Rel-12 | 65 |  |  |  | LTE_SC_enh_dualC-CT | CP-140487 | Small cell |
| 6009 | 1992.5 | UE Conformance Test Aspects - Dual connectivity for LTE | 591d? | 2015-06-15 A | 2017-09-15 A | 100% |  |  |  |  |  | finish no earlier than 2017-09-15 | R5 | 4728h | 4728h | LTE_SC_enh_dualC-UEConTest | 35 | Ericsson | Rel-12 | 68 |  |  |  |  |  |  |

Notes:
- 5981: RP#61 stopped. Continue discussion on use cases and requirements for a NCT in LTE beyond Rel-12. Action: Ericsson to provide at RP#62 a summary of work done so far / Impacted TSs and TRs: LTE / WI rapporteur e-mail: daniel.n.larsson@ericsson.com
- 5982: RP#61 stopped at 20% completion / Impacted TSs and TRs: 36.101; 36.104; 36.133; 36.211; 36.212; 36.213; 36.321; 36.331 / WI rapporteur e-mail: daniel.n.larsson@ericsson.com
- 5983: RP#61 stopped at 0% completion / Impacted TSs and TRs: 36.101; 36.104; 36.133; 36.141 / WI rapporteur e-mail: daniel.n.larsson@ericsson.com
- 5984: Stage 3. Triggered by Rel-11 TR 36.828 Study on Further Enhancements to LTE TDD for DL-UL Interference Management and Traffic Adaptation (FS_LTE_TDD_eIMTA) UID_510039 / Impacted TSs and TRs: LTE / WI rapporteur e-mail: Zukang Shen (shenzukang@catt.cn)
- 5985: RP#64 completed / Impacted TSs and TRs: 36.101; 36.104; 36.133; 36.211; 36.212; 36.213; 36.214; 36.300; 36.321; 36.331; 36.413; 36.423 / WI rapporteur e-mail: Zukang Shen (shenzukang@catt.cn)
- 5986: ¦CD:Thu 18/06/15->Mon 15/06/15¦WID: RP-141966->RP-142235¦Stat Rep: RP-141342->RP-141948 1st Apr 15: Compl:30%->55% 1st Apr 15: Stat Rep: RP-141948->RP-150154 03/07/15: Compl:55%->95% 03/07/15: CD:Mon 15/06/15->Tue 15/09/15 03/07/15: Stat Rep: RP-150 / Impacted TSs and TRs: 36.101; 36.104; 36.133; 36.141 / WI rapporteur e-mail: Zukang Shen (shenzukang@catt.cn)
- 5987: tested: REL-12 WI LTE_TDD_eIMTA-Core;1/1/16: Compl:0%->5%¦22/3/16: Compl:5%->15% 21/3/ 19 827/3
- 5988: Stage 3. Triggered by Rel-11 TR 36.839 Study on HetNet mobility enhancements for LTE (FS_HetNet_eMOB_LTE) / Impacted TSs and TRs: LTE / WI rapporteur e-mail: sudeep.palat@alcatel-lucent.com
- 5989: SP#65 completed / Impacted TSs and TRs: 36.133; 36.304; 36.331 / WI rapporteur e-mail: sudeep.palat@alcatel-lucent.com
- 5990: Rel-10 H(e)NB Mobility Enhancements adds signalling via horizontal RAN interfaces (Iurh, X2) to support H(e)NB to H(e)NB mobility. Rel-11 TR37.803 triggered WI UID_560014 partly completed in Rel-11¦remaining work including solution definition is Rel-12 / Impacted TSs and TRs: LTE / WI rapporteur e-mail: Philippe.Godin@alcatel-lucent.com
- 5991: RP#64 completed / Impacted TSs and TRs: 36.300; 36.413; 36.423 / WI rapporteur e-mail: Philippe.Godin@alcatel-lucent.com
- 5992: WI has perf. part only (as change from 4Rx to 8Rx has no Core spec impact) / Impacted TSs and TRs: LTE / WI rapporteur e-mail: Shan Yang (yangshan@ctbri.com.cn)
- 5993: RP#62 completed / Impacted TSs and TRs: 36.104; 36.141 / WI rapporteur e-mail: Shan Yang (yangshan@ctbri.com.cn)
- 5994: - / Impacted TSs and TRs: LTE / WI rapporteur e-mail: lars.e.lindh@nokia.com
- 5995: RP#64 completed / Impacted TSs and TRs: 36.101; 36.104; 36.133; 36.201; 36.211; 36.212; 36.213; 36.300; 36.302; 36.306; 36.331; new 36.847 / WI rapporteur e-mail: lars.e.lindh@nokia.com, Xiaodong Shen (shenxiaodong@chinamobile.com)
- 5996: ¦CD:Thu 18/06/15->Mon 15/06/15¦WID: RP-130848->RP-140522¦Stat Rep: RP-141374->RP-141972 / Impacted TSs and TRs: 36.101; 36.104; 36.133 / WI rapporteur e-mail: lars.e.lindh@nokia.com
- 5997: Triggered by Rel-11 TR 36.824 (FS_Cov_Enh_LTE) / Impacted TSs and TRs: LTE / WI rapporteur e-mail: Xiaoming She (shexm@ctbri.com.cn)
- 5998: RP#64 completed / Impacted TSs and TRs: 36.101; 36.104; 36.133; 36.211; 36.212; 36.213; 36.300; 36.321; 36.331 / WI rapporteur e-mail: Xiaoming She (shexm@ctbri.com.cn)
- 5999: ¦CD:Thu 18/06/15->Mon 15/06/15¦WID: RP-141966->RP-142235¦Stat Rep: RP-141149->RP-141833 / Impacted TSs and TRs: 36.101; 36.104; 36.133; 36.141 / WI rapporteur e-mail: Xiaoming She (shexm@ctbri.com.cn)
- 6000: ¦Stat Rep: -->RP-141834 03/07/15: Compl:5%->100% 03/07/15: CD:Tue 15/09/15->Mon 15/06/15 03/07/15: Stat Rep: RP-141834->RP-150631 / Impacted TSs and TRs: 36.508; 36.523-1; 36.523-2; 36.523-3 / WI rapporteur e-mail: YANG Shan (yangshan@ctbri.com.cn)
- 6001: Solutions for Minimization of Drive Tests (MDT), in order to reduce the need for manual drive testing for MBMS. / Impacted TSs and TRs: LTE / WI rapporteur e-mail: yeesin.chan@verizonwireless.com
- 6002: ¦CD:Thu 18/06/15->Mon 15/06/15¦WID: RP-130848->RP-140522¦Stat Rep: RP-141431->RP-141821 / Impacted TSs and TRs: 36.133; 36.214; 36.300; 36.304; 36.306; 36.331; 36.413; 36.423; 37.320 / WI rapporteur e-mail: yeesin.chan@verizonwireless.com
- 6003: ¦CD:Wed 17/12/14->Mon 15/12/14¦WID: RP-130848->RP-140522¦Stat Rep: RP-141431->RP-141821 / Impacted TSs and TRs: 36.133 / WI rapporteur e-mail: yeesin.chan@verizonwireless.com
- 6004: Triggered by TR 36.842 Study on Small Cell Enhancements for E-UTRA and E-UTRAN Higher-layer aspects (UID_580044) / Impacted TSs and TRs: LTE / WI rapporteur e-mail: tooru.uchino.fv@nttdocomo.com
- 6005: ¦CD:Wed 18/03/15->Sun 15/03/15¦WID: RP-130848->RP-140522¦Stat Rep: RP-141264->RP-141796 / Impacted TSs and TRs: 36.101; 36.104; 36.133; 36.211; 36.212; 36.213; 36.300; 36.302; 36.306; 36.321; 36.322; 36.323; 36.331; 36.410; 36.413; 36.420; 36.423; new RAN3 36.425 / WI rapporteur e-mail: RAN1/2/4 tooru.uchino.fv@nttdocomo.com, RAN3 Chenghock Ng (ngcheng@da.jp.nec.com)
- 6006: ¦Stat Rep: RP-141264->RP-141796 1st Apr 15: Compl:15%->45% 1st Apr 15: Stat Rep: RP-141796->RP-150160 03/07/15: Compl:45%->100% 03/07/15: Stat Rep: RP-150160->RP-150791 / Impacted TSs and TRs: 36.101; 36.104; 36.133 / WI rapporteur e-mail: kunihiko.teshima.hg@nttdocomo.com
- 6007: SP#64 Three CRs agreed in SP-140262 (23.251CR0099, 23.401CR2658&CR2707). Dec.14:99->100% / Impacted TSs and TRs: 23.251; 23.401
- 6008: Stage 2/3. CP#65 exception in CP-140487. LM70->100 / Impacted TSs and TRs: 23.007; 23.008; 29.274; 29.281 / WI rapporteur e-mail: Xiaoyan SHI (sean.shixiaoyan@huawei.com)
- 6009: tested Core part: LTE_SC_enh_dualC-Core 29/09/15: Compl:0%->3% 29/09/15: Stat Rep: -->RP-1511671/1/16: Compl:3%->15%1/1/16: CD:Tue 15/03/16->Wed 15/06/16¦ ;

| ID | WBS | Task | Duration | Start | Finish | Complete | Baseline start | Baseline finish | Baseline duration | Constraint | Resources | Work | Actual work | Acronym | PCG approved | WI rapporteur name | WI rapporteur e-mail | Release | TSG approved | MCC resp | Special Focus Doc | Acronym_3GU_Export | Status Report |
| --- | --- | --- | --- | --- | --- | --- | --- | --- | --- | --- | --- | --- | --- | --- | --- | --- | --- | --- | --- | --- | --- | --- | --- |
| 6010 | 1993 | **E-UTRA Small cell enhancements - Physical layer aspects** | 1324d? | 2013-12-15 A | 2017-06-15 A | 100% | 2013-07-19 | 2014-12-05 | 364.75d? |  | R1; R2; R4 | 32364.7h | 32364.7h | LTE_SC_enh_L1 | 32 | Huawei | Elean FAN (fanxiaoan@huawei.com) | Rel-12 | 62 | Patrick | Small cell | LTE_SC_enh_L1 |  |
| 6011 | 1993.1 | Core part: E-UTRA Small cell enhancements - Physical layer aspects | 161.25d? | 2013-12-15 A | 2014-12-15 A | 100% | 2013-07-19 | 2014-09-12 | 202d? | finish no earlier than 2014-12-15 | R1; R2; R4 | 3870h | 3870h | LTE_SC_enh_L1-Core | 32 | Huawei | Elean FAN (fanxiaoan@huawei.com) | Rel-12 | 62 | Patrick | Small cell | LTE_SC_enh_L1-Core | RP-141899 |
| 6012 | 1993.2 | Perf. part: E-UTRA Small cell enhancements - Physical layer aspects | 394d? | 2013-12-15 A | 2015-06-15 A | 100% | 2013-12-09 | 2014-12-05 | 261d? | finish no earlier than 2015-06-15 | R4 | 3152h | 3152h | LTE_SC_enh_L1-Perf | 32 | Huawei | Elean FAN (fanxiaoan@huawei.com) | Rel-12 | 62 | Issam | Small cell | LTE_SC_enh_L1-Perf | RP-150690 |
| 6013 | 1993.3 | UE Conformance Test Aspects - E-UTRA Small cell enhancements - Physical layer aspects | 525d? | 2015-06-15 A | 2017-06-15 A | 100% |  |  |  | finish no earlier than 2017-06-15 | R5 | 4200h | 4200h | LTE_SC_enh_L1-UEConTest | 35 | Huawei |  | Rel-12 | 68 |  |  |  |  |
| 6014 | 1994 | **Inter-eNB Coordinated Multi-Point (CoMP) for LTE** | 375.38d? | 2013-12-15 A | 2014-12-12 A | 100% | 2014-03-14 | 2014-09-12 | 130.65d? |  | R3; R1 | 4738.38h | 4738.38h | COMP_LTE_IeNB | 32 | Samsung | Sung Hwan Won (sunghwan.won@samsung.com) | Rel-12 | 62 | Juha |  | COMP_LTE_IeNB |  |
| 6015 | 1994.1 | Core part: Inter-eNB Coordinated Multi-Point (CoMP) for LTE | 165.5d? | 2013-12-15 A | 2014-12-12 A | 100% | 2014-03-14 | 2014-09-12 | 100.5d? | finish no earlier than 2014-12-15 | R3; R1 | 2648h | 2648h | COMP_LTE_IeNB-Core | 32 | Samsung | Sung Hwan Won (sunghwan.won@samsung.com) | Rel-12 | 62 | Juha |  | COMP_LTE_IeNB-Core | RP-141804 |
| 6016 | 1995 | **Smart Congestion Mitigation in E-UTRAN** | 579.62d? | 2014-03-05 A | 2015-09-15 A | 100% | 2014-03-05 | 2014-09-12 | 138d? |  | R2; S1; C1 | 12376h | 12376h | SCM_LTE | 32 | LG Electronics | youngdae.lee@lge.com | Rel-12 | 63 | Yong-Jun |  | SCM_LTE |  |
| 6017 | 1995.1 | Core part: Smart Congestion Mitigation in E-UTRAN | 137d? | 2014-03-06 A | 2014-09-12 A | 100% | 2014-03-06 | 2014-09-12 | 137d? | finish no earlier than 2014-09-12 | R2 | 1096h | 1096h | SCM_LTE-Core | 32 | LG Electronics | youngdae.lee@lge.com | Rel-12 | 63 | Yong-Jun |  | SCM_LTE-Core | RP-141292 |
| 6018 | 1995.2 | Stage 1 Prioritization of Multimedia Telephony (MMTel) and Mobile Originating-SMS for Access Class Barring (ACB) | 3d? | 2014-03-05 A | 2014-03-07 A | 100% | 2014-03-05 | 2014-03-07 | 3d? | finish no earlier than 2013-12-11 | S1 | 24h | 24h |  | 33 |  |  | Rel-12 | 64 |  |  |  |  |
| 6019 | 1995.3 | CT aspects of Smart Congestion Mitigation in E-UTRAN (Stage 3) | 94.12d? | 2014-06-13 A | 2014-09-11 A | 100% | 2014-06-13 | 2014-09-12 | 66d? | start no earlier than 2014-06-13 | C1 | 528h | 528h | SCM_LTE-CT | 33 | LG Electronics | Kim, Jaehyun (jaehyun7.kim@lge.com) | Rel-12 | 64 |  |  | SCM_LTE-CT |  |
| 6020 | 1995.4 | UE Conformance Test Aspects - Smart Congestion Mitigation in E-UTRAN | 132d? | 2015-03-16 A | 2015-09-15 A | 100% |  |  |  | finish no earlier than 2015-09-15 | R5 | 1056h | 1056h | SCM_LTE-UEConTest | 34 | NTT DOCOMO |  | Rel-12 | 67 |  |  |  | RP-151445 |
| 6021 | 1996 | **Positioning Enhancements for RF Pattern Matching in E-UTRA** | 51.75d? | 2014-04-25 A | 2014-06-13 A | 100% | 2014-04-25 | 2014-06-13 | 36d? |  | R3; R2 | 1152h | 1152h | LCS_LTE_RFPMT | 32 | Polaris Wireless | Gordon Scot (sgordon@polariswireless.com) | Rel-12 | 63 | Juha |  | LCS_LTE_RFPMT |  |
| 6022 | 1996.1 | Core part: Positioning Enhancements for RF Pattern Matching in E-UTRA | 36d? | 2014-04-25 A | 2014-06-13 A | 100% | 2014-04-25 | 2014-06-13 | 36d? | finish no earlier than 2014-06-13 | R3; R2 | 576h | 576h | LCS_LTE_RFPMT-Core | 32 | Polaris Wireless | Gordon Scot (sgordon@polariswireless.com) | Rel-12 | 63 | Juha |  | LCS_LTE_RFPMT-Core | RP-140591 |
| 6023 | 1997 | **Network-Assisted Interference Cancellation and Suppression for LTE** | 1139.75d? | 2014-03-11 A | 2017-03-15 A | 100% | 2014-03-06 | 2015-06-12 | 332d? |  | R1; R2; R4; R3 | 15467.9h | 15467.9h | LTE_NAICS | 32 | MediaTek | Craig.Burnet@mediatek.com | Rel-12 | 63 | Patrick |  | LTE_NAICS |  |
| 6024 | 1997.1 | Core part: Network-Assisted Interference Cancellation and Suppression for LTE | 113.67d? | 2014-07-11 A | 2014-12-15 A | 100% | 2014-07-11 | 2014-09-12 | 45.67d? | finish no earlier than 2014-12-15 | R1; R2; R4; R3 | 2803.87h | 2803.87h | LTE_NAICS-Core | 32 | MediaTek | Craig.Burnet@mediatek.com | Rel-12 | 63 | Patrick |  | LTE_NAICS-Core | RP-141866 |
| 6025 | 1997.2 | Perf. part: Network-Assisted Interference Cancellation and Suppression for LTE | 399d? | 2014-03-11 A | 2015-09-15 A | 100% | 2014-03-06 | 2015-06-12 | 332d? | finish no earlier than 2015-09-15 | R4 | 3192h | 3192h | LTE_NAICS-Perf | 32 | MediaTek | Craig.Burnet@mediatek.com | Rel-12 | 63 | Issam |  | LTE_NAICS-Perf | RP-151296 |
| 6026 | 1997.3 | UE Conformance Test Aspects: Network-Assisted Interference Cancellation and Suppression for LTE | 393d? | 2015-09-15 A | 2017-03-15 A | 100% |  |  |  | finish no earlier than 2017-03-15 | R5 | 3144h | 3144h | LTE_NAICS-UEConTest | 35 | Mediatek |  | Rel-12 | 69 |  |  |  |  |
| 6027 | 1998 | **Performance requirements of interference cancellation and suppression receiver for SU-MIMO** | 672.88d? | 2014-03-06 A | 2015-12-15 A | 100% | 2014-03-06 | 2015-03-13 | 267d? |  | R4 | 7448h | 7448h | LTE_SUMIMO_RX | 32 | Huawei | Qian Cheng (Q.Cheng@Huawei.com) | Rel-12 | 63 | Issam |  | LTE_SUMIMO_RX |  |
| 6028 | 1998.1 | Perf. part: Performance requirements of interference cancellation and suppression receiver for SU-MIMO | 267d? | 2014-03-06 A | 2015-03-13 A | 100% | 2014-03-06 | 2015-03-13 | 267d? | finish no earlier than 2015-03-15 | R4 | 2136h | 2136h | LTE_SUMIMO_RX-Perf | 32 | Huawei | Qian Cheng (Q.Cheng@Huawei.com) | Rel-12 | 63 | Issam |  | LTE_SUMIMO_RX-Perf | RP-150229 |
| 6029 | 1998.2 | UE Conformance Test Aspects - Performance Requirements of Interference Cancellation and Suppression Receiver for SU-MIMO for E-UTRA | 197d? | 2015-03-16 A | 2015-12-15 A | 100% |  |  |  | finish no earlier than 2016-03-15 | R5 | 1576h | 1576h | LTE_SUMIMO_RX-UEConTest | 34 | Huawei |  | Rel-12 | 67 |  |  |  | RP-151245 |
| 6030 | 1999 | **HSPA signalling enhancements for more efficient resource usage for LCR** | 387.62d? | 2012-12-11 A | 2013-12-20 A | 100% | 2012-12-10 | 2013-12-06 | 265d? |  | R1; R2; R3; R4 | 16832h | 16832h | LCR_TDD_HSPA_sign_enh | 30 | CATT | Yanping Xing (xingyanping@catt.cn) | Rel-12 | 58 | Patrick |  | LCR_TDD_HSPA_sign_enh |  |
| 6031 | 1999.1 | Core part: HSPA signalling enhancements for more efficient resource usage for LCR TDD | 270d? | 2012-12-15 A | 2013-12-20 A | 100% | 2012-12-10 | 2013-12-06 | 265d? | finish no earlier than 2013-12-15 | R1; R2; R3 | 6480h | 6480h | LCR_TDD_HSPA_sign_enh-Core | 30 | CATT | Yanping Xing (xingyanping@catt.cn) | Rel-12 | 58 | Patrick |  | LCR_TDD_HSPA_sign_enh-Core | RP-131499 |
| 6032 | 1999.2 | Perf. part: HSPA signalling enhancements for more efficient resource usage for LCR TDD | 198d? | 2012-12-11 A | 2013-09-06 A | 100% | 2012-12-11 | 2013-09-06 | 198d? | finish no earlier than 2013-09-06 | R4 | 1584h | 1584h | LCR_TDD_HSPA_sign_enh-Perf | 30 | CATT | Yanping Xing (xingyanping@catt.cn) | Rel-12 | 58 | Issam |  | LCR_TDD_HSPA_sign_enh-Perf | RP-130968 |
| 6033 | 2000 | **HNB Positioning for UTRA** | 177.62d? | 2013-06-18 A | 2013-12-06 A | 100% | 2013-06-18 | 2013-12-06 | 127d? |  | R3 | 2032h | 2032h | UTRA_HNB_Pos | 31 | Alcatel-Lucent | Martin.Warner@alcatel-lucent.com | Rel-12 | 60 | Juha | HNB | UTRA_HNB_Pos |  |
| 6034 | 2000.1 | Core part: HNB Positioning for UTRA | 127d? | 2013-06-18 A | 2013-12-06 A | 100% | 2013-06-18 | 2013-12-06 | 127d? | finish no earlier than 2013-12-06 | R3 | 1016h | 1016h | UTRA_HNB_Pos-Core | 31 | Alcatel-Lucent | Martin.Warner@alcatel-lucent.com | Rel-12 | 60 | Juha | HNB | UTRA_HNB_Pos-Core | RP-131974 |

Notes:
- 6010: Triggered by TR 36.872 Study on Small Cell Enhancements for E-UTRA and E-UTRAN Physical-layer aspects (UID_580041) / Impacted TSs and TRs: LTE
- 6011: ¦CD:Tue 12/05/15->Mon 15/12/14¦WID: RP-130848->RP-140522¦Stat Rep: RP-141632->RP-141899 / Impacted TSs and TRs: 36.101; 36.104; 36.133; 36.211; 36.212; 36.213; 36.214; 36.300; 36.306; 36.321; 36.331; 36.413; 36.423; 36.443
- 6012: ¦CD:Wed 18/03/15->Sun 15/03/15¦WID: RP-130848->RP-140522¦Stat Rep: RP-141632->RP-141899 1st Apr 15: Compl:40%->80% 1st Apr 15: CD:Sun 15/03/15->Mon 15/06/15 1st Apr 15: Stat Rep: RP-141899->RP-150173 03/07/15: Compl:80%->100% 03/07/15: Stat Rep: RP- / Impacted TSs and TRs: 36.101; 36.104; 36.133; 36.141
- 6013: tested Core part: LTE_SC_enh_L1-Core 29/09/15: Compl:0%->10% 29/09/15: CD:Wed 15/06/16->Thu 15/12/16 29/09/15: Stat Rep: -->RP-151247¦1/1/16: Compl:10%->40%¦
- 6014: Stage 3. Rel-11 did not address support of a network interface for CoMP involving multiple eNBs with non-ideal backhaul (affected operators might not take advantage of performance benefit from inter-eNB CoMP operation). / Impacted TSs and TRs: LTE
- 6015: CD:Thu 11/12/14->Mon 15/12/14¦Compl:85%->100%¦Stat Rep: RP-140597->RP-141804 / Impacted TSs and TRs: 36.300; 36.423
- 6016: follow-up of TR 36.848 FS_SCM_LTE / Impacted TSs and TRs: LTE
- 6017: RP#65 completed / Impacted TSs and TRs: 36.331
- 6018: SP#63 SP-140065 CR under TEI12 / Impacted TSs and TRs: 22.011
- 6019: CP#65 completed / Impacted TSs and TRs: 24.173; 24.301; 24.341; 27.007
- 6020: 03/07/15: Compl:0%->60% 03/07/15: WID: RP-150202->RP-150797 03/07/15: Stat Rep: ->RP-150794 29/09/15: Compl:60%->100% 29/09/15: Stat Rep: RP-150794->RP-151445
- 6021: follow-up of TR 36.809 FS_LCS_LTE_RFPMT / Impacted TSs and TRs: LTE
- 6022: RP#64 completed / Impacted TSs and TRs: 36.305; 36.455
- 6023: follow-up of TR 36.866 FS_LTE_NAICS / Impacted TSs and TRs: LTE
- 6024: CD:Mon 08/12/14->Mon 15/12/14¦Compl:95%->100%¦Stat Rep: RP-141621->RP-141866 / Impacted TSs and TRs: 36.211; 36.213; 36.300; 36.331; 36.423
- 6025: CD:Fri 12/06/15->Mon 15/06/15¦Compl:0%->25%¦Stat Rep: RP-141621->RP-141866 1st Apr 15: Compl:25%->50% 1st Apr 15: Stat Rep: RP-141866->RP-150179 03/07/15: Compl:50%->85% 03/07/15: CD:Mon 15/06/15->Tue 15/09/15 03/07/15: Stat Rep: RP-150179->RP-150862 / Impacted TSs and TRs: 36.101
- 6026: tested: LTE_NAICS was a REL-12 RAN1 WI¦1/1/16: Compl:0%->35%¦1/1/16: WID: RP-151298->RP-151945¦
- 6027: no Core part / Impacted TSs and TRs: LTE
- 6028: CD:Fri 13/03/15->Sun 15/03/15¦Compl:50%->80%¦Stat Rep: RP-141255->RP-141906 1st Apr 15: Compl:80%->100% 1st Apr 15: Stat Rep: RP-141906->RP-150229 / Impacted TSs and TRs: 36.101
- 6029: 03/07/15: Compl:0%->5% 03/07/15: Stat Rep: ->RP-150692 29/09/15: Compl:5%->55% 29/09/15: WID: RP-150245->RP-151463 29/09/15: Stat Rep: RP-150692->RP-1512451/1/16: Compl:55%->100%1/1/16: CD:Tue 15/03/16->Tue 15/1
- 6030: Stage 2/3. Triggered by Rel-11 TR 25.874 Study on HSPA feedback and signalling efficiency enhancements for LCR TDD (FS_LCRTDD_HSPAenh) UID_540026 / Impacted TSs and TRs: UTRA
- 6031: Prev CD:Fri 06/12/13¦Prev %:100% / Impacted TSs and TRs: 25.222; 25.224; 25.331; 25.423; 25.433
- 6032: RP#61 completed / Impacted TSs and TRs: 25.102
- 6033: RP#62 completed / Impacted TSs and TRs: UTRA
- 6034: RP#62 closed at 85% completion. Not completed work on HNB positioning / No consensus (may be TEI12, if contribution and support). Updated WID RP-130868=>RP-132037 (HNB positiong was not addressed in this WI, however it was NOT remoded from the WID) / Impacted TSs and TRs: 25.305; 25.467; new 25.470

| ID | WBS | Task | Duration | Start | Finish | Complete | Remaining | Baseline start | Baseline finish | Baseline duration | Total slack | Constraint | Resources | Work | Actual work | Acronym | PCG approved | WI rapporteur name | WI rapporteur e-mail | Release | TSG approved | MCC resp | Acronym_3GU_Export | Status Report | Special Focus Doc | PCG stopped | TSG stopped |
| --- | --- | --- | --- | --- | --- | --- | --- | --- | --- | --- | --- | --- | --- | --- | --- | --- | --- | --- | --- | --- | --- | --- | --- | --- | --- | --- | --- |
| 6035 | 2001 | **Dedicated Channel (DCH) enhancements for UMTS** | 1040.38d? | 2013-09-15 A | 2016-06-15 A | 100% |  | 2013-09-10 | 2014-12-05 | 326d? |  |  | R1; R2; R3; R4 | 32048h | 32048h | UTRA_DCHenh | 31 | Qualcomm | arjunb@qti.qualcomm.com | Rel-12 | 61 | Patrick | UTRA_DCHenh |  |  |  |  |
| 6036 | 2001.1 | Core part: Dedicated Channel (DCH) enhancements for UMTS | 115.25d? | 2013-11-18 A | 2014-09-12 A | 100% |  | 2013-11-18 | 2014-09-12 | 115.25d? |  | finish no earlier than 2014-09-12 | R1; R2; R3; R4 | 3688h | 3688h | UTRA_DCHenh-Core | 31 | Qualcomm | arjunb@qti.qualcomm.com | Rel-12 | 61 | Patrick | UTRA_DCHenh-Core | RP-141137 |  |  |  |
| 6037 | 2001.2 | Perf. part: Dedicated Channel (DCH) enhancements for UMTS | 329d? | 2013-09-15 A | 2014-12-15 A | 100% |  | 2013-09-10 | 2014-12-05 | 326d? |  | finish no earlier than 2014-12-15 | R4 | 2632h | 2632h | UTRA_DCHenh-Perf | 31 | Qualcomm | arjunb@qti.qualcomm.com | Rel-12 | 61 | Issam | UTRA_DCHenh-Perf | RP-141970 |  |  |  |
| 6038 | 2001.3 | UE Conformance Test Aspects - DCH Enhancements for UMTS | 328d? | 2015-03-16 A | 2016-06-15 A | 100% |  |  |  |  |  | finish no earlier than 2016-06-15 | R5 | 2624h | 2624h | UTRA_DCHenh-UEConTest | 34 | Qualcomm | NA | Rel-12 | 67 |  |  | RP-151279 |  |  |  |
| 6039 | 2002 | **UMTS Mobility enhancements for heterogeneous networks** | 336.85d? | 2013-07-23 A | 2014-06-13 A | 100% |  | 2013-07-23 | 2014-06-13 | 237.85d? |  |  | R2; R3; R4 | 8040h | 8040h | UTRA_HetNet_mob | 31 | Huawei | Xudong Yang (yangxudong@huawei.com) | Rel-12 | 61 | Yong-Jun | UTRA_HetNet_mob |  |  |  |  |
| 6040 | 2002.1 | Core part: UMTS Mobility enhancements for heterogeneous networks | 67d? | 2013-07-23 A | 2014-06-13 A | 100% |  | 2013-07-23 | 2014-06-13 | 67d? |  | finish no earlier than 2014-06-13 | R2; R3; R4 | 1608h | 1608h | UTRA_HetNet_mob-Core | 31 | Huawei | Xudong Yang (yangxudong@huawei.com) | Rel-12 | 61 | Yong-Jun | UTRA_HetNet_mob-Core | RP-140636 |  |  |  |
| 6041 | 2002.2 | Perf. part: UMTS Mobility enhancements for heterogeneous networks | 201d? | 2013-09-09 A | 2014-06-13 A | 100% |  | 2013-09-09 | 2014-06-13 | 201d? |  | finish no earlier than 2014-06-13 | R4 | 1608h | 1608h | UTRA_HetNet_mob-Perf | 31 | Huawei | Xudong Yang (yangxudong@huawei.com) | Rel-12 | 61 | Issam | UTRA_HetNet_mob-Perf | RP-140636 |  |  |  |
| 6042 | 2003 | **UMTS Heterogeneous Networks enhancements** | 388d? | 2013-12-06 A | 2014-12-15 A | 100% |  | 2013-12-06 | 2014-12-05 | 262d? |  |  | R1; R2; R3; R4 | 12408h | 12408h | UTRA_HetNet_enh | 32 | Huawei | carmela.cozzo@huawei.com | Rel-12 | 62 | Patrick | UTRA_HetNet_enh |  |  |  |  |
| 6043 | 2003.1 | Core part: Heterogeneous Networks enhancements | 202d? | 2013-12-06 A | 2014-09-12 A | 100% |  | 2013-12-06 | 2014-09-12 | 202d? |  | finish no earlier than 2014-09-15 | R1 | 1616h | 1616h | UTRA_HetNet_enh-Core | 32 | Huawei | carmela.cozzo@huawei.com | Rel-12 | 62 | Patrick | UTRA_HetNet_enh-Core | RP-141702 |  |  |  |
| 6044 | 2003.2 | Perf. part: Heterogeneous Networks enhancements | 265d? | 2013-12-15 A | 2014-12-15 A | 100% |  | 2013-12-09 | 2014-12-05 | 261d? |  | finish no earlier than 2014-12-15 | R4 | 2120h | 2120h | UTRA_HetNet_enh-Perf | 32 | Huawei | carmela.cozzo@huawei.com | Rel-12 | 62 | Issam | UTRA_HetNet_enh-Perf | RP-141898 |  |  |  |
| 6045 | 2004 | **Enhanced Broadcast of System Information** | 388d? | 2013-12-06 A | 2014-12-15 A | 100% |  | 2013-12-06 | 2014-12-05 | 262d? |  |  | R2; R1; R3; R4 | 16385.6h | 16385.6h | UTRA_SIBenh | 32 | Ericsson | martin.van.der.zee@ericsson.com | Rel-12 | 62 | Yong-Jun | UTRA_SIBenh |  |  |  |  |
| 6046 | 2004.1 | Core part: Enhanced Broadcast of System Information | 174.8d? | 2013-12-06 A | 2014-09-12 A | 100% |  | 2013-12-06 | 2014-09-12 | 174.8d? |  | finish no earlier than 2014-09-12 | R2; R1; R3; R4 | 5593.6h | 5593.6h | UTRA_SIBenh-Core | 32 | Ericsson | martin.van.der.zee@ericsson.com | Rel-12 | 62 | Yong-Jun | UTRA_SIBenh-Core | RP-141230 |  |  |  |
| 6047 | 2004.2 | Perf. part: Enhanced Broadcast of System Information | 265d? | 2013-12-15 A | 2014-12-15 A | 100% |  | 2013-12-09 | 2014-12-05 | 261d? |  | finish no earlier than 2014-12-15 | R4 | 2120h | 2120h | UTRA_SIBenh-Perf | 32 | Ericsson | martin.van.der.zee@ericsson.com | Rel-12 | 62 | Issam | UTRA_SIBenh-Perf | RP-142080 |  |  |  |
| 6048 | 2005 | **Further Enhanced Uplink (EUL) enhancements** | 469.62d? | 2013-12-15 A | 2015-03-13 A | 100% |  | 2013-12-09 | 2014-12-05 | 261d? |  |  | R2 | 13704h | 13704h | EDCH_enh | 32 | Ericsson | mark.curran@ericsson.com | Rel-12 | 62 | Yong-Jun | EDCH_enh |  |  |  |  |
| 6049 | 2005.1 | Core part: Further Enhanced Uplink (EUL) enhancements | 264d? | 2013-12-15 A | 2014-12-15 A | 100% |  | 2014-04-29 | 2014-09-12 | 99d? |  | finish no earlier than 2014-12-15 | R2; R1; R3; R4 | 8448h | 8448h | EDCH_enh-Core | 32 | Ericsson | mark.curran@ericsson.com | Rel-12 | 62 | Yong-Jun | EDCH_enh-Core | RP-141860 |  |  |  |
| 6050 | 2005.2 | Perf. part: Further Enhanced Uplink (EUL) enhancements | 328d? | 2013-12-15 A | 2015-03-13 A | 100% |  | 2013-12-09 | 2014-12-05 | 261d? |  | finish no earlier than 2015-03-15 | R4 | 2624h | 2624h | EDCH_enh-Perf | 32 | Ericsson | mark.curran@ericsson.com | Rel-12 | 62 | Issam | EDCH_enh-Perf | RP-150062 |  |  |  |
| 6051 | 2006 | (Small) Technical Enhancements and Improvements for Rel-12 | 197.5d? | 2012-12-25 A | 2014-09-16 A | 100% |  | 2012-12-25 | 2014-09-17 | 197.5d? |  | finish no earlier than 2014-09-17 | SP; CP; RP; GP | 6320h | 6320h | TEI12 | 29 |  |  | Rel-12 | 56 |  | TEI12 |  |  |  |  |
| 6052 | 2007 | (IETF) (Small) Technical Enhancements and Improvements for Rel-12 (draft-ietf-insipid-session-id) | 131d? | 2014-06-13 A | 2014-12-09 A | 100% |  |  |  |  |  | start no earlier than 2014-06-13 | C1-IETF | 1048h | 1048h | TEI12_IETF | 34 | Alcatel-Lucent |  | Rel-12 | 66 |  |  |  |  |  |  |
| 6053 | 2008 | Test - (Small) Technical Enhancements and Improvements for Rel-12 | 295.5d? | 2014-10-24 A | 2015-12-11 A | 100% |  | 2014-10-24 | 2015-12-11 | 295.5d? |  | finish no earlier than 2015-12-11 | R5; G3new | 4728h | 4728h | TEI12_Test | 31 |  |  | Rel-12 | 61 | Ingbert | TEI12_Test |  |  |  |  |
| 6054 | 2009 | Release 12 Studies | 384.25d? | 2013-08-05 A | 2014-08-22 | 80% | 147.05d? | 2013-08-05 | 2014-09-17 | 296.5d? | 42104.6d | finish no earlier than 2014-09-17 | SP; CP; GP; RP | 9488h | 7590.4h |  |  |  |  | Rel-12 |  |  |  |  |  |  |  |
| 6055 | 2010 | Study on Alternatives to E.164 for Machine-Type Communications | 513d? | 2010-03-25 A | 2012-03-07 A | 100% |  | 2010-03-25 | 2012-03-07 | 513d? |  | finish no earlier than 2012-03-07 | S1 | 4080h | 4080h | FS_AMTC | 24 | T-Mobile USA | gary.jones@T-Mobile.com | Rel-12 | 47 | Alain | FS_AMTC |  | MTC, M2M |  |  |
| 6056 | 2011 | Study on enhancements for Machine-Type Communications (MTC) | 720d? | 2010-06-10 A | 2013-03-06 A | 100% |  | 2010-06-10 | 2013-03-06 | 720d? |  | finish no earlier than 2013-03-06 | S1 | 5751.26h | 5751.26h | FS_MTCe | 25 | Huawei | laurence.meriau@huawei.com | Rel-12 | 48 | Alain | FS_MTCe |  | MTC, M2M |  |  |
| 6057 | 2012 | Study on Integration of Single Sign-On (SSO) frameworks with 3GPP networks | 383d? | 2010-09-23 A | 2012-03-07 A | 100% |  | 2010-09-23 | 2012-03-07 | 383d? |  | finish no earlier than 2011-09-08 | S1 | 3041.15h | 3041.15h | FS_SSO_Int | 25 | InterDigital | christopher.wallace@interdigital.com | Rel-12 | 49 | Alain | FS_SSO_Int |  |  |  |  |
| 6058 | 2013 | Study on Continuity of Data Sessions to Local Networks | 262.85d? | 2010-12-16 A | 2011-12-14 A | 100% |  | 2010-12-16 | 2011-12-14 | 262.85d? |  | finish no earlier than 2011-12-14 | S1 | 2084.27h | 2084.27h | FS_CSN | 26 | NEC | joerg.swetina@neclab.eu | Rel-12 | 50 | Alain | FS_CSN |  |  |  |  |
| 6059 | 2014 | Study on non-MTC Mobile Data Applications Impacts | 262.77d? | 2010-12-16 A | 2011-12-14 A | 100% |  | 2010-12-16 | 2011-12-14 | 262.77d? |  | finish no earlier than 2011-12-14 | S1 | 2083.59h | 2083.59h | FS_MODAI | 26 | Huawei, China Mobile | Amar Deol (adeol@huawei.com), Gang Li | Rel-12 | 50 | Alain | FS_MODAI |  |  |  |  |
| 6060 | 2015 | Study on Proximity-based Services | 384d? | 2011-09-22 A | 2013-03-05 A | 100% |  | 2011-09-22 | 2013-03-05 | 384d? |  | finish no earlier than 2012-12-12 | S1 | 3045.82h | 3045.82h | FS_ProSe | 27 | Qualcomm | Rich Hovey (rhovey@qualcomm.com) | Rel-12 | 53 | Alain | FS_ProSe |  | Public Safety (A-A) |  |  |
| 6061 | 2016 | Study on User Plane Congestion management | 198d? | 2011-12-14 A | 2012-09-12 A | 100% |  | 2011-12-14 | 2012-09-12 | 198d? |  | finish no earlier than 2012-09-12 | S1 | 1568h | 1568h | FS_UPCON | 28 | KDDI | John Visser (jvisser@rogers.com) | Rel-12 | 54 | Alain | FS_UPCON |  |  |  |  |
| 6062 | 2017 | Study on RAN Sharing Enhancements | 401d? | 2011-12-14 A | 2013-06-19 A | 100% |  | 2011-12-14 | 2013-06-19 | 401d? |  | finish no earlier than 2013-06-19 | S1 | 3192h | 3192h | FS_RSE | 28 | NEC | joerg.swetina@neclab.eu | Rel-12 | 54 | Alain | FS_RSE |  |  |  |  |
| 6063 | 2018 | Deleted - Study on UICC/USIM enhancements | 588d? | 2009-12-10 A | 2012-03-07 A | 100% |  | 2009-12-10 | 2012-03-07 | 588d? |  | finish no earlier than 2012-03-07 | S1 | 4704h | 4704h | FS_U2e | 24 | Giesecke & Devrient | ilario.macchi@gi-de.com | Rel-12 | 46 | Alain | FS_U2e |  |  | PCG-28 | SP-55 |

Notes:
- 6035: Triggered by Rel-12 TR 25.702 Study on Dedicated Channel (DCH) enhancements for UMTS (FS_UTRA_DCHenh) UID_580040. Stage 2/3 / Impacted TSs and TRs: UTRA
- 6036: RP#65 completed / Impacted TSs and TRs: 25.101; 25.104; 25.133; 25.211; 25.212; 25.213; 25.214; 25.215; 25.306; 25.308; 25.321; 25.331; 25.423; 25.433
- 6037: ¦Stat Rep: RP-141137->RP-141970 / Impacted TSs and TRs: 25.101; 25.104; 25.133
- 6038: 03/07/15: Compl:0%->15% 03/07/15: Stat Rep: ->RP-150764 29/09/15: Compl:15%->50% 29/09/15: CD:Tue 15/12/15->Wed 15/06/16 29/09/15: Stat Rep: RP-150764->RP-1512791/1/16: Compl:50%->65%;
- 6039: Triggered by Rel-12 TR 25.800 Study on UMTS heterogeneous networks (FS_UTRA_hetnet) UID_570024. Stage 2/3 / Impacted TSs and TRs: UTRA
- 6040: RP#64 completed. TS 25.300v100 for 1-step Approval / Impacted TSs and TRs: 25.101; 25.104; 25.133; 25.141; 25.304; 25.306; 25.331; 25.433; new 25.300
- 6041: RP#64 completed / Impacted TSs and TRs: 25.101; 25.104; 25.133; 25.141
- 6042: Triggered by the 2nd part of TR 25.800 (FS_UTRA_HetNet)¦the 1st part is addressed by UTRA_HetNet_mob UID_610026 / Impacted TSs and TRs: UTRA
- 6043: RP#65 completed. Updated WID RP-140463=>RP-141701 / Impacted TSs and TRs: 25.101; 25.211; 25.212; 25.213; 25.214; 25.300; 25.302; 25.306; 25.308; 25.319; 25.331; 25.423; 25.433
- 6044: ¦Stat Rep: RP-141702->RP-141898 / Impacted TSs and TRs: 25.101; 25.104; 25.133; 25.141
- 6045: Triggered by Rel-12 UTRA TR 25.704 Study on Enhanced Broadcast of System Information (FS_UTRA_SIBenh) / Impacted TSs and TRs: UTRA
- 6046: RP#65 completed / Impacted TSs and TRs: 25.211; 25.212 ; 25.213; 25.214; 25.301; 25.302; 25.304; 25.306; 25.321; 25.331; 25.433
- 6047: ¦Stat Rep: RP-141230->RP-142080 / Impacted TSs and TRs: 25.101; 25.104; 25.133; 25.141
- 6048: Triggered by Rel-12 UTRA TR 25.700 Study on Further Enhanced Uplink (EUL) enhancements (FS_EDCH_enh) / Impacted TSs and TRs: UTRA
- 6049: ¦Stat Rep: RP-141684->RP-141860 / Impacted TSs and TRs: 25.211; 25.212; 25.214; 25.304; 25.306; 25.308; 25.319; 25.321; 25.331; 25.423; 25.425; 25.433; 25.435
- 6050: ¦CD:Wed 18/03/15->Sun 15/03/15¦Stat Rep: RP-141684->RP-141860 1st Apr 15: Compl:75%->100% 1st Apr 15: Stat Rep: RP-141860->RP-150062 / Impacted TSs and TRs: 25.101; 25.104; 25.133; 25.141
- 6051: -
- 6052: Mar15: In WGLC¦21/3/17: 50%->100; 9/4/21: RFC 7989 added; / Impacted TSs and TRs: draft-ietf-insipid-session-id; RFC 7989
- 6053: -
- 6054: -
- 6055: SP#55 completed. Determine an alternative to E.164 for identifying individual devices and route messages between those devices / Impacted TSs and TRs: 22.988
- 6056: SP#59 completed. TR 22.888 v100 for Information & Approval. Study addition of new MTC-related use cases and functionality and improvements to existing requirements in TS 22.368 / Impacted TSs and TRs: 22.888
- 6057: SP#55 completed. Linked to SA3 Study on Single Sign On (SSO) Application Security for IMS - based on SIP Digest (UID_480048), SA3 TR 33.924 Extended Identity Management (GBA-IdM) and SA3 TR 33.980 (LibSec) / Impacted TSs and TRs: 22.895
- 6058: SP#54 completed. Linked to SA1 Rel-11 Feature UID_490030 SIPTO Service Continuity of IP Data Session (SIPTO_SC) / Impacted TSs and TRs: 22.896
- 6059: SP#54 completed. Linked to UID_490036 SA2 Rel-11 TR 23.843 Study on Core Network Overload solutions (FS_CNO) / Impacted TSs and TRs: 22.801
- 6060: SP#59 completed / Impacted TSs and TRs: 22.803
- 6061: SP#57 completed. Linked to SAPP (Service Awareness and Privacy Policies), FS_UMONC (Study on Usage Monitoring Control Enhancement), QoS_SSL (QoS Control Based on Subscriber Spending Limits) / Impacted TSs and TRs: 22.805
- 6062: SP#60 completed. Extend Rel-6 Network Sharing UID_31018 (basic scenarios of network/RAN sharing) to cover more complex scenarios that arise due to recent needs for more dynamic co-operation among operators / Impacted TSs and TRs: 22.852
- 6063: SP#55 work stopped. Triggered by GSMA Smart SIM and 3GNBK projects, and to evolve from traditional USAT to multimedia USIM toolkit support, particularly to Smart Card Web Server / Impacted TSs and TRs: 22.817

| ID | WBS | Task | Duration | Start | Finish | Complete | Baseline start | Baseline finish | Baseline duration | Constraint | Resources | Work | Actual work | Acronym | PCG approved | Impacted TSs and TRs | WI rapporteur name | WI rapporteur e-mail | Release | TSG approved | MCC resp | Acronym_3GU_Export | Special Focus Doc | PCG stopped | TSG stopped | Status Report |
| --- | --- | --- | --- | --- | --- | --- | --- | --- | --- | --- | --- | --- | --- | --- | --- | --- | --- | --- | --- | --- | --- | --- | --- | --- | --- | --- |
| 6064 | 2019 | **Study on IMS based Peer-to-Peer Content Distribution Services (Stage 2)** | 840.12d? | 2010-09-23 A | 2012-12-12 A | 100% | 2010-09-23 | 2012-12-12 | 587d? |  | S2; S1; S3 | 19472h | 19472h | FS_IMS_P2P_CDS | 25 | 23.844 | China Mobile | Yu Qing (yuqing@chinamobile.com) | Rel-12 | 49 | Maurice | FS_IMS_P2P_CDS |  |  |  |  |
| 6065 | 2019.1 | SA1 part of Study on IMS based Peer-to-Peer Content Distribution Services (Stage 2) | 262d? | 2010-09-23 A | 2011-09-21 A | 100% | 2010-09-23 | 2011-09-21 | 262d? | finish no earlier than 2011-09-21 | S1 | 2080h | 2080h | FS_IMS_P2P_CDS | 25 | 23.844 | China Mobile | Yu Qing (yuqing@chinamobile.com) | Rel-12 | 49 | Maurice |  |  |  |  |  |
| 6066 | 2019.2 | SA2 part of Study on IMS based Peer-to-Peer Content Distribution Services (Stage 2) | 347d? | 2010-09-23 A | 2012-06-20 A | 100% | 2010-09-23 | 2012-06-20 | 347d? | finish no earlier than 2012-06-08 | S2 | 2776h | 2776h | FS_IMS_P2P_CDS | 25 | 23.844 | China Mobile | Yu Qing (yuqing@chinamobile.com) | Rel-12 | 49 | Maurice |  |  |  |  |  |
| 6067 | 2019.3 | SA3 part of Study on IMS based Peer-to-Peer Content Distribution Services (Stage 2) | 68d? | 2012-09-12 A | 2012-12-12 A | 100% | 2012-09-12 | 2012-12-12 | 68d? | finish no earlier than 2012-12-12 | S3 | 528h | 528h | FS_IMS_P2P_CDS | 29 | 33.844 | China Mobile | Zhu Judy(zhuhongru@chinamobile.com) | Rel-12 | 57 | Mirko |  |  |  |  |  |
| 6068 | 2020 | **Study on Core Network Overload solutions** | 1216.5d? | 2010-09-23 A | 2013-12-11 A | 100% | 2010-09-23 | 2013-12-11 | 852d? |  | S2 | 18240.6h | 18240.6h | FS_CNO | 25 | 23.843 | Huawei | Mirko.Schramm@huawei.com | Rel-12 | 49 | Maurice | FS_CNO |  |  |  |  |
| 6069 | 2020.1 | Study on Core Network Overload solutions (Phase 1) | 587d? | 2010-09-23 A | 2012-12-12 A | 100% | 2010-09-23 | 2012-12-12 | 587d? | finish no earlier than 2012-12-12 | S2 | 4684.11h | 4684.11h | FS_CNO | 25 | 23.843 | Huawei | Mirko.Schramm@huawei.com | Rel-12 | 49 | Maurice |  |  |  |  |  |
| 6070 | 2020.2 | Study on Core Network Overload solutions (Phase 2) | 844d? | 2010-09-23 A | 2013-12-11 A | 100% | 2010-09-23 | 2013-12-11 | 844d? | finish no earlier than 2013-12-11 | S2 | 6744h | 6744h | FS_CNO | 25 | 23.843 | Huawei | Mirko.Schramm@huawei.com | Rel-12 | 49 | Maurice |  |  |  |  |  |
| 6071 | 2021 | Study on System Enhancements for Energy Efficiency | 399d? | 2010-12-16 A | 2012-06-20 A | 100% | 2010-12-16 | 2012-06-20 | 399d? | finish no earlier than 2012-06-20 | S2 | 3192h | 3192h | FS_SEEE | 26 | 23.866 | Huawei | frank.mademann@huawei.com | Rel-12 | 50 | Maurice | FS_SEEE |  |  |  |  |
| 6072 | 2022 | Study on S2a Mobility based On GTP and WLAN access to EPC | 934.88d? | 2011-03-23 A | 2013-09-11 A | 100% | 2011-03-23 | 2013-09-11 | 657d? | finish no earlier than 2013-09-11 | S2 | 5165.94h | 5165.94h | FS_SaMOG | 26 | 23.852 | ZTE | Tricci So (tso@zteusa.com) | Rel-12 | 51 | Maurice | FS_SaMOG | WLAN |  |  |  |
| 6073 | 2023 | Study on Optimized Offloading to WLAN in 3GPP-RAT Mobility | 326d? | 2012-06-18 A | 2013-09-11 A | 100% | 2012-06-18 | 2013-09-11 | 326d? | finish no earlier than 2013-09-11 | S2 | 2592h | 2592h | FS_WORM | 29 | 23.890 | BlackBerry | Steve Barrett (sbarrett@blackberry.com) | Rel-12 | 56 | Maurice | FS_WORM | WLAN |  |  |  |
| 6074 | 2024 | Study on Application Based Charging | 190d? | 2012-06-18 A | 2013-03-06 A | 100% | 2012-06-18 | 2013-03-06 | 190d? | finish no earlier than 2013-03-06 | S2 | 1520h | 1520h | FS_ABC | 29 | 23.800 | Allot | Alla Goldner (agoldner@allot.com) | Rel-12 | 56 | Maurice | FS_ABC |  |  |  |  |
| 6075 | 2025 | **Study on Multi Access PDN connectivity and IP flow Mobility** | 1643.71d? | 2008-08-08 A | 2012-12-12 A | 100% | 2008-08-08 | 2012-12-12 | 1141.96d? |  | S2; S1 | 27327.4h | 27327.4h | FS_MAPIM | 21 | 23.861 | Qualcomm | Gerardo Giaretta (gerardog@qualcomm.com) | Rel-12 | 41 | Maurice | FS_MAPIM |  |  |  |  |
| 6076 | 2025.1 | SA1 part of Study on Multi Access PDN connectivity and IP flow Mobility | 22d? | 2008-08-08 A | 2011-09-21 A | 100% | 2008-08-08 | 2011-09-21 | 22d? | finish no earlier than 2011-09-21 | S1 | 160h | 160h | FS_MAPIM | 21 | 23.861 | Qualcomm | Gerardo Giaretta (gerardog@qualcomm.com) | Rel-12 | 41 | Maurice |  |  |  |  |  |
| 6077 | 2025.2 | SA2 part of Study on Multi Access PDN connectivity and IP flow Mobility | 1113d? | 2008-09-18 A | 2012-12-12 A | 100% | 2008-09-18 | 2012-12-12 | 1113d? | finish no earlier than 2012-12-12 | S2 | 8896h | 8896h | FS_MAPIM | 21 | 23.861 | Qualcomm | Gerardo Giaretta (gerardog@qualcomm.com) | Rel-12 | 41 | Maurice |  |  |  |  |  |
| 6078 | 2026 | Deleted - Study on IP Flow Mobility support for S2a and S2b Interfaces | 190d? | 2012-06-18 A | 2013-03-06 A | 100% | 2012-06-18 | 2013-03-06 | 190d? | finish no earlier than 2013-03-06 | S2 | 1520h | 1520h | FS_NBIFOM | 29 | 23.861 | ZTE | Tricci So (tso@zteusa.com) | Rel-12 | 56 | Maurice | FS_NBIFOM |  | PCG-30 | SP-59 |  |
| 6079 | 2027 | Study on Extended IMS Media Plane Security features | 719d? | 2010-06-10 A | 2013-03-06 A | 100% | 2010-06-10 | 2013-03-06 | 719d? | finish no earlier than 2013-03-06 | S3 | 5736h | 5736h | FS_eMEDIASEC | 25 | 33.829 | Vodafone | Aguibou.Barry@vodafone.com | Rel-12 | 48 | Mirko | FS_eMEDIASEC |  |  |  |  |
| 6080 | 2028 | Deleted - Study on Firewall traversal (Stage 2) | 854d? | 2011-06-17 A | 2014-09-17 A | 100% | 2011-06-17 | 2014-09-17 | 854d? | finish no earlier than 2014-09-17 | S3 | 6832h | 6832h | FS_Fire | 27 | 33.830 | Acme Packet | Prashant Kumar (PKumar@acmepacket.com) | Rel-12 | 53 | Mirko | FS_Fire |  | PCG-33 | SP-65 |  |
| 6081 | 2029 | Study on Security on spoofed call detection and prevention (Stage 2) | 662d? | 2012-03-07 A | 2014-09-17 A | 100% | 2012-03-07 | 2014-09-17 | 662d? | finish no earlier than 2014-09-17 | S3 | 5296h | 5296h | FS_SPOOF | 28 | 33.831 | China Mobile | lixiangjun@chinamobile.com | Rel-12 | 55 | Mirko | FS_SPOOF |  |  |  |  |
| 6082 | 2030 | Study on Security Assurance Methodology for 3GPP Network Elements | 466d? | 2012-09-13 A | 2014-06-18 A | 100% | 2012-09-13 | 2014-06-18 | 466d? | finish no earlier than 2014-03-07 | S3 | 3696h | 3696h | FS_SECAM | 29 | 33.805 | Orange | loic.habermacher@orange.com | Rel-12 | 57 | Mirko | FS_SECAM |  |  |  |  |
| 6083 | 2031 | Study on Improved Support for Dynamic Adaptive Streaming over HTTP in 3GPP | 729d? | 2011-12-14 A | 2014-09-16 A | 100% | 2011-12-14 | 2014-09-17 | 729d? | finish no earlier than 2014-09-17 | S4 | 5824h | 5824h | FS_IS_DASH | 28 | 26.938 | Qualcomm | c_tstock@qualcomm.com | Rel-12 | 54 | Paolo | FS_IS_DASH |  |  |  |  |
| 6084 | 2032 | Study on HTML5 for a new presentation layer in 3GPP services | 266d? | 2013-09-12 A | 2014-09-16 A | 100% | 2013-09-12 | 2014-09-17 | 266d? | finish no earlier than 2014-09-17 | S4 | 2128h | 2128h | FS_HTML5 | 31 | 26.907 | Samsung | Imed Bouazizi (i.bouazizi@sta.samsung.com) | Rel-12 | 61 | Paolo | FS_HTML5 |  |  |  |  |
| 6085 | 2033 | Study on version handling | 716d? | 2010-03-25 A | 2012-12-12 A | 100% | 2010-03-25 | 2012-12-12 | 716d? | finish no earlier than 2012-12-12 | S5 | 5704h | 5704h | FS_OAM_VH | 24 | 32.830 | Ericsson | thomas.tovinger@ericsson.com | Rel-12 | 47 | Mirko | FS_OAM_VH |  |  |  |  |
| 6086 | 2034 | Study on management of Heterogeneous Networks | 852d? | 2011-03-23 A | 2014-06-18 A | 100% | 2011-03-23 | 2014-06-18 | 852d? | finish no earlier than 2014-06-18 | S5 | 6816h | 6816h | FS_OAM_HetNet | 26 | 32.835 | Ericsson | ulf.hubinette@ericsson.com | Rel-12 | 51 | Mirko | FS_OAM_HetNet |  |  |  |  |
| 6087 | 2035 | Study on OAM aspects of Network Sharing | 464d? | 2011-12-07 A | 2013-09-11 A | 100% | 2011-12-07 | 2013-09-11 | 464d? | finish no earlier than 2013-09-11 | S5 | 3696h | 3696h | FS_OAM_SHARE | 28 | 32.851 | Alcatel-Lucent, Huawei | Padma.Sudarsan@alcatel-lucent.com, zoulan@huawei.com | Rel-12 | 54 | Mirko | FS_OAM_SHARE |  |  |  |  |
| 6088 | 2036 | Study on Enhanced Network Management (NM) centralized Coverage and Capacity Optimization | 590d? | 2011-09-21 A | 2014-09-17 A | 100% | 2011-09-21 | 2014-09-17 | 590d? | finish no earlier than 2014-09-17 | S5 | 4712h | 4712h | FS_SON_NM_CCO | 29 | 32.836 | Ericsson | robert.petersen@ericsson.com | Rel-12 | 56 | Mirko | FS_SON_NM_CCO | SON |  |  |  |
| 6089 | 2037 | Study on WLAN management | 788d? | 2011-09-21 A | 2014-09-17 A | 100% | 2012-06-20 | 2014-09-17 | 590d? | finish no earlier than 2014-09-17 | S5 | 6304h | 6304h | FS_WLAN_OAM | 29 | 28.680; 28.681; 28.682; 28.683; 28.403 | Intel | joey.chou@intel.com | Rel-12 | 56 | Mirko | FS_WLAN_OAM | WLAN |  |  |  |
| 6090 | 2038 | Study on Alarm Management | 201d? | 2012-12-07 A | 2013-09-11 A | 100% | 2012-12-07 | 2013-09-11 | 201d? | finish no earlier than 2013-09-11 | S5 | 1592h | 1592h | FS_OAM_AM | 30 | 32.859 | TeliaSonera | tommy.berggren@teliasonera.com | Rel-12 | 58 | Mirko | FS_OAM_AM |  |  |  |  |
| 6091 | 2039 | Study on Indication of Network to Network Interface (NNI) Routeing scenarios in SIP requests | 400d? | 2012-12-10 A | 2014-06-13 A | 100% | 2012-12-10 | 2014-06-13 | 400d? | finish no earlier than 2014-03-06 | C3 | 3190.27h | 3190.27h | FS_NNI_RS | 30 | 24.802 | Ericsson | Jan.Holm@ericsson.com | Rel-12 | 58 | Adrian | FS_NNI_RS |  |  |  |  |
| 6092 | 2040 | Study on Diameter Overload Control Mechanisms | 464d? | 2012-01-05 A | 2014-09-11 A | 100% | 2012-01-05 | 2014-09-12 | 464d? | finish no earlier than 2014-09-12 | C4 | 3712h | 3712h | FS_DOCME | 30 | 29.809 | Orange | lionel.morand@orange.com | Rel-12 | 58 | Kimmo | FS_DOCME |  |  |  |  |
| 6093 | 2041 | Study on XML based access of AF to the PCRF | 288.5d? | 2013-03-01 A | 2013-12-04 A | 100% | 2013-03-01 | 2014-06-13 | 341d? | finish no earlier than 2014-06-13 | C3 | 1608h | 1608h | FS_XML_AF_PCRF | 30 | 29.817 | Alcatel-Lucent | horst.brinkman@alcatel-lucent.com | Rel-12 | 59 | Adrian | FS_XML_AF_PCRF |  |  |  |  |
| 6094 | 2042 | Study on Technical aspects on Roaming End-to-end scenarios with VoLTE IMS and other networks | 328d? | 2013-09-09 A | 2014-12-09 A | 100% | 2013-09-09 | 2014-09-12 | 266d? | finish no earlier than 2014-12-09 | C3 | 2624h | 2624h | FS_REVOLTE_IMS | 31 | 29.949 | Deutsche Telekom | Roland Jesske (r.jesske@telekom.de) | Rel-12 | 61 | Adrian | FS_REVOLTE_IMS |  |  |  |  |
| 6095 | 2043 | Study on Development of conformance requirements for the IP Multimedia Services Identity Module (ISIM) application support in ME | 263d? | 2013-12-09 A | 2014-12-09 A | 100% | 2013-12-09 | 2014-09-12 | 201d? | finish no earlier than 2014-12-09 | C6 | 2104h | 2104h | FS_ISIM_CR | 32 | 31.829 | Gemalto | ly-thanh.phan@gemalto.com | Rel-12 | 62 | Xavier | FS_ISIM_CR |  |  |  |  |
| 6096 | 2044 | Study on Shared Data Update for Multiple Subscribers | 263d? | 2013-12-06 A | 2014-12-09 A | 100% | 2013-12-06 | 2014-09-12 | 201d? | finish no earlier than 2014-12-09 | C4 | 2104h | 2104h | FS_SHARED_SubData_UPD | 32 | 29.854 | Huawei | Susan Shi (susan.shishufeng@huawei.com) | Rel-12 | 62 | Kimmo | FS_SHARED_SubData_UPD |  |  |  |  |
| 6097 | 2045 | Study on GERAN improvements for Machine-Type Communications | 661d? | 2010-05-24 A | 2012-11-23 A | 100% | 2010-05-24 | 2012-11-23 | 661d? | finish no earlier than 2012-11-23 | G1; G2 | 10576h | 10576h | FS_NIMTC_GERAN | 24 | 43.868 | Ericsson | paul.schliwa-bertling@ericsson.com | Rel-12 | 44 | Paolo | FS_NIMTC_GERAN | MTC, M2M |  |  |  |
| 6098 | 2046 | Study on Voice services over Adaptive Multi-user channels on One Slot (VAMOS) enhancements | 267.67d? | 2010-10-27 A | 2014-05-30 A | 100% | 2010-10-27 | 2014-05-30 | 267.67d? | finish no earlier than 2014-05-30 | GP; G2; G1 | 6424h | 6424h | FS_eVAMOS | 27 | 43.801 | China Mobile, Huawei | Chao Luo (chluo@huawei.com), dengjuan@chinamobile.com | Rel-12 | 50 | Paolo | FS_eVAMOS |  |  |  |  |
| 6099 | 2047 | Study on GERAN enhancements for Mobile Data Applications | 430d? | 2011-04-04 A | 2014-08-29 A | 100% | 2011-04-04 | 2014-08-29 | 430d? | finish no earlier than 2014-08-29 | G2; G1 | 6880h | 6880h | FS_GERAN_eMDA | 27 | 43.802 | Huawei | ming.fang@huawei.com | Rel-12 | 50 | Gert | FS_GERAN_eMDA |  |  |  |  |
| 6100 | 2048 | Study on Inclusion of RF Pattern Matching Technologies as a positioning method in the E-UTRAN | 722d? | 2010-12-10 A | 2013-09-06 A | 100% | 2010-12-10 | 2013-09-06 | 722d? | finish no earlier than 2013-09-06 | R4 | 5776h | 5776h | FS_LCS_LTE_RFPMT | 26 | LTE 36.809 | Polaris Wireless | Scot Gordon (sgordon@polariswireless.com) | Rel-12 | 50 | Issam | FS_LCS_LTE_RFPMT |  |  |  | RP-131082 |
| 6101 | 2049 | Study on Provision of low-cost MTC UEs based on LTE | 462d? | 2011-09-19 A | 2013-06-14 A | 100% | 2011-09-19 | 2013-06-14 | 462d? | finish no earlier than 2013-06-14 | R1; R2; R4 | 11088h | 11088h | FS_LC_MTC_LTE | 27 | LTE 36.888 | Vodafone | prakash.bhat@vodafone.com | Rel-12 | 53 | Patrick | FS_LC_MTC_LTE | MTC, M2M |  |  | RP-130583 |
| 6102 | 2050 | Deleted - Study on Mobile Relay for E-UTRA | 881.5d? | 2005-05-19 A | 2014-06-23 A | 100% | 2005-05-19 | 2014-06-23 | 881.5d? | finish no earlier than 2014-06-23 | R3; R1 | 14104h | 14104h | FS_LTE_mobRelay | 27 | LTE 36.836 | CATT | Haijing Hu (huhaijing@catt.cn) | Rel-12 | 53 | Juha | FS_LTE_mobRelay |  | PCG-33 | RP-64 | RP-140726 |
| 6103 | 2051 | Study on Scenarios and Requirements of LTE Small Cell Enhancements for E-UTRA and E-UTRAN | 66d? | 2012-09-11 A | 2012-12-07 A | 100% | 2012-09-11 | 2012-12-07 | 66d? | finish no earlier than 2012-12-07 | RP | 528h | 528h | FS_LTE_SC_enh_req | 29 | LTE 36.932 | China Mobile | Hai TANG (tanghai@chinamobile.com) | Rel-12 | 57 | Yong-Jun | FS_LTE_SC_enh_req | Small cell |  |  | RP-121651 |
| 6104 | 2052 | Study on Small Cell Enhancements for E-UTRA and E-UTRAN – Physical-layer aspects | 265d? | 2012-09-11 A | 2013-09-06 A | 100% | 2012-09-11 | 2013-09-06 | 265d? | finish no earlier than 2013-09-06 | R1; R2; R4 | 6360h | 6360h | FS_LTE_SC_enh_L1 | 30 | LTE 36.872 | Huawei | Elean Fan (fanxiaoan@huawei.com) | Rel-12 | 58 | Patrick | FS_LTE_SC_enh_L1 | Small cell |  |  | RP-131618 |
| 6105 | 2053 | Study on Small Cell Enhancements for E-UTRA and E-UTRAN – Higher-layer aspects | 265d? | 2012-12-10 A | 2013-12-06 A | 100% | 2012-12-10 | 2013-12-06 | 265d? | finish no earlier than 2013-12-06 | R2; R3 | 4240h | 4240h | FS_LTE_SC_enh_hilayer | 30 | LTE 36.842 | NTT DOCOMO | Hideaki Takahashi (h-takahashi@nttdocomo.co.jp) | Rel-12 | 58 | Yong-Jun | FS_LTE_SC_enh_hilayer | Small cell |  |  | RP-131619 |
| 6106 | 2054 | Study on LTE Device-to-Device Proximity Services - Radio Aspects | 325d? | 2012-12-17 A | 2014-03-06 A | 100% | 2012-12-17 | 2014-03-06 | 325d? | finish no earlier than 2014-03-06 | R1; R2; R3; R4 | 10400h | 10400h | FS_LTE_D2D_Prox | 30 | LTE 36.843 | Qualcomm | Shailesh Patil (patil@qti.qualcomm.com) | Rel-12 | 58 | Patrick | FS_LTE_D2D_Prox | Public Safety (A-A) |  |  | RP-140416 |
| 6107 | 2055 | Study on 3D-channel model for Elevation Beamforming and FD-MIMO studies for LTE | 463d? | 2012-12-10 A | 2014-09-12 A | 100% | 2012-12-10 | 2014-09-12 | 463d? | finish no earlier than 2014-09-12 | R1 | 3704h | 3704h | FS_LTE_3D_channel | 30 | LTE 36.873 | Nokia Networks | bishwarup.mondal@nsn.com | Rel-12 | 58 | Patrick | FS_LTE_3D_channel |  |  |  | RP-141206 |
| 6108 | 2056 | Study on Energy Saving Enhancement for E-UTRAN | 397d? | 2012-12-10 A | 2014-06-13 A | 100% | 2012-12-10 | 2014-06-13 | 397d? | finish no earlier than 2014-06-13 | R3 | 3176h | 3176h | FS_Netw_Energy_enh_LTE | 30 | LTE 36.887 | China Mobile | Kimba Dit Adamou, Boubacar (jinba@chinamobile.com) | Rel-12 | 58 | Juha | FS_Netw_Energy_enh_LTE |  |  |  | RP-140604 |
| 6109 | 2057 | Study on Expansion of LTE_FDD_1670_US to include 1670-1680MHz Band for LTE in the US | 469d? | 2013-03-01 A | 2014-12-15 A | 100% | 2013-03-01 | 2014-09-12 | 403d? | finish no earlier than 2014-12-15 | R4 | 3752h | 3752h | FS_LTE_FDD_1670_US | 30 | LTE 36.844 | LightSquared | masoud.olfat@lightsquared.com | Rel-13 | 59 | Issam | FS_LTE_FDD_1670_US |  |  |  | RP-141815 |
| 6110 | 2058 | Study on Cell-specific Reference Signals (CRS) Interference Mitigation for homogenous deployments for LTE | 201d? | 2013-03-04 A | 2013-12-06 A | 100% | 2013-03-04 | 2013-12-06 | 201d? | finish no earlier than 2013-12-06 | R4 | 1608h | 1608h | FS_LTE_CRSIC | 30 | LTE 36.863 | Ericsson | shaohua.li@ericsson.com | Rel-12 | 59 | Issam | FS_LTE_CRSIC |  |  |  | RP-131623 |
| 6111 | 2059 | Study on Network-Assisted Interference Cancellation and Suppression for LTE | 265d? | 2013-03-08 A | 2014-03-06 A | 100% | 2013-03-08 | 2014-03-06 | 265d? | finish no earlier than 2014-03-06 | R1; R4 | 4240h | 4240h | FS_LTE_NAICS | 30 | LTE 36.866 | MediaTek | jeff.zhuang@mediatek.com | Rel-12 | 59 | Patrick | FS_LTE_NAICS |  |  |  | RP-132108 |
| 6112 | 2060 | Study on Coordinated Multi-Point (CoMP) operation for LTE with Non-Ideal Backhaul | 126d? | 2013-06-18 A | 2013-12-06 A | 100% | 2013-06-18 | 2013-12-06 | 126d? | finish no earlier than 2013-12-06 | R1 | 1008h | 1008h | FS_COMP_LTE_nibackhaul | 31 | LTE 36.874 | Samsung | Hyojin Lee (hyojin257.lee@samsung.com) | Rel-12 | 60 | Patrick | FS_COMP_LTE_nibackhaul |  |  |  | RP-131626 |
| 6113 | 2061 | Study on Group Communication for LTE | 130d? | 2013-09-10 A | 2014-03-06 A | 100% | 2013-09-10 | 2014-03-06 | 130d? | finish no earlier than 2014-03-06 | R2; R3 | 2080h | 2080h | FS_LTE_GC | 31 | LTE 36.868 | Alcatel-Lucent | chandrika.worrall@alcatel-lucent.com | Rel-12 | 61 | Yong-Jun | FS_LTE_GC | Public Safety (A-A) |  |  | RP-140182 |
| 6114 | 2062 | Study on Smart Congestion Mitigation in E-UTRAN | 130d? | 2013-09-09 A | 2014-03-06 A | 100% | 2013-09-09 | 2014-03-06 | 130d? | finish no earlier than 2014-03-06 | R2 | 1040h | 1040h | FS_SCM_LTE | 31 | LTE 36.848 | LG Electronics | youngdae.lee@lge.com | Rel-12 | 61 | Yong-Jun | FS_SCM_LTE |  |  |  | RP-140102 |
| 6115 | 2063 | Study on RAN aspects of RAN Sharing Enhancements for LTE | 136d? | 2013-12-06 A | 2014-06-13 A | 100% | 2013-12-06 | 2014-06-13 | 136d? | finish no earlier than 2014-06-13 | R3 | 1088h | 1088h | FS_RSE-RAN_LTE | 32 | LTE 36.856 | NEC | Siva.Vakeesar@emea.nec.com | Rel-12 | 62 | Juha | FS_RSE-RAN_LTE |  |  |  | RP-140746 |
| 6116 | 2064 | Study on RF and EMC requirements for active Antenna Array System (AAS) Base Station | 386d? | 2011-09-19 A | 2013-03-01 A | 100% | 2011-09-19 | 2013-03-01 | 386d? | finish no earlier than 2013-03-01 | R4; R1 | 6176h | 6176h | FS_AAS_BS_LTE_UTRA | 27 | UTRA; LTE 37.840 | Huawei | Ronnie.zhang@huawei.com | Rel-12 | 53 | Issam | FS_AAS_BS_LTE_UTRA |  |  |  | RP-130124 |
| 6117 | 2065 | Study on LTE-HRPD (High Rate Packet Data in 3GPP2) inter-RAT SON | 340d? | 2012-03-02 A | 2013-06-14 A | 100% | 2012-03-02 | 2013-06-14 | 340d? | finish no earlier than 2013-06-14 | R3 | 2712h | 2712h | FS_LTE_HRPD_SON | 28 | UTRA; LTE 37.813 | China Telecom | Wu Jinlian (wujl@gsta.com) | Rel-12 | 55 | Juha | FS_LTE_HRPD_SON | SON |  |  | RP-130585 |
| 6118 | 2066 | Study on Passive InterModulation (PIM) handling for UTRA and LTE Base Stations | 403d? | 2012-03-05 A | 2013-09-06 A | 100% | 2012-03-05 | 2013-09-06 | 403d? | finish no earlier than 2013-09-06 | R4; G1 | 6448h | 6448h | FS_BS_PIM | 28 | UTRA; LTE 37.808 | Ericsson | johan.skold@ericsson.com | Rel-12 | 55 | Issam | FS_BS_PIM |  |  |  | RP-131076 |
| 6119 | 2067 | Study on WLAN/3GPP Radio Interworking | 264d? | 2012-12-10 A | 2013-12-06 A | 100% | 2012-12-10 | 2013-12-06 | 264d? | finish no earlier than 2013-12-06 | R2 | 2104h | 2104h | FS_UTRA_LTE_WLAN_interw | 30 | UTRA; LTE 37.834 | Intel | sasha.sirotkin@intel.com | Rel-12 | 58 | Yong-Jun | FS_UTRA_LTE_WLAN_interw | WLAN |  |  | RP-131611 |
| 6120 | 2068 | Study on RAN Enhancements for UMTS/HSPA and LTE Interworking | 261d? | 2012-12-10 A | 2013-12-06 A | 100% | 2012-12-10 | 2013-12-06 | 261d? | finish no earlier than 2013-12-06 | R3 | 2088h | 2088h | FS_HSPA_LTE_interworking | 30 | UTRA; LTE 37.852 | China Unicom | Meng Zhang (zhangmeng68@chinaunicom.cn) | Rel-12 | 58 | Juha | FS_HSPA_LTE_interworking |  |  |  | RP-131612 |
| 6121 | 2069 | Study on Next-Generation SON for UTRA and LTE | 397d? | 2012-12-10 A | 2014-06-13 A | 100% | 2012-12-10 | 2014-06-13 | 397d? | finish no earlier than 2014-06-13 | R3 | 3176h | 3176h | FS_UTRA_LTE_NG_SON | 30 | UTRA; LTE 37.822 | NSN | krzysztof.kordybach@nsn.com | Rel-12 | 58 | Juha | FS_UTRA_LTE_NG_SON | SON |  |  | RP-140747 |
| 6122 | 2070 | Study on 2GHz FDD for UTRA and LTE in Region 1 (1980-2010MHz and 2170-2200MHz Bands) | 462d? | 2012-12-11 A | 2014-09-12 A | 100% | 2012-12-11 | 2014-09-12 | 462d? | finish no earlier than 2014-09-12 | R4 | 3696h | 3696h | FS_UTRA_LTE_1980_2170_REG1 | 30 | UTRA; LTE 37.846 | DISH Network | johny.kim@dish.com, mariam.sorond@dish.com | Rel-12 | 58 | Issam | FS_UTRA_LTE_1980_2170_REG1 |  |  |  | RP-141099 |
| 6123 | 2071 | Study on Base Station specification structure | 136d? | 2012-12-10 A | 2013-06-14 A | 100% | 2012-12-10 | 2013-06-14 | 136d? | finish no earlier than 2013-06-14 | R4 | 1088h | 1088h | FS_BSspec_struc | 30 | UTRA; LTE; MSR 37.810 | Ericsson | johan.skold@ericsson.com | Rel-12 | 58 | Issam | FS_BSspec_struc |  |  |  | RP-130580 |
| 6124 | 2072 | Study on RAN aspects of Machine Type and other mobile data applications Communications enhancements | 137d? | 2013-03-01 A | 2013-09-06 A | 100% | 2013-03-01 | 2013-09-06 | 137d? | finish no earlier than 2013-09-06 | R2 | 1096h | 1096h | FS_MTCe_RAN | 30 | UTRA; LTE 37.869 | ZTE | sergio.parolari@zteitaly.com | Rel-12 | 59 | Yong-Jun | FS_MTCe_RAN | MTC, M2M |  |  | RP-131081 |
| 6125 | 2073 | Study on UMTS heterogeneous networks | 331d? | 2012-06-12 A | 2013-09-06 A | 100% | 2012-06-12 | 2013-09-06 | 331d? | finish no earlier than 2013-09-06 | R1; R2; R3 | 7944h | 7944h | FS_UTRA_HetNet | 29 | UTRA 25.800 | Huawei | carmela.cozzo@huawei.com | Rel-12 | 57 | Patrick | FS_UTRA_HetNet |  |  |  | RP-131606 |
| 6126 | 2074 | Study on Scalable UMTS FDD bandwidth | 265d? | 2012-12-10 A | 2013-12-06 A | 100% | 2012-12-10 | 2013-12-06 | 265d? | finish no earlier than 2013-12-06 | R1; R4 | 4240h | 4240h | FS_UTRA_SCAL | 30 | UTRA 25.701 | China Unicom | Han Xiao (hanxiao91@chinaunicom.cn) | Rel-12 | 58 | Patrick | FS_UTRA_SCAL |  |  |  | RP-132035 |
| 6127 | 2075 | Deleted - Study on Scalable UMTS FDD bandwidth by Filtering | 136d? | 2013-12-09 A | 2014-06-13 A | 100% | 2013-12-09 | 2014-06-13 | 136d? | finish no earlier than 2014-06-13 | R1 | 1088h | 1088h | FS_UTRA_SCAL_FILT | 32 | UTRA 25.701 | China Unicom | Han Xiao (hanxiao91@chinaunicom.cn) | Rel-12 | 62 | Patrick | FS_UTRA_SCAL_FILT |  | PCG-33 | RP-64 | RP-140988 |
| 6128 | 2076 | Study on Dedicated Channel (DCH) enhancements for UMTS | 197d? | 2012-12-10 A | 2013-09-06 A | 100% | 2012-12-10 | 2013-09-06 | 197d? | finish no earlier than 2013-09-06 | R1 | 1576h | 1576h | FS_UTRA_DCHenh | 30 | UTRA 25.702 | Qualcomm | Arjun Bharadwaj (arjunb@qti.qualcomm.com) | Rel-12 | 58 | Patrick | FS_UTRA_DCHenh |  |  |  | RP-131073 |
| 6129 | 2077 | Study on Further Enhanced Uplink (EUL) enhancements | 265d? | 2012-12-10 A | 2013-12-06 A | 100% | 2012-12-10 | 2013-12-06 | 265d? | finish no earlier than 2013-12-06 | R2; R1; R3 | 6360h | 6360h | FS_EDCH_enh | 30 | UTRA 25.700 | Ericsson | alessandro.caverni@ericsson.com | Rel-12 | 58 | Yong-Jun | FS_EDCH_enh |  |  |  | RP-131608 |
| 6130 | 2078 | Study on HNB Emergency Warning Area for UTRA | 191d? | 2013-06-18 A | 2014-03-06 A | 100% | 2013-06-18 | 2014-03-06 | 191d? | finish no earlier than 2014-03-06 | R3 | 1520h | 1520h | FS_HNB_warn_area | 31 | UTRA 25.703 | Alcatel-Lucent, Ip.access | Martin.Warner@alcatel-lucent.com, Kit.kilgour@ipaccess.com | Rel-12 | 60 | Juha | FS_HNB_warn_area | HNB |  |  | RP-140129 |
| 6131 | 2079 | Study on Enhanced Broadcast of System Information | 66d? | 2013-09-09 A | 2013-12-06 A | 100% | 2013-09-09 | 2013-12-06 | 66d? | finish no earlier than 2013-12-06 | R2; R1 | 1056h | 1056h | FS_UTRA_SIBenh | 31 | UTRA 25.704 | Ericsson | martin.van.der.zee@ericsson.com | Rel-12 | 61 | Yong-Jun | FS_UTRA_SIBenh |  |  |  | RP-131610 |
| 6132 | 2080 | --- RELEASE 11 --- | 342.75d? | 2013-06-02 A | 2014-09-16 A | 100% | 2013-06-02 | 2014-09-17 | 342.75d? | finish no earlier than 2014-09-17 | SP; CP; GP; RP | 10968h | 10968h |  |  |  |  |  | Rel-11 |  | All |  |  |  |  |  |

Notes:
- 6064: Triggered by TR 22.906 SA1 Study on IMS based Peer-to-Peer Content Distribution Services UID_450047
- 6065: SP#53 completed
- 6066: SP#56 completed. TR 23.844v100 for Information and Approval
- 6067: SP#58 completed. TR 33.844 v100 for Information and Approval
- 6068: SP#62 completed. Linked to CT4 TR 23.857 Study on EPC Nodes Restoration (UID_490014)
- 6069: Phase 1: complete study of overload control related to MAP /Diameter signalling, other 3GPP Core Network signalling optimization
- 6070: SP#62 completed
- 6071: SP#56 completed
- 6072: SP#61 completed. Covers generic non-3GPP access (e.g. WLAN, WIMAX, CDMA/HRPD). Spin-off Feature SaMOG_WLAN. Linked to Rel-8 Support for non-3GPP accesses, Rel-10 SMOG, Rel-11 BBAI
- 6073: SP#61 completed. Linked to UID_350027 SAE for support for non-3GPP accesses (SAES-SA-FP_n3GPP), UID_410043 MAPIM, UID_450041 IFOM, UID_530046 SaMOG
- 6074: SP#59 completed. Linked to Rel-11 Feature UID_500032 Service Awareness and Privacy Policies (SAPP)
- 6075: Spin-off Features MAPCON, IFOM. SP#58 completed FS_MAPIM part of 23.861 (continued under FS_NBIFOM)
- 6076: SP#53 completed
- 6077: SP#43 TR 23.861v100 for Information. SP#56 Rel-9 TR 23.861v130 renamed & progressed under new Study FS_NBIFOM. SP#58 completed the FS_MAPIM part of TR 23.861 (TR continued under FS_NBIFOM).
- 6078: SP#59 stopped (at 40% completion). SP#56 revives dormant Study FS_MAPIM. TR 23.861 title changed from (Multi Access PDN connectivity and IP flow mobility) to (Network based IP flow mobility)
- 6079: SP#59 completed. Continuation of Rel-9 Feature UID_430036 IMS Media Plane Security (MEDIASEC). Study solutions and extensions to features and functionality described in TR 33.828 and TS 33.328
- 6080: SP#65 stopped. Linked to Rel-12 Service and Media Reachability for Users over Restrictive Firewalls (SMURFs) UID_530043
- 6081: SP#65 completed. TR 33.831v100 for 1-step Approval. Linked to Rel-11 SPUCI TR 33.838
- 6082: SP#64 completed. Spin-off Rel-13 Feature SCAS. Study methodologies for specifying product security assurance and hardening requirements on 3GPP network elements (with associated test cases when feasible)
- 6083: SP#65 completed. TR 26.938v200 for Approval. SP#60 TR 26.938v100 for Information. Linked to Feature UID_470034 HTTP-based Streaming and Download Services
- 6084: SP#65 completed. TR 26.907v200 for Approval. SP#64 TR 26.907v100 for Information.
- 6085: SP#58 completed
- 6086: SP#64 completed
- 6087: SP#61 completed. Linked to Network Sharing UID_31018, SA1 22.951 (Service aspects and requirements for network sharing), SA2 23.251 (Network Sharing¦Architecture)
- 6088: SP#65 completed. TR 32.836v200 for Approval. SP#63 split of Rel-12 SP-130045 WID (Enhanced NM Centralized Coverage and Capacity Optimization) into a Rel-12 Study (SP-140028) and a Rel-13 Normative WID (SP-140060)
- 6089: SP#65 revised WID SP-130042=>SP-140536 (split into Rel-12 Study & Rel-13 normative WI). Changed Title from "TR on WLAN impacts to Type-2 management interface to the 3GPP Network Manager". TR 32.841v200 for Approval. Completed¦14/09/15: WID:SP-140536->
- 6090: SP#61 completed
- 6091: CP#64 completed
- 6092: CP#65 completed. TR 29.809 v200 for Approval. Triggered by SA2 Rel-12 TR 23.843 Study on Core Network Overload solutions (FS_CNO) UID_490036. Coordinate with CT3, SA5
- 6093: CP#64 completed. Investigate introducing an XML-based protocol (e.g. SOAP, Restful HTTP, etc.) between AF and PCRF for non-IMS applications
- 6094: CP#65 completion 09/14=>12/14. CP#64 TR 29.949v100 for Information.Dec.14:95->100
- 6095: CP#65 completion 09/14=>12/14. Gathering of all ISIM-related conformance requirements and the assessment of CT6 coverage¦June2015: Compl:30%->100
- 6096: CP#65 TR 29.854v200 for Approval. Completion 09/14=>12/14. Dec.14: 80->85%. Mar.15: 100%
- 6097: GP#56 completed. GP#44 approved WID
- 6098: GP#62 completed. TR 43.801v100 for 1-step Approval. GP#50 approved WID. Triggered by Rel-8 TR 45.914 Study Multi-User-Reusing One Timeslot (MUROS) UID_50590 and Rel-9 VAMOS UID_420002
- 6099: GP#63 completed. TR~43.802v200 for Approval. GP#50 approved WID (mobile coucou). Triggered by RAN#51 (Mar 2011) WID in RP-110454 (LTE RAN Enhancements for Diverse Data Applications) UID_510031
- 6100: RP#61 completed. Linked to Rel-10 WI on Inclusion of RF Pattern Matching Technologies as a positioning method in the UTRAN (LCS_UMTS_RFPMT) UID_460005
- 6101: RP#60 completed
- 6102: RP#64 stopped at 80% completion
- 6103: RP#58 completed. TR 36.932 v100 for Information and Approval
- 6104: RP#62 completed. RP#61 TR 36.872v100 for 1-step approval. Triggered by Rel-12 TR 36.932 Study on Scenarios and Requirements of LTE Small Cell Enhancements for E-UTRA and E-UTRAN UID_570023
- 6105: RP#62 completed. Triggered by Rel-12 TR 36.932 Study on Scenarios and Requirements of LTE Small Cell Enhancements for E-UTRA and E-UTRAN UID_570023
- 6106: RP#63 completed. TR 36.843 for 1-step approval (90% complete). Started normative work. Linked to Rel-12 TR 22.803 Study on Proximity-based Services (FS_ProSe) and Feature ProSe
- 6107: RP#65 completed. Updated WID RP-130811=>RP-141237. TR 36.873v210 for Approval. Enhance performance with 3D-beamforming or with FD-MIMO. Study new channel modelling in both vertical and horizontal dimensions awa user locations in the network
- 6108: RP#64 completed. Identify potential solutions for energy saving in E-UTRAN non-overlapping scenario. Evaluate possible enhancements in overlapping scenario, so that a subset can be used for further investigation/standardization
- 6109: CD:Thu 11/12/14->Mon 15/12/14¦Compl:80%->100%¦Stat Rep: RP-141453->RP-141815
- 6110: RP#62 completed. Updated WID RP-130393=>RP-131840
- 6111: RP#63 completed. TR 36.866 (90% complete) for Approval. Started normative work
- 6112: RP#62 completed. Extension of Rel-11 CoMP Operation for LTE Downlink UID_530332)
- 6113: RP#63 completed. Evaluate ability of LTE to meet public safety requirements agreed in SA for GC (GC is a key functionality of Land Mobile Radio/Private Mobile Radio and public safety systems)
- 6114: RP#63 completed
- 6115: RP#64 completed. TR 36.856v100 for 1-step approval. Triggered by SA1 Re-12 TR 22.852 Study on RAN Sharing Enhancements (FS_RSE) and Rel-13 Feature RSE (TS 22.101 Stage 1)
- 6116: RP#59 completed
- 6117: RP#60 completed
- 6118: RP#61 completed (Conclusion: no spin-off WI). Linked to Rel-10 WI on Multi-standard radio Base Station RF requirements for non-contiguous spectrum deployments (MSR_NC) UID_480025
- 6119: RP#62 completed. Evaluate LTE-WLAN/UTRA-WLAN i/w procedures while improving (non-)seamless mobility. Deployed WLAN often under-utilized¦User experience suboptimal when UE connects to overloaded WLAN.
- 6120: RP#62 completed. TR 37.852v100 for Information & Approval
- 6121: RP#64 completed. The study of SON features for small cell functionality covered by the Rel-12 small cell enhancement SIs (e.g. dual connectivity) is not in the scope of this study item
- 6122: RP#65 completed. Within EU these bands can be used for terrestrial mobile as a complement to mobile satellite services. Study adding an FDD band into UTRA/E-UTRA in applicable countries of Region 1
- 6123: RP#60 completed (1-step approval). Study new BS spec structure to avoid duplicate work for new RF features (in case of identical features among different RATs)¦avoid future discussions on how to implement new featurES in CP-150single-RAT/multi-RAT specs
- 6124: RP#61 completed
- 6125: RP#62 completed
- 6126: RP#62 completed. TR 25.701v200 for Approval
- 6127: RP#64 stopped at 85% completion. Follow-up of Rel-12 Study on scalable UMTS FDD bandwidth (FS_UTRA_SCAL). The result is captured in the same TR 25.701
- 6128: RP#61 completed
- 6129: RP#62 completed. TR 25.700v100 for Approval. Identify potential solutions to increase the uplink capacity, coverage and end-user performance (e.g. latency, achievable rates, etc.)
- 6130: RP#63 completed. TR 25.703 v100 for 1-step approval
- 6131: RP#62 completed. TR 25.704v100 for Information & Approval. Study need to add capacity to present SI Broadcast mechanism unchanged since R99
- 6132: -

| ID | WBS | Task | Duration | Start | Finish | Complete | Baseline start | Baseline finish | Baseline duration | Constraint | Resources | Work | Actual work | Acronym | PCG approved | WI rapporteur name | WI rapporteur e-mail | Release | TSG approved | MCC resp | Acronym_3GU_Export | Impacted TSs and TRs | Special Focus Doc | PCG stopped | TSG stopped |
| --- | --- | --- | --- | --- | --- | --- | --- | --- | --- | --- | --- | --- | --- | --- | --- | --- | --- | --- | --- | --- | --- | --- | --- | --- | --- |
| 6133 | 2081 | **Advanced IP Interconnection of Services** | 934.62d? | 2010-03-25 A | 2012-09-12 A | 100% | 2010-03-25 | 2012-09-12 | 650d? |  | S1; S2; C1; C3 | 34381.9h | 34381.9h | IPXS | 24 | Telefónica | chris.friel@O2.com | Rel-11 | 47 | Alain | IPXS |  |  |  |  |
| 6134 | 2081.1 | Stage 1 for Advanced IP Interconnection of Services | 392d | 2010-03-25 A | 2011-09-21 A | 100% | 2010-03-25 | 2011-09-21 | 392d | finish no earlier than 2011-09-21 | S1 | 3120h | 3120h | IPXS | 24 | Telefónica | chris.friel@O2.com | Rel-11 | 47 | Alain |  | 22.101; 22.228 |  |  |  |
| 6135 | 2081.2 | Stage 2 for Advanced IP Interconnection of Services | 263d? | 2010-12-16 A | 2011-12-14 A | 100% | 2010-12-16 | 2011-12-14 | 263d? | finish no earlier than 2012-03-21 | S2 | 2085.91h | 2085.91h | IPXS | 26 | Ericsson | fredrik.lindholm@ericsson.com | Rel-11 | 50 | Maurice |  | 23.228 |  |  |  |
| 6136 | 2081.3 | **Stage 3 for Advanced IP Interconnection of Services** | 378.62d? | 2011-09-13 A | 2012-09-12 A | 100% | 2011-09-13 | 2012-09-12 | 265d? |  | C1; C3 | 8376h | 8376h | IPXS | 27 | Ericsson | christer.holmberg@ericsson.com | Rel-11 | 53 | Frederic |  | Stage 3 |  |  |  |
| 6137 | 2081.3.1 | CT1 part of Stage 3 for Advanced IP Interconnection of Services | 375.62d? | 2011-09-16 A | 2012-09-12 A | 100% | 2011-09-16 | 2012-09-12 | 262d? | finish no earlier than 2012-12-07 | C1 | 2048h | 2048h | IPXS | 27 | Ericsson | christer.holmberg@ericsson.com | Rel-11 | 53 | Frederic |  | 24.229 |  |  |  |
| 6138 | 2081.3.2 | CT3 part of Stage 3 for Advanced IP Interconnection of Services | 373.38d? | 2011-09-13 A | 2012-09-07 A | 100% | 2011-09-13 | 2012-09-07 | 262d? | finish no earlier than 2012-09-07 | C3 | 2088h | 2088h | IPXS | 27 | Ericsson | christer.holmberg@ericsson.com | Rel-11 | 53 | Adrian |  | 29.165 |  |  |  |
| 6139 | 2082 | **System Improvements to Machine-Type Communications** | 1601.62d? | 2009-12-10 A | 2014-03-06 A | 100% | 2009-12-10 | 2014-03-06 | 1119d? |  | S1; S2; S5; C1; C3; C4; C6; R2; R3; R5 | 198763h | 198763h | SIMTC | 25 | KPN | toon.norp@tno.nl | Rel-11 | 48 | Alain | SIMTC |  | MTC, M2M |  |  |
| 6140 | 2082.1 | Stage 1 for SIMTC | 337d? | 2010-06-10 A | 2011-09-21 A | 100% | 2010-06-10 | 2011-09-21 | 337d? |  | S1 | 2683.46h | 2683.46h | SIMTC | 25 | KPN | toon.norp@tno.nl | Rel-11 | 48 | Alain |  | 22.368; 21.905 (MTC definitions) | MTC, M2M |  |  |
| 6141 | 2082.2 | TR on Stage 2 for SIMTC | 593d? | 2010-06-10 A | 2012-09-12 A | 100% | 2010-06-10 | 2012-09-12 | 593d? | finish no earlier than 2012-09-12 | S2 | 4736h | 4736h | SIMTC | 25 | Intel | puneet.jain@intel.com | Rel-11 | 48 | Maurice |  | New 23.888 | MTC, M2M |  |  |
| 6142 | 2082.3 | **BB1: Stage 2 Reachability Aspects of SIMTC** | 391d? | 2011-06-09 A | 2012-06-20 A | 100% | 2011-06-09 | 2012-06-20 | 274d? |  | S2 | 10773.1h | 10773.1h | SIMTC-Reach | 27 | Intel | puneet.jain@intel.com | Rel-11 | 52 | Maurice | SIMTC-Reach | 23.221; New 23.368 | MTC, M2M |  |  |
| 6143 | 2082.3.1 | Deleted - MTC Feature Control (described in TS 22.368, clause 7.1.1 and 23.888, clause 5.7) | 137d? | 2011-06-10 A | 2011-12-14 A | 100% | 2011-06-10 | 2011-12-14 | 137d? | finish no earlier than 2011-11-09 | S2 | 1088h | 1088h | SIMTC-Reach | 27 | Intel | puneet.jain@intel.com | Rel-11 | 52 | Maurice |  |  | MTC, M2M | PCG-28 | SP-54 |
| 6144 | 2082.3.2 | On-line device trigger | 273d? | 2011-06-09 A | 2012-06-20 A | 100% | 2011-06-09 | 2012-06-20 | 273d? | finish no earlier than 2012-06-20 | S2 | 2170.29h | 2170.29h | SIMTC-Reach | 27 | Intel | puneet.jain@intel.com | Rel-11 | 52 | Maurice |  | New 23.682 | MTC, M2M |  |  |
| 6145 | 2082.3.3 | MTC Addressing | 138d? | 2011-06-09 A | 2011-12-14 A | 100% | 2011-06-09 | 2011-12-14 | 138d? | finish no earlier than 2012-03-21 | S2 | 1097.24h | 1097.24h | SIMTC-Reach | 27 | Intel | puneet.jain@intel.com | Rel-11 | 52 | Maurice |  | 23.221; New 23.682 | MTC, M2M |  |  |
| 6146 | 2082.3.4 | Identifiers – especially removal of MSISDN dependencies in the architecture | 273d? | 2011-06-09 A | 2012-06-20 A | 100% | 2011-06-09 | 2012-06-20 | 273d? | finish no earlier than 2012-06-20 | S2 | 2169.53h | 2169.53h | SIMTC-Reach | 27 | Intel | puneet.jain@intel.com | Rel-11 | 52 | Maurice |  | New 23.682 | MTC, M2M |  |  |
| 6147 | 2082.3.5 | MSISDN-less / PS-Only | 196d? | 2011-06-13 A | 2012-03-07 A | 100% | 2011-06-13 | 2012-03-07 | 196d? | finish no earlier than 2012-03-07 | S2 | 1568h | 1568h | SIMTC-Reach | 27 | Intel | puneet.jain@intel.com | Rel-11 | 52 | Maurice |  | 23.060; 23.272; New 23.682 | MTC, M2M |  |  |
| 6148 | 2082.3.6 | MTC related interfaces and functional entities to support above features (MTCsp, etc.) | 61d? | 2011-12-14 A | 2012-03-07 A | 100% | 2011-12-14 | 2012-03-07 | 61d? | finish no earlier than 2012-03-07 | S2 | 488h | 488h | SIMTC-Reach | 28 | Intel | puneet.jain@intel.com | Rel-11 | 54 | Maurice |  | New 23.682 | MTC, M2M |  |  |
| 6149 | 2082.4 | **BB1: Stage 3 (CS+PS) Reachability Aspects of SIMTC** | 461.12d? | 2011-09-19 A | 2012-12-07 A | 100% | 2011-09-19 | 2012-12-07 | 325d? |  | C1; C3; C4; C6 | 19112h | 19112h | SIMTC-ReachCSPS | 27 | Ericsson | mikael.wass@ericsson.com | Rel-11 | 53 | Frederic |  | Stage 3 | MTC, M2M |  |  |
| 6150 | 2082.4.1 | CT1 part of Stage 3 BB1: Reachability Aspects of SIMTC | 257d? | 2011-09-19 A | 2012-09-07 A | 100% | 2011-09-19 | 2012-09-07 | 257d? | finish no earlier than 2012-09-07 | C1 | 2048h | 2048h | SIMTC-ReachCSPS | 27 | Ericsson | mikael.wass@ericsson.com | Rel-11 | 53 | Frederic |  | 23.040; 24.008; 24.301; 24.341; 24.368 | MTC, M2M |  |  |
| 6151 | 2082.4.2 | CT3 part of Stage 3 BB1: Reachability Aspects of SIMTC | 257d? | 2011-09-19 A | 2012-09-07 A | 100% | 2011-09-19 | 2012-09-07 | 257d? | finish no earlier than 2012-09-07 | C3 | 2048h | 2048h | SIMTC-ReachCSPS | 27 | Ericsson | mikael.wass@ericsson.com | Rel-11 | 53 | Adrian |  | 29.061; New 29.368 | MTC, M2M |  |  |
| 6152 | 2082.4.3 | CT4 part of Stage 3 BB1: Reachability Aspects of SIMTC | 324d? | 2011-09-19 A | 2012-12-07 A | 100% | 2011-09-19 | 2012-12-07 | 324d? | finish no earlier than 2012-12-07 | C4 | 2568h | 2568h | SIMTC-ReachCSPS | 27 | Ericsson | mikael.wass@ericsson.com | Rel-11 | 53 | Kimmo |  | 23.003; 23.008; 29.002; 29.060; 29.230; New (29.336; 29.337) | MTC, M2M |  |  |
| 6153 | 2082.4.4 | CT6 part of Stage 3 BB1: Reachability Aspects of SIMTC | 257d? | 2011-09-19 A | 2012-09-07 A | 100% | 2011-09-19 | 2012-09-07 | 257d? | finish no earlier than 2012-09-07 | C6 | 2048h | 2048h | SIMTC-ReachCSPS | 27 | ST Ericsson | Andrzej Winiarski | Rel-11 | 53 | Xavier |  | 31.102 | MTC, M2M |  |  |
| 6154 | 2082.5 | **Stage 2/3 for CS aspects for SIMTC** | 370.38d? | 2011-09-16 A | 2012-09-07 A | 100% | 2011-09-16 | 2012-09-07 | 259d? |  | C4; C1; C6 | 16544h | 16544h | SIMTC-CS | 27 | Ericsson | mikael.wass@ericsson.com | Rel-11 | 53 | Kimmo | SIMTC-CS | Stage 2/3 | MTC, M2M |  |  |
| 6155 | 2082.5.1 | Deleted - Stage 2 CS aspects for SIMTC | 369.38d? | 2011-09-16 A | 2012-09-06 A | 100% | 2011-09-16 | 2012-09-06 | 258d? | finish no earlier than 2012-09-07 | C4 | 2056h | 2056h | SIMTC-CS | 27 | Ericsson | mikael.wass@ericsson.com | Rel-11 | 53 | Kimmo |  | 23.012 | MTC, M2M | PCG-29 | CP-57 |
| 6156 | 2082.5.2 | **Stage 3 CS aspects for SIMTC** | 370.38d? | 2011-09-16 A | 2012-09-07 A | 100% | 2011-09-16 | 2012-09-07 | 259d? |  | C1; C6 | 8272h | 8272h | SIMTC-CS | 27 | Ericsson | mikael.wass@ericsson.com | Rel-11 | 53 | Frederic |  | Stage 3 | MTC, M2M |  |  |
| 6157 | 2082.5.2.1 | CT1 part of Stage 3 CS aspects for SIMTC | 259d? | 2011-09-16 A | 2012-09-07 A | 100% | 2011-09-16 | 2012-09-07 | 259d? | start no earlier than 2011-09-16 | C1 | 2064h | 2064h | SIMTC-CS | 27 | Ericsson | mikael.wass@ericsson.com | Rel-11 | 53 | Frederic |  | 24.008; 24.301 | MTC, M2M |  |  |
| 6158 | 2082.5.2.2 | Deleted - CT6 part of Stage 3 CS aspects for SIMTC | 259d? | 2011-09-16 A | 2012-09-07 A | 100% | 2011-09-16 | 2012-09-07 | 259d? | start no earlier than 2011-09-16 | C6 | 2064h | 2064h | SIMTC-CS | 27 | Ericsson | mikael.wass@ericsson.com | Rel-11 | 53 | Xavier |  | 31.102 | MTC, M2M | PCG-29 | CP-57 |

Notes:
- 6133: CP#58 completed. Triggered by Rel-10 TR 22.893 UID_380083 Study on advanced requirements for IP interconnect (FS_IPXS)
- 6134: SP#53 completed
- 6135: SP#54 completed
- 6136: CP#58 completed
- 6137: CP#58 completed
- 6138: CP#57 completed
- 6139: SP#58 completed. Updated WID SP-110877=>SP-120848. Enhancements to Rel-10 Feature UID_410031 (NIMTC) based on Rel-11 Study on enhancements to MTC
- 6140: SP#53 completed. SP#57 added MTC definitions in 21.905
- 6141: SP#57 completed. TR 23.888v200 for Approval. Was Rel-10 UID_450028 (TR on Stage 2 for NIMTC)
- 6142: SP#56 completed. SP#58 updated WID SP-110877=>S3-121111 (SA3 normative work on Security aspects of SIMTC incorporated in SA2 TS 23.682)
- 6143: SP#54 work stopped
- 6144: SP#56 completed
- 6145: SP#54 completed
- 6146: SP#56 completed
- 6147: SP#55 completed
- 6148: SP#55 completed
- 6149: 22/01: acronym modified
- 6150: 22/01: acronym modified
- 6151: 22/01: acronym modified
- 6152: 22/01: acronym modified
- 6153: 22/01: acronym modified
- 6154: CP#57 completed. Updated WID CP-120418=>CP-120617
- 6155: CP#57 stopped
- 6156: CP#57 completed
- 6157: CP#57 completed
- 6158: CP#57 stopped

| ID | WBS | Task | Duration | Start | Finish | Complete | Baseline start | Baseline finish | Baseline duration | Constraint | Resources | Work | Actual work | Acronym | PCG approved | WI rapporteur name | WI rapporteur e-mail | Release | TSG approved | MCC resp | Special Focus Doc | Acronym_3GU_Export | Status Report | PCG stopped | TSG stopped |
| --- | --- | --- | --- | --- | --- | --- | --- | --- | --- | --- | --- | --- | --- | --- | --- | --- | --- | --- | --- | --- | --- | --- | --- | --- | --- |
| 6159 | 2082.6 | **Stage 2/3 for SMS in MME architecture option and related PS-only service subscription** | 181.88d? | 2012-06-15 A | 2012-12-07 A | 100% | 2012-06-15 | 2012-12-07 | 129d? |  | C1; C4 | 3560h | 3560h | SIMTC-PS_Only | 29 | Ericsson | mikael.wass@ericsson.com | Rel-11 | 56 | Frederic | MTC, M2M | SIMTC-PS_Only |  |  |  |
| 6160 | 2082.6.1 | CT1 part of Stage 2/3 for SMS in MME architecture option and related PS-only service subscription | 62d? | 2012-06-15 A | 2012-09-07 A | 100% | 2012-06-15 | 2012-09-07 | 62d? | finish no earlier than 2012-09-07 | C1 | 488h | 488h | SIMTC-PS_Only | 29 | Ericsson | mikael.wass@ericsson.com | Rel-11 | 56 | Frederic | MTC, M2M |  |  |  |  |
| 6161 | 2082.6.2 | CT4 part of Stage 2/3 for SMS in MME architecture option and related PS-only service subscription | 129d? | 2012-06-15 A | 2012-12-07 A | 100% | 2012-06-15 | 2012-12-07 | 129d? | finish no earlier than 2012-12-07 | C4 | 1008h | 1008h | SIMTC-PS_Only | 29 | Ericsson | mikael.wass@ericsson.com | Rel-11 | 56 | Kimmo | MTC, M2M |  |  |  |  |
| 6162 | 2082.7 | **RAN overload control for Machine-Type Communications** | 370.38d? | 2011-09-16 A | 2012-09-07 A | 100% | 2011-09-16 | 2012-09-07 | 259d? |  | R2; R3; C1; C6 | 20178.3h | 20178.3h | SIMTC-RAN_OC | 27 | Huawei | Jeff Gao (gaoyongqiang@huawei.com) | Rel-11 | 53 | Yong-Jun | MTC, M2M | SIMTC-RAN_OC |  |  |  |
| 6163 | 2082.7.1 | Core part: RAN overload control for Machine-Type Communications | 258d? | 2011-09-19 A | 2012-09-07 A | 100% | 2011-09-19 | 2012-09-07 | 258d? | finish no earlier than 2012-09-07 | R2; R3 | 4128h | 4128h | SIMTC-RAN_OC-Core | 27 | Huawei | Jeff Gao (gaoyongqiang@huawei.com) | Rel-11 | 53 | Yong-Jun | MTC, M2M | SIMTC-RAN_OC-Core |  |  |  |
| 6164 | 2082.7.2 | **Stage 3 (CS+PS) Extended Access Barring for UTRAN and E-UTRAN** | 370.38d? | 2011-09-16 A | 2012-09-07 A | 100% | 2011-09-16 | 2012-09-07 | 259d? |  | C1; C6 | 7762.29h | 7762.29h | SIMTC-RAN_OC | 27 | Ericsson | mikael.wass@ericsson.com | Rel-11 | 53 | Frederic | MTC, M2M |  |  |  |  |
| 6165 | 2082.7.2.1 | CT1 part of Stage 3 Extended Access Barring for UTRAN and E-UTRAN | 198d? | 2011-09-16 A | 2012-06-15 A | 100% | 2011-09-16 | 2012-06-15 | 198d? | finish no earlier than 2012-09-14 | C1 | 1570.29h | 1570.29h | SIMTC-RAN_OC | 27 | Ericsson | mikael.wass@ericsson.com | Rel-11 | 53 | Frederic | MTC, M2M |  |  |  |  |
| 6166 | 2082.7.2.2 | CT6 part of Stage 3 Extended Access Barring for UTRAN and E-UTRAN | 257d? | 2011-09-20 A | 2012-09-07 A | 100% | 2011-09-20 | 2012-09-07 | 257d? | finish no earlier than 2012-09-07 | C6 | 2048h | 2048h | SIMTC-RAN_OC | 27 | ST Ericsson | Andrzej Winiarski | Rel-11 | 53 | Xavier | MTC, M2M |  |  |  |  |
| 6167 | 2082.8 | Test part: System Improvements for Machine-Type Communications | 130d? | 2013-09-09 A | 2014-03-06 A | 100% | 2013-09-09 | 2014-03-06 | 130d? | finish no earlier than 2014-03-06 | R5 | 1040h | 1040h | SIMTC-UEConTest | 31 | Ericsson | calle.hagenfeldt@ericsson.com | Rel-11 | 61 | Ingbert | MTC, M2M | SIMTC-UEConTest | RP-140075 |  |  |
| 6168 | 2082.9 | BB5: Charging of SIMTC (Stage 2/3) | 269d? | 2011-12-07 A | 2012-12-12 A | 100% | 2011-12-07 | 2012-12-12 | 269d? | finish no earlier than 2012-12-12 | S5 | 2144h | 2144h | SIMTC-CH | 28 | Ericsson | patrik.teppo@ericsson.com | Rel-11 | 54 | Mirko | MTC, M2M | SIMTC-CH |  |  |  |
| 6169 | 2082.10 | **Deleted - BB2: Stage 2 Signalling Optimizations of SIMTC** | 194.38d? | 2011-06-10 A | 2011-12-14 A | 100% | 2011-06-10 | 2011-12-14 | 137d? |  | S2 | 5240h | 5240h | SIMTC-Sig | 27 | Intel | puneet.jain@intel.com | Rel-11 | 52 | Maurice | MTC, M2M | SIMTC-Sig |  | PCG-28 | SP-55 |
| 6170 | 2082.10.1 | Deleted - Effectively maintain connectivity for a large number of MTC Devices (TS 22.368, 7.1.1) | 137d? | 2011-06-10 A | 2011-12-14 A | 100% | 2011-06-10 | 2011-12-14 | 137d? | finish no earlier than 2011-12-07 | S2 | 1088h | 1088h | SIMTC-Sig | 27 | Intel | puneet.jain@intel.com | Rel-11 | 52 | Maurice | MTC, M2M |  |  | PCG-28 | SP-55 |
| 6171 | 2082.10.2 | Deleted - Small Data Transmissions (TS 22.368, 7.2.5) | 137d? | 2011-06-10 A | 2011-12-14 A | 100% | 2011-06-10 | 2011-12-14 | 137d? | finish no earlier than 2011-12-07 | S2 | 1088h | 1088h | SIMTC-Sig | 27 | Intel | puneet.jain@intel.com | Rel-11 | 52 | Maurice | MTC, M2M |  |  | PCG-28 | SP-55 |
| 6172 | 2082.10.3 | **Deleted - Stage 3 (CS+PS) Signalling Optimizations of SIMTC** | 87.88d? | 2011-09-16 A | 2011-12-09 A | 100% | 2011-09-16 | 2011-12-09 | 62d? |  | C1; C6 | 1968h | 1968h | SIMTC-Sig | 27 | Ericsson | mikael.wass@ericsson.com | Rel-11 | 53 | Frederic | MTC, M2M |  |  | PCG-28 | CP-55 |
| 6173 | 2082.10.3.1 | Deleted - CT1 part of Stage 3 Signalling Optimizations of SIMTC | 62d? | 2011-09-16 A | 2011-12-09 A | 100% | 2011-09-16 | 2011-12-09 | 62d? | finish no earlier than 2011-12-02 | C1 | 488h | 488h | SIMTC-Sig | 27 | Ericsson | mikael.wass@ericsson.com | Rel-11 | 53 | Frederic | MTC, M2M |  |  | PCG-28 | CP-55 |
| 6174 | 2082.10.3.2 | Deleted - CT6 part of Stage 3 Signalling Optimizations of SIMTC | 62d? | 2011-09-16 A | 2011-12-09 A | 100% | 2011-09-16 | 2011-12-09 | 62d? | finish no earlier than 2011-12-02 | C6 | 488h | 488h | SIMTC-Sig | 27 | ST Ericsson | Andrzej Winiarski | Rel-11 | 53 | Xavier | MTC, M2M |  |  | PCG-28 | CP-55 |
| 6175 | 2082.11 | **Deleted - BB3: Stage 2 CN-based requirements and Power Considerations of SIMTC** | 196.38d? | 2011-06-08 A | 2011-12-14 A | 100% | 2011-06-08 | 2011-12-14 | 139d? |  | S2 | 6360h | 6360h | SIMTC-CN_Pow | 27 | Intel | puneet.jain@intel.com | Rel-11 | 52 | Maurice | MTC, M2M | SIMTC-CN_Pow |  | PCG-28 | SP-55 |
| 6176 | 2082.11.1 | Deleted - Charging Requirements (TS 22.368, 7.1.5) | 137d? | 2011-06-10 A | 2011-12-14 A | 100% | 2011-06-10 | 2011-12-14 | 137d? | finish no earlier than 2012-03-21 | S2 | 1088h | 1088h | SIMTC-CN_Pow | 27 | Intel | puneet.jain@intel.com | Rel-11 | 52 | Maurice | MTC, M2M |  |  | PCG-28 | SP-55 |
| 6177 | 2082.11.2 | Deleted - Lower Power Consumption (TS 22.368, 7.1.1) | 137d? | 2011-06-10 A | 2011-12-14 A | 100% | 2011-06-10 | 2011-12-14 | 137d? | finish no earlier than 2011-12-07 | S2 | 1088h | 1088h | SIMTC-CN_Pow | 27 | Intel | puneet.jain@intel.com | Rel-11 | 52 | Maurice | MTC, M2M |  |  | PCG-28 | SP-55 |
| 6178 | 2082.11.3 | Deleted - MTC Monitoring (TS 22.368, 7.2.8) | 139d? | 2011-06-08 A | 2011-12-14 A | 100% | 2011-06-08 | 2011-12-14 | 139d? | finish no earlier than 2011-12-07 | S2 | 1104h | 1104h | SIMTC-CN_Pow | 27 | Intel | puneet.jain@intel.com | Rel-11 | 52 | Maurice | MTC, M2M |  |  | PCG-28 | SP-55 |
| 6179 | 2082.11.4 | **Deleted - Stage 3 (CS+PS) CN-based requirements and Power Considerations of SIMTC** | 87.88d? | 2011-09-16 A | 2011-12-09 A | 100% | 2011-09-16 | 2011-12-09 | 62d? |  | C1; C6 | 1968h | 1968h | SIMTC-CN_Pow | 27 | Ericsson | mikael.wass@ericsson.com | Rel-11 | 53 | Frederic | MTC, M2M |  |  | PCG-28 | CP-55 |
| 6180 | 2082.11.4.1 | Deleted - CT1 part of Stage 3 CN-based requirements and Power Considerations of SIMTC | 62d? | 2011-09-16 A | 2011-12-09 A | 100% | 2011-09-16 | 2011-12-09 | 62d? | finish no earlier than 2011-12-02 | C1 | 488h | 488h | SIMTC-CN_Pow | 27 | Ericsson | mikael.wass@ericsson.com | Rel-11 | 53 | Frederic | MTC, M2M |  |  | PCG-28 | CP-55 |
| 6181 | 2082.11.4.2 | Deleted - CT6 part of Stage 3 CN-based requirements and Power Considerations of SIMTC | 62d? | 2011-09-16 A | 2011-12-09 A | 100% | 2011-09-16 | 2011-12-09 | 62d? | finish no earlier than 2011-12-02 | C6 | 488h | 488h | SIMTC-CN_Pow | 27 | ST Ericsson | Andrzej Winiarski | Rel-11 | 53 | Xavier | MTC, M2M |  |  | PCG-28 | CP-55 |
| 6182 | 2082.12 | Deleted - TR on Security aspects of Machine-Type Communications | 662d? | 2009-12-10 A | 2012-06-20 A | 100% | 2009-12-10 | 2012-06-20 | 662d? | finish no earlier than 2012-06-20 | S3 | 5288h | 5288h |  | 25 | Samsung | Rajavelsamy R (rajvel@samsung.com) | Rel-11 | 49 | Mirko | MTC, M2M |  |  | PCG-29 | SP-56 |

Notes:
- 6159: CP#58 completed / Impacted TSs and TRs: Stage 2/3
- 6160: CP#57 completed / Impacted TSs and TRs: 23.040; 24.008; 24.011; 24.301; 29.018; 29.118
- 6161: CP#58 completed. TS 29.338 v200 for Approval / Impacted TSs and TRs: 23.003; 23.008; 23.012; 29.002; 29.272; 29.305; New 29.338
- 6162: Stage 2,3. TSG#57 completed / Impacted TSs and TRs: UTRA; LTE
- 6163: RP#57 completed / Impacted TSs and TRs: 25.304; 25.331; 25.413; 36.304; 36.331; 36.413
- 6164: CP#57 completed. Updated WID CP-120418=>CP-120617 / Impacted TSs and TRs: Stage 3
- 6165: CP#56 completed / Impacted TSs and TRs: 23.122; 24.008; 24.301
- 6166: CP#57 completed / Impacted TSs and TRs: 31.102
- 6167: RP#63 completed. Updated WID RP-131341=>RP-140077 (added affected TS 36.508). Testing for core part: SIMTC-Reach, SIMTC-CS, SIMTC-PS_Only, SIMTC-RAN_OC / Impacted TSs and TRs: 34.123-1; 34.123-2; 34.123-3; 36.508; 36.523-1; 36.523-2; 36.523-3
- 6168: SP#58 completed / Impacted TSs and TRs: 32.240; 32.251; 32.298; 32.299
- 6169: SP#54 work stopped. SP#58 updated WID SP-110877=>SP-120848 / Impacted TSs and TRs: TBD
- 6170: SP#54 work stopped / Impacted TSs and TRs: TBD
- 6171: SP#54 work stopped / Impacted TSs and TRs: TBD
- 6172: CP#54 work stopped / Impacted TSs and TRs: Stage 3
- 6173: - / Impacted TSs and TRs: 23.122; 24.008; 24.301; 24.368
- 6174: - / Impacted TSs and TRs: 31.102
- 6175: SP#54 work stopped / Impacted TSs and TRs: TBD
- 6176: SP#54 work stopped / Impacted TSs and TRs: TBD
- 6177: SP#54 work stopped / Impacted TSs and TRs: TBD
- 6178: SP#54 work stopped / Impacted TSs and TRs: TBD
- 6179: CP#54 work stopped / Impacted TSs and TRs: Stage 3
- 6180: - / Impacted TSs and TRs: 23.122; 24.008; 24.301; 24.368
- 6181: - / Impacted TSs and TRs: 31.101; 31.102
- 6182: Was Rel-10 UID_460023 (Security for NIMTC). SP#56 stopped (activity transferred to Rel-12 Feature MTCe under UID_560722). / Impacted TSs and TRs: New 33.868

| ID | WBS | Task | Type | Duration | Start | Finish | Complete | Baseline start | Baseline finish | Baseline duration | Constraint | Resources | Work | Actual work | Acronym | PCG approved | Impacted TSs and TRs | WI rapporteur name | Release | TSG approved | MCC resp | PCG stopped | TSG stopped | Special Focus Doc | Acronym_3GU_Export |
| --- | --- | --- | --- | --- | --- | --- | --- | --- | --- | --- | --- | --- | --- | --- | --- | --- | --- | --- | --- | --- | --- | --- | --- | --- | --- |
| 6183 | 2082.13 | **Deleted - BB4: Secure Connection and Privacy of SIMTC** |  | 478.88d? | 2011-06-08 A | 2012-09-12 A | 100% | 2011-06-08 | 2012-09-12 | 336d? |  | S3 | 7424h | 7424h | SIMTC-Sec | 27 | TBD | Samsung | Rel-11 | 52 | Mirko | PCG-29 | CP-57 | MTC, M2M | SIMTC-Sec |
| 6184 | 2082.13.1 | Deleted - Secure Connection MTC Feature (TS 22.368, 7.2.10) |  | 333d? | 2011-06-08 A | 2012-09-12 A | 100% | 2011-06-08 | 2012-09-12 | 333d? | finish no earlier than 2012-09-12 | S3 | 2656h | 2656h | SIMTC-Sec | 27 | TBD | Samsung | Rel-11 | 52 | Mirko | PCG-29 | CP-57 | MTC, M2M |  |
| 6185 | 2082.13.2 | Deleted - MTC Location Privacy |  | 261d? | 2011-09-19 A | 2012-09-12 A | 100% | 2011-09-19 | 2012-09-12 | 261d? | finish no earlier than 2012-09-12 | S3 | 2080h | 2080h | SIMTC-Priv | 27 | TBD | Samsung | Rel-11 | 53 | Mirko | PCG-29 | CP-57 | MTC, M2M | SIMTC-Priv |
| 6186 | 2082.14 | Deleted - Stage 2 on SA2 part for System Improvements to Machine-Type Communications |  | 260d? | 2010-06-10 A | 2011-06-08 A | 100% | 2010-06-10 | 2011-06-08 | 260d? | finish no earlier than 2011-06-08 | S2 | 2080h | 2080h | SIMTC | 25 | TBD | Intel | Rel-11 | 48 | Maurice | PCG-27 | SP-52 | MTC, M2M |  |
| 6187 | 2082.15 | Deleted - Stage 2 on Security part for System Improvements to Machine-Type Communications |  | 260d? | 2010-06-10 A | 2011-06-08 A | 100% | 2010-06-10 | 2011-06-08 | 260d? | finish no earlier than 2011-06-08 | S3 | 2080h | 2080h | SIMTC | 25 | TBD | Samsung | Rel-11 | 48 | Mirko | PCG-27 | SP-52 | MTC, M2M |  |
| 6188 | 2083 | **Unstructured Supplementary Service Data (USSD) simulation service in IMS** |  | 943.62d? | 2010-06-10 A | 2012-12-07 A | 100% | 2010-06-10 | 2012-12-07 | 659d? |  | S1; C1; C3 | 28112.1h | 28112.1h | USSI | 25 |  | Deutsche Telekom | Rel-11 | 48 | Alain |  |  |  | USSI |
| 6189 | 2083.1 | Stage 1 for USSD simulation service in IMS | milestone | 0d? | 2010-06-10 A | 2010-06-10 A | 100% | 2010-06-10 | 2010-06-10 | 0d? | finish no earlier than 2010-06-10 | S1 |  |  | USSI | 25 | 22.173 | Deutsche Telekom | Rel-11 | 48 | Alain |  |  |  |  |
| 6190 | 2083.2 | **Stage 3 for USSD simulation service in IMS** |  | 572.88d? | 2011-06-03 A | 2012-12-07 A | 100% | 2011-06-03 | 2012-12-07 | 403d? |  | C1; C3 | 12296.1h | 12296.1h | USSI | 27 |  | Deutsche Telekom | Rel-11 | 52 | Frederic |  |  |  |  |
| 6191 | 2083.2.1 | CT1 part of Stage 3 for USSD simulation service in IMS |  | 402d? | 2011-06-03 A | 2012-12-07 A | 100% | 2011-06-03 | 2012-12-07 | 402d? | finish no earlier than 2012-12-07 | C1 | 3184.06h | 3184.06h | USSI | 27 | 24.173; 24.229; new 24.390 | Deutsche Telekom | Rel-11 | 52 | Frederic |  |  |  |  |
| 6192 | 2083.2.2 | CT3 part of Stage 3 for USSD simulation service in IMS |  | 334d? | 2011-06-07 A | 2012-09-07 A | 100% | 2011-06-07 | 2012-09-07 | 334d? | finish no earlier than 2012-09-07 | C3 | 2664h | 2664h | USSI | 27 | 29.165 | Deutsche Telekom | Rel-11 | 52 | Adrian |  |  |  |  |
| 6193 | 2084 | **QoS Control Based on Subscriber Spending Limits** |  | 659.25d? | 2010-09-23 A | 2012-06-20 A | 100% | 2010-09-23 | 2012-06-20 | 459d? |  | S1; S2; S5; C3 | 23152h | 23152h | QoS_SSL | 25 |  | Vodafone | Rel-11 | 49 | Alain |  |  |  | QoS_SSL |
| 6194 | 2084.1 | Stage 1 for QoS Control Based on Subscriber Spending Limits |  | 262d? | 2010-09-23 A | 2011-09-21 A | 100% | 2010-09-23 | 2011-09-21 | 262d? | finish no earlier than 2011-09-21 | S1 | 2080h | 2080h | QoS_SSL | 25 | 22.115 | Vodafone | Rel-11 | 49 | Alain |  |  |  |  |
| 6195 | 2084.2 | Stage 2 for QoS Control Based on Subscriber Spending Limits |  | 133d? | 2011-03-23 A | 2011-09-21 A | 100% | 2011-03-23 | 2011-09-21 | 133d? | finish no earlier than 2011-12-14 | S2 | 1048h | 1048h | QoS_SSL | 26 | 23.203 | Huawei | Rel-11 | 51 | Maurice |  |  |  |  |
| 6196 | 2084.3 | Charging for QoS Control Based on Subscriber Spending Limits (Stage 2) |  | 397d? | 2010-12-16 A | 2012-06-20 A | 100% | 2010-12-16 | 2012-06-20 | 397d? | finish no earlier than 2012-06-20 | S5 | 3168h | 3168h | QoS_SSL | 26 | 32.240; 32.296 | Nokia Siemens Networks, Huawei | Rel-11 | 50 | Mirko |  |  |  |  |
| 6197 | 2084.4 | CT3 aspects of QoS Control Based on Subscriber Spending Limits (Stage 3) |  | 273d? | 2011-06-03 A | 2012-06-15 A | 100% | 2011-06-03 | 2012-06-15 | 273d? | finish no earlier than 2012-06-15 | C3 | 2168h | 2168h | QoS_SSL-CT3 | 27 | 29.212; 29.213; 29.214; 29.215; new 29.219 | Huawei | Rel-11 | 52 | Adrian |  |  |  | QoS_SSL-CT3 |
| 6198 | 2085 | **Optimized Service Charging and Allocation of Resources in IMS whilst Roaming** |  | 550.62d? | 2010-09-23 A | 2012-03-07 A | 100% | 2010-09-23 | 2012-03-07 | 383d? |  | S1; S2 | 14288h | 14288h | OSCAR | 25 |  | Vodafone | Rel-11 | 49 | Alain |  |  |  | OSCAR |
| 6199 | 2085.1 | TR on Stage 2 aspects of Optimized Service Charging and Allocation of Resources in IMS whilst Roaming |  | 383d? | 2010-09-23 A | 2012-03-07 A | 100% | 2010-09-23 | 2012-03-07 | 383d? | finish no earlier than 2011-12-07 | S2 | 3040h | 3040h | OSCAR | 25 | new 23.849 | Vodafone | Rel-11 | 49 | Maurice |  |  |  |  |
| 6200 | 2085.2 | Stage 1 for Optimized Service Charging and Allocation of Resources in IMS whilst Roaming |  | 262d? | 2010-09-23 A | 2011-09-21 A | 100% | 2010-09-23 | 2011-09-21 | 262d? | finish no earlier than 2011-09-21 | S1 | 2080h | 2080h | OSCAR | 25 | 22.115; 22.173; 22.228 | Vodafone | Rel-11 | 49 | Alain |  |  |  |  |
| 6201 | 2085.3 | Deleted - Stage 2 for Optimized Service Charging and Allocation of Resources in IMS whilst Roaming |  | 380d? | 2010-09-28 A | 2012-03-07 A | 100% | 2010-09-28 | 2012-03-07 | 380d? | finish no earlier than 2012-03-07 | S2 | 3040h | 3040h | OSCAR | 25 | None | Vodafone | Rel-11 | 49 | Maurice | PCG-28 | SP-55 |  |  |
| 6202 | 2086 | **Inclusion of Media Resource Broker (Stage 2/3)** |  | 659.88d? | 2011-09-16 A | 2013-06-14 A | 100% | 2011-09-16 | 2013-06-14 | 463d? |  | C1; C3; IETF | 30500h | 30500h | MRB | 27 | Stage 2/3 | AT&T | Rel-11 | 53 | Frederic |  |  |  | MRB |
| 6203 | 2086.1 | Stage 2 for Inclusion of Media Resource Broker |  | 259d? | 2011-09-16 A | 2012-09-07 A | 100% | 2011-09-16 | 2012-09-07 | 259d? | finish no earlier than 2012-09-07 | C1 | 2049.98h | 2049.98h | MRB | 27 | 23.218 | AT&T | Rel-11 | 53 | Frederic |  |  |  |  |
| 6204 | 2086.2 | **Stage 3 for Inclusion of Media Resource Broker** |  | 659.88d? | 2011-09-16 A | 2013-06-14 A | 100% | 2011-09-16 | 2013-06-14 | 463d? |  | C1; C3; IETF | 17338h | 17338h | MRB | 27 |  | AT&T | Rel-11 | 53 | Frederic |  |  |  |  |
| 6205 | 2086.2.1 | CT1 part of Stage 3 for Inclusion of Media Resource Broker |  | 258d? | 2011-09-16 A | 2012-09-07 A | 100% | 2011-09-16 | 2012-09-07 | 258d? | finish no earlier than 2012-09-07 | C1 | 2049.98h | 2049.98h | MRB | 27 | 24.229; 29.165 | AT&T | Rel-11 | 53 | Frederic |  |  |  |  |
| 6206 | 2086.2.2 | (IETF) Inclusion of Media Resource Broker [RFC 6917 (was draft-ietf-mediactrl-mrb)] |  | 462d? | 2011-09-16 A | 2013-06-14 A | 100% | 2011-09-16 | 2013-06-14 | 462d? | finish no earlier than 2013-06-14 | C1-IETF | 3688h | 3688h | MRB | 27 | RFC 6917 (was draft-ietf-mediactrl-mrb) | Keith Drage | Rel-11 | 53 | Frederic |  |  |  |  |
| 6207 | 2086.2.3 | CT3 part of Stage 3 for Inclusion of Media Resource Broker |  | 62d? | 2012-06-15 A | 2012-09-07 A | 100% | 2012-06-15 | 2012-09-07 | 62d? | finish no earlier than 2012-09-07 | C3 | 488h | 488h | MRB | 29 | 29.165 | AT&T | Rel-11 | 56 | Adrian |  |  |  |  |

Notes:
- 6183: SP#57 stopped (activity transferred to Rel-12 Feature MTCe under UID_560522) / WI rapporteur e-mail: Rajavelsamy R (rajvel@samsung.com)
- 6184: SP#57 stopped (activity transferred to Rel-12 Feature MTCe / WI rapporteur e-mail: Rajavelsamy R (rajvel@samsung.com)
- 6185: SP#57 stopped (activity transferred to Rel-12 Feature MTCe / WI rapporteur e-mail: Rajavelsamy R (rajvel@samsung.com)
- 6186: SP#52 stopped / WI rapporteur e-mail: puneet.jain@intel.com
- 6187: SP#52 stopped / WI rapporteur e-mail: Rajavelsamy R (rajvel@samsung.com)
- 6188: CP#58 completed / WI rapporteur e-mail: kurt.bischinger@t-mobile.at
- 6189: SP#48 completed. Specify a CS domain USSD like service over IMS (see GSM Mobile User Initiated USSD) / WI rapporteur e-mail: kurt.bischinger@t-mobile.at
- 6190: SP#58 completed. No stage 2 impact, as reuse existing IMS architecture in TS 23.228 / WI rapporteur e-mail: reinhard.lauster@t-mobile.at
- 6191: CP#58 completed / WI rapporteur e-mail: reinhard.lauster@t-mobile.at, TS 24.390 Rapp: lili.yang@huawei.com
- 6192: CP#57 completed / WI rapporteur e-mail: reinhard.lauster@t-mobile.at
- 6193: TSG#56 completed / WI rapporteur e-mail: mona.mustapha@vodafone.com
- 6194: SP#53 completed. Use cases & service requirements to allow: 1) modification of QoS based on subscribers spending limits 2) enforcing of spending limits for roaming subscribers without having dedicated support in the visited network / WI rapporteur e-mail: mona.mustapha@vodafone.com
- 6195: SP#53 completed / WI rapporteur e-mail: Xu Xia (xiatony@huawei.com)
- 6196: SP#56 completed / WI rapporteur e-mail: Gerald.Goermer@nsn.com, shan.mingjun@huawei.com
- 6197: CP#56 completed / WI rapporteur e-mail: QiaoWeihua@huawei.com
- 6198: SP#55 completed (Stage 2/3 specified under CT1 Rel-11 Feature MRB (Inclusion of Media Resource Broker) UID_530021. Triggered by S1-102236/GSMA RILTE 10_007r1 (IREG LS_038 to 3GPP on Optimal Media Routing drawbacks) / WI rapporteur e-mail: mona.mustapha@vodafone.com
- 6199: SP#55 completed / WI rapporteur e-mail: Susana.Sabater@vodafone.com
- 6200: SP#53 completed / WI rapporteur e-mail: mona.mustapha@vodafone.com
- 6201: SP#55 no normative work in SA2. Stage 2/3 to be done in under CT1 Rel-11 Feature MRB (Inclusion of Media Resource Broker) UID_530021 / WI rapporteur e-mail: Susana.Sabater@vodafone.com
- 6202: Stage 1 and TR on Stage 2 in Rel-11 Feature OSCAR UID_490032 / WI rapporteur e-mail: Martin Dolly (md3135@att.com)
- 6203: CP#57 completed / WI rapporteur e-mail: Martin Dolly (md3135@att.com)
- 6204: CP#60 completed / WI rapporteur e-mail: Martin Dolly (md3135@att.com)
- 6205: CP#57 completed / WI rapporteur e-mail: Martin Dolly (md3135@att.com)
- 6206: CP#60 completed
- 6207: CP#57 completed / WI rapporteur e-mail: Martin Dolly (md3135@att.com)

| ID | WBS | Task | Duration | Start | Finish | Complete | Baseline start | Baseline finish | Baseline duration | Constraint | Resources | Work | Actual work | Acronym | PCG approved | WI rapporteur name | WI rapporteur e-mail | Release | TSG approved | MCC resp | Acronym_3GU_Export | Special Focus Doc | PCG stopped | TSG stopped |
| --- | --- | --- | --- | --- | --- | --- | --- | --- | --- | --- | --- | --- | --- | --- | --- | --- | --- | --- | --- | --- | --- | --- | --- | --- |
| 6208 | 2087 | **Non Voice Emergency Services** | 463.62d? | 2010-12-16 A | 2012-03-07 A | 100% | 2010-12-16 | 2012-03-07 | 323d? |  | S1; S2 | 7736h | 7736h | NOVES | 26 | Qualcomm | dwilliams@qualcomm.com | Rel-11 | 50 | Alain | NOVES |  |  |  |
| 6209 | 2087.1 | Stage 1 for Non Voice Emergency Services | 202d? | 2010-12-16 A | 2011-09-21 A | 100% | 2010-12-16 | 2011-09-21 | 202d? | finish no earlier than 2011-09-21 | S1 | 1600h | 1600h | NOVES | 26 | Qualcomm | dwilliams@qualcomm.com | Rel-11 | 50 | Alain |  |  |  |  |
| 6210 | 2087.2 | Stage 2 for Non Voice Emergency Services (Support of IMS Emergency Sessions with Other Media on UTRAN and E-UTRAN) | 121d? | 2011-09-22 A | 2012-03-07 A | 100% | 2011-09-22 | 2012-03-07 | 121d? | finish no earlier than 2012-03-07 | S2 | 968h | 968h | NOVES-IMSESOM | 27 | Alcatel-Lucent | Deb.Barclay@alcatel-lucent.com | Rel-11 | 53 | Maurice | NOVES-IMSESOM |  |  |  |
| 6211 | 2088 | **Support for 3GPP Voice Interworking with Enterprise IP-PBX** | 734.25d? | 2011-03-23 A | 2013-03-01 A | 100% | 2011-03-23 | 2013-03-01 | 516d? |  | S1; C1 | 12376h | 12376h | VINE | 26 | Tatara Systems | Phillip Brown (pbrown@tatarasystems.com) | Rel-11 | 51 | Alain | VINE |  |  |  |
| 6212 | 2088.1 | Stage 1 for Support for 3GPP Voice Interworking with Enterprise IP-PBX | 133d? | 2011-03-23 A | 2011-09-21 A | 100% | 2011-03-23 | 2011-09-21 | 133d? | finish no earlier than 2011-09-21 | S1 | 1048h | 1048h | VINE | 26 | Tatara Systems | Phillip Brown (pbrown@tatarasystems.com) | Rel-11 | 51 | Alain |  |  |  |  |
| 6213 | 2088.2 | Stage 2/3 for Support for 3GPP Voice Interworking with Enterprise IP-PBX | 385d? | 2011-09-20 A | 2013-03-01 A | 100% | 2011-09-20 | 2013-03-01 | 385d? | finish no earlier than 2013-03-01 | C1 | 3072h | 3072h | VINE-CT1 | 27 | Alcatel-Lucent | keith.drage@alcatel-lucent.com | Rel-11 | 53 | Frederic | VINE-CT1 |  |  |  |
| 6214 | 2089 | **Anonymous Call Rejection in the CS domain** | 184.88d? | 2011-06-07 A | 2011-12-02 A | 100% | 2011-06-07 | 2011-12-02 | 132d? |  | S1; C4; C3 | 4616h | 4616h | ACR_CS | 27 | Alcatel-Lucent | Betsy.Covell@alcatel-lucent.com | Rel-11 | 52 | Alain | ACR_CS |  |  |  |
| 6215 | 2089.1 | Stage 1 for Anonymous Call Rejection in the CS domain | 2d? | 2011-06-07 A | 2011-06-08 A | 100% | 2011-06-07 | 2011-06-08 | 2d? | finish no earlier than 2011-06-07 | S1 | 16h | 16h | ACR_CS | 27 | Alcatel-Lucent | Betsy.Covell@alcatel-lucent.com | Rel-11 | 52 | Alain |  |  |  |  |
| 6216 | 2089.2 | **Core Network aspects of Anonymous Call Rejection in the CS domain** | 82.62d? | 2011-09-14 A | 2011-12-02 A | 100% | 2011-09-14 | 2011-12-02 | 59d? |  | C4; C3 | 1432h | 1432h | ACR_CS-CN | 27 | Alcatel-Lucent | bruno.landais@alcatel-lucent.com | Rel-11 | 53 | Kimmo | ACR_CS-CN |  |  |  |
| 6217 | 2089.2.1 | CT4 part of Core Network aspects of Anonymous Call Rejection in the CS domain (Stage 2/3) | 59d? | 2011-09-14 A | 2011-12-02 A | 100% | 2011-09-14 | 2011-12-02 | 59d? | finish no earlier than 2011-12-02 | C4 | 464h | 464h | ACR_CS-CN | 27 | Alcatel-Lucent | bruno.landais@alcatel-lucent.com | Rel-11 | 53 | Kimmo |  |  |  |  |
| 6218 | 2089.2.2 | CT3 part of Core Network aspects of Anonymous Call Rejection in the CS domain (Stage 3) | 3d? | 2011-09-14 A | 2011-09-16 A | 100% | 2011-09-14 | 2011-09-16 | 3d? | start no earlier than 2011-09-14 | C3 | 24h | 24h | ACR_CS-CN | 27 | Alcatel-Lucent | bruno.landais@alcatel-lucent.com | Rel-11 | 53 | Adrian |  |  |  |  |
| 6219 | 2090 | **Support for BroadBand Forum Accesses Interworking** | 1137.38d? | 2009-12-10 A | 2012-12-12 A | 100% | 2009-12-10 | 2012-12-12 | 792d? |  | S2; S1; C1; C3; C4; IETF | 97983.8h | 97983.8h | BBAI | 24 | Ericsson | peter.bleckert@ericsson.com | Rel-11 | 46 | Alain | BBAI | HNB, WLAN |  |  |
| 6220 | 2090.1 | Stage 1 BB I: BBF interworking with home routed traffic for WLAN and H(e)NB | 76d? | 2009-12-10 A | 2010-03-25 A | 100% | 2009-12-10 | 2010-03-25 | 76d? | start no earlier than 2009-12-10 | S1 | 608h | 608h | BBAI | 24 | Ericsson | Olle.Eriksson@ericsson.com | Rel-11 | 46 | Alain |  | HNB, WLAN |  |  |
| 6221 | 2090.2 | TR on Stage 2 for BBAI | 588d? | 2010-03-26 A | 2012-06-20 A | 100% | 2010-03-26 | 2012-06-20 | 588d? | finish no earlier than 2012-06-19 | S2 | 4704h | 4704h | BBAI | 24 | Ericsson | marco.spini@huawei.com | Rel-11 | 47 | Maurice |  | HNB, WLAN |  |  |
| 6222 | 2090.3 | Stage 2 BB I: BBF interworking with home routed traffic for WLAN and H(e)NB | 588d? | 2010-03-26 A | 2012-06-20 A | 100% | 2010-03-26 | 2012-06-20 | 588d? | finish no earlier than 2012-06-20 | S2 | 4688.06h | 4688.06h | BBAI | 24 | Ericsson | stefan.rommer@ericsson.com | Rel-11 | 47 | Maurice |  | HNB, WLAN |  |  |
| 6223 | 2090.4 | (IETF) Stage 2 BB I: BBF interworking with home routed traffic for WLAN and H(e)NB | 266d? | 2011-12-12 A | 2012-12-12 A | 100% | 2011-12-12 | 2012-12-12 | 266d? | finish no earlier than 2012-11-24 | S2-IETF | 2119.59h | 2119.59h | BBAI | 28 | Lionel Morand | Lionel Morand | Rel-11 | 54 | Maurice |  | HNB, WLAN |  |  |
| 6224 | 2090.5 | **Stage 3 BB I - Core Network impacts: BBF interworking with home routed traffic for WLAN and H(e)NB** | 464.38d? | 2011-09-16 A | 2012-12-07 A | 100% | 2011-09-16 | 2012-12-07 | 326d? |  | C1; C3; C4 | 17288.2h | 17288.2h | BBAI_BBI-CT | 27 | Ericsson | Zu.Qiang@Ericsson.com | Rel-11 | 53 | Frederic | BBAI_BBI-CT | HNB, WLAN |  |  |
| 6225 | 2090.5.1 | TR on Stage 3 BB I for BBAI; UE to network protocols | 198d? | 2011-09-16 A | 2012-06-15 A | 100% | 2011-09-16 | 2012-06-15 | 198d? | finish no earlier than 2012-06-15 | C1 | 1568.15h | 1568.15h | BBAI_BBI-CT | 27 | Ericsson | Zu.Qiang@Ericsson.com | Rel-11 | 53 | Frederic |  | HNB, WLAN |  |  |
| 6226 | 2090.5.2 | TR on Stage 3 BB I for BBAI; Home (e)Node B – Security Gateway Interface | 77d? | 2012-03-02 A | 2012-06-15 A | 100% | 2012-03-02 | 2012-06-15 | 77d? | finish no earlier than 2012-06-01 | C4 | 608h | 608h | BBAI_BBI-CT | 28 | Ericsson | Zu.Qiang@Ericsson.com | Rel-11 | 55 | Kimmo |  | HNB, WLAN |  |  |
| 6227 | 2090.5.3 | Deleted - (IETF) on Stage 3 BB I for BBAI; Home (e)Node B – Security Gateway Interface | 77d? | 2012-03-02 A | 2012-06-15 A | 100% | 2012-03-02 | 2012-06-15 | 77d? | finish no earlier than 2012-06-15 | C4-IETF | 616h | 616h | BBAI_BBI-CT | 28 | Lionel Morand |  | Rel-11 | 55 | Kimmo |  | HNB, WLAN | PCG-29 | CP-56 |
| 6228 | 2090.5.4 | CT1 part of Stage 3 BB I: BBF interworking with home routed traffic for WLAN and H(e)NB | 258d? | 2011-09-16 A | 2012-09-07 A | 100% | 2011-09-16 | 2012-09-07 | 258d? | finish no earlier than 2012-09-07 | C1 | 2048h | 2048h | BBAI_BBI-CT | 27 | Ericsson | Zu.Qiang@Ericsson.com | Rel-11 | 53 | Frederic |  | HNB, WLAN |  |  |
| 6229 | 2090.5.5 | CT3 part of Stage 3 BB I: BBF interworking with home routed traffic for WLAN and H(e)NB | 259d? | 2011-09-16 A | 2012-09-07 A | 100% | 2011-09-16 | 2012-09-07 | 259d? | finish no earlier than 2012-09-07 | C3 | 2048h | 2048h | BBAI_BBI-CT | 27 | Ericsson | Zu.Qiang@Ericsson.com | Rel-11 | 53 | Adrian |  | HNB, WLAN |  |  |
| 6230 | 2090.5.6 | CT4 part of Stage 3 BB I: BBF interworking with home routed traffic for WLAN and H(e)NB | 326d? | 2011-09-16 A | 2012-12-07 A | 100% | 2011-09-16 | 2012-12-07 | 326d? | finish no earlier than 2012-12-07 | C4 | 2576h | 2576h | BBAI_BBI-CT | 27 | Ericsson | Zu.Qiang@Ericsson.com | Rel-11 | 53 | Kimmo |  | HNB, WLAN |  |  |
| 6231 | 2090.6 | Stage 1 BB II: BBF interworking with offload in access network for WLAN and for H(e)NB | 262d? | 2010-09-23 A | 2011-09-21 A | 100% | 2010-09-23 | 2011-09-21 | 262d? | finish no earlier than 2011-09-21 | S1 | 2080h | 2080h | BBAI_BBII-CTofldS1 | 25 | Ericsson | Olle.Eriksson@ericsson.com | Rel-11 | 49 | Alain |  | HNB, WLAN |  |  |
| 6232 | 2090.7 | Stage 2 BB II: BBF interworking with offload in access network for WLAN and for H(e)NB | 455d? | 2010-09-28 A | 2012-06-20 A | 100% | 2010-09-28 | 2012-06-20 | 455d? | finish no earlier than 2012-06-20 | S2 | 3640h | 3640h | BBAI_BBII-CTofldS2 | 24 | Ericsson | stefan.rommer@ericsson.com | Rel-11 | 47 | Maurice |  | HNB, WLAN |  |  |

Notes:
- 6208: SP#55 Stage 2 completed. Triggered by SA1 Rel-11 TR 22.871 Study on Non Voice Emergency Services (FS_NOVES)
- 6209: SP#53 completed / Impacted TSs and TRs: 22.101
- 6210: SP#55 completed / Impacted TSs and TRs: 23.060; 23.167; 23.203; 23.401
- 6211: SP#53 Stage 1 completed. CP#59 completed. Triggered by Rel-11 TR 22.809 Study on Support for 3GPP Voice Interworking with Enterprise IP-PBX (FS_VINE) UID_480033
- 6212: SP#53 completed / Impacted TSs and TRs: 22.228
- 6213: CP#59 completed / Impacted TSs and TRs: 23.218; 24.229
- 6214: CP#54 completed
- 6215: SP#52 completed under TEI11. Approved WID and CRs in SP-110376 (22.082 CR#0005, 22.085 CR#0004, 22.081 CR#0007, 22.088 CR#0003, 22.004 CR#0013) / Impacted TSs and TRs: 22.004; 22.081; 22.082; 22.085; 22.088
- 6216: CP#54 completed / Impacted TSs and TRs: Stage 2/3
- 6217: CP#54 completed / Impacted TSs and TRs: 23.018; 23.081; 23.082; 23.085; 23.088; 23.205; 23.231; 24.088; 29.002; 29.011
- 6218: CP#53 completed / Impacted TSs and TRs: 29.163; 29.292
- 6219: SP#57 updated WID SP-120419=>SP-120539 (removed BB3 objectives not implemented in Stage 2). SP#56 completed. Triggered by BBF WT 203, WT-134 (interworking btw 3GPP EPS and BBF's fixed broadband accesses)
- 6220: SP#57 updated WID SP-120419=>SP-120539 (removed BB3 objectives not implemented in Stage 2). SP#47 completed. Provide service requirements for supporting interworking between 3GPP EPS and the fixed broadband accesses defined by BBF / Impacted TSs and TRs: 22.278 CR#0058
- 6221: TR 23.839 not Approved in Rel-11¦progressed in Rel-12 under P4C-TI (UID_560824) / Impacted TSs and TRs: new 23.839
- 6222: SP#56 completed / Impacted TSs and TRs: 23.203; new 23.139
- 6223: Solved by IANA-registration. No RFC needed
- 6224: CP#58 completed / Impacted TSs and TRs: Stage 3
- 6225: CP#56 completed. Identify additional FMC specific procedurES in CP-150addition to those in 24.302 (on access authentication & authorization and tunnel management¦IP mobility mode selection¦security aspects) / Impacted TSs and TRs: new 24.820
- 6226: CP#56 completed / Impacted TSs and TRs: new 29.839
- 6227: Draft removed from 3GPP documentation / Impacted TSs and TRs: draft-so-ipsecme-ikev2-cpext
- 6228: CP#57 completed / Impacted TSs and TRs: 24.229; new 24.139
- 6229: CP#57 completed / Impacted TSs and TRs: 29.212; 29.213; 29.215
- 6230: CP#58 completed / Impacted TSs and TRs: 23.008; 29.273; 29.274; new 29.139
- 6231: SP#53 completed. 22/01: acronym modified / Impacted TSs and TRs: 22.278
- 6232: SP#56 completed. 22/01: acronym modified / Impacted TSs and TRs: 23.203; 23.401; 23.402; 23.139

| ID | WBS | Task | Duration | Start | Finish | Complete | Baseline start | Baseline finish | Baseline duration | Constraint | Resources | Work | Actual work | Acronym | PCG approved | Impacted TSs and TRs | WI rapporteur name | WI rapporteur e-mail | Release | TSG approved | MCC resp | Special Focus Doc | Acronym_3GU_Export | PCG stopped | TSG stopped |
| --- | --- | --- | --- | --- | --- | --- | --- | --- | --- | --- | --- | --- | --- | --- | --- | --- | --- | --- | --- | --- | --- | --- | --- | --- | --- |
| 6233 | 2090.8 | **Stage 3 BB II - Core Network impacts: BBF interworking with offload in access network for WLAN and for H(e)NB** | 370.38d? | 2011-09-16 A | 2012-09-07 A | 100% | 2011-09-16 | 2012-09-07 | 259d? |  | C3; C1; C4 | 12888h | 12888h | BBAI_BBII-CT | 27 | Stage 3 | Ericsson | Susana.Fernandez@ericsson.com | Rel-11 | 53 | Adrian | HNB, WLAN | BBAI_BBII-CT |  |  |
| 6234 | 2090.8.1 | TR on Stage 3 BB II for 3GPP System to Fixed Broadband Access Network Interworking; UE to network protocols | 198d? | 2011-09-16 A | 2012-06-15 A | 100% | 2011-09-16 | 2012-06-15 | 198d? | finish no earlier than 2012-06-15 | C1 | 1576h | 1576h | BBAI_BBII-CT | 27 | 24.820 | Ericsson | Susana.Fernandez@ericsson.com | Rel-11 | 53 | Frederic | HNB, WLAN |  |  |  |
| 6235 | 2090.8.2 | CT1 part of Stage 3 BB II: BBF interworking with offload in access network for WLAN and for H(e)NB | 259d? | 2011-09-16 A | 2012-09-07 A | 100% | 2011-09-16 | 2012-09-07 | 259d? | finish no earlier than 2012-09-07 | C1 | 2064h | 2064h | BBAI_BBII-CT | 27 | new 24.320 | Ericsson | Susana.Fernandez@ericsson.com | Rel-11 | 53 | Frederic | HNB, WLAN |  |  |  |
| 6236 | 2090.8.3 | CT3 part of Stage 3 BB II: BBF interworking with offload in access network for WLAN and for H(e)NB | 259d? | 2011-09-16 A | 2012-09-07 A | 100% | 2011-09-16 | 2012-09-07 | 259d? | start no earlier than 2011-09-16 | C3 | 2056h | 2056h | BBAI_BBII-CT | 27 | 29.212; 29.213; 29.215 | Ericsson | Susana.Fernandez@ericsson.com | Rel-11 | 53 | Adrian | HNB, WLAN |  |  |  |
| 6237 | 2090.8.4 | CT4 part of Stage 3 BB II: BBF interworking with offload in access network for WLAN and for H(e)NB | 122d? | 2011-09-16 A | 2012-03-02 A | 100% | 2011-09-16 | 2012-03-02 | 122d? | start no earlier than 2011-09-16 | C4 | 976h | 976h | BBAI_BBII-CT | 27 | 23.008; 29.273 | Ericsson | Susana.Fernandez@ericsson.com | Rel-11 | 53 | Kimmo | HNB, WLAN |  |  |  |
| 6238 | 2090.9 | Deleted - Stage 1 BB III: BBF convergence and network based mobility | 262d? | 2010-09-23 A | 2011-09-21 A | 100% | 2010-09-23 | 2011-09-21 | 262d? | finish no earlier than 2011-09-21 | S1 | 2080h | 2080h |  | 25 | 22.278 | Huawei | Amar Deol (adeol@huawei.com) | Rel-11 | 49 | Alain | HNB, WLAN |  | PCG-29 | SP-57 |
| 6239 | 2090.10 | Deleted - Stage 2 BB III: BBF convergence and network based mobility | 380d? | 2010-09-28 A | 2012-03-07 A | 100% | 2010-09-28 | 2012-03-07 | 380d? | finish no earlier than 2012-03-07 | S2 | 3040h | 3040h |  | 24 | 23.203; 23.401; 23.402; 23.139 | Huawei | marco.spini@huawei.com | Rel-11 | 47 | Maurice | HNB, WLAN |  | PCG-28 | SP-55 |
| 6240 | 2090.11 | **Deleted - Stage 3 BB III - Core Network impacts: BBF convergence and network based mobility** | 174.88d? | 2011-09-16 A | 2012-03-02 A | 100% | 2011-09-16 | 2012-03-02 | 122d? |  | C3; C1; C4 | 6832h | 6832h |  | 27 | Stage 3 | Huawei | qiaoweihua@huawei.com | Rel-11 | 53 | Adrian | HNB, WLAN | BBAI_BBIII-CT | PCG-28 | CP-55 |
| 6241 | 2090.11.1 | Deleted - TR on Stage 3 BB III for 3GPP System to Fixed Broadband Access Network Interworking; UE to network protocols | 122d? | 2011-09-16 A | 2012-03-02 A | 100% | 2011-09-16 | 2012-03-02 | 122d? | start no earlier than 2011-09-16 | C1 | 976h | 976h |  | 27 | new 24.820 | Huawei | qiaoweihua@huawei.com | Rel-11 | 53 | Frederic | HNB, WLAN |  | PCG-28 | CP-55 |
| 6242 | 2090.11.2 | Deleted - CT1 part of Stage 3 BB III: BBF convergence and network based mobility | 122d? | 2011-09-16 A | 2012-03-02 A | 100% | 2011-09-16 | 2012-03-02 | 122d? | start no earlier than 2011-09-16 | C1 | 976h | 976h |  | 27 | TBD | Huawei | qiaoweihua@huawei.com | Rel-11 | 53 | Frederic | HNB, WLAN |  | PCG-28 | CP-55 |
| 6243 | 2090.11.3 | Deleted - CT3 part of Stage 3 BB III: BBF convergence and network based mobility | 122d? | 2011-09-16 A | 2012-03-02 A | 100% | 2011-09-16 | 2012-03-02 | 122d? | start no earlier than 2011-09-16 | C3 | 976h | 976h |  | 27 | 29.212; 29.213; 29.215 | Huawei | qiaoweihua@huawei.com | Rel-11 | 53 | Adrian | HNB, WLAN |  | PCG-28 | CP-55 |
| 6244 | 2090.11.4 | Deleted - CT4 part of Stage 3 BB III: BBF convergence and network based mobility | 122d? | 2011-09-16 A | 2012-03-02 A | 100% | 2011-09-16 | 2012-03-02 | 122d? | start no earlier than 2011-09-16 | C4 | 976h | 976h |  | 27 | 23.008; 29.273 | Huawei | qiaoweihua@huawei.com | Rel-11 | 53 | Kimmo | HNB, WLAN |  | PCG-28 | CP-55 |
| 6245 | 2091 | **Single Radio Voice Call Continuity (SRVCC) aspect of enhancements for Multimedia Priority Service** | 572.38d? | 2010-06-10 A | 2011-12-14 A | 100% | 2010-06-10 | 2011-12-14 | 398d? |  | S2 | 8432h | 8432h | eMPS_SRVCC | 25 | Stage 2 | NTT DoCoMo | Atsushi Minokuchi (minokuchi@nttdocomo.co.jp) | Rel-11 | 48 | Maurice | Public Safety (I-A) | eMPS_SRVCC |  |  |
| 6246 | 2091.1 | TR on SRVCC for eMPS | 260d? | 2010-06-10 A | 2011-06-08 A | 100% | 2010-06-10 | 2011-06-08 | 260d? | finish no earlier than 2011-06-08 | S2 | 2080h | 2080h | eMPS_SRVCC | 25 | new 23.854 | NTT DoCoMo | Atsushi Minokuchi (minokuchi@nttdocomo.co.jp) | Rel-11 | 48 | Maurice | Public Safety (I-A) |  |  |  |
| 6247 | 2091.2 | Stage 2 on SRVCC for eMPS | 398d? | 2010-06-10 A | 2011-12-14 A | 100% | 2010-06-10 | 2011-12-14 | 398d? | finish no earlier than 2011-12-14 | S2 | 3168h | 3168h | eMPS_SRVCC | 25 | 23.216; 23.237 | NTT DoCoMo | Atsushi Minokuchi (minokuchi@nttdocomo.co.jp) | Rel-11 | 48 | Maurice | Public Safety (I-A) |  |  |  |
| 6248 | 2092 | **Single Radio Video Call Continuity for 3G-CS** | 631.25d? | 2010-10-15 A | 2012-06-15 A | 100% | 2010-10-15 | 2012-06-15 | 440d? |  | S2; C1; C3; C4 | 26572.4h | 26572.4h | vSRVCC | 26 |  | Samsung | xiaowan.ke@samsung.com | Rel-11 | 50 | Maurice |  | vSRVCC |  |  |
| 6249 | 2092.1 | Stage 2 for Single Radio Video Call Continuity for 3G-CS | 199.85d? | 2010-10-15 A | 2011-09-21 A | 100% | 2010-10-15 | 2011-09-21 | 199.85d? | finish no earlier than 2011-12-07 | S2 | 1580.41h | 1580.41h | vSRVCC | 26 | 23.203; 23.216; 23.237 | Samsung | xiaowan.ke@samsung.com | Rel-11 | 50 | Maurice |  |  |  |  |
| 6250 | 2092.2 | **CN aspects of Single Radio Video Call Continuity for 3G-CS** | 392d? | 2011-06-03 A | 2012-06-15 A | 100% | 2011-06-03 | 2012-06-15 | 275d? |  | C1; C3; C4 | 10912h | 10912h | vSRVCC-CT | 27 |  | NEC | gottfried.punz@neclab.eu | Rel-11 | 52 | Frederic |  | vSRVCC-CT |  |  |
| 6251 | 2092.2.1 | CT1 aspects of Single Radio Video Call Continuity for 3G-CS | 275d? | 2011-06-03 A | 2012-06-15 A | 100% | 2011-06-03 | 2012-06-15 | 275d? | finish no earlier than 2012-06-15 | C1 | 2184h | 2184h | vSRVCC-CT | 27 | 24.008; 24.237; 24.301 | NEC | gottfried.punz@neclab.eu | Rel-11 | 52 | Frederic |  |  |  |  |
| 6252 | 2092.2.2 | CT3 aspects of Single Radio Video Call Continuity for 3G-CS | 134d? | 2011-06-03 A | 2011-12-02 A | 100% | 2011-06-03 | 2011-12-02 | 134d? | finish no earlier than 2011-12-02 | C3 | 1064h | 1064h | vSRVCC-CT | 27 | 29.211; 29.212; 29.213; 29.215 | NEC | gottfried.punz@neclab.eu | Rel-11 | 52 | Adrian |  |  |  |  |
| 6253 | 2092.2.3 | CT4 aspects of Single Radio Video Call Continuity for 3G-CS | 134d? | 2011-06-03 A | 2011-12-02 A | 100% | 2011-06-03 | 2011-12-02 | 134d? | finish no earlier than 2011-12-02 | C4 | 1064h | 1064h | vSRVCC-CT | 27 | 29.280 | NEC | gottfried.punz@neclab.eu | Rel-11 | 52 | Kimmo |  |  |  |  |
| 6254 | 2093 | **Network-provided Location information for IMS (NETLOC)** | 1030.5d? | 2010-06-10 A | 2013-03-01 A | 100% | 2010-06-10 | 2013-03-01 | 720d? |  | S2; S1; S5; C3; C4; C1 | 57274.7h | 57274.7h | NWK-PL2IMS | 25 |  | T-Mobile | michele.zarri@t-mobile.co.uk | Rel-11 | 48 | Maurice |  | NWK-PL2IMS |  |  |
| 6255 | 2093.1 | Stage 1 for Network-provided Location information for IMS | 203d? | 2010-12-15 A | 2011-09-21 A | 100% | 2010-12-15 | 2011-09-21 | 203d? | finish no earlier than 2011-09-21 | S1 | 1608h | 1608h | NWK-PL2IMS | 26 | 22.115 | n/a | n/a | Rel-11 | 50 | Alain |  |  |  |  |
| 6256 | 2093.2 | TR on Stage 2 for Network-provided Location information for IMS | 395d? | 2010-06-10 A | 2011-12-14 A | 100% | 2010-06-10 | 2011-12-14 | 395d? | finish no earlier than 2011-12-06 | S2 | 3160h | 3160h | NWK-PL2IMS | 25 | new 23.842 | T-Mobile | michele.zarri@t-mobile.co.uk | Rel-11 | 48 | Maurice |  |  |  |  |
| 6257 | 2093.3 | Stage 2 for Network-provided Location information for IMS | 455d? | 2010-06-15 A | 2012-03-07 A | 100% | 2010-06-15 | 2012-03-07 | 455d? | finish no earlier than 2012-03-07 | S2 | 3640h | 3640h | NWK-PL2IMS | 25 | 23.060; 23.203; 23.228; 23.401 | T-Mobile | michele.zarri@t-mobile.co.uk | Rel-11 | 48 | Maurice |  |  |  |  |
| 6258 | 2093.4 | Charging for Network-provided Location information for IMS | 515d? | 2010-09-23 A | 2012-09-12 A | 100% | 2010-09-23 | 2012-09-12 | 515d? | finish no earlier than 2012-09-12 | S5 | 4120h | 4120h | NWK-PL2IMS_CH | 25 | Stage 2 (32.240; 32.260); Stage 3 (32.298; 32.299) | Nokia Siemens Networks | Gerald.Goermer@nsn.com | Rel-11 | 49 | Mirko |  | NWK-PL2IMS_CH |  |  |

Notes:
- 6233: CP#57 completed
- 6234: CP#56 completed
- 6235: CP#57 completed
- 6236: CP#57 completed
- 6237: CP#55 completed
- 6238: SP#57 stopped. Updated WID SP-120419=>SP-120539 (removed BB3 objectives not implemented in Stage 2). SP#53 completed
- 6239: SP#57 updated WID SP-120419=>SP-120539 (removed BB3 objectives not implemented in Stage 2). SP#55 stopped
- 6240: CP#55 stopped
- 6241: CP#55 stopped
- 6242: CP#55 stopped
- 6243: CP#55 stopped
- 6244: CP#55 stopped
- 6245: SP#54 completed. Analyze and if needed specify mechanisms for the priority handling of SRVCC with regard to LTE/EPC
- 6246: SP#52 completed
- 6247: SP#54 completed
- 6248: CP#56 completed. Provide Single Radio VIDEO Call Continuity from E-UTRAN to UTRAN-CS based on the agreed architecture alternative in TR 23.886
- 6249: SP#53 completed. Triggered by Feasibility Study on video call handover capability in TR 23.886 UID_470048 Study on Single Radio Video Call Continuity for 3G-CS (FS_vSRVCC)
- 6250: Stage 3. CP#56 completed
- 6251: CP#56 completed
- 6252: CP#54 completed
- 6253: CP#54 completed
- 6254: Covers the case where UE is served by a 3GPP RAN. Architecture making Cell/PLMN ID (UE is camped on) available to IMS nodes when the operator needs to record this information either to fulfil legal obligations or for charging.
- 6255: SP#53 completed
- 6256: SP#54 completed
- 6257: SP#55 completed
- 6258: SP#57 completed

| ID | WBS | Task | Type | Duration | Start | Finish | Complete | Baseline start | Baseline finish | Baseline duration | Constraint | Resources | Work | Actual work | Acronym | PCG approved | WI rapporteur name | WI rapporteur e-mail | Release | TSG approved | MCC resp | Acronym_3GU_Export | Special Focus Doc | PCG stopped | TSG stopped |
| --- | --- | --- | --- | --- | --- | --- | --- | --- | --- | --- | --- | --- | --- | --- | --- | --- | --- | --- | --- | --- | --- | --- | --- | --- | --- |
| 6259 | 2093.5 | **CT aspects of Network-provided Location information for IMS (Stage 3)** |  | 377.38d? | 2012-03-02 A | 2013-03-01 A | 100% | 2012-03-02 | 2013-03-01 | 266d? |  | C3; C4; C1 | 10186.7h | 10186.7h | NWK-PL2IMS-CT | 28 | Huawei | Qiao Weihua (qiaoweihua@huawei.com) | Rel-11 | 55 | Adrian | NWK-PL2IMS_CT |  |  |  |
| 6260 | 2093.5.1 | CT3 part of CT aspects of Network-provided Location information for IMS |  | 138d? | 2012-03-02 A | 2012-09-07 A | 100% | 2012-03-02 | 2012-09-07 | 138d? | finish no earlier than 2012-09-07 | C3 | 1088h | 1088h | NWK-PL2IMS-CT | 28 | Huawei | Qiao Weihua (qiaoweihua@huawei.com) | Rel-11 | 55 | Adrian |  |  |  |  |
| 6261 | 2093.5.2 | CT4 part of CT aspects of Network-provided Location information for IMS |  | 77d? | 2012-03-02 A | 2012-06-15 A | 100% | 2012-03-02 | 2012-06-15 | 77d? | finish no earlier than 2012-06-01 | C4 | 608h | 608h | NWK-PL2IMS-CT | 28 | Huawei | Qiao Weihua (qiaoweihua@huawei.com) | Rel-11 | 55 | Kimmo |  |  |  |  |
| 6262 | 2093.5.3 | CT1 part of CT aspects of Network-provided Location information for IMS |  | 266d? | 2012-03-02 A | 2013-03-01 A | 100% | 2012-03-02 | 2013-03-01 | 266d? | finish no earlier than 2013-06-14 | C1 | 2106.67h | 2106.67h | NWK-PL2IMS-CT | 28 | Huawei | Qiao Weihua (qiaoweihua@huawei.com) | Rel-11 | 55 | Frederic |  |  |  |  |
| 6263 | 2094 | **Service Awareness and Privacy Policies** |  | 430.52d? | 2010-10-12 A | 2011-12-02 A | 100% | 2010-10-12 | 2011-12-02 | 301.15d? |  | S2; S1; C3 | 10667.6h | 10667.6h | SAPP | 26 | Allot | Alla Goldner (agoldner@allot.com) | Rel-11 | 50 | Maurice | SAPP |  |  |  |
| 6264 | 2094.1 | Stage 1 for Service Awareness and Privacy Policies |  | 46.15d? | 2010-10-12 A | 2010-12-15 A | 100% | 2010-10-12 | 2010-12-15 | 46.15d? | finish no earlier than 2010-12-15 | S1 | 369.2h | 369.2h | SAPP | 26 | Allot | Alla Goldner (agoldner@allot.com) | Rel-11 | 50 | Maurice |  |  |  |  |
| 6265 | 2094.2 | Stage 2 for Service Awareness and Privacy Policies |  | 199.85d? | 2010-10-15 A | 2011-09-21 A | 100% | 2010-10-15 | 2011-09-21 | 199.85d? | finish no earlier than 2011-09-21 | S2 | 1582.8h | 1582.8h | SAPP | 26 | Allot | Alla Goldner (agoldner@allot.com) | Rel-11 | 50 | Maurice |  |  |  |  |
| 6266 | 2094.3 | CT3 part of Service Awareness and Privacy Policies |  | 187d? | 2011-03-18 A | 2011-12-02 A | 100% | 2011-03-18 | 2011-12-02 | 187d? | finish no earlier than 2011-12-02 | C3 | 1488h | 1488h | SAPP-CT3 | 26 | Allot | Alla Goldner (agoldner@allot.com) | Rel-11 | 51 | Adrian | SAPP-CT3 |  |  |  |
| 6267 | 2095 | **VPLMN Autonomous CSG Roaming** |  | 440.88d? | 2010-10-15 A | 2011-12-14 A | 100% | 2010-10-15 | 2011-12-14 | 307d? |  | S2; C4 | 6974.61h | 6974.61h | VCSG | 26 | Qualcomm | AC Mahendran (ac@qualcomm.com) | Rel-11 | 50 | Maurice | VCSG |  |  |  |
| 6268 | 2095.1 | Stage 2 for VPLMN Autonomous CSG Roaming |  | 260.85d? | 2010-10-15 A | 2011-12-14 A | 100% | 2010-10-15 | 2011-12-14 | 260.85d? | finish no earlier than 2011-12-07 | S2 | 2062.61h | 2062.61h | VCSG | 26 | Qualcomm | AC Mahendran (ac@qualcomm.com) | Rel-11 | 50 | Maurice |  |  |  |  |
| 6269 | 2095.2 | CT aspects of VPLMN Autonomous CSG Roaming | milestone | 0d? | 2011-12-07 A | 2011-12-07 A | 100% | 2011-12-07 | 2011-12-07 | 0d? | finish no earlier than 2012-09-07 | C4 |  |  | VCSG-St3 | 27 | ZTE | Fei Lu (lu.fei1@zte.com.cn) | Rel-11 | 53 | Kimmo | VCSG-St3 |  |  |  |
| 6270 | 2096 | **Data Identification in Access Network Discovery and Selection Function (ANDSF)** |  | 647.38d? | 2011-03-23 A | 2012-12-07 A | 100% | 2011-03-23 | 2012-12-07 | 455d? |  | S2; C1 | 12488h | 12488h | DIDA | 26 | Qualcomm | Gerardo Giaretta (gerardo@qualcomm.com) | Rel-11 | 51 | Maurice | DIDA |  |  |  |
| 6271 | 2096.1 | TR on Stage 2 for Data Identification in ANDSF |  | 193d? | 2011-03-23 A | 2011-12-14 A | 100% | 2011-03-23 | 2011-12-14 | 193d? | finish no earlier than 2011-12-07 | S2 | 1544h | 1544h | DIDA | 26 | Qualcomm | Gerardo Giaretta (gerardo@qualcomm.com) | Rel-11 | 51 | Maurice |  |  |  |  |
| 6272 | 2096.2 | Stage 2 for Data Identification in ANDSF |  | 253d? | 2011-03-24 A | 2012-03-07 A | 100% | 2011-03-24 | 2012-03-07 | 253d? | finish no earlier than 2012-03-07 | S2 | 2024h | 2024h | DIDA | 26 | Qualcomm | Gerardo Giaretta (gerardo@qualcomm.com) | Rel-11 | 51 | Maurice |  |  |  |  |
| 6273 | 2096.3 | CT aspects of Data Identification in Access Network Discovery and Selection Function (ANDSF) Stage 3 |  | 290.5d? | 2012-03-02 A | 2012-12-07 A | 100% | 2012-03-02 | 2012-12-07 | 205d? | finish no earlier than 2012-12-07 | C1 | 1640h | 1640h | DIDA-CT | 28 | Qualcomm | Patrick Stupar (pstupar@qualcomm.com) | Rel-11 | 55 | Frederic | DIDA-CT |  |  |  |
| 6274 | 2097 | **LOcation-Based Selection of gaTEways foR WLAN** |  | 466.5d? | 2011-03-23 A | 2012-06-15 A | 100% | 2011-03-23 | 2012-06-15 | 327d? |  | S2; C4 | 10170.5h | 10170.5h | LOBSTER | 26 | ZTE | zhu.chunhui@zte.com.cn | Rel-11 | 51 | Maurice | LOBSTER | WLAN |  |  |
| 6275 | 2097.1 | Stage 2 for LOcation-Based Selection of gaTEways foR WLAN |  | 194d? | 2011-03-23 A | 2011-12-14 A | 100% | 2011-03-23 | 2011-12-14 | 194d? | finish no earlier than 2011-12-07 | S2 | 1546.52h | 1546.52h | LOBSTER | 26 | ZTE | zhu.chunhui@zte.com.cn | Rel-11 | 51 | Maurice |  | WLAN |  |  |
| 6276 | 2097.2 | **CT aspects of LOcation-Based Selection of gaTEways foR WLAN** |  | 203.88d? | 2011-12-02 A | 2012-06-15 A | 100% | 2011-12-02 | 2012-06-15 | 142d? |  | C4 | 3392h | 3392h | LOBSTER-CT | 28 | ZTE | zhou.xingyue@zte.com.cn | Rel-11 | 54 | Kimmo | LOBSTER-CT | WLAN |  |  |
| 6277 | 2097.2.1 | CT4 part of CT aspects of LOcation-Based Selection of gaTEways foR WLAN |  | 142d? | 2011-12-02 A | 2012-06-15 A | 100% | 2011-12-02 | 2012-06-15 | 142d? | finish no earlier than 2012-06-15 | C4 | 1128h | 1128h | LOBSTER-CT | 28 | ZTE | zhou.xingyue@zte.com.cn | Rel-11 | 54 | Kimmo |  | WLAN |  |  |
| 6278 | 2097.2.2 | Deleted - CT1 part of CT aspects of LOcation-Based Selection of gaTEways foR WLAN |  | 142d? | 2011-12-02 A | 2012-06-15 A | 100% | 2011-12-02 | 2012-06-15 | 142d? | finish no earlier than 2012-06-15 | C1 | 1128h | 1128h | LOBSTER-CT | 28 | ZTE | zhou.xingyue@zte.com.cn | Rel-11 | 54 | Frederic |  | WLAN | PCG-29 | CP-56 |
| 6279 | 2098 | **Single Radio Voice Call Continuity from UTRAN/GERAN to E-UTRAN/HSPA** |  | 1322.75d? | 2011-09-12 A | 2015-03-13 A | 100% | 2011-09-12 | 2014-12-05 | 856d? |  | S2; C1; C3; C4; G2; R2; R3; R5 | 83776.8h | 83776.8h | rSRVCC | 27 | Orange | antoine.mouquet@orange-ftgroup.com | Rel-11 | 53 | Maurice | rSRVCC |  |  |  |
| 6280 | 2098.1 | Stage 2 for Single Radio Voice Call Continuity from UTRAN/GERAN to E-UTRAN/HSPA |  | 197d? | 2011-09-22 A | 2012-06-20 A | 100% | 2011-09-22 | 2012-06-20 | 197d? | finish no earlier than 2012-06-20 | S2 | 1568h | 1568h | rSRVCC | 27 | Orange | antoine.mouquet@orange-ftgroup.com | Rel-11 | 53 | Maurice |  |  |  |  |
| 6281 | 2098.2 | **CT aspects for Single Radio Voice Call Continuity from UTRAN/GERAN to E-UTRAN/HSPA (Stage 3)** |  | 370.38d? | 2011-09-16 A | 2012-09-07 A | 100% | 2011-09-16 | 2012-09-07 | 259d? |  | C1; C3; C4 | 12360h | 12360h | rSRVCC-CT | 27 | Ericsson | ivo.sedlacek@ericsson.com | Rel-11 | 53 | Frederic | rSRVCC-CT |  |  |  |
| 6282 | 2098.2.1 | CT1 part for Single Radio Voice Call Continuity from UTRAN/GERAN to E-UTRAN/HSPA |  | 258d? | 2011-09-16 A | 2012-09-07 A | 100% | 2011-09-16 | 2012-09-07 | 258d? | finish no earlier than 2012-09-07 | C1 | 2048h | 2048h | rSRVCC-CT | 27 | Ericsson | ivo.sedlacek@ericsson.com | Rel-11 | 53 | Frederic |  |  |  |  |
| 6283 | 2098.2.2 | CT3 part for Single Radio Voice Call Continuity from UTRAN/GERAN to E-UTRAN/HSPA |  | 257d? | 2011-09-19 A | 2012-09-07 A | 100% | 2011-09-19 | 2012-09-07 | 257d? | finish no earlier than 2012-09-07 | C3 | 2048h | 2048h | rSRVCC-CT | 27 | Ericsson | ivo.sedlacek@ericsson.com | Rel-11 | 53 | Adrian |  |  |  |  |
| 6284 | 2098.2.3 | CT4 part for Single Radio Voice Call Continuity from UTRAN/GERAN to E-UTRAN/HSPA |  | 257d? | 2011-09-19 A | 2012-09-07 A | 100% | 2011-09-19 | 2012-09-07 | 257d? | finish no earlier than 2012-09-07 | C4 | 2048h | 2048h | rSRVCC-CT | 27 | Ericsson | ivo.sedlacek@ericsson.com | Rel-11 | 53 | Kimmo |  |  |  |  |
| 6285 | 2098.3 | GERAN aspects of Single Radio Voice Call Continuity from UTRAN/GERAN to E-UTRAN/HSPA (Stage 3) |  | 677.48d? | 2011-09-12 A | 2013-06-28 A | 100% | 2011-09-12 | 2013-06-28 | 476.1d? | finish no earlier than 2013-11-22 | G2 | 2048h | 2048h | rSRVCC-GERAN | 27 | ZTE | li.jing4@zte.com.cn | Rel-11 | 51 | Gert | rSRVCC-GERAN |  |  |  |

Notes:
- 6259: Stage 3. 3/3: Acronym changed from "NWK-PL2IMS_CT"
- 6260: CP#57 completed. 3/3: Acronym changed from "NWK-PL2IMS_CT" / Impacted TSs and TRs: 29.212; 29.214; 29.215
- 6261: CP#57 completed. 3/3: Acronym changed from "NWK-PL2IMS_CT" / Impacted TSs and TRs: 23.008; 29.002; 29.060; 29.230; 29.272; 29.274; 29.305; 29.328; 29.329
- 6262: CP#57 completed. 3/3: Acronym changed from "NWK-PL2IMS_CT" / Impacted TSs and TRs: 24.229; 24.292
- 6263: CP#54 completed. Triggered by the SA1,SA2 Rel-10 TR 23.813 Study on Policy solutions and enhancements (FS_PP) UID_440047
- 6264: For deep packet inspection (i.e. Traffic Detection Functionality) SA1 indicated that no new requirements are needed (see Objective of FS_PP SA1,SA2 Rel-10 Study on Policy solutions and enhancements UID_440047 TR 23.813)
- 6265: SP#53 completed / Impacted TSs and TRs: 23.203
- 6266: CP#54 completed. Stage 3 to support Application Detection and Control Functionality. Update Gx / introduce Sd reference points and procedures. Update S9 reference point in roaming scenarios / Impacted TSs and TRs: 29.212; 29.213; 29.214; 29.215
- 6267: CP#56 completed. Linked to Rel-10 UID_450053 Enhanced Home NodeB / eNodeB (EHNB). Implements Rel-9 requirements for CSG support in SA1 TS 22.220
- 6268: SP#54 completed / Impacted TSs and TRs: 23.002; 23.060; 23.401
- 6269: CP#57 completed / Impacted TSs and TRs: 23.003; 23.007; 23.008; 23.012; 29.002; 29.230; 29.272
- 6270: SP#58 completed. Linked to Rel-10 IFOM (IP Flow Mobility and seamless WLAN offload) UID_450041. Defines IP flow mobility, seamless and non seamless WLAN offload and respective ANDSF extensions / Impacted TSs and TRs: Stage 2/3
- 6271: SP#54 completed / Impacted TSs and TRs: New 23.855
- 6272: SP#55 completed / Impacted TSs and TRs: 23.402
- 6273: CP#58 completed / Impacted TSs and TRs: 24.302; 24.312
- 6274: CP#56 completed. Related to UID_350027 SAE for support for non-3GPP accesses (SAES-SA-FP_n3GPP). Enhancements to ePDG and PDN GW selection functions for S2b and S2c based on UE location
- 6275: SP#54 completed / Impacted TSs and TRs: 23.402
- 6276: Stage 3. CP#56 completed / Impacted TSs and TRs: Stage 3
- 6277: CP#56 completed / Impacted TSs and TRs: 29.273
- 6278: CP#56 stopped / Impacted TSs and TRs: 24.302
- 6279: Stage 1 in Rel-8 TS 22.278 clause 7.1.4.2. Triggered by Rel-11 TR 23.885 Study on Single Radio Voice Call Continuity from UTRAN/GERAN to E-UTRAN/HSPA (FS_rSRVCC) UID_460030
- 6280: SP#56 completed / Impacted TSs and TRs: 23.216; 23.237
- 6281: CP#57 completed / Impacted TSs and TRs: Stage 3
- 6282: CP#57 completed / Impacted TSs and TRs: 23.009; 24.008; 24.229; 24.237; 24.292; 24.301
- 6283: CP#57 completed / Impacted TSs and TRs: 29.165; 29.292
- 6284: CP#57 completed / Impacted TSs and TRs: 23.003; 23.008; 29.002; 29.230; 29.272; 29.280; 29.303; 29.305; 29.328
- 6285: GP#60 completed. GP#51 approved WID / Impacted TSs and TRs: 44.018; 48.008

| ID | WBS | Task | Duration | Start | Finish | Complete | Baseline start | Baseline finish | Baseline duration | Constraint | Resources | Work | Actual work | Acronym | PCG approved | Impacted TSs and TRs | WI rapporteur name | Release | TSG approved | MCC resp | Acronym_3GU_Export | Status Report | Special Focus Doc | PCG stopped | TSG stopped |
| --- | --- | --- | --- | --- | --- | --- | --- | --- | --- | --- | --- | --- | --- | --- | --- | --- | --- | --- | --- | --- | --- | --- | --- | --- | --- |
| 6286 | 2098.4 | **UTRAN aspects of Single Radio Voice Call Continuity from UTRAN/GERAN to E-UTRAN/HSPA** | 461.12d? | 2011-09-19 A | 2012-12-07 A | 100% | 2011-09-19 | 2012-12-07 | 325d? |  | R3; R2 | 10400h | 10400h | rSRVCC-RAN_UTRA | 27 | UTRA | Huawei | Rel-11 | 53 | Juha | rSRVCC-RAN_UTRA |  |  |  |  |
| 6287 | 2098.4.1 | Core part: UTRAN aspects of Single Radio Voice Call Continuity from UTRAN/GERAN to E-UTRAN/HSPA | 325d? | 2011-09-19 A | 2012-12-07 A | 100% | 2011-09-19 | 2012-12-07 | 325d? | finish no earlier than 2012-12-07 | R3; R2 | 5200h | 5200h | rSRVCC-RAN_UTRA-Core | 27 | 25.331; 25.401; 25.413 | Huawei | Rel-11 | 53 | Juha | rSRVCC-RAN_UTRA-Core | RP-121553 |  |  |  |
| 6288 | 2098.5 | Test part: Single Radio Voice Call Continuity from UTRAN/GERAN to E-UTRAN/HSPA | 196d? | 2014-06-15 A | 2015-03-13 A | 100% | 2014-06-13 | 2014-12-05 | 126d? | finish no earlier than 2015-03-15 | R5 | 1568h | 1568h | rSRVCC-UEConTest | 33 | 36.508; 36.523-1; 36.523-2; 36.523-3 | Ericsson | Rel-11 | 64 |  | rSRVCC-UEConTest | RP-150133 |  |  |  |
| 6289 | 2099 | **S2a Mobility based On GTP and WLAN access to EPC** | 926.62d? | 2011-09-22 A | 2014-03-05 A | 100% | 2011-09-22 | 2014-03-05 | 651d? |  | S2; C4; C1; C3; IETF | 54000h | 54000h | SaMOG_WLAN | 27 | Stage 2/3 | ZTE | Rel-11 | 53 | Maurice | SaMOG_WLAN |  | WLAN |  |  |
| 6290 | 2099.1 | Stage 2 for S2a Mobility based On GTP and WLAN access to EPC | 121d? | 2011-09-22 A | 2012-03-07 A | 100% | 2011-09-22 | 2012-03-07 | 121d? | finish no earlier than 2012-03-07 | S2 | 968h | 968h | SaMOG_WLAN | 27 | 23.002; 23.203; 23.402 | ZTE | Rel-11 | 53 | Maurice |  |  | WLAN |  |  |
| 6291 | 2099.2 | **CN aspects of Mobility based On GTP & PMIPv6 for WLAN access to EPC** | 853.25d? | 2011-12-02 A | 2014-03-05 A | 100% | 2011-12-02 | 2014-03-05 | 599d? |  | C4; C1; C3; IETF | 26992h | 26992h | SaMOG_WLAN-CN | 28 | Stage 3 | Alcatel-Lucent | Rel-11 | 54 | Kimmo | SaMOG_WLAN-CN |  | WLAN |  |  |
| 6292 | 2099.2.1 | CT4 part of CN aspects of Mobility based On GTP & PMIPv6 for WLAN access to EPC | 203d? | 2011-12-02 A | 2012-09-07 A | 100% | 2011-12-02 | 2012-09-07 | 203d? | finish no earlier than 2012-09-07 | C4 | 1608h | 1608h | SaMOG_WLAN-CN | 28 | 23.003; 23.007; 23.008; 29.273; 29.274; 29.281; 29.303 | Alcatel-Lucent | Rel-11 | 54 | Kimmo |  |  | WLAN |  |  |
| 6293 | 2099.2.2 | Deleted - (IETF) CT4 part of CN aspects of Mobility based On GTP & PMIPv6 for WLAN access to EPC | 498d? | 2012-04-23 A | 2014-03-05 A | 100% | 2012-04-23 | 2014-03-05 | 498d? | finish no earlier than 2014-03-05 | C4-IETF | 3960h | 3960h | SaMOG_WLAN-CN | 29 | draft-ietf-radext-ieee802ext | Lionel Morand | Rel-11 | 56 | Kimmo |  |  | WLAN | PCG-32 | CP-53 |
| 6294 | 2099.2.3 | Deleted - CT1 part of CN aspects of Mobility based On GTP & PMIPv6 for WLAN access to EPC | 142d? | 2011-12-02 A | 2012-06-15 A | 100% | 2011-12-02 | 2012-06-15 | 142d? | finish no earlier than 2012-06-15 | C1 | 1128h | 1128h | SaMOG_WLAN-CN | 28 | 24.302 | Alcatel-Lucent | Rel-11 | 54 | Frederic |  |  | WLAN | PCG-29 | CP-56 |
| 6295 | 2099.2.4 | CT3 part of CN aspects of Mobility based On GTP & PMIPv6 for WLAN access to EPC | 142d? | 2011-12-02 A | 2012-06-15 A | 100% | 2011-12-02 | 2012-06-15 | 142d? | finish no earlier than 2012-09-07 | C3 | 1128h | 1128h | SaMOG_WLAN-CN | 28 | 29.212; 29.213; 29.215 | Alcatel-Lucent | Rel-11 | 54 | Adrian |  |  | WLAN |  |  |
| 6296 | 2100 | **Roaming Architecture for Voice over IMS with Local Breakout** | 387.75d? | 2011-11-28 A | 2012-12-07 A | 100% | 2011-11-28 | 2012-12-07 | 273d? |  | S2; S5; C1; C3 | 16904h | 16904h | RAVEL | 28 | Stage 2/3 | Deutsche Telekom | Rel-11 | 54 | Maurice | RAVEL |  |  |  |  |
| 6297 | 2100.1 | Stage 2 for Roaming Architecture for Voice over IMS with Local Breakout | 12d? | 2011-11-28 A | 2011-12-14 A | 100% | 2011-11-28 | 2011-12-14 | 12d? | finish no earlier than 2012-03-07 | S2 | 96h | 96h | RAVEL | 28 | 23.002; 23.228 | Deutsche Telekom | Rel-11 | 54 | Maurice |  |  |  |  |  |
| 6298 | 2100.2 | Charging for Roaming Architecture for Voice over IMS with Local Breakout | 196d? | 2011-12-14 A | 2012-09-12 A | 100% | 2011-12-14 | 2012-09-12 | 196d? | finish no earlier than 2012-09-12 | S5 | 1568h | 1568h | RAVEL-CH | 28 | 32.240; 32.260; 32.298; 32.299 | Nokia Siemens Networks | Rel-11 | 54 | Mirko | RAVEL-CH |  |  |  |  |
| 6299 | 2100.3 | **CT aspects of Roaming Architecture for Voice over IMS with Local Breakout (Stage 3)** | 290.5d? | 2012-03-02 A | 2012-12-07 A | 100% | 2012-03-02 | 2012-12-07 | 205d? |  | C1; C3 | 6504h | 6504h | RAVEL-CT | 28 | Stage 3 | Deutsche Telekom | Rel-11 | 55 | Frederic | RAVEL-CT |  |  |  |  |
| 6300 | 2100.3.1 | CT1 part of CT aspects of Roaming Architecture for Voice over IMS with Local Breakout | 204d? | 2012-03-02 A | 2012-12-07 A | 100% | 2012-03-02 | 2012-12-07 | 204d? | finish no earlier than 2012-12-07 | C1 | 1608h | 1608h | RAVEL-CT | 28 | 24.229; 24.292; 24.237 | Deutsche Telekom | Rel-11 | 55 | Frederic |  |  |  |  |  |
| 6301 | 2100.3.2 | CT3 part of CT aspects of Roaming Architecture for Voice over IMS with Local Breakout | 204d? | 2012-03-02 A | 2012-12-07 A | 100% | 2012-03-02 | 2012-12-07 | 204d? | finish no earlier than 2012-12-07 | C3 | 1616h | 1616h | RAVEL-CT | 28 | 29.165; 29.162; 29.079 | Deutsche Telekom | Rel-11 | 55 | Adrian |  |  |  |  |  |
| 6302 | 2101 | **IMS Overload Control** | 935.75d? | 2012-06-18 A | 2014-12-09 A | 100% | 2012-06-18 | 2014-12-05 | 654d? |  | S2; C1; C3; IETF | 52408h | 52408h | IOC | 29 | Stage 2/3 | Orange, China Mobile | Rel-11 | 56 | Maurice | IOC |  |  |  |  |
| 6303 | 2101.1 | Stage 2 for IMS Overload Control | 64d? | 2012-06-18 A | 2012-09-12 A | 100% | 2012-06-18 | 2012-09-12 | 64d? | finish no earlier than 2012-09-12 | S2 | 504h | 504h | IOC | 29 | 23.228 | Orange, China Mobile | Rel-11 | 56 | Maurice |  |  |  |  |  |
| 6304 | 2101.2 | **Stage 3 for IMS Overload Control** | 854.12d? | 2012-09-05 A | 2014-12-09 A | 100% | 2012-09-05 | 2014-12-05 | 596d? |  | C1; C3; IETF | 30816h | 30816h | IOC | 29 |  | Alcatel-Lucent | Rel-11 | 57 | Frederic |  |  |  |  |  |
| 6305 | 2101.2.1 | CT1 part of Stage 3 for IMS Overload Control | 70d? | 2012-09-05 A | 2012-12-07 A | 100% | 2012-09-05 | 2012-12-07 | 70d? | finish no earlier than 2012-12-07 | C1 | 544h | 544h | IOC | 29 | 24.229 | Alcatel-Lucent | Rel-11 | 57 | Frederic |  |  |  |  |  |
| 6306 | 2101.2.2 | CT3 part of Stage 3 for IMS Overload Control | 70d? | 2012-09-05 A | 2012-12-07 A | 100% | 2012-09-05 | 2012-12-07 | 70d? | finish no earlier than 2012-12-07 | C3 | 552h | 552h | IOC | 29 | 29.165 | Alcatel-Lucent | Rel-11 | 57 | Adrian |  |  |  |  |  |
| 6307 | 2101.2.3 | (IETF) CT part of Stage 3 for IMS Overload Control (soc-overload-control) | 361d? | 2013-07-29 A | 2014-12-09 A | 100% | 2013-07-29 | 2014-12-05 | 359d? | finish no earlier than 2014-12-09 | C1-IETF; C3-IETF | 5776h | 5776h | IOC | 29 | RFC 7339 | Keith Drage | Rel-11 | 57 | Frederic |  |  |  |  |  |
| 6308 | 2101.2.4 | (IETF) CT part of Stage 3 for IMS Overload Control (soc-overload-rate-control) | 361d? | 2013-07-29 A | 2014-12-09 A | 100% | 2013-07-29 | 2014-12-05 | 359d? | finish no earlier than 2014-12-09 | C1-IETF; C3-IETF | 5776h | 5776h | IOC | 29 | RFC 7415 | Keith Drage | Rel-11 | 57 | Frederic |  |  |  |  |  |
| 6309 | 2101.2.5 | (IETF) CT part of Stage 3 for IMS Overload Control (RFC 7200) | 234d? | 2013-07-29 A | 2014-06-13 A | 100% | 2013-07-29 | 2014-06-13 | 234d? | finish no earlier than 2014-06-13 | C1-IETF; C3-IETF | 3744h | 3744h | IOC | 29 | RFC 7200 (was draft-ietf-soc-load-control-event-package) | Keith Drage | Rel-11 | 57 | Frederic |  |  |  |  |  |
| 6310 | 2102 | Rel-11 Security small Enhancements | 336d? | 2011-06-08 A | 2012-09-12 A | 100% | 2011-06-08 | 2012-09-12 | 336d? | finish no earlier than 2012-09-12 | S3 | 2680h | 2680h | SEC11 | 27 |  |  | Rel-11 | 52 | Mirko | SEC11 |  |  |  |  |
| 6311 | 2103 | Lawful Interception in the 3GPP Rel-11 | 272d? | 2011-06-10 A | 2012-06-20 A | 100% | 2011-06-10 | 2012-06-20 | 272d? | finish no earlier than 2012-06-20 | S3 | 2176h | 2176h | LI11 | 27 | 33.106; 33.107; 33.108 | PIDS, Alcatel-Lucent | Rel-11 | 52 | Mirko | LI11 |  |  |  |  |

Notes:
- 6286: RP#58 completed / WI rapporteur e-mail: liwei.qiu@huawei.com
- 6287: RP#58 completed / WI rapporteur e-mail: liwei.qiu@huawei.com
- 6288: ¦Stat Rep: RP-141167->RP-141771 1st Apr 15: Compl:40%->100% 1st Apr 15: Stat Rep: RP-141771->RP-150133 / WI rapporteur e-mail: calle.hagenfeldt@ericsson.com
- 6289: Triggered by Rel-11 TR 23.852 FS_SaMOG UID_510061, Rel-8 UID_350027 SAE for support for non-3GPP accesses (defines PMIP-S2a) / WI rapporteur e-mail: Chunhui Zhu (zhu.chunhui@zte.com.cn)
- 6290: SP#55 completed / WI rapporteur e-mail: zhu.chunhui@zte.com.cn
- 6291: - / WI rapporteur e-mail: bruno.landais@alcatel-lucent.com
- 6292: CP#57 completed / WI rapporteur e-mail: bruno.landais@alcatel-lucent.com
- 6293: CP#63 Draft removed from 3GPP documentation
- 6294: CP#56 stopped (no CT1 impact) / WI rapporteur e-mail: bruno.landais@alcatel-lucent.com
- 6295: CP#56 completed / WI rapporteur e-mail: bruno.landais@alcatel-lucent.com
- 6296: CP#58 completed. Triggered by Rel-11 TR 23.850 Study on Roaming Architecture for Voice over IMS with Local Breakout (FS_RAVEL). GSMA CPWP LS_in S5-102806 asked 3GPP SA5 to check if CS voice charging principles also apply to voice over IMS / WI rapporteur e-mail: michele.zarri@telekom.com
- 6297: SP#54 completed / WI rapporteur e-mail: michele.zarri@telekom.com
- 6298: Stage 2/3. SP#57 completed / WI rapporteur e-mail: Gerald.Goermer@nsn.com
- 6299: CP#58 completed / WI rapporteur e-mail: reinhard.lauster@)t-mobile.at
- 6300: CP#58 completed / WI rapporteur e-mail: reinhard.lauster@)t-mobile.at
- 6301: CP#58 completed / WI rapporteur e-mail: reinhard.lauster@)t-mobile.at
- 6302: SP#57 Stage 2 completed. Moved Rel-12=>Rel-11 as CT finished Stage 3. Linked to UID_410041 Study on IMS Evolution (TR 23.812). Solutions from IETF SOC WG and existing 3GPP procedures to be re-used if possible & backward compatibility ensured / WI rapporteur e-mail: Antoine MOUQUET, YU Qing
- 6303: SP#57 completed. Moved Rel-12=>Rel-11 as CT finished Stage 3. / WI rapporteur e-mail: antoine.mouquet@orange-ftgroup.com, YU Qing
- 6304: - / WI rapporteur e-mail: Keith Drage
- 6305: CP#58 completed / WI rapporteur e-mail: Keith Drage
- 6306: CP#58 completed / WI rapporteur e-mail: Keith Drage
- 6307: in RFC Ed-queue. Dec.14: 75->100. Mar15: impacted spec updated (was draft-ietf-soc-overload-control). Jun 15: RFC 7339 (was draft-ietf-soc-overload-control) / WI rapporteur e-mail: Keith Drage
- 6308: Submitted to IESG for publication. Dec14: 50->90%. Mar15: 100%. Impacted RFC updated (was draft-ietf-soc-overload-rate-control). Jun 15: RFC 7415 (was draft-ietf-soc-overload-rate-control) / WI rapporteur e-mail: Keith Drage
- 6309: CP#64 completed / WI rapporteur e-mail: Keith Drage
- 6310: SEC11 is an umbrella Feature for Security related TEI11 type of changes that are not part of any other dedicated feature
- 6311: Stage 1/2/3. SP#56 completed / WI rapporteur e-mail: Koen Jaspers (k.b.jaspers@minjus.nl), terry.jacobson@alcatel-lucent.com

| ID | WBS | Task | Duration | Start | Finish | Complete | Baseline start | Baseline finish | Baseline duration | Constraint | Resources | Work | Actual work | Acronym | PCG approved | WI rapporteur name | Release | TSG approved | MCC resp | Acronym_3GU_Export | Status Report | Special Focus Doc |
| --- | --- | --- | --- | --- | --- | --- | --- | --- | --- | --- | --- | --- | --- | --- | --- | --- | --- | --- | --- | --- | --- | --- |
| 6312 | 2104 | **ZUC EEA3 and EIA3 (new Encryption & Integrity EPS security Algorithms)** | 1233.88d? | 2009-06-04 A | 2012-09-07 A | 100% | 2009-06-04 | 2012-09-07 | 857d? |  | S3; R5 | 19488h | 19488h | EEA3_EIA3 | 23 | CATR | Rel-11 | 44 | Mirko | EEA3_EIA3 |  |  |
| 6313 | 2104.1 | ZUC EEA3 and EIA3 | 663d? | 2009-06-04 A | 2011-12-14 A | 100% | 2009-06-04 | 2011-12-14 | 663d? | finish no earlier than 2011-09-21 | S3 | 5288h | 5288h | EEA3_EIA3 | 23 | CATR | Rel-11 | 44 | Mirko |  |  |  |
| 6314 | 2104.2 | Conformance Test Aspects – ZUC (EEA3 and EIA3 Encryption & Integrity EPS security Algorithms) | 61d? | 2012-06-18 A | 2012-09-07 A | 100% | 2012-06-18 | 2012-09-07 | 61d? | finish no earlier than 2013-03-01 | R5 | 488h | 488h | EEA3_EIA3_UEConTest | 29 | CATR | Rel-11 | 56 | Ingbert | EEA3_EIA3_UEConTest | RP-120968 |  |
| 6315 | 2105 | Specification of Protection against Unsolicited Communication for IMS (produced TR-only) | 456d? | 2010-06-10 A | 2012-03-07 A | 100% | 2010-06-10 | 2012-03-07 | 456d? | finish no earlier than 2012-03-07 | S3 | 3640h | 3640h | SPUCI | 25 | NEC | Rel-11 | 48 | Mirko | SPUCI |  |  |
| 6316 | 2106 | H(e)NB security features for UE mobility scenarios (Stage 2) | 252d? | 2011-03-23 A | 2012-03-07 A | 100% | 2011-03-23 | 2012-03-07 | 252d? | finish no earlier than 2012-03-07 | S3 | 2008h | 2008h | HNB_mob_Sec | 26 | Huawei | Rel-11 | 51 | Mirko | HNB_mob_Sec |  | HNB |
| 6317 | 2107 | **Generic Bootstrapping Architecture (GBA) extensions for re-use of SIP Digest credentials** | 290.75d? | 2011-12-02 A | 2012-09-07 A | 100% | 2011-12-02 | 2012-09-07 | 203d? |  | S3; C4; C1 | 11824h | 11824h | GBA-ext | 28 | Nokia | Rel-11 | 54 | Mirko | GBA-ext |  |  |
| 6318 | 2107.1 | Stage 2 for GBA extensions for re-use of SIP Digest credentials | 61d? | 2011-12-14 A | 2012-03-07 A | 100% | 2011-12-14 | 2012-03-07 | 61d? | finish no earlier than 2012-02-28 | S3 | 488h | 488h | GBA-ext | 28 | Nokia | Rel-11 | 54 | Mirko |  |  |  |
| 6319 | 2107.2 | **Stage 3 for GBA extensions for re-use of SIP Digest credentials** | 290.75d? | 2011-12-02 A | 2012-09-07 A | 100% | 2011-12-02 | 2012-09-07 | 203d? |  | C4; C1 | 6464h | 6464h | GBA-ext-St3 | 28 | Alcatel-Lucent | Rel-11 | 54 | Kimmo | GBA-ext-St3 |  |  |
| 6320 | 2107.2.1 | CT4 part of Stage 3 for GBA extensions for re-use of SIP Digest credentials | 203d? | 2011-12-02 A | 2012-09-07 A | 100% | 2011-12-02 | 2012-09-07 | 203d? | finish no earlier than 2012-09-07 | C4 | 1608h | 1608h | GBA-ext-St3 | 28 | Alcatel-Lucent | Rel-11 | 54 | Kimmo |  |  |  |
| 6321 | 2107.2.2 | CT1 part of Stage 3 for GBA extensions for re-use of SIP Digest credentials | 202d? | 2011-12-05 A | 2012-09-07 A | 100% | 2011-12-05 | 2012-09-07 | 202d? | finish no earlier than 2012-09-07 | C1 | 1608h | 1608h | GBA-ext-St3 | 28 | Alcatel-Lucent | Rel-11 | 54 | Frederic |  |  |  |
| 6322 | 2108 | Extensions of Acoustic Test Specifications in TS 26.131 and TS 26.132 | 332d? | 2011-06-08 A | 2012-09-12 A | 100% | 2011-06-08 | 2012-09-12 | 332d? | finish no earlier than 2012-09-12 | S4 | 2648h | 2648h | Ext_ATS | 27 | Orange, Qualcomm | Rel-11 | 52 | Paolo | Ext_ATS |  |  |
| 6323 | 2109 | **Enhancements to Multimedia: PSS, MMS, and MBMS Enhancements and Performance Improvements** | 565.75d? | 2011-09-07 A | 2013-03-06 A | 100% | 2011-09-07 | 2013-03-06 | 397d? |  | S4 | 10928.6h | 10928.6h | EMM | 27 | Qualcomm | Rel-11 | 53 | Paolo | EMM |  |  |
| 6324 | 2109.1 | Enhancement to FEC for MBMS | 386d? | 2011-09-21 A | 2013-03-06 A | 100% | 2011-09-21 | 2013-03-06 | 386d? | finish no earlier than 2013-03-06 | S4 | 3048h | 3048h | EMM-EFEC | 27 | Qualcomm | Rel-11 | 53 | Paolo | EMM-EFEC |  |  |
| 6325 | 2109.2 | Download Delivery Enhancements for MBMS | 325d? | 2011-09-21 A | 2012-12-12 A | 100% | 2011-09-21 | 2012-12-12 | 325d? | finish no earlier than 2012-12-12 | S4 | 2576.59h | 2576.59h | EMM-DDE | 27 | Qualcomm | Rel-11 | 53 | Paolo | EMM-DDE |  |  |
| 6326 | 2109.3 | IMS-based PSS and MBMS Streaming Synchronization Enhancements | 268d? | 2011-09-07 A | 2012-09-12 A | 100% | 2011-09-07 | 2012-09-12 | 268d? | finish no earlier than 2012-09-12 | S4 | 2128h | 2128h | EMM-IPME | 27 | InterDigital Communications | Rel-11 | 53 | Paolo | EMM-IPME |  |  |
| 6327 | 2110 | Mobile 3D Video Coding | 71d? | 2012-06-07 A | 2012-09-12 A | 100% | 2012-06-07 | 2012-09-12 | 71d? | finish no earlier than 2012-09-12 | S4 | 560h | 560h | M3DV | 29 | Orange | Rel-11 | 56 | Paolo | M3DV |  |  |
| 6328 | 2111 | **Rel-11 Operations, Administration, Maintenance and Provisioning (OAM&P)** | 739.5d? | 2011-03-23 A | 2013-03-06 A | 100% | 2011-03-23 | 2013-03-06 | 519d? |  | S5 | 39394.5h | 39394.5h | OAM11 | 26 |  | Rel-11 | 51 | Mirko | OAM11 |  |  |
| 6329 | 2111.1 | **Rel-11 Network Infrastructure Management** | 739.5d? | 2011-03-23 A | 2013-03-06 A | 100% | 2011-03-23 | 2013-03-06 | 519d? |  | S5 | 8256h | 8256h | OAM11-NIM | 26 |  | Rel-11 | 51 | Mirko | OAM11-NIM |  |  |
| 6330 | 2111.1.1 | IRP framework enhancements to support Management of Converged Networks | 515d? | 2011-03-23 A | 2013-03-06 A | 100% | 2011-03-23 | 2013-03-06 | 515d? | finish no earlier than 2013-03-06 | S5 | 4104h | 4104h | OAM-FMC-IRP | 26 | Nokia Siemens Networks, Ericsson | Rel-11 | 51 | Mirko | OAM-FMC-IRP |  |  |
| 6331 | 2111.2 | **Rel-11 Performance Management** | 652.62d? | 2011-03-23 A | 2012-12-12 A | 100% | 2011-03-23 | 2012-12-12 | 458d? |  | S5 | 14530.5h | 14530.5h | OAM11-PM | 26 |  | Rel-11 | 51 | Mirko | OAM11-PM |  |  |
| 6332 | 2111.2.1 | IMS Performance Management enhancements | 252d? | 2011-03-23 A | 2012-03-07 A | 100% | 2011-03-23 | 2012-03-07 | 252d? | finish no earlier than 2012-09-12 | S5 | 2010.52h | 2010.52h | OAM-ePM-IMS | 26 | ZTE | Rel-11 | 51 | Mirko | OAM-ePM-IMS |  |  |
| 6333 | 2111.2.2 | Enhanced Management of UE based network performance measurements | 455d? | 2011-03-23 A | 2012-12-12 A | 100% | 2011-03-23 | 2012-12-12 | 455d? | finish no earlier than 2012-12-12 | S5 | 3624h | 3624h | OAM-ePM-UE | 26 | Huawei, Ericsson, Nokia Siemens Networks | Rel-11 | 51 | Mirko | OAM-ePM-UE |  |  |
| 6334 | 2111.2.3 | CN performance measurements enhancement | 334d? | 2011-06-08 A | 2012-09-12 A | 100% | 2011-06-08 | 2012-09-12 | 334d? | finish no earlier than 2012-09-12 | S5 | 2648h | 2648h | OAM-ePM-CN | 27 | China Mobile | Rel-11 | 52 | Mirko | OAM-ePM-CN |  |  |
| 6335 | 2111.2.4 | Management of Carrier Aggregation for LTE | 325d? | 2011-09-21 A | 2012-12-12 A | 100% | 2011-09-21 | 2012-12-12 | 325d? | finish no earlier than 2012-12-12 | S5 | 2584h | 2584h | OAM-CA | 27 | Nokia Siemens Networks, Ericsson | Rel-11 | 53 | Mirko | OAM-CA |  | CA |

Notes:
- 6312: RP#57 completed testing / WI rapporteur e-mail: Yuan Qi (yuanqi@catr.cn)
- 6313: SP#53 completed new EPS algorithms e.g. for China / Impacted TSs and TRs: 33.401; New (35.221; 35.222; 35.223; 35.924) / WI rapporteur e-mail: Yuan Qi (yuanqi@catr.cn)
- 6314: RP#57 completed. Testing for SA3 TSs 33.401, new (35.221, 35.222, 35.223) / Impacted TSs and TRs: 36.523-1; 36.523-2; 36.523-3 / WI rapporteur e-mail: Ms Jun Chen (chenjun@catr.cn)
- 6315: SP#55 completed (No normative work). TR 33.838v200 for Approval & abandoned new TS 33.237. Continuation of Rel-9 UID_410027/410029. Builds on TR 33.937 Study of Mechanisms for PUCI / Impacted TSs and TRs: New 33.838; abandoned New 33.237 / WI rapporteur e-mail: Anand R. Prasad (anand@bq.jp.nec.com)
- 6316: SP#55 completed. Add HeNB Security extensions to Extended H(e)NB Features (EHNBF) UID_450053 / Impacted TSs and TRs: 33.320 / WI rapporteur e-mail: Marcus Wong (mwong@huawei.com)
- 6317: Stage 2/3. CP#57 completed / WI rapporteur e-mail: Silke.Holtmanns@nokia.com
- 6318: SP#55 completed / Impacted TSs and TRs: 33.220 / WI rapporteur e-mail: Silke.Holtmanns@nokia.com
- 6319: CP#57 completed / Impacted TSs and TRs: Stage 3 / WI rapporteur e-mail: jean-jacques.trottin@alcatel-lucent.com
- 6320: CP#57 completed / Impacted TSs and TRs: 29.109 / WI rapporteur e-mail: jean-jacques.trottin@alcatel-lucent.com
- 6321: CP#57 completed / Impacted TSs and TRs: 24.109 / WI rapporteur e-mail: jean-jacques.trottin@alcatel-lucent.com
- 6322: SP#57 completed / Impacted TSs and TRs: 26.131; 26.132 / WI rapporteur e-mail: stephane.ragot@orange-ftgroup.com, Andre Schevciw (aschevci@qualcomm.com)
- 6323: Stage 3. SP#59 completed / Impacted TSs and TRs: 26.140; 26.234; 26.247; New 26.951=>26.851 / WI rapporteur e-mail: Nikolai Leung (nleung@qualcomm.com)
- 6324: SP#59 completed / Impacted TSs and TRs: 26.346; new 26.947 / WI rapporteur e-mail: Thomas Stockhammer (c_tstock@qualcomm.com)
- 6325: SP#58 completed / Impacted TSs and TRs: 26.346; new 26.951=>26.851 / WI rapporteur e-mail: Nikolai Leung (nleung@qualcomm.com)
- 6326: SP#58 completed / Impacted TSs and TRs: 26.237; new 26.951=>26.851 / WI rapporteur e-mail: hang.liu@interdigital.com
- 6327: SP#57 completed. Triggered by UID_520036 Rel-11 Study on Mobile 3D Video Coding (FS_M3DVC) TR 26.905. / Impacted TSs and TRs: 26.140; 26.234; 26.244; 26.245; 26.247; 26.346; 26.430; 26.905 / WI rapporteur e-mail: gilles.teniou@orange.com
- 6328: OAM11 is an umbrella Feature also for OAM&P related TEI11 type of changes that are not part of any other dedicated feature/WI
- 6329: -
- 6330: SP#59 completed. Triggered by SA5 Studies TR 32.833, 32.828, 32.831 / Impacted TSs and TRs: 32.101/103/150; new (28.620/621/622/623/624/625/626/627/628/629/631/632/633/651/652/653/654/655/656/657/658/659/661/662/663/671/672/673/674/675/676/701/702/703/704/705/706/707/708/709/731/732/733/734/735/736/751/752/753; 32.107/156/157/853/854 / WI rapporteur e-mail: thomas.tovinger@ericsson.com, olaf.pollakowski@nsn.com
- 6331: -
- 6332: SP#55 completed / Impacted TSs and TRs: 32.409 / WI rapporteur e-mail: guo.wenjie1@zte.com.cn
- 6333: SP#58 completed / Impacted TSs and TRs: 32.421; 32.422; 32.423; 32.441; 32.442; 32.446 / WI rapporteur e-mail: Zou Lan (zlan@huawei.com), ulf.hubinette@ericsson.com, gyula.bodog@nsn.com
- 6334: SP#57 completed / Impacted TSs and TRs: 32.406; 32.407; 32.426 / WI rapporteur e-mail: Liang Shuangchun (liangshuangchun@cmdi.chinamobile.com), Li Jian (lijian@chinamobile.com)
- 6335: SP#58 completed. Updated WID SP-110636=>SP-120776. Stage 2 in Rel-10 RAN Feature UID_460007 Carrier Aggregation for LTE (LTE_CA) / Impacted TSs and TRs: 32.425 / WI rapporteur e-mail: yizhi.yao@nsn.com, per.elmdahl@ericsson.com

| ID | WBS | Task | Type | Duration | Start | Finish | Complete | Baseline start | Baseline finish | Baseline duration | Constraint | Resources | Work | Actual work | Acronym | PCG approved | Release | TSG approved | MCC resp | Special Focus Doc | Acronym_3GU_Export | WI rapporteur name | WI rapporteur e-mail |
| --- | --- | --- | --- | --- | --- | --- | --- | --- | --- | --- | --- | --- | --- | --- | --- | --- | --- | --- | --- | --- | --- | --- | --- |
| 6336 | 2111.3 | **Rel-11 Self-Organizing Networks (SON) - OAM aspects** |  | 739.5d? | 2011-03-23 A | 2013-03-06 A | 100% | 2011-03-23 | 2013-03-06 | 519d? |  | S5 | 12456h | 12456h | OAM11-SON | 26 | Rel-11 | 51 | Mirko | SON | OAM11-SON |  |  |
| 6337 | 2111.3.1 | UTRAN Self-Organizing Networks (SON) management |  | 388d? | 2011-03-23 A | 2012-09-12 A | 100% | 2011-03-23 | 2012-09-12 | 388d? | finish no earlier than 2012-09-12 | S5 | 3088h | 3088h | OAM-SON-UTRAN | 26 | Rel-11 | 51 | Mirko | SON | OAM-SON-UTRAN | Huawei | kai.zhangkai@huawei.com |
| 6338 | 2111.3.2 | LTE Self-Organizing Networks (SON) coordination management |  | 387d? | 2011-09-21 A | 2013-03-06 A | 100% | 2011-09-21 | 2013-03-06 | 387d? | finish no earlier than 2013-03-06 | S5 | 3072h | 3072h | OAM-SON-LTE_COORD | 27 | Rel-11 | 53 | Mirko | SON | OAM-SON-LTE_COORD | Huawei, Nokia Siemens Networks | kai.zhangkai@huawei.com, clemens.suerbaum@nsn.com |
| 6339 | 2111.3.3 | Inter-RAT Energy Saving Management |  | 269d? | 2011-12-07 A | 2012-12-12 A | 100% | 2011-12-07 | 2012-12-12 | 269d? | finish no earlier than 2012-12-12 | S5 | 2144h | 2144h | OAM-IRAT-ESM | 28 | Rel-11 | 54 | Mirko | SON | OAM-IRAT-ESM | Nokia Siemens Networks, Huawei | clemens.suerbaum@nsn.com, xiahaitao@huawei.com |
| 6340 | 2112 | **Rel-11 Charging Management small Enhancements** |  | 1028.62d? | 2010-03-25 A | 2012-12-12 A | 100% | 2010-03-25 | 2012-12-12 | 717d? |  | S5 | 11528h | 11528h | CH11 | 26 | Rel-11 | 51 | Mirko |  | CH11 |  |  |
| 6341 | 2112.1 | Add solutions for Rc - reference point within the Online Charging System (OCS) |  | 392d? | 2010-03-25 A | 2011-09-21 A | 100% | 2010-03-25 | 2011-09-21 | 392d? | finish no earlier than 2011-08-26 | S5 | 3120h | 3120h | CH-Rc | 24 | Rel-11 | 47 | Mirko |  | CH-Rc | Huawei | shan.mingjun@huawei.com |
| 6342 | 2112.2 | Charging for Policy Enhancements for Sponsored Connectivity and Coherent Access to Policy related Data Bases |  | 135d? | 2011-03-21 A | 2011-09-21 A | 100% | 2011-03-21 | 2011-09-21 | 135d? | finish no earlier than 2011-09-21 | S5 | 1064h | 1064h | PEST-CH | 26 | Rel-11 | 51 | Mirko |  | PEST-CH | Ericsson | patrik.teppo@@ericsson.com |
| 6343 | 2112.3 | Unification of Charging session from SIP AS and SRVCC functions in IMS |  | 203d? | 2012-03-07 A | 2012-12-12 A | 100% | 2012-03-07 | 2012-12-12 | 203d? | finish no earlier than 2012-12-12 | S5 | 1608h | 1608h | UCHIMS_AS-SRVCC | 28 | Rel-11 | 55 | Mirko |  | UCHIMS_AS-SRVCC | Alcatel-Lucent | maryse.gardella@alcatel-lucent.com |
| 6344 | 2113 | **Transit Inter Operator Identifier for IMS Interconnection Charging in multi operator environment** |  | 618.75d? | 2010-10-27 A | 2012-06-15 A | 100% | 2010-10-27 | 2012-06-15 | 432d? |  | S5; S1; C1 | 15921.1h | 15921.1h | IOI_IMS_CH | 26 | Rel-11 | 51 | Mirko |  | IOI_IMS_CH | Deutsche Telekom | matthias.seibel@telekom.de |
| 6345 | 2113.1 | Stage 1 for Transit Inter Operator Identifier for IMS Interconnection Charging in multi operator environment |  | 237d? | 2010-10-27 A | 2011-09-21 A | 100% | 2010-10-27 | 2011-09-21 | 237d? |  | S1 | 1896h | 1896h | IOI_IMS_CH | 26 | Rel-11 | 51 | Dionisio |  |  | Deutsche Telekom | matthias.seibel@telekom.de |
| 6346 | 2113.2 | Stage 2/3 SA5 part of Transit Inter Operator Identifier for IMS Interconnection Charging in multi operator environment |  | 187d? | 2010-10-27 A | 2011-12-07 A | 100% | 2010-10-27 | 2011-12-07 | 187d? | finish no earlier than 2012-03-21 | S5 | 1488h | 1488h | IOI_IMS_CH | 26 | Rel-11 | 51 | Mirko |  |  | Deutsche Telekom | matthias.seibel@telekom.de |
| 6347 | 2113.3 | Stage 3 for Transit Inter Operator Identifier for IMS Interconnection Charging in multi operator environment |  | 273d? | 2011-06-07 A | 2012-06-15 A | 100% | 2011-06-07 | 2012-06-15 | 273d? | finish no earlier than 2012-06-01 | C1 | 2169.09h | 2169.09h | IOI_IMS_CH | 27 | Rel-11 | 52 | Frederic |  |  | Deutsche Telekom | martin.huelsemann@telekom.de] |
| 6348 | 2114 | **User Data Convergence - Data Model** |  | 929.38d? | 2010-03-25 A | 2012-09-07 A | 100% | 2010-03-25 | 2012-09-07 | 647d? |  | C4; S1 | 22984h | 22984h | UDC_DM | 25 | Rel-11 | 48 | Kimmo |  | UDC_DM | Telecom Italia | mauro.ficaccio@telecomitalia.it |
| 6349 | 2114.1 | Stage 1 for UDC Data Model |  | 392d? | 2010-03-25 A | 2011-09-21 A | 100% | 2010-03-25 | 2011-09-21 | 392d? | finish no earlier than 2010-06-10 | S1 | 3136h | 3136h | UDC_DM | 25 | Rel-11 | 48 | Alain |  |  | Telecom Italia | mauro.ficaccio@telecomitalia.it |
| 6350 | 2114.2 | TR on User Data Convergence (UDC) Data Model |  | 593d? | 2010-06-04 A | 2012-09-07 A | 100% | 2010-06-04 | 2012-09-07 | 593d? | finish no earlier than 2012-09-07 | C4 | 4736h | 4736h | UDC_DM | 25 | Rel-11 | 48 | Kimmo |  |  | Telecom Italia | mauro.ficaccio@telecomitalia.it |
| 6351 | 2114.3 | User Data Convergence (UDC) Data Model |  | 596d? | 2010-06-04 A | 2012-09-07 A | 100% | 2010-06-04 | 2012-09-07 | 596d? | finish no earlier than 2012-09-07 | C4 | 4760h | 4760h | UDC_DM | 25 | Rel-11 | 48 | Kimmo |  |  | Telecom Italia | mauro.ficaccio@telecomitalia.it |
| 6352 | 2115 | Definition of the UICC Application for Hosting Party Module |  | 327d? | 2011-03-18 A | 2012-06-15 A | 100% | 2011-03-18 | 2012-06-15 | 327d? | finish no earlier than 2012-06-15 | C6 | 2608h | 2608h | HPM_UICC | 26 | Rel-11 | 51 | Xavier |  | HPM_UICC | Gemalto | Denis.Lheriteau@gemalto.com |
| 6353 | 2116 | Usability improvement of Inter-IMS Network to Network Interface (II-NNI) specification for inter-connection by means of Option Item list |  | 273d? | 2011-06-07 A | 2012-06-15 A | 100% | 2011-06-07 | 2012-06-15 | 273d? | finish no earlier than 2012-06-01 | C3 | 2169.56h | 2169.56h | NNI_OI | 27 | Rel-11 | 52 | Adrian |  | NNI_OI | NTT | arai.kenjiro@lab.ntt.co.jp |
| 6354 | 2117 | **enhanced Nodes Restoration for EPC (Stage 2/3)** |  | 949.25d? | 2011-06-03 A | 2013-12-06 A | 100% | 2011-06-03 | 2013-12-06 | 668d? |  | C4; C1; C3; IETF | 27728h | 27728h | eNR_EPC | 27 | Rel-11 | 52 | Kimmo |  | eNR_EPC | ZTE | lu.fei1@zte.com.cn |
| 6355 | 2117.1 | CT4 part of enhanced Nodes Restoration for EPC |  | 402d? | 2011-06-03 A | 2012-12-07 A | 100% | 2011-06-03 | 2012-12-07 | 402d? | finish no earlier than 2012-12-07 | C4 | 3192h | 3192h | eNR_EPC | 27 | Rel-11 | 52 | Kimmo |  |  | ZTE | lu.fei1@zte.com.cn |
| 6356 | 2117.2 | (IETF) CT4 part of enhanced Nodes Restoration for EPC (RFC 7077) |  | 266d? | 2012-12-07 A | 2013-12-06 A | 100% | 2012-12-07 | 2013-12-06 | 266d? | finish no earlier than 2013-12-06 | C4-IETF | 2104h | 2104h | eNR_EPC | 30 | Rel-11 | 58 | Kimmo |  |  | Lionel Morand | Lionel Morand |
| 6357 | 2117.3 | CT1 part of enhanced Nodes Restoration for EPC |  | 66d? | 2011-12-02 A | 2012-03-02 A | 100% | 2011-12-02 | 2012-03-02 | 66d? | finish no earlier than 2012-06-15 | C1 | 528h | 528h | eNR_EPC | 28 | Rel-11 | 54 | Frederic |  |  | ZTE | lu.fei1@zte.com.cn |
| 6358 | 2117.4 | CT3 part of enhanced Nodes Restoration for EPC |  | 67d? | 2012-09-10 A | 2012-12-07 A | 100% | 2012-09-10 | 2012-12-07 | 67d? | finish no earlier than 2012-12-07 | C3 | 528h | 528h | eNR_EPC | 29 | Rel-11 | 57 | Adrian |  |  | ZTE | lu.fei1@zte.com.cn |
| 6359 | 2118 | **Reference Location Information (Stage 3)** |  | 109.5d? | 2011-06-03 A | 2011-09-16 A | 100% | 2011-06-03 | 2011-09-16 | 78d? |  | C4; C1 | 1860.74h | 1860.74h | RLI | 27 | Rel-11 | 52 | Kimmo |  | RLI | Huawei | susan.shishufeng@Huawei.com |
| 6360 | 2118.1 | CT4 part of Reference Location Information (Stage 3) | milestone | 0d? | 2011-06-03 A | 2011-06-03 A | 100% | 2011-06-03 | 2011-06-03 | 0d? | finish no earlier than 2011-06-03 | C4 |  |  | RLI | 27 | Rel-11 | 52 | Kimmo |  |  | Huawei | susan.shishufeng@Huawei.com |
| 6361 | 2118.2 | CT1 part of Reference Location Information (Stage 3) |  | 78d? | 2011-06-03 A | 2011-09-16 A | 100% | 2011-06-03 | 2011-09-16 | 78d? | finish no earlier than 2011-08-30 | C1 | 612.74h | 612.74h | RLI | 27 | Rel-11 | 52 | Frederic |  |  | Huawei | susan.shishufeng@Huawei.com |

Notes:
- 6336: -
- 6337: SP#57 completed. Updated WID SP-110518=>SP-120552 / Impacted TSs and TRs: UTRA 32.405; 32.500; 32.511; 32.521; 32.522; 32.526; 32.642; 32.646
- 6338: SP#59 completed / Impacted TSs and TRs: LTE 32.425; 32.500; 32.521; 32.522; 32.526; 32.762; 32.766
- 6339: SP#58 completed. Triggered by Rel-11 TR 32.834 (Study on OAM aspects of inter-RAT Energy Saving) UID_510045. Needs coordination with RAN WGs / Impacted TSs and TRs: 32.405; 32.551; 32.522; 32.526; 32.642; 32.646; 32.762; 32.766
- 6340: CH11 is an umbrella Feature also for OAM&P related TEI11 type of changes that are not part of any other dedicated feature/WI / Impacted TSs and TRs: 30.821
- 6341: SP#53 completed. Stage 3 (Stage 1 in 22.115). Triggered by Rel-10 TR 32.825 SA5 Study on Rc Reference Point Functionalities and Message Flows (UID_410044) / Impacted TSs and TRs: 32.296; 32.299
- 6342: SP#53 completed. Stage 3 / Impacted TSs and TRs: 32.251; 32.298; 32.299
- 6343: Stage 2/3. SP#58 completed / Impacted TSs and TRs: 32.260; 32.275; 32.298; 32.299
- 6344: Stage 2/3. CP#56 completed. Stage 1 in SA1 22.115
- 6345: SP#53 completed under IPXS / Impacted TSs and TRs: 22.115
- 6346: SP#54 completed / Impacted TSs and TRs: 32.240; 32.260; 32.298; 32.299
- 6347: CP#56 completed / Impacted TSs and TRs: 24.229
- 6348: CP#57 completed. SP#48 Stage 1 completed as Rel-10
- 6349: SP#53 completed under Rel-10 UDC / Impacted TSs and TRs: 22.101
- 6350: CP#57 completed / Impacted TSs and TRs: new 29.935
- 6351: CP#57 completed / Impacted TSs and TRs: 29.335
- 6352: CP#56 completed / Impacted TSs and TRs: 31.102; New 31.104
- 6353: CP#56 completed. Stage 3 (No architectural change, specify the list of selectable items related to control plane signalling directly for the same architecture) / Impacted TSs and TRs: 29.165
- 6354: Triggered by DRAFT TR 23.857 Study on EPC Nodes Restoration UID_490014
- 6355: CP#58 completed / Impacted TSs and TRs: 23.007; 23.008; 23.018; 29.274; 29.275
- 6356: CP#62 completed / Impacted TSs and TRs: RFC 7077 (was draft-ietf-netext-update-notifications)
- 6357: CP#55 completed / Impacted TSs and TRs: 29.118
- 6358: CP#58 completed / Impacted TSs and TRs: 29.212
- 6359: CP#53 completed. Stage 2 clause C.1.1 of SA2 TS 23.167 CR#0182 (WI code: TEI11)
- 6360: CP#52 completed / Impacted TSs and TRs: 23.008; 29.228; 29.328; 29.329
- 6361: CP#53 completed / Impacted TSs and TRs: 24.229

| ID | WBS | Task | Duration | Start | Finish | Complete | Baseline start | Baseline finish | Baseline duration | Constraint | Resources | Work | Actual work | Acronym | PCG approved | WI rapporteur name | WI rapporteur e-mail | Release | TSG approved | MCC resp | Acronym_3GU_Export | PCG stopped | TSG stopped | Special Focus Doc |
| --- | --- | --- | --- | --- | --- | --- | --- | --- | --- | --- | --- | --- | --- | --- | --- | --- | --- | --- | --- | --- | --- | --- | --- | --- |
| 6362 | 2119 | **IMS Stage 3 IETF Protocol Alignment - phase 5** | 1234.75d? | 2011-06-07 A | 2014-09-12 A | 100% | 2011-06-07 | 2014-12-05 | 927d? |  | C1; C3; IETF | 37516h | 37516h | IMSProtoc5 | 27 | Alcatel-Lucent | keith.drage@alcatel-lucent.com | Rel-11 | 52 | Frederic | IMSProtoc5 |  |  |  |
| 6363 | 2119.1 | CT1 part of IMS Stage 3 IETF Protocol Alignment - phase 5 | 333d? | 2011-06-07 A | 2012-09-07 A | 100% | 2011-06-07 | 2012-09-07 | 333d? | finish no earlier than 2012-09-07 | C1 | 2648h | 2648h | IMSProtoc5 | 27 | Alcatel-Lucent | keith.drage@alcatel-lucent.com | Rel-11 | 52 | Frederic |  |  |  |  |
| 6364 | 2119.2 | (IETF) CT1 part of IMS Stage 3 IETF Protocol Alignment - phase 5 (RFC 7315) | 356.5d? | 2013-03-01 A | 2014-09-12 A | 100% | 2013-03-01 | 2014-12-05 | 416.5d? | finish no earlier than 2014-09-12 | C1-IETF | 2812h | 2812h | IMSProtoc5 | 30 | Roland Jesske | Roland Jesske | Rel-11 | 59 | Frederic |  |  |  |  |
| 6365 | 2119.3 | (IETF) A P-Served-User Header Field Parameter for Originating CDIV session case in SIP (draft-ietf-sipcore-originating-cdiv-parameter) --> RFC 8498 | 407d? | 2013-03-01 A | 2014-09-12 A | 100% |  |  |  | finish no earlier than 2014-09-12 | C1-IETF | 3256h | 3256h | IMSProtoc5 | 41 | Roland Jesske | Roland Jesske | Rel-11 | 80 |  |  |  |  |  |
| 6366 | 2119.4 | (IETF) CT1 part of IMS Stage 3 IETF Protocol Alignment - phase 5 (RFC 7135) | 203d? | 2013-09-06 A | 2014-06-13 A | 100% | 2013-09-06 | 2014-06-13 | 203d? | finish no earlier than 2014-06-13 | C1-IETF | 1608h | 1608h | IMSProtoc5 | 31 | Roland Jesske | Roland Jesske | Rel-11 | 61 |  |  |  |  |  |
| 6367 | 2119.5 | CT3 part of IMS Stage 3 IETF Protocol Alignment - phase 5 | 333d? | 2011-06-07 A | 2012-09-07 A | 100% | 2011-06-07 | 2012-09-07 | 333d? | finish no earlier than 2012-09-07 | C3 | 2648h | 2648h | IMSProtoc5 | 27 | Alcatel-Lucent | keith.drage@alcatel-lucent.com | Rel-11 | 52 | Adrian |  |  |  |  |
| 6368 | 2119.6 | Deleted - (IETF) CT3 part of IMS Stage 3 IETF Protocol Alignment - phase 5 (avasarala-dispatch-comm-div-notification) | 466d? | 2012-12-07 A | 2014-09-12 A | 100% | 2012-12-07 | 2014-12-05 | 526d? | finish no earlier than 2014-09-12 | C3-IETF | 3712h | 3712h | IMSProtoc5 | 30 | Andrew Allen | Andrew Allen | Rel-11 | 58 | Adrian |  | PCG-33 | CP-65 |  |
| 6369 | 2120 | **Service Identification for RRC Improvements in GERAN (Stage 2/3)** | 367.12d? | 2011-09-19 A | 2012-09-07 A | 100% | 2011-09-19 | 2012-09-07 | 258d? |  | S2; C4; C3; G2 | 16216h | 16216h | SIRIG | 27 | China Mobile | zhanghao@chinamobile.com | Rel-11 | 51 | Maurice | SIRIG |  |  |  |
| 6370 | 2120.1 | Stage 2 for Service Identification for RRC Improvements in GERAN | 61d? | 2012-06-18 A | 2012-09-07 A | 100% | 2012-06-18 | 2012-09-07 | 61d? | finish no earlier than 2012-09-07 | S2 | 480h | 480h | SIRIG | 29 |  |  | Rel-11 | 56 | Maurice |  |  |  |  |
| 6371 | 2120.2 | **CN aspects of Service Identification for RRC Improvements in GERAN** | 290.75d? | 2011-12-02 A | 2012-09-07 A | 100% | 2011-12-02 | 2012-09-07 | 203d? |  | C4; C3 | 5464h | 5464h | SIRIG | 28 | China Mobile | zhanghao@chinamobile.com | Rel-11 | 54 | Kimmo |  |  |  |  |
| 6372 | 2120.2.1 | CT4 part of CN aspects of Service Identification for RRC Improvements in GERAN | 290.75d? | 2011-12-02 A | 2012-09-07 A | 100% | 2011-12-02 | 2012-09-07 | 203d? | finish no earlier than 2012-09-07 | C4 | 1608h | 1608h | SIRIG | 28 | China Mobile | zhanghao@chinamobile.com | Rel-11 | 54 | Kimmo |  |  |  |  |
| 6373 | 2120.2.2 | Deleted - CT3 part of CN aspects of Service Identification for RRC Improvements in GERAN | 77d? | 2012-03-02 A | 2012-06-15 A | 100% | 2012-03-02 | 2012-06-15 | 77d? | finish no earlier than 2012-06-01 | C3 | 608h | 608h | SIRIG | 28 | China Mobile | zhanghao@chinamobile.com | Rel-11 | 55 | Adrian |  | PCG-29 | CP-56 |  |
| 6374 | 2120.3 | GERAN2 part of Service Identification for RRC Improvements in GERAN | 252d? | 2011-09-19 A | 2012-08-31 A | 100% | 2011-09-19 | 2012-08-31 | 252d? | finish no earlier than 2012-08-31 | G2 | 2016h | 2016h | SIRIG | 27 | China Mobile, Huawei | Juan Deng, Yang Zhao | Rel-11 | 51 | Gert |  |  |  |  |
| 6375 | 2121 | **SAE Protocol Development - Phase 2** | 370.38d? | 2011-09-16 A | 2012-09-07 A | 100% | 2011-09-16 | 2012-09-07 | 259d? |  | C1 | 6168h | 6168h | SAES2 | 27 | Nokia Siemens Networks | robert.zaus@nsn.com | Rel-11 | 53 | Frederic | SAES2 |  |  |  |
| 6376 | 2121.1 | SAE Protocol Development (Stage 3) - Phase 2 | 259d? | 2011-09-16 A | 2012-09-07 A | 100% | 2011-09-16 | 2012-09-07 | 259d? | finish no earlier than 2012-09-07 | C1 | 2048h | 2048h | SAES2 | 27 | Nokia Siemens Networks | robert.zaus@nsn.com | Rel-11 | 53 | Frederic |  |  |  |  |
| 6377 | 2121.2 | CS Fallback in EPS - Phase 2 | 259d? | 2011-09-16 A | 2012-09-07 A | 100% | 2011-09-16 | 2012-09-07 | 259d? | finish no earlier than 2012-09-07 | C1 | 2048h | 2048h | SAES2-CSFB | 27 | Nokia Siemens Networks | robert.zaus@nsn.com | Rel-11 | 53 | Frederic | SAES2-CSFB |  |  |  |
| 6378 | 2122 | **GCSMSC and GCR Redundancy for VGCS/VBS (Stage 2/3)** | 367.12d? | 2011-09-19 A | 2012-09-07 A | 100% | 2011-09-19 | 2012-09-07 | 258d? |  | C1 | 5680h | 5680h | RT_VGCS_Red | 27 | Nokia Siemens Networks | robert.zaus@nsn.com | Rel-11 | 53 | Frederic | RT_VGCS_Red |  |  |  |
| 6379 | 2122.1 | CT1 part of GCSMSC and GCR Redundancy for VGCS/VBS | 258d? | 2011-09-19 A | 2012-09-07 A | 100% | 2011-09-19 | 2012-09-07 | 258d? | finish no earlier than 2012-09-07 | C1 | 2048h | 2048h | RT_VGCS_Red | 27 | Nokia Siemens Networks | robert.zaus@nsn.com | Rel-11 | 53 | Frederic |  |  |  |  |
| 6380 | 2122.2 | Deleted - CT4 part of GCSMSC and GCR Redundancy for VGCS/VBS | 197d? | 2011-09-19 A | 2012-06-15 A | 100% | 2011-09-19 | 2012-06-15 | 197d? | finish no earlier than 2012-06-15 | C4 | 1568h | 1568h | RT_VGCS_Red | 27 | Nokia Siemens Networks | robert.zaus@nsn.com | Rel-11 | 53 | Kimmo |  | PCG-29 | CP-56 |  |
| 6381 | 2123 | Support of RFC 6140 in IMS | 203d? | 2011-12-02 A | 2012-09-07 A | 100% | 2011-12-02 | 2012-09-07 | 203d? | finish no earlier than 2012-09-07 | C1 | 1608h | 1608h | GINI | 28 | Deutsche Telekom | martin.huelsemann@telekom.de | Rel-11 | 54 | Frederic | GINI |  |  |  |
| 6382 | 2124 | **Enhancements for Multimedia Priority Service (MPS) – Gateway Control Priority** | 290.75d? | 2011-12-02 A | 2012-09-07 A | 100% | 2011-12-02 | 2012-09-07 | 203d? |  | C4; C3 | 6464h | 6464h | eMPS_Gateway | 28 | Telcordia | Viqar Shaikh | Rel-11 | 54 | Kimmo | eMPS_Gateway |  |  | Public Safety (I-A) |
| 6383 | 2124.1 | CT4 part of Enhancements for Multimedia Priority Service (MPS) – Gateway Control Priority | 202d? | 2011-12-02 A | 2012-09-07 A | 100% | 2011-12-02 | 2012-09-07 | 202d? | finish no earlier than 2012-09-07 | C4 | 1608h | 1608h | eMPS_Gateway | 28 | Telcordia | Viqar Shaikh | Rel-11 | 54 | Kimmo |  |  |  | Public Safety (I-A) |
| 6384 | 2124.2 | CT3 part of Enhancements for Multimedia Priority Service (MPS) – Gateway Control Priority | 202d? | 2011-12-02 A | 2012-09-07 A | 100% | 2011-12-02 | 2012-09-07 | 202d? | finish no earlier than 2012-09-07 | C3 | 1608h | 1608h | eMPS_Gateway | 28 | Telcordia | Viqar Shaikh | Rel-11 | 54 | Adrian |  |  |  | Public Safety (I-A) |
| 6385 | 2125 | Inter-IMS Network to Network Interface (II-NNI) enhancements: SIP timers applicability (Stage 3) | 196.5d? | 2012-03-02 A | 2012-09-07 A | 100% | 2012-03-02 | 2012-09-07 | 138d? | start no earlier than 2012-03-02 | C3 | 1088h | 1088h | NNI_timers | 28 | Telecom Italia | antonio.ascolese@telecomitalia.it | Rel-11 | 55 | Adrian | NNI_timers |  |  |  |
| 6386 | 2126 | AT commands for Universal Resource Identifier (URI) support | 188d? | 2012-06-15 A | 2013-03-01 A | 100% | 2012-06-15 | 2013-03-01 | 188d? | finish no earlier than 2013-03-01 | C1 | 1496h | 1496h | ATURI | 29 | Intel | frank.kowalewski@intel.com | Rel-11 | 56 | Frederic | ATURI |  |  |  |
| 6387 | 2127 | PS Additional Number (Stage 3) | 62d? | 2012-06-15 A | 2012-09-07 A | 100% | 2012-06-15 | 2012-09-07 | 62d? | finish no earlier than 2012-09-07 | C4 | 488h | 488h | PSAN | 29 | Deutsche Telekom | Yvette.koza@t-mobile.at | Rel-11 | 56 | Kimmo | PSAN |  |  |  |
| 6388 | 2128 | Generic IMS User Group Over Sh | 62d? | 2012-06-15 A | 2012-09-07 A | 100% | 2012-06-15 | 2012-09-07 | 62d? | finish no earlier than 2012-09-07 | C4 | 488h | 488h | GenUG_Sh | 29 | Alcatel-Lucent | jean-jacques.trottin@alcatel-lucent.com | Rel-11 | 56 | Kimmo | GenUG_Sh |  |  |  |

Notes:
- 6362: CP#57 completed
- 6363: CP#57 completed / Impacted TSs and TRs: 23.218; 24.229; 24.930
- 6364: CP#65 completed / Impacted TSs and TRs: RFC 7315 (was draft-drage-sipping-rfc3455bis); draft-mohali-dispatch-originating-cdiv-parameter
- 6365: 26/6/19: 25%->100; 23/4/20: 100%->100
- 6366: CP#64 completed / Impacted TSs and TRs: RFC 7135 (was draft-polk-local-emergency-rph-namespace)
- 6367: CP#57 completed / Impacted TSs and TRs: 29.163; 29.165
- 6368: CP#64 Draft removed from 3GPP documentation / Impacted TSs and TRs: draft-avasarala-dispatch-comm-div-notification
- 6369: TSG#57, GP#55 completed. CT defined a generic solution (not only for GERAN) / Impacted TSs and TRs: GERAN
- 6370: SP#57 completed / Impacted TSs and TRs: 23.060; 23.251
- 6371: CP#57 completed
- 6372: CP#57 completed / Impacted TSs and TRs: 29.281
- 6373: CP#56 stopped (SA2 decided NO CT3 impact) / Impacted TSs and TRs: 29.212
- 6374: GP#55 completed. GP#51 approved WID / Impacted TSs and TRs: 48.018
- 6375: CP#57 completed. Stage 3 continuation of Rel-8 Feature SAES (3GPP System Architecture Evolution Specification - Evolved Packet System) UID_320005
- 6376: CP#57 completed / Impacted TSs and TRs: 23.122; 24.008; 24.167; 24.229; 24.301; 24.302; 24.303; 24.304; 24.305; 24.312; 29.018; 29.118
- 6377: CP#57 completed / Impacted TSs and TRs: 23.122; 24.008; 24.167; 24.229; 24.301; 24.302; 24.303; 24.304; 24.305; 24.312; 29.018; 29.118
- 6378: CP#57 completed. Stage 2/3 adding a CN internal functionality, not affecting Voice Group Call Service (VGCS)/VBS as perceived by service subscriber. Hence, no Stage 1 impact for VGCS/VBS (42.068, 42.069) / Impacted TSs and TRs: Stage 2/3
- 6379: CP#57 completed / Impacted TSs and TRs: 43.068; 43.069
- 6380: CP#56 stopped (no CT4 impact) / Impacted TSs and TRs: 29.002
- 6381: CP#57 completed. Stage 3. Support procedures and protocol extensions in RFC6140 "Registration for Multiple Phone Numbers in SIP" to IMS for complex UEs. Ensure co-existence with NGCN IP-PBX registration procedures already defined in IMS. / Impacted TSs and TRs: 24.229
- 6382: CP#57 completed. Stage 3. Stage 1 for MPS in 22.153. Details of any MGW actions for priority needs to be further studied within the scope of this WI. / Impacted TSs and TRs: Stage 3
- 6383: CP#57 completed / Impacted TSs and TRs: 23.333; 23.334; 29.232; 29.238; 29.332; 29.333; 29.334
- 6384: CP#57 completed / Impacted TSs and TRs: 29.162; 29.163; 29.292
- 6385: CP#57 completed / Impacted TSs and TRs: 29.165
- 6386: CP#59 completed. Define new AT cmd for URI addresses for IMS services (eg VoLTE). 27.007(AT cmd to control MT functions and GSM/UMTS/LTE network services from TE), 27.005(AT commands for SMS). Currently address types for AT cmd based on dialling# / Impacted TSs and TRs: 27.005; 27.007
- 6387: CP#57 completed. Stage 1 in Rel-11 SA1 TS 22.101 clause 17.7.3 (No Stage 2 needed since no architecture impact) / Impacted TSs and TRs: 23.003; 23.008; 29.002; 29.272; 29.230
- 6388: CP#57 completed / Impacted TSs and TRs: 29.364

| ID | WBS | Task | Duration | Start | Finish | Complete | Baseline start | Baseline finish | Baseline duration | Constraint | Resources | Work | Actual work | Acronym | PCG approved | WI rapporteur name | WI rapporteur e-mail | Release | TSG approved | MCC resp | Acronym_3GU_Export | PCG stopped | TSG stopped | Status Report |
| --- | --- | --- | --- | --- | --- | --- | --- | --- | --- | --- | --- | --- | --- | --- | --- | --- | --- | --- | --- | --- | --- | --- | --- | --- |
| 6389 | 2129 | **IMS Operator Determined Call Barring** | 290.5d? | 2012-09-07 A | 2013-06-14 A | 100% | 2012-09-07 | 2013-06-14 | 205d? |  | C1; C4 | 5411.54h | 5411.54h | IODB | 29 | Orange | Youssef.Chadli@Orange.com | Rel-11 | 57 | Frederic | IODB |  |  |  |
| 6390 | 2129.1 | CT1 part of IMS Operator Determined Call Barring | 203d? | 2012-09-10 A | 2013-06-14 A | 100% | 2012-09-10 | 2013-06-14 | 203d? | finish no earlier than 2013-06-14 | C1 | 1616h | 1616h | IODB | 29 | Orange | Youssef.Chadli@Orange.com | Rel-11 | 57 | Frederic |  |  |  |  |
| 6391 | 2129.2 | CT4 part of IMS Operator Determined Call Barring | 69d? | 2012-09-07 A | 2013-03-12 A | 100% | 2012-09-07 | 2013-03-12 | 69d? | finish no earlier than 2012-12-07 | C4 | 515.54h | 515.54h | IODB | 29 | Orange | Youssef.Chadli@Orange.com | Rel-11 | 57 | Kimmo |  |  |  |  |
| 6392 | 2130 | **Enhanced T.38 FAX support (Stage 3)** | 96d? | 2012-09-06 A | 2012-12-07 A | 100% | 2012-09-06 | 2012-12-07 | 69d? |  | C3; C1; C4 | 2728h | 2728h | MMTel_T.38_FAX | 29 | NEC | Naoaki Suzuki (n-suzuki@en.jp.nec.com) | Rel-11 | 57 | Adrian | MMTel_T.38_FAX |  |  |  |
| 6393 | 2130.1 | CT3 part of Enhanced T.38 FAX support | 68d? | 2012-09-07 A | 2012-12-07 A | 100% | 2012-09-07 | 2012-12-07 | 68d? | finish no earlier than 2012-12-07 | C3 | 528h | 528h | MMTel_T.38_FAX | 29 | NEC | Naoaki Suzuki (n-suzuki@en.jp.nec.com) | Rel-11 | 57 | Adrian |  |  |  |  |
| 6394 | 2130.2 | CT1 part of Enhanced T.38 FAX support | 67d? | 2012-09-07 A | 2012-12-07 A | 100% | 2012-09-07 | 2012-12-07 | 67d? | finish no earlier than 2012-12-07 | C1 | 528h | 528h | MMTel_T.38_FAX | 29 | NEC | Naoaki Suzuki (n-suzuki@en.jp.nec.com) | Rel-11 | 57 | Frederic |  |  |  |  |
| 6395 | 2130.3 | CT4 part of Enhanced T.38 FAX support | 2d? | 2012-09-06 A | 2012-09-07 A | 100% | 2012-09-06 | 2012-09-07 | 2d? | finish no earlier than 2012-12-07 | C4 | 16h | 16h | MMTel_T.38_FAX | 29 | NEC | Naoaki Suzuki (n-suzuki@en.jp.nec.com) | Rel-11 | 57 | Kimmo |  |  |  |  |
| 6396 | 2131 | **Deleted - Enhancement of the Protocols for SMS over SGs (Stage 3)** | 203.88d? | 2011-12-02 A | 2012-06-15 A | 100% | 2011-12-02 | 2012-06-15 | 142d? |  | C4; C1 | 5664h | 5664h | PROTOC_SMS_SGs | 28 | Alcatel-Lucent | jean-jacques.trottin@alcatel-lucent.com | Rel-11 | 54 | Kimmo | PROTOC_SMS_SGs | PCG-29 | CP-56 |  |
| 6397 | 2131.1 | Deleted - TR Study on enhancement of protocols for SMS service over SGs | 142d? | 2011-12-02 A | 2012-06-15 A | 100% | 2011-12-02 | 2012-06-15 | 142d? | finish no earlier than 2012-06-15 | C4 | 1128h | 1128h | PROTOC_SMS_SGs | 28 | Alcatel-Lucent | jean-jacques.trottin@alcatel-lucent.com | Rel-11 | 54 | Kimmo |  | PCG-29 | CP-56 |  |
| 6398 | 2131.2 | Deleted - CT4 part of Enhancement of the Protocols for SMS over SGs | 142d? | 2011-12-02 A | 2012-06-15 A | 100% | 2011-12-02 | 2012-06-15 | 142d? | finish no earlier than 2012-06-15 | C4 | 1128h | 1128h | PROTOC_SMS_SGs | 28 | Alcatel-Lucent | jean-jacques.trottin@alcatel-lucent.com | Rel-11 | 54 | Kimmo |  | PCG-29 | CP-56 |  |
| 6399 | 2131.3 | Deleted - CT1 part of Enhancement of the Protocols for SMS over SGs | 142d? | 2011-12-02 A | 2012-06-15 A | 100% | 2011-12-02 | 2012-06-15 | 142d? | finish no earlier than 2012-06-15 | C1 | 1136h | 1136h | PROTOC_SMS_SGs | 28 | Alcatel-Lucent | jean-jacques.trottin@alcatel-lucent.com | Rel-11 | 54 | Frederic |  | PCG-29 | CP-56 |  |
| 6400 | 2132 | **Full Support of Multi-Operator Core Network by GERAN** | 833.75d? | 2011-03-04 A | 2013-05-17 A | 100% | 2011-03-04 | 2013-05-17 | 584d? |  | G2; S2; C1 | 31293.3h | 31293.3h | Full_MOCN-GERAN | 26 | Alcatel-Lucent | michel.robert@alcatel-lucent.com | Rel-11 | 49 | Paolo | Full_MOCN-GERAN |  |  |  |
| 6401 | 2132.1 | GERAN part of Full Support of Multi-Operator Core Network by GERAN | 584d? | 2011-03-04 A | 2013-05-17 A | 100% | 2011-03-04 | 2013-05-17 | 584d? | finish no earlier than 2013-06-07 | G2 | 4656.4h | 4656.4h | Full_MOCN-GERAN | 26 | Alcatel-Lucent | michel.robert@alcatel-lucent.com | Rel-11 | 49 | Gert |  |  |  |  |
| 6402 | 2132.2 | Stage 2 for Full Support of Multi-Operator Core Network by GERAN | 160.8d? | 2011-06-08 A | 2012-03-07 A | 100% | 2011-06-08 | 2012-03-07 | 160.8d? | finish no earlier than 2012-03-07 | S2 | 1278.4h | 1278.4h | Full_MOCN-GERAN | 26 | Alcatel-Lucent | nicolas.drevon@alcatel-lucent.com | Rel-11 | 49 | Maurice |  |  |  |  |
| 6403 | 2132.3 | **CN Stage 3 for Full Support of Multi-Operator Core Network by GERAN** | 572.88d? | 2011-06-03 A | 2012-12-07 A | 100% | 2011-06-03 | 2012-12-07 | 403d? |  | C1; C4 | 9838.51h | 9838.51h | Full_MOCN-GERAN | 26 | Alcatel-Lucent | jennifer.liu@alcatel-lucent.com | Rel-11 | 49 | Frederic |  |  |  |  |
| 6404 | 2132.3.1 | CT1 part of CN Stage 3 for Full Support of Multi-Operator Core Network by GERAN | 362.8d? | 2011-06-03 A | 2012-12-07 A | 100% | 2011-06-03 | 2012-12-07 | 362.8d? | finish no earlier than 2012-12-07 | C1 | 2886.51h | 2886.51h | Full_MOCN-GERAN | 26 | Alcatel-Lucent | jennifer.liu@alcatel-lucent.com | Rel-11 | 49 | Frederic |  |  |  |  |
| 6405 | 2132.3.2 | CT4 part of CN Stage 3 for Full Support of Multi-Operator Core Network by GERAN | 64d? | 2012-06-13 A | 2012-09-07 A | 100% | 2012-06-13 | 2012-09-07 | 64d? | finish no earlier than 2012-09-07 | C4 | 504h | 504h | Full_MOCN-GERAN | 29 | Alcatel-Lucent | michel.robert@alcatel-lucent.com | Rel-11 | 54 | Kimmo |  |  |  |  |
| 6406 | 2132.4 | Stage 2 for Gateway Core Network Sharing for GERAN | 192d? | 2012-06-18 A | 2013-03-06 A | 100% | 2012-06-18 | 2013-03-06 | 192d? | finish no earlier than 2013-03-06 | S2 | 1504h | 1504h | Full_MOCN-GERAN-GWCN | 29 | Vodafone | chris.pudney@vodafone.com | Rel-11 | 56 | Maurice | Full_MOCN-GERAN-GWCN |  |  |  |
| 6407 | 2133 | **Medium range/local area requirements for multicarrier BTS** | 377.62d? | 2011-11-25 A | 2012-11-23 A | 100% | 2011-11-25 | 2012-11-23 | 264d? |  | G1 | 6296h | 6296h | MRLA | 28 | Ericsson | Eric Nordström | Rel-11 | 52 | Paolo | MRLA |  |  |  |
| 6408 | 2133.1 | Core part: Medium range/local area requirements for multicarrier BTS | 263d? | 2011-11-25 A | 2012-11-23 A | 100% | 2011-11-25 | 2012-11-23 | 263d? | finish no earlier than 2012-11-23 | G1 | 2096h | 2096h | MRLA-Core | 28 | Ericsson | Eric Nordström | Rel-11 | 52 | Paolo | MRLA-Core |  |  |  |
| 6409 | 2133.2 | Perf. part: Medium range/local area requirements for multicarrier BTS | 262d? | 2011-11-28 A | 2012-11-23 A | 100% | 2011-11-28 | 2012-11-23 | 262d? | finish no earlier than 2012-11-23 | G1 | 2088h | 2088h | MRLA-Perf | 28 | Ericsson | Eric Nordström | Rel-11 | 52 | Paolo | MRLA-Perf |  |  |  |
| 6410 | 2134 | Domain Specific Access Control in GERAN | 131d? | 2012-03-05 A | 2012-08-31 A | 100% | 2012-03-05 | 2012-08-31 | 131d? | finish no earlier than 2012-08-31 | G2 | 1048h | 1048h | GDSAC | 28 | Vodafone | chris.pudney@vodafone.com | Rel-11 | 53 | Gert | GDSAC |  |  |  |
| 6411 | 2135 | **Extending 850 MHz Upper Band (814 – 849 MHz)** | 841d? | 2010-12-10 A | 2013-03-01 A | 100% | 2010-12-10 | 2013-03-01 | 589d? |  | R4; R2; R3; R5 | 33352h | 33352h | e850_UB | 26 | Sprint | John.J.Humbert@Sprint.com | Rel-11 | 50 | Issam | e850_UB |  |  |  |
| 6412 | 2135.1 | Core part: Extending 850 MHz Upper Band (814 – 849 MHz) | 324d? | 2010-12-10 A | 2012-03-02 A | 100% | 2010-12-10 | 2012-03-02 | 324d? | finish no earlier than 2012-03-02 | R4; R2; R3 | 7776h | 7776h | e850_UB-Core | 26 | Sprint | John.J.Humbert@Sprint.com | Rel-11 | 50 | Issam | e850_UB-Core |  |  | RP-120075 |
| 6413 | 2135.2 | Perf. part: Extending 850 MHz Upper Band (814 – 849 MHz) | 324d? | 2010-12-10 A | 2012-03-02 A | 100% | 2010-12-10 | 2012-03-02 | 324d? | finish no earlier than 2012-03-02 | R4 | 2592h | 2592h | e850_UB-Perf | 26 | Sprint | John.J.Humbert@Sprint.com | Rel-11 | 50 | Issam | e850_UB-Perf |  |  | RP-120076 |
| 6414 | 2135.3 | Test part: Extending 850 MHz Upper Band (814 – 849 MHz) | 517d? | 2011-03-18 A | 2013-03-01 A | 100% | 2011-03-18 | 2013-03-01 | 517d? | finish no earlier than 2013-03-01 | R5 | 4136h | 4136h | e850_UB-UEConTest | 26 | Sprint | John.J.Humbert@Sprint.com | Rel-11 | 51 | Ingbert | e850_UB-UEConTest |  |  | RP-130043 |

Notes:
- 6389: LS_in C4-121615 GSMA IREG RILTE concluded that TS 22.041 clause 5.4 Stage 1 requirements are not covered by stage 3 specifications
- 6390: CP#60 completed. Handling of premium rate numbers remained OPEN in Rel-11 (shifted to Rel-12). CP-130384 LS_out sent to SA1 / GSMA informing this TSG CT decision. / Impacted TSs and TRs: New 24.315
- 6391: CP#58 completed / Impacted TSs and TRs: 23.008 ; 23.015 ; 29.328 ; 29.329 ; 29.364
- 6392: CP#58 completed. Linked to Rel-8 Feature: IMS Multimedia Telephony Service (IMS-MMTel) UID_7038. SA1 added FAX stage 1 requirement only in Rel-10 under TEI10 to TS 22.173 (CR#0064)
- 6393: CP#58 completed / Impacted TSs and TRs: 29.163
- 6394: CP#58 completed / Impacted TSs and TRs: 24.229
- 6395: CP#57 completed / Impacted TSs and TRs: 29.332
- 6396: CP#56 stopped. Reason: Protocols for SMS over SGs is replaced by the SIMTC SMS in MME solution (as solution not only for MTC user but for general subscribers) / Impacted TSs and TRs: Stage 3
- 6397: CP#56 stopped (abandonned new TR 29.818) / Impacted TSs and TRs: new 29.818
- 6398: CP#56 stopped (abandonned new TS 29.218 Diameter based protocols for SMS service over SGs) / Impacted TSs and TRs: 29.305; new 29.218
- 6399: CP#56 stopped / Impacted TSs and TRs: 23.040; 24.011; 43.068
- 6400: GP#58 completed. GP#49 approved WID. Standardization of management of MOCN supporting MSs/UES in CP-150GERAN. Continuation of Rel-10 MOCN-GERAN UID_490001 / Impacted TSs and TRs: GERAN
- 6401: GP#58 completed. GP#49 approved WID / Impacted TSs and TRs: 44.018; 44.060; 45.002; 45.008; 48.008; 48.018
- 6402: SP#55 completed / Impacted TSs and TRs: 23.251; 23.272
- 6403: CP#58 completed
- 6404: CP#58 completed / Impacted TSs and TRs: 24.008
- 6405: CP#57 completed / Impacted TSs and TRs: 23.003
- 6406: SP#59 completed. (23.251CR0062R2 as TEI11. TS 23.251 specifies both MOCN and GWCN for E-UTRAN and UTRAN, but GWCN is not yet supported on GERAN. Extend Full_MOCN-GERAN to also cover GWCN GERAN / Impacted TSs and TRs: 23.251
- 6407: GP#56 completed. GP#52 approved WID / Impacted TSs and TRs: GERAN
- 6408: Stage 3. GP#56 completed. GP#52 approved WID / Impacted TSs and TRs: 45.005
- 6409: Test spec. GP#56 completed. GP#52 approved WID / Impacted TSs and TRs: 51.021
- 6410: GP#55 completed. GP#53 approved WID. Work is dependent upon Full_MOCN-GERAN (UID_510001) / Impacted TSs and TRs: GERAN 44.018
- 6411: Stage 3. Triggered by R4 Rel-10 LTE TR 37.806 Study on Extending 850 MHz (UID_440016) / Impacted TSs and TRs: UTRA; LTE
- 6412: RP#55 completed / Impacted TSs and TRs: 25.101; 25.104; 25.113; 25.133; 25.141; 25.461; 25.466; 36.101; 36.104; 36.113; 36.124; 36.133; 36.141; 36.307; 36.331; 37.104; 37.113; 37.141
- 6413: RP#55 completed / Impacted TSs and TRs: 25.101; 25.104; 25.113; 25.133; 25.141; 25.461; 25.466; 36.101; 36.104; 36.124; 36.133; 36.141; 36.307; 36.331; 37.104; 37.113; 37.141
- 6414: RP#59 completed / Impacted TSs and TRs: 34.108; 34.121-1; 34.121-2; 34.123-1; 34.123-2; 34.123-3; 36.508; 36.521-1; 36.521-2; 36.521-3; 36.523-1; 36.523-2; 36.523-3

| ID | WBS | Task | Duration | Start | Finish | Complete | Baseline start | Baseline finish | Baseline duration | Constraint | Resources | Work | Actual work | Acronym | PCG approved | WI rapporteur name | WI rapporteur e-mail | Release | TSG approved | MCC resp | Special Focus Doc | Acronym_3GU_Export | Status Report |
| --- | --- | --- | --- | --- | --- | --- | --- | --- | --- | --- | --- | --- | --- | --- | --- | --- | --- | --- | --- | --- | --- | --- | --- |
| 6415 | 2136 | **Further Self Optimizing Networks (SON) enhancements** | 461.12d? | 2011-09-19 A | 2012-12-07 A | 100% | 2011-09-19 | 2012-12-07 | 325d? |  | R3; R2 | 10400h | 10400h | SONenh2_LTE_UTRA | 27 | Nokia Siemens Networks | krzysztof.kordybach@nsn.com | Rel-11 | 53 | Juha | SON | SONenh2_LTE_UTRA |  |
| 6416 | 2136.1 | Core part: Further Self Optimizing Networks (SON) enhancements | 325d? | 2011-09-19 A | 2012-12-07 A | 100% | 2011-09-19 | 2012-12-07 | 325d? | finish no earlier than 2012-12-07 | R3; R2 | 5200h | 5200h | SONenh2_LTE_UTRA-Core | 27 | Nokia Siemens Networks | krzysztof.kordybach@nsn.com | Rel-11 | 53 | Juha | SON | SONenh2_LTE_UTRA-Core | RP-121557 |
| 6417 | 2137 | **Enhancement of Minimization of Drive Tests for E-UTRAN and UTRAN** | 837.5d? | 2011-09-19 A | 2013-12-06 A | 100% | 2011-09-19 | 2013-12-06 | 590d? |  | R2; R1; R3; R4; R5 | 35608h | 35608h | eMDT_UMTSLTE | 27 | MediaTek | Johan Johansson | Rel-11 | 53 | Yong-Jun |  | eMDT_UMTSLTE |  |
| 6418 | 2137.1 | Core part: Enhancement of Minimization of Drive Tests for E-UTRAN and UTRAN | 325d? | 2011-09-19 A | 2012-12-07 A | 100% | 2011-09-19 | 2012-12-07 | 325d? | finish no earlier than 2012-12-07 | R2; R1; R3; R4 | 10400h | 10400h | eMDT_UMTSLTE-Core | 27 | MediaTek | Johan Johansson | Rel-11 | 53 | Yong-Jun |  | eMDT_UMTSLTE-Core | RP-121556 |
| 6419 | 2137.2 | Test part: Enhancement of Minimization of Drive Tests for E-UTRAN and UTRAN | 202d? | 2013-03-04 A | 2013-12-06 A | 100% | 2013-03-04 | 2013-12-06 | 202d? | finish no earlier than 2013-12-06 | R5 | 1608h | 1608h | eMDT_UMTSLTE-UEConTest | 30 | NTT DoCoMo | masahiro.tamaoki.eu@nttdocomo.com | Rel-11 | 59 | Ingbert |  | eMDT_UMTSLTE-UEConTest | RP-131447 |
| 6420 | 2138 | **Network Energy Saving for E-UTRAN** | 367.12d? | 2011-09-19 A | 2012-09-07 A | 100% | 2011-09-19 | 2012-09-07 | 258d? |  | R3; GP | 6224h | 6224h | Netw_Energy_LTE | 27 | China Mobile | yangning@chinamobile.com | Rel-11 | 53 | Juha |  | Netw_Energy_LTE |  |
| 6421 | 2138.1 | Core part: Network Energy Saving for E-UTRAN | 257d? | 2011-09-19 A | 2012-09-07 A | 100% | 2011-09-19 | 2012-09-07 | 257d? | finish no earlier than 2012-09-07 | R3 | 2056h | 2056h | Netw_Energy_LTE-Core | 27 | China Mobile | yangning@chinamobile.com | Rel-11 | 53 | Juha |  | Netw_Energy_LTE-Core | RP-121016 |
| 6422 | 2138.2 | GERAN part: Network Energy Saving for E-UTRAN | 5d? | 2012-08-27 A | 2012-08-31 A | 100% | 2012-08-27 | 2012-08-31 | 5d? | finish no earlier than 2012-08-31 | GP | 40h | 40h |  | 29 | Alcatel-Lucent | marguerite.woch@alcatel-lucent.com | Rel-11 | 55 | Paolo |  |  |  |
| 6423 | 2139 | **E-UTRA medium range and MSR medium range/local area BS class requirements** | 461.12d? | 2011-09-19 A | 2012-12-07 A | 100% | 2011-09-19 | 2012-12-07 | 325d? |  | R4; G1 | 12432h | 12432h | medBS_class_LTE_MSR | 27 | Ericsson | johan.skold@ericsson.com | Rel-11 | 53 | Issam |  | medBS_class_LTE_MSR |  |
| 6424 | 2139.1 | Core part: E-UTRA medium range and MSR medium range/local area BS class requirements | 323d? | 2011-09-19 A | 2012-12-07 A | 100% | 2011-09-19 | 2012-12-07 | 323d? | finish no earlier than 2012-12-07 | R4 | 2576h | 2576h | medBS_class_LTE_MSR-Core | 27 | Ericsson | johan.skold@ericsson.com | Rel-11 | 53 | Issam |  | medBS_class_LTE_MSR-Core | RP-121558 |
| 6425 | 2139.2 | Perf. part: E-UTRA medium range and MSR medium range/local area BS class requirements | 321d? | 2011-09-23 A | 2012-12-07 A | 100% | 2011-09-23 | 2012-12-07 | 321d? | finish no earlier than 2012-12-07 | R4 | 2568h | 2568h | medBS_class_LTE_MSR-Perf | 27 | Ericsson | johan.skold@ericsson.com | Rel-11 | 53 | Issam |  | medBS_class_LTE_MSR-Perf | RP-121559 |
| 6426 | 2139.3 | GERAN part: E-UTRA medium range and MSR medium range/local area BS class requirements | 261d? | 2011-11-28 A | 2012-11-23 A | 100% | 2011-11-28 | 2012-11-23 | 261d? | finish no earlier than 2012-11-23 | G1 | 2088h | 2088h | medBS_class_LTE_MSR-GERAN | 28 | Ericsson | Eric Nordström | Rel-11 | 52 | Paolo |  | medBS_class_LTE_MSR-GERAN |  |
| 6427 | 2140 | **RF Requirements for Multi-Band and Multi-Standard Radio (MB-MSR) Base Station** | 784.85d? | 2012-02-06 A | 2014-03-06 A | 100% | 2012-02-06 | 2014-03-06 | 553.1d? |  | R4; G1 | 20915.2h | 20915.2h | MB_MSR_RF | 28 | Huawei | Liu Ye (leo.liuye@huawei.com) | Rel-11 | 55 | Issam |  | MB_MSR_RF |  |
| 6428 | 2140.1 | Core part: RF Requirements for Multi-Band and Multi-Standard Radio (MB-MSR) Base Station | 223.1d? | 2012-02-06 A | 2012-12-07 A | 100% | 2012-02-06 | 2012-12-07 | 223.1d? | finish no earlier than 2012-12-07 | R4; G1 | 3569.6h | 3569.6h | MB_MSR_RF-Core | 28 | Huawei | Liu Ye (leo.liuye@huawei.com) | Rel-11 | 55 | Issam |  | MB_MSR_RF-Core | RP-121985 |
| 6429 | 2140.2 | Perf. part: RF Requirements for Multi-Band and Multi-Standard Radio (MB-MSR) Base Station | 531d? | 2012-03-08 A | 2014-03-06 A | 100% | 2012-03-08 | 2014-03-06 | 531d? | finish no earlier than 2014-03-06 | R4; G1 | 8496h | 8496h | MB_MSR_RF-Perf | 28 | Huawei | Liu Ye (leo.liuye@huawei.com) | Rel-11 | 55 | Issam |  | MB_MSR_RF-Perf | RP-140064 |
| 6430 | 2141 | **Further enhancements to H(e)NB mobility - Part 1** | 181.88d? | 2012-06-15 A | 2012-12-07 A | 100% | 2012-06-15 | 2012-12-07 | 129d? |  | R3; R2 | 4128h | 4128h | EHNB_enh1 | 29 | Alcatel-Lucent | Martin.Warner@alcatel-lucent.com | Rel-11 | 56 | Juha | HNB | EHNB_enh1 |  |
| 6431 | 2141.1 | Core part: Further enhancements to H(e)NB mobility - Part 1 | 129d? | 2012-06-15 A | 2012-12-07 A | 100% | 2012-06-15 | 2012-12-07 | 129d? | finish no earlier than 2012-12-07 | R3; R2 | 2064h | 2064h | EHNB_enh1-Core | 29 | Alcatel-Lucent | Martin.Warner@alcatel-lucent.com | Rel-11 | 56 | Juha | HNB | EHNB_enh1-Core | RP-121563 |
| 6432 | 2142 | **Further enhancements to H(e)NB mobility - Part 2** | 177.62d? | 2012-06-19 A | 2012-12-07 A | 100% | 2012-06-19 | 2012-12-07 | 127d? |  | R3; R2 | 4064h | 4064h | EHNB_enh2 | 29 | Alcatel-Lucent | Martin.Warner@alcatel-lucent.com | Rel-11 | 56 | Juha | HNB | EHNB_enh2 |  |
| 6433 | 2142.1 | Core part: Further enhancements to H(e)NB mobility - Part 2 | 127d? | 2012-06-19 A | 2012-12-07 A | 100% | 2012-06-19 | 2012-12-07 | 127d? | finish no earlier than 2012-12-07 | R3; R2 | 2032h | 2032h | EHNB_enh2-Core | 29 | Alcatel-Lucent | Martin.Warner@alcatel-lucent.com | Rel-11 | 56 | Juha | HNB | EHNB_enh2-Core | RP-121564 |
| 6434 | 2143 | **Network-Based Positioning Support for LTE** | 1994d? | 2009-03-05 A | 2014-06-13 A | 100% | 2009-03-05 | 2014-06-13 | 1391d? |  | R2; R1; R3; R4 | 91464h | 91464h | LCS_LTE-NBPS | 22 | TruePosition | terri.brooks@trueposition.com | Rel-11 | 43 | Yong-Jun |  | LCS_LTE-NBPS |  |
| 6435 | 2143.1 | Core part: Network-Based Positioning Support for LTE | 1125d? | 2009-03-05 A | 2013-06-12 A | 100% | 2009-03-05 | 2013-06-12 | 1125d? | finish no earlier than 2013-06-12 | R2; R1; R3; R4 | 36000h | 36000h | LCS_LTE-NBPS-Core | 22 | TruePosition | terri.brooks@trueposition.com | Rel-11 | 43 | Yong-Jun |  | LCS_LTE-NBPS-Core | RP-130483 |
| 6436 | 2143.2 | Perf. part: Network-Based Positioning Support for LTE | 1377d? | 2009-03-24 A | 2014-06-13 A | 100% | 2009-03-24 | 2014-06-13 | 1377d? | finish no earlier than 2014-06-13 | R4 | 11016h | 11016h | LCS_LTE-NBPS-Perf | 22 | TruePosition | terri.brooks@trueposition.com | Rel-11 | 43 | Yong-Jun |  | LCS_LTE-NBPS-Perf | RP-140626 |
| 6437 | 2144 | **Service continuity improvements for MBMS for LTE** | 1419.38d? | 2010-06-04 A | 2014-03-06 A | 100% | 2010-06-04 | 2014-03-06 | 993d? |  | R2; R3; R5 | 35496h | 35496h | MBMS_LTE_SC | 25 | Huawei | David.Lecompte@huawei.com | Rel-11 | 48 | Yong-Jun |  | MBMS_LTE_SC |  |
| 6438 | 2144.1 | Core part: Service continuity improvements for MBMS for LTE | 596d? | 2010-06-04 A | 2012-09-07 A | 100% | 2010-06-04 | 2012-09-07 | 596d? | finish no earlier than 2012-09-07 | R2; R3 | 9536h | 9536h | MBMS_LTE_SC-Core | 25 | Huawei | David.Lecompte@huawei.com | Rel-11 | 48 | Yong-Jun |  | MBMS_LTE_SC-Core | RP-121001 |
| 6439 | 2144.2 | Test part: Service continuity improvements for MBMS for LTE | 266d? | 2013-03-04 A | 2014-03-06 A | 100% | 2013-03-04 | 2014-03-06 | 266d? | finish no earlier than 2014-03-06 | R5 | 2128h | 2128h | MBMS_LTE_SC-UEConTest | 30 | Ericsson | leif.mattisson@ericsson.com | Rel-11 | 59 | Ingbert |  | MBMS_LTE_SC-UEConTest | RP-140074 |

Notes:
- 6415: Stage 1/2/3 / Impacted TSs and TRs: UTRA; LTE
- 6416: RP#58 completed / Impacted TSs and TRs: 25.331; 25.401; 25.410; 25.413; 25.423; 25.433; 36.300; 36.331; 36.413; 36.423
- 6417: Stage 2/3 / Impacted TSs and TRs: UTRA; LTE
- 6418: RP#58 completed / Impacted TSs and TRs: 25.133; 25.123; 25.304; 25.331; 25.413; 25.423; 36.133; 36.304; 36.306; 36.331; 36.413; 36.423; 37.320; 36.300
- 6419: RP#62 completed / Impacted TSs and TRs: 34.108; 34.109; 34.123-1; 34.123-2; 34.123-3; 36.508; 36.509; 36.523-1; 36.523-2; 36.523-3
- 6420: Stage 2/3 / Impacted TSs and TRs: LTE; GERAN
- 6421: RP#57 completed. Inter-RAT aspect can affect UTRA and GERAN as well / Impacted TSs and TRs: 25.413; 36.300; 36.413; 36.423
- 6422: GP#55 approved WID and completed. Stage 3. ChangES in CP-150RIM protocol and in SON Transfer RIM application to provide support for Energy Savings Indication feature / Impacted TSs and TRs: 48.018 [Serving GPRS Support Node (SGSN); BSS GPRS protocol (BSSGP)]
- 6423: Stage 3. GERAN BS RF requirements specs need aligned with RAN4 ongoing Rel-11 Feature UID_530037 E-UTRA medium range and MSR medium range/local area BS class requirements (medBS_class_LTE_MSR) / Impacted TSs and TRs: UTRA; LTE; GERAN
- 6424: RP#58 completed. TR 37.809 v200 for Approval / Impacted TSs and TRs: 25.104; 36.104; 37.104; new 37.809
- 6425: RP#58 completed / Impacted TSs and TRs: 25.141; 36.141; 37.141
- 6426: GP#56 completed. GP#52 approved WID / Impacted TSs and TRs: 45.005; 51.021
- 6427: - / Impacted TSs and TRs: UTRA; LTE; GERAN
- 6428: RP#58 completed / Impacted TSs and TRs: 25.104; 25.105; 36.104; 37.104; new 37.812
- 6429: RP#63 completed / Impacted TSs and TRs: 25.141; 25.142; 36.141; 37.141
- 6430: Stage 2/3. Triggered by FS_EHNB_enh (UTRA, LTE TR 37.803 under AI 12.3.2). Compare also Rel-10 WI HNB_HENB_mob_enh RP-110183 / Impacted TSs and TRs: UTRA; LTE
- 6431: RP#58 completed / Impacted TSs and TRs: 25.413; 25.467; 25.469; 36.300; 36.413; 36.423
- 6432: Stage 2/3. Legacy UE Handling (X2-GW, 20% complete, moved to Rel-12 UID_580030). Triggered by FS_EHNB_enh (UTRA, LTE TR 37.803 under AI 12.3.2) / Impacted TSs and TRs: UTRA; LTE
- 6433: RP#58 completed Legacy UE Handling (X2-GW, 20% complete, moved to Rel-12 UID_580030). Updated WID RP-121147=>RP-121712 / Impacted TSs and TRs: 25.413; 25.467; 25.469; 25.471
- 6434: - / Impacted TSs and TRs: LTE
- 6435: RP#60 completed / Impacted TSs and TRs: 36.214; 36.300; 36.305; 36.401; 36.413; 36.455; new (36.111; 36.456; 36.457; 36.458; 36.459)
- 6436: RP#64 completed. TS 36.112v100 for 1-step Approval / Impacted TSs and TRs: 36.111; new 36.112
- 6437: - / Impacted TSs and TRs: LTE
- 6438: RP#57 completed / Impacted TSs and TRs: 25.446; 36.300; 36.304; 36.321; 36.322; 36.323; 36.331; 36.440; 36.441; 36.442; 36.443; 36.444; 36.445
- 6439: RP#63 completed / Impacted TSs and TRs: 36.508; 36.523-1; 36.523-2; 36.523-3

| ID | WBS | Task | Duration | Start | Finish | Complete | Baseline start | Baseline finish | Baseline duration | Constraint | Resources | Work | Actual work | Acronym | PCG approved | WI rapporteur name | WI rapporteur e-mail | Release | TSG approved | MCC resp | Acronym_3GU_Export | Status Report | Special Focus Doc |
| --- | --- | --- | --- | --- | --- | --- | --- | --- | --- | --- | --- | --- | --- | --- | --- | --- | --- | --- | --- | --- | --- | --- | --- |
| 6440 | 2145 | **Further Enhanced Non CA-based ICIC for LTE** | 1411.75d? | 2011-03-22 A | 2014-12-15 A | 100% | 2011-03-22 | 2014-09-12 | 922d? |  | R1; R2; R3; R4; R5 | 63112h | 63112h | eICIC_enh_LTE | 26 | China Mobile | ShenXiaodong@chinamobile.com | Rel-11 | 51 | Patrick | eICIC_enh_LTE |  |  |
| 6441 | 2145.1 | Core part: Further Enhanced Non CA-based ICIC for LTE | 456d? | 2011-03-22 A | 2012-12-07 A | 100% | 2011-03-22 | 2012-12-07 | 456d? | finish no earlier than 2012-12-07 | R1; R2; R3; R4 | 14592h | 14592h | eICIC_enh_LTE-Core | 26 | China Mobile | ShenXiaodong@chinamobile.com | Rel-11 | 51 | Patrick | eICIC_enh_LTE-Core | RP-121986 |  |
| 6442 | 2145.2 | Perf. part: Further Enhanced Non CA-based ICIC for LTE | 715d? | 2011-03-23 A | 2013-12-06 A | 100% | 2011-03-23 | 2013-12-06 | 715d? | finish no earlier than 2013-12-06 | R4 | 5720h | 5720h | eICIC_enh_LTE-Perf | 26 | China Mobile | ShenXiaodong@chinamobile.com | Rel-11 | 51 | Issam | eICIC_enh_LTE-Perf | RP-131463 |  |
| 6443 | 2145.3 | Test part: Further Enhanced Non CA-based ICIC for LTE | 395d? | 2013-06-15 A | 2014-12-15 A | 100% | 2013-06-18 | 2014-09-12 | 326d? | finish no earlier than 2014-12-15 | R5 | 3160h | 3160h | eICIC_enh_LTE-UEConTest | 31 | ZTE | Carolyn Taylor (carolyn.tayl@zte.com.cn) | Rel-11 | 60 | Ingbert | eICIC_enh_LTE-UEConTest | RP-141847 |  |
| 6444 | 2146 | **New Band LTE Downlink FDD 716-728 MHz (Band 29, Carrier Aggregation of Band 2 and Band 29 and of Band 4 and Band 29)** | 648.38d? | 2011-03-22 A | 2012-12-07 A | 100% | 2011-03-22 | 2012-12-07 | 456d? |  | R4 | 10880h | 10880h | LTE_DL_FDD700 | 26 | AT&T | marc.grant@att.com | Rel-11 | 51 | Issam | LTE_DL_FDD700 |  | CA |
| 6445 | 2146.1 | Core part: New Band LTE Downlink FDD 716-728 MHz (Band 29), Carrier Aggregation of Band 2 and Band 29 and of Band 4 and Band 29 | 453d? | 2011-03-22 A | 2012-12-07 A | 100% | 2011-03-22 | 2012-12-07 | 453d? | finish no earlier than 2012-12-07 | R4 | 3624h | 3624h | LTE_DL_FDD700-Core | 26 | AT&T | marc.grant@att.com | Rel-11 | 51 | Issam | LTE_DL_FDD700-Core | RP-121604 |  |
| 6446 | 2146.2 | Perf. part: New Band LTE Downlink FDD 716-728 MHz (Band 29), Carrier Aggregation of Band 2 and Band 29 and of Band 4 and Band 29 | 451d? | 2011-03-29 A | 2012-12-07 A | 100% | 2011-03-29 | 2012-12-07 | 451d? | finish no earlier than 2012-12-07 | R4 | 3608h | 3608h | LTE_DL_FDD700-Perf | 26 | AT&T | marc.grant@att.com | Rel-11 | 51 | Issam | LTE_DL_FDD700-Perf | RP-121605 |  |
| 6447 | 2147 | **LTE RAN Enhancements for Diverse Data Applications** | 934.88d? | 2011-03-18 A | 2013-09-06 A | 100% | 2011-03-18 | 2013-09-06 | 657d? |  | R2; R5 | 15248h | 15248h | LTE_eDDA | 26 | BlackBerry | Gordon Young (gyoung@rim.com) | Rel-11 | 51 | Yong-Jun | LTE_eDDA |  |  |
| 6448 | 2147.1 | Core part: LTE RAN Enhancements for Diverse Data Applications | 456d? | 2011-03-18 A | 2012-12-07 A | 100% | 2011-03-18 | 2012-12-07 | 456d? | finish no earlier than 2012-12-07 | R2 | 3648h | 3648h | LTE_eDDA-Core | 26 | BlackBerry | Gordon Young (gyoung@rim.com) | Rel-11 | 51 | Yong-Jun | LTE_eDDA-Core | RP-121571 |  |
| 6449 | 2147.2 | Test part: LTE RAN Enhancements for Diverse Data Applications | 136d? | 2013-03-04 A | 2013-09-06 A | 100% | 2013-03-04 | 2013-09-06 | 136d? | finish no earlier than 2013-09-06 | R5 | 1088h | 1088h | LTE_eDDA-UEConTest | 30 | BlackBerry | Enikő Sokondár (esokondar@rim.com) | Rel-11 | 59 | Ingbert | LTE_eDDA-UEConTest | RP-130946 |  |
| 6450 | 2148 | **LTE E850 - Lower Band for Region 2 (non-US), Band 27** | 734.25d? | 2011-03-23 A | 2013-03-01 A | 100% | 2011-03-23 | 2013-03-01 | 516d? |  | R1; R2; R4; R5 | 28496h | 28496h | LTE_e850_LB | 26 | NII Holdings | bill.shvodian@nii.com | Rel-11 | 51 | Patrick | LTE_e850_LB |  |  |
| 6451 | 2148.1 | Core part: LTE E850 - Lower Band for Region 2 (non-US), Band 27 | 328d? | 2011-06-15 A | 2012-09-07 A | 100% | 2011-06-15 | 2012-09-07 | 328d? | finish no earlier than 2012-09-07 | R1; R2; R4 | 7872h | 7872h | LTE_e850_LB-Core | 26 | NII Holdings | bill.shvodian@nii.com | Rel-11 | 51 | Patrick | LTE_e850_LB-Core | RP-120570 |  |
| 6452 | 2148.2 | Perf. part: LTE E850 - Lower Band for Region 2 (non-US), Band 27 | 326d? | 2011-03-23 A | 2012-06-15 A | 100% | 2011-03-23 | 2012-06-15 | 326d? | finish no earlier than 2012-12-07 | R4 | 2608h | 2608h | LTE_e850_LB-Perf | 26 | NII Holdings | bill.shvodian@nii.com | Rel-11 | 51 | Issam | LTE_e850_LB-Perf | RP-120571 |  |
| 6453 | 2148.3 | Test part: LTE E850 - Lower Band for Region 2 (non-US), Band 27 | 189d? | 2012-06-18 A | 2013-03-01 A | 100% | 2012-06-18 | 2013-03-01 | 189d? | finish no earlier than 2013-03-01 | R5 | 1504h | 1504h | LTE_e850_LB-UEConTest | 29 | NII Holdings | bill.shvodian@nii.com | Rel-11 | 56 | Ingbert | LTE_e850_LB-UEConTest | RP-130045 |  |
| 6454 | 2149 | **LTE for 700 MHz Digital Dividend** | 764.12d? | 2011-06-07 A | 2013-06-14 A | 100% | 2011-06-07 | 2013-06-14 | 538d? |  | R4; R2; R3; R5 | 28032h | 28032h | LTE_APAC700 | 27 | Ericsson | olav.queseth@ericsson.com | Rel-11 | 52 | Issam | LTE_APAC700 |  |  |
| 6455 | 2149.1 | Core part: LTE for 700 MHz Digital Dividend | 273d? | 2011-06-07 A | 2012-06-15 A | 100% | 2011-06-07 | 2012-06-15 | 273d? | finish no earlier than 2012-06-15 | R4; R2; R3 | 6552h | 6552h | LTE_APAC700-Core | 27 | Ericsson | olav.queseth@ericsson.com | Rel-11 | 52 | Issam | LTE_APAC700-Core | RP-120572 |  |
| 6456 | 2149.2 | Perf. part: LTE for 700 MHz Digital Dividend | 271d? | 2011-06-09 A | 2012-06-15 A | 100% | 2011-06-09 | 2012-06-15 | 271d? | finish no earlier than 2012-06-15 | R4 | 2168h | 2168h | LTE_APAC700-Perf | 27 | Ericsson | olav.queseth@ericsson.com | Rel-11 | 52 | Issam | LTE_APAC700-Perf | RP-120573 |  |
| 6457 | 2149.3 | Test part: LTE for 700 MHz Digital Dividend | 262d? | 2012-06-18 A | 2013-06-14 A | 100% | 2012-06-18 | 2013-06-14 | 262d? | finish no earlier than 2013-06-14 | R5 | 2096h | 2096h | LTE_APAC700-UEConTest | 29 | Ericsson | fredrik.sundstrom@ericsson.com | Rel-11 | 56 | Ingbert | LTE_APAC700-UEConTest | RP-130467 |  |
| 6458 | 2150 | **Relays for LTE (part 2)** | 1333.88d? | 2009-12-04 A | 2013-06-14 A | 100% | 2009-12-04 | 2013-06-14 | 930d? |  | R4 | 17496.4h | 17496.4h | LTE_Relay2 | 24 | Ericsson | christian.hoymann@ericsson.com | Rel-11 | 46 | Patrick | LTE_Relay2 |  |  |
| 6459 | 2150.1 | Core part: Relays for LTE (part 2) | 333d? | 2011-06-07 A | 2012-09-07 A | 100% | 2011-06-07 | 2012-09-07 | 333d? | finish no earlier than 2012-09-07 | R4 | 2656.39h | 2656.39h | LTE_Relay2-Core | 27 | Ericsson | christian.hoymann@ericsson.com | Rel-11 | 52 | Issam | LTE_Relay2-Core | RP-121008 |  |
| 6460 | 2150.2 | Perf. part: Relays for LTE (part 2) | 925d? | 2009-12-04 A | 2013-06-14 A | 100% | 2009-12-04 | 2013-06-14 | 925d? | finish no earlier than 2013-06-14 | R4 | 7400h | 7400h | LTE_Relay2-Perf | 24 | Ericsson | christian.hoymann@ericsson.com | Rel-11 | 46 | Issam | LTE_Relay2-Perf | RP-130487 |  |
| 6461 | 2151 | **Signalling and Procedure for Interference Avoidance for in-device coexistence** | 461.12d? | 2011-09-19 A | 2012-12-07 A | 100% | 2011-09-19 | 2012-12-07 | 325d? |  | R2; R4 | 12976h | 12976h | SPIA_IDC_LTE | 27 | China Mobile | Zhenping HU | Rel-11 | 53 | Yong-Jun | SPIA_IDC_LTE |  |  |
| 6462 | 2151.1 | Core part: Signalling and Procedure for Interference Avoidance for in-device coexistence | 325d? | 2011-09-19 A | 2012-12-07 A | 100% | 2011-09-19 | 2012-12-07 | 325d? | finish no earlier than 2012-12-07 | R2; R4 | 5200h | 5200h | SPIA_IDC_LTE-Core | 27 | China Mobile | Zhenping HU | Rel-11 | 53 | Yong-Jun | SPIA_IDC_LTE-Core | RP-121573 |  |
| 6463 | 2151.2 | Perf. part: Signalling and Procedure for Interference Avoidance for in-device coexistence | 322d? | 2011-09-20 A | 2012-12-07 A | 100% | 2011-09-20 | 2012-12-07 | 322d? | finish no earlier than 2012-12-07 | R4 | 2576h | 2576h | SPIA_IDC_LTE-Perf | 27 | China Mobile | Zhenping HU | Rel-11 | 53 | Issam | SPIA_IDC_LTE-Perf | RP-121574 |  |

Notes:
- 6440: - / Impacted TSs and TRs: LTE
- 6441: RP#58 completed / Impacted TSs and TRs: 36.101; 36.133; 36.201; 36.211; 36.212; 36.213; 36.214; 36.300; 36.304; 36.321; 36.331; 36.413; 36.423
- 6442: RP#62 completed / Impacted TSs and TRs: 36.101; 36.104; 36.133; 36.141
- 6443: ¦Stat Rep: RP-141131->RP-141847 / Impacted TSs and TRs: 36.508; 36.521-1; 36.521-2; 36.521-3; 36.523-1; 36.523-2; 36.523-3
- 6444: Stage 3 / Impacted TSs and TRs: LTE
- 6445: RP#58 completed / Impacted TSs and TRs: 36.101; 36.104; 36.141; 36.307
- 6446: RP#58 completed / Impacted TSs and TRs: 36.101; 36.104; 36.133; 36.141; 36.307
- 6447: Stage 2/3 / Impacted TSs and TRs: LTE
- 6448: RP#58 completed / Impacted TSs and TRs: 36.300; 36.321; 36.331; new 36.822
- 6449: RP#61 completed / Impacted TSs and TRs: 36.523-1; 36.523-2; 36.523-3
- 6450: Stage 3 / Impacted TSs and TRs: LTE
- 6451: RP#56 completed / Impacted TSs and TRs: 25.101; 25.104; 25.461; 25.466; 36.101; 36.104; 36.113; 36.124; 36.307; 37.104; 37.113
- 6452: RP#56 completed / Impacted TSs and TRs: 25.123; 25.133; 25.141; 36.133; 36.141; 37.141
- 6453: RP#59 completed / Impacted TSs and TRs: 36.508; 36.521-1; 36.521-2; 36.521-3; 36.523-2; 36.523-3; 37.571-1
- 6454: Stage 3. Asian Pacific American Caucus (APAC) Asia-Pacific Telecommunity (APT) Wireless Forum / Impacted TSs and TRs: LTE
- 6455: RP#56 completed. TR 36.820 v100 for Information and Approval / Impacted TSs and TRs: 25.461; 25.466; 36.101; 36.104; 36.113; 36.124; 36.133; 36.307; 37.104; 37.113; new 36.820
- 6456: RP#56 completed / Impacted TSs and TRs: 36.133; 36.141; 37.141
- 6457: RP#60 completed / Impacted TSs and TRs: 36.508; 36.521-1; 36.521-2; 36.521-3; 36.523-2; 36.523-3; 37.571-1
- 6458: Continuation of Rel-10 (open RAN4 Core & Perf parts) / Impacted TSs and TRs: LTE
- 6459: RP#57 completed. TS 36.116, TR 36.826 v100 for Information & Approval. RP#52 Core part not completed in Rel-10 / Impacted TSs and TRs: 36.133; new RAN4 (36.116; 36.826)
- 6460: RP#60 completed. New TS 36.117 v100 for 1-step Approval. RP#52 transferred completely from Rel-10 UID_460213 / Impacted TSs and TRs: 36.133; new 36.117 (E-UTRA Relay conformance testing)
- 6461: Stage 2/3 / Impacted TSs and TRs: LTE
- 6462: RP#58 completed / Impacted TSs and TRs: 36.133; 36.300; 36.306; 36.321; 36.331
- 6463: RP#58 completed / Impacted TSs and TRs: 36.133

| ID | WBS | Task | Duration | Start | Finish | Complete | Baseline start | Baseline finish | Baseline duration | Constraint | Resources | Work | Actual work | Acronym | PCG approved | WI rapporteur name | Release | TSG approved | MCC resp | Acronym_3GU_Export | Status Report | Special Focus Doc |
| --- | --- | --- | --- | --- | --- | --- | --- | --- | --- | --- | --- | --- | --- | --- | --- | --- | --- | --- | --- | --- | --- | --- |
| 6464 | 2152 | **Coordinated Multi-Point Operation for LTE** | 1224.5d? | 2011-09-19 A | 2014-12-15 A | 100% | 2011-09-19 | 2014-09-12 | 791d? |  | R1; R2; R3; R4; R5 | 66128h | 66128h | COMP_LTE | 27 | Huawei, Samsung | Rel-11 | 53 | Patrick | COMP_LTE |  |  |
| 6465 | 2152.1 | Core part: Coordinated Multi-Point Operation for LTE – Uplink | 325d? | 2011-09-19 A | 2012-12-07 A | 100% | 2011-09-19 | 2012-12-07 | 325d? | finish no earlier than 2012-12-07 | R1; R2; R3; R4 | 10400h | 10400h | COMP_LTE_UL-Core | 27 | Huawei | Rel-11 | 53 | Patrick | COMP_LTE_UL-Core | RP-121575 |  |
| 6466 | 2152.2 | Perf. part: Coordinated Multi-Point Operation for LTE – Uplink | 321d? | 2011-09-23 A | 2012-12-07 A | 100% | 2011-09-23 | 2012-12-07 | 321d? | finish no earlier than 2012-12-07 | R4 | 2568h | 2568h | COMP_LTE_UL-Perf | 27 | Huawei | Rel-11 | 53 | Issam | COMP_LTE_UL-Perf | RP-121576 |  |
| 6467 | 2152.3 | Core part: Coordinated Multi-Point Operation for LTE – Downlink | 325d? | 2011-09-19 A | 2012-12-07 A | 100% | 2011-09-19 | 2012-12-07 | 325d? | finish no earlier than 2012-12-07 | R1; R2; R3; R4 | 10400h | 10400h | COMP_LTE_DL-Core | 27 | Samsung | Rel-11 | 53 | Patrick | COMP_LTE_DL-Core | RP-121577 |  |
| 6468 | 2152.4 | Perf. part: Coordinated Multi-Point Operation for LTE – Downlink | 582d? | 2011-09-23 A | 2013-12-06 A | 100% | 2011-09-23 | 2013-12-06 | 582d? | finish no earlier than 2013-12-06 | R4 | 4656h | 4656h | COMP_LTE_DL-Perf | 27 | Samsung | Rel-11 | 53 | Issam | COMP_LTE_DL-Perf | RP-131465 |  |
| 6469 | 2152.5 | Test part: Coordinated Multi-Point Operation for LTE | 463d? | 2013-03-15 A | 2014-12-15 A | 100% | 2013-03-04 | 2014-09-12 | 404d? | finish no earlier than 2014-12-15 | R5 | 3704h | 3704h | COMP_LTE-UEConTest | 30 | Samsung | Rel-11 | 59 | Ingbert | COMP_LTE-UEConTest | RP-141782 |  |
| 6470 | 2153 | **Enhanced downlink control channel(s) for LTE Advanced** | 1043.62d? | 2011-12-09 A | 2014-09-12 A | 100% | 2011-12-09 | 2014-09-12 | 731d? |  | R1; R2; R4; R5 | 38272h | 38272h | LTE_enh_dl_ctrl | 28 | Alcatel-Lucent | Rel-11 | 54 | Patrick | LTE_enh_dl_ctrl |  |  |
| 6471 | 2153.1 | Core part: Enhanced downlink control channel(s) for LTE Advanced | 265d? | 2011-12-09 A | 2012-12-07 A | 100% | 2011-12-09 | 2012-12-07 | 265d? | finish no earlier than 2012-12-07 | R1; R2; R4 | 6360h | 6360h | LTE_enh_dl_ctrl-Core | 28 | Alcatel-Lucent | Rel-11 | 54 | Patrick | LTE_enh_dl_ctrl-Core | RP-121579 |  |
| 6472 | 2153.2 | Perf. part: Enhanced downlink control channel(s) for LTE Advanced | 659d? | 2011-12-16 A | 2014-06-13 A | 100% | 2011-12-16 | 2014-06-13 | 659d? | finish no earlier than 2014-06-13 | R4 | 5272h | 5272h | LTE_enh_dl_ctrl-Perf | 28 | Alcatel-Lucent | Rel-11 | 54 | Issam | LTE_enh_dl_ctrl-Perf | RP-140651 |  |
| 6473 | 2153.3 | Test part: Enhanced downlink control channel(s) for LTE Advanced | 402d? | 2013-03-04 A | 2014-09-12 A | 100% | 2013-03-04 | 2014-09-12 | 402d? | finish no earlier than 2014-09-12 | R5 | 3216h | 3216h | LTE_enh_dl_ctrl-UEConTest | 30 | Huawei | Rel-11 | 59 | Ingbert | LTE_enh_dl_ctrl-UEConTest | RP-141256 |  |
| 6474 | 2154 | **Public Safety Broadband High Power UE for Band 14 for Region 2** | 569.5d? | 2012-03-05 A | 2013-09-06 A | 100% | 2012-03-05 | 2013-09-06 | 403d? |  | R4; R5 | 9144h | 9144h | LTE_B14_PSBB_HPUE | 28 | Motorola Solutions | Rel-11 | 55 | Issam | LTE_B14_PSBB_HPUE |  | Public Safety (A-A) |
| 6475 | 2154.1 | Core part: Public Safety Broadband High Power UE for Band 14 for Region 2 | 201d? | 2012-03-05 A | 2012-12-07 A | 100% | 2012-03-05 | 2012-12-07 | 201d? | finish no earlier than 2012-12-07 | R4 | 1608h | 1608h | LTE_B14_PSBB_HPUE-Core | 28 | Motorola Solutions | Rel-11 | 55 | Issam | LTE_B14_PSBB_HPUE-Core | RP-121581 | Public Safety (A-A) |
| 6476 | 2154.2 | Test part: Public Safety Broadband High Power UE for Band 14 for Region 2 | 138d? | 2013-03-04 A | 2013-09-06 A | 100% | 2013-03-04 | 2013-09-06 | 138d? | finish no earlier than 2013-09-06 | R5 | 1088h | 1088h | LTE_B14_PSBB_HPUE-UEConTest | 30 | Motorola Solutions | Rel-11 | 59 | Ingbert | LTE_B14_PSBB_HPUE-UEConTest | RP-130949 | Public Safety (A-A) |
| 6477 | 2155 | **Improved Minimum Performance Requirements for E-UTRA: Interference Rejection** | 953.38d? | 2012-03-05 A | 2014-09-12 A | 100% | 2012-03-05 | 2014-09-12 | 670d? |  | R4; R5 | 14952h | 14952h | LTE_Interf_Rej | 28 | Renesas Mobile | Rel-11 | 55 | Issam | LTE_Interf_Rej |  |  |
| 6478 | 2155.1 | Perf. part: Improved Minimum Performance Requirements for E-UTRA: Interference Rejection | 201d? | 2012-03-05 A | 2012-12-07 A | 100% | 2012-03-05 | 2012-12-07 | 201d? | finish no earlier than 2012-12-07 | R4 | 1608h | 1608h | LTE_Interf_Rej-Perf | 28 | Renesas Mobile | Rel-11 | 55 | Issam | LTE_Interf_Rej-Perf | RP-121582 |  |
| 6479 | 2155.2 | Test part: Improved Minimum Performance Requirements for E-UTRA: Interference Rejection | 327d? | 2013-06-18 A | 2014-09-12 A | 100% | 2013-06-18 | 2014-09-12 | 327d? | finish no earlier than 2014-09-12 | R5 | 2608h | 2608h | LTE_Interf_Rej-UEConTest | 31 | Broadcom | Rel-11 | 60 | Ingbert | LTE_Interf_Rej-UEConTest | RP-141602 |  |
| 6480 | 2156 | **Additional special subframe configuration for LTE TDD** | 482.75d? | 2012-03-05 A | 2013-06-14 A | 100% | 2012-03-05 | 2013-06-14 | 341d? |  | R4; R2; R3; R5 | 14808h | 14808h | LTE_TDD_add_subframe | 28 | China Mobile | Rel-11 | 55 | Issam | LTE_TDD_add_subframe |  |  |
| 6481 | 2156.1 | Core part: Additional special subframe configuration for LTE TDD | 137d? | 2012-03-05 A | 2012-09-07 A | 100% | 2012-03-05 | 2012-09-07 | 137d? | finish no earlier than 2012-09-07 | R4; R2; R3 | 3288h | 3288h | LTE_TDD_add_subframe-Core | 28 | China Mobile | Rel-11 | 55 | Issam | LTE_TDD_add_subframe-Core | RP-121019 |  |
| 6482 | 2156.2 | Test part: Additional special subframe configuration for LTE TDD | 76d? | 2013-03-04 A | 2013-06-14 A | 100% | 2013-03-04 | 2013-06-14 | 76d? | finish no earlier than 2013-09-13 | R5 | 608h | 608h | LTE_TDD_add_subframe-UEConTest | 30 | Huawei | Rel-11 | 59 | Ingbert | LTE_TDD_add_subframe-UEConTest | RP-130475 |  |
| 6483 | 2157 | **Rel-11 LTE Carrier Aggregation** | 1514.25d? | 2010-12-10 A | 2014-12-12 A | 100% | 2010-12-10 | 2014-12-05 | 1054d? |  | R1; R2; R3; R4; R5 | 315760h | 315760h | LTE_CA_Rel-11 | 30 |  | Rel-11 | 58 | Patrick | LTE_CA_Rel-11 |  | CA |
| 6484 | 2157.1 | **LTE Carrier Aggregation Enhancements** | 1415.75d? | 2011-03-15 A | 2014-12-12 A | 100% | 2011-03-22 | 2014-12-05 | 982d? |  | R1; R2; R3; R4; R5 | 70824h | 70824h | LTE_CA_enh | 26 | Nokia | Rel-11 | 51 | Patrick | LTE_CA_enh |  | CA |
| 6485 | 2157.1.1 | Core part: LTE Carrier Aggregation Enhancements | 646.25d? | 2011-03-22 A | 2013-08-27 A | 100% | 2011-03-22 | 2013-03-01 | 517d? | finish no earlier than 2013-03-01 | R1; R2; R4; R3 | 20680h | 20680h | LTE_CA_enh-Core | 26 | Nokia | Rel-11 | 51 | Patrick | LTE_CA_enh-Core | RP-130059 | CA |
| 6486 | 2157.1.2 | Perf. part: LTE Carrier Aggregation Enhancements | 994d? | 2011-03-15 A | 2014-12-12 A | 100% | 2011-03-29 | 2014-12-05 | 977d? | finish no earlier than 2014-12-15 | R4 | 7936h | 7936h | LTE_CA_enh-Perf | 26 | Nokia | Rel-11 | 51 | Issam | LTE_CA_enh-Perf | RP-141969 | CA |
| 6487 | 2157.1.3 | Test part: LTE Carrier Aggregation Enhancements | 326d? | 2013-06-18 A | 2014-09-12 A | 100% | 2013-06-18 | 2014-09-12 | 326d? | finish no earlier than 2014-09-12 | R5 | 2608h | 2608h | LTE_CA_enh-UEConTest | 31 | Microsoft | Rel-11 | 60 | Ingbert | LTE_CA_enh-UEConTest | RP-141443 | CA |
| 6488 | 2157.2 | UE Conformance Test Aspects – LTE Advanced Carrier Aggregation of Intra-band contiguous and Inter-band configurations | 329d? | 2012-09-11 A | 2013-12-06 A | 100% | 2012-09-11 | 2013-12-06 | 329d? | finish no earlier than 2013-12-06 | R5 | 2624h | 2624h | LTE_CA_intraC_inter_UEConTest | 29 | Nokia | Rel-11 | 57 | Ingbert | LTE_CA_intraC_inter_UEConTest | RP-131446 | CA |

Notes:
- 6464: Stage 3. Triggered by Rel-11 TR 36.819 Study on Coordinated Multi-Point Operation for LTE (FS_CoMP_LTE) / Impacted TSs and TRs: LTE / WI rapporteur e-mail: Juho Lee (juho95.lee@samsung.com), david.mazzarese@huawei.com
- 6465: RP#58 completed / Impacted TSs and TRs: 36.101; 36.104; 36.133; 36.201; 36.211; 36.212; 36.213; 36.214; 36.300; 36.306; 36.321; 36.331; 36.423 / WI rapporteur e-mail: david.mazzarese@huawei.com
- 6466: RP#58 completed / Impacted TSs and TRs: 36.101; 36.104; 36.133; 36.141 / WI rapporteur e-mail: Xinwei Zhi (zhixinwei@huawei.com)
- 6467: RP#58 completed / Impacted TSs and TRs: 36.101; 36.104; 36.133; 36.201; 36.211; 36.212; 36.213; 36.214; 36.300; 36.306; 36.321; 36.331; 36.423 / WI rapporteur e-mail: Juho Lee (juho95.lee@samsung.com)
- 6468: RP#62 completed / Impacted TSs and TRs: 36.101; 36.104; 36.133; 36.141; 36.307 / WI rapporteur e-mail: xutao.zhou@samsung.com
- 6469: Impacted TSs and TRs: 36.508; 36.521-1; 36.521-2; 36.523-1; 36.523-2; 36.523-3 / WI rapporteur e-mail: Stoyan.Baev@partner.samsung.com
- 6470: Stage 3. RP#58 Core completed. Triggered by UID_510037 Rel-11 TR 36.871 Study on further Downlink MIMO enhancements for LTE-Advanced (FS_LTE_eDL_MIMO_enh) / Impacted TSs and TRs: LTE / WI rapporteur e-mail: sigen.ye@alcatel-lucent.com
- 6471: RP#58 completed / Impacted TSs and TRs: 36.101; 36.211; 36.212; 36.213; 36.331 / WI rapporteur e-mail: sigen.ye@alcatel-lucent.com
- 6472: RP#64 completed / Impacted TSs and TRs: 36.101; 36.104; 36.133; 36.141 / WI rapporteur e-mail: teck.hu@alcatel-lucent.com
- 6473: RP#65 completed / Impacted TSs and TRs: 36.508; 36.521-1; 36.521-2; 36.523-1; 36.523-2; 36.523-3 / WI rapporteur e-mail: Xu Kai (xk.xukai@huawei.com)
- 6474: Stage 3 / Impacted TSs and TRs: LTE / WI rapporteur e-mail: xiaowei.jin@motorolasolutions.com
- 6475: RP#58 completed. TR 36.837 v100 for Information and Approval / Impacted TSs and TRs: 36.101; new 36.837 / WI rapporteur e-mail: xiaowei.jin@motorolasolutions.com
- 6476: RP#61 completed / Impacted TSs and TRs: 36.521-1; 36.521-2 / WI rapporteur e-mail: xiaowei.jin@motorolasolutions.com
- 6477: RP#58 completed. Triggered by FS_enh_perf_UE_LTE. Adds Perf. requirements for demodulation of the already specified PDSCH with the transmission modes defined in Rel-8 to Rel-10 / Impacted TSs and TRs: LTE / WI rapporteur e-mail: Timo Roman
- 6478: RP#58 completed / Impacted TSs and TRs: 36.101 / WI rapporteur e-mail: Timo Roman
- 6479: RP#65 completed. TR 36.904 for 1-step Approval. Testing for 36.101 / Impacted TSs and TRs: 36.508; 36.521-1; 36.521-2; New 36.904 / WI rapporteur e-mail: jarkko.hellsten@kolumbus.fi
- 6480: Stage 3. Exists already for 1UL a WI LTE_CA_B3_B5 / Impacted TSs and TRs: LTE / WI rapporteur e-mail: Xiaodong Shen
- 6481: RP#57 completed / Impacted TSs and TRs: 36.211; 36.213; 36.331; 36.423 / WI rapporteur e-mail: Xiaodong Shen
- 6482: RP#60 completed / Impacted TSs and TRs: 36.508; 36.523-1; 36.523-2; 36.523-3 / WI rapporteur e-mail: Li Xiang (tricia.li@huawei.com)
- 6483: LTE_CA_Rel-11 / Impacted TSs and TRs: LTE
- 6484: Stage 3 / Impacted TSs and TRs: LTE / WI rapporteur e-mail: lars.e.lindh@nokia.com
- 6485: RP#59 completed. New TR 36.823 v100 for Information and Approval / Impacted TSs and TRs: 36.101; 36.104; 36.133; 36.201; 36.211; 36.212; 36.213; 36.300; 36.302; 36.306; 36.321; 36.331; 36.413; 36.423; new 36.823 / WI rapporteur e-mail: lars.e.lindh@nokia.com
- 6486: ¦Stat Rep: RP-141377->RP-141969 / Impacted TSs and TRs: 36.101; 36.104; 36.133; 36.141 / WI rapporteur e-mail: lars.e.lindh@nokia.com
- 6487: SP#65 completed / Impacted TSs and TRs: 36.508; 36.521-1; 36.521-2; 36.521-3; 36.523-1; 36.523-2; 36.523-3 / WI rapporteur e-mail: jussi.kuusisto@microsoft.com
- 6488: RP#62 completed / Impacted TSs and TRs: 36.508; 36.521-1; 36.521-2; 36.521-3; 36.523-1; 36.523-2; 36.523-3; 37.571-1 / WI rapporteur e-mail: jussi.kuusisto@nokia.com

| ID | WBS | Task | Duration | Start | Finish | Complete | Baseline start | Baseline finish | Baseline duration | Constraint | Resources | Work | Actual work | PCG approved | Impacted TSs and TRs | Release | TSG approved | MCC resp | Special Focus Doc | Acronym | WI rapporteur name | WI rapporteur e-mail | Acronym_3GU_Export | Status Report |
| --- | --- | --- | --- | --- | --- | --- | --- | --- | --- | --- | --- | --- | --- | --- | --- | --- | --- | --- | --- | --- | --- | --- | --- | --- |
| 6489 | 2157.3 | **Rel-11 inter-band Carrier Aggregation** | 754.12d? | 2010-12-10 A | 2012-12-07 A | 100% | 2010-12-10 | 2012-12-07 | 528d? |  | R4 | 180968h | 180968h | 30 | LTE | Rel-11 | 58 | Issam | CA |  |  |  |  |  |
| 6490 | 2157.3.1 | **LTE Advanced Carrier Aggregation of Band 3 and Band 7** | 754.12d? | 2010-12-10 A | 2012-12-07 A | 100% | 2010-12-10 | 2012-12-07 | 528d? |  | R4 | 12040h | 12040h | 25 | LTE | Rel-11 | 48 | Issam | CA | LTE_CA_B3_B7 | TeliaSonera | Ralf.Schuh@TeliaSonera.com | LTE_CA_B3_B7 |  |
| 6491 | 2157.3.1.1 | Core part: LTE Advanced Carrier Aggregation of Band 3 and Band 7 | 456d? | 2010-12-10 A | 2012-09-07 A | 100% | 2010-12-10 | 2012-09-07 | 456d? | finish no earlier than 2012-09-07 | R4 | 3648h | 3648h | 25 | 36.101; 36.104; 36.307; new generic 36.850 | Rel-11 | 48 | Issam | CA | LTE_CA_B3_B7-Core | TeliaSonera | Ralf.Schuh@TeliaSonera.com | LTE_CA_B3_B7-Core | RP-121022 |
| 6492 | 2157.3.1.2 | Perf. part: LTE Advanced Carrier Aggregation of Band 3 and Band 7 | 523d? | 2010-12-17 A | 2012-12-07 A | 100% | 2010-12-17 | 2012-12-07 | 523d? | finish no earlier than 2012-12-07 | R4 | 4168h | 4168h | 25 | 36.133; 36.141 | Rel-11 | 48 | Issam | CA | LTE_CA_B3_B7-Perf | TeliaSonera | Ralf.Schuh@TeliaSonera.com | LTE_CA_B3_B7-Perf | RP-121023 |
| 6493 | 2157.3.2 | **LTE Advanced Carrier Aggregation of Band 4 and Band 17** | 754.12d? | 2010-12-10 A | 2012-12-07 A | 100% | 2010-12-10 | 2012-12-07 | 528d? |  | R4 | 12064h | 12064h | 26 | LTE | Rel-11 | 50 | Issam | CA | LTE_CA_B4_B17 | AT&T | marc.grant@att.com | LTE_CA_B4_B17 |  |
| 6494 | 2157.3.2.1 | Core part: LTE Advanced Carrier Aggregation of Band 4 and Band 17 | 459d? | 2010-12-10 A | 2012-09-07 A | 100% | 2010-12-10 | 2012-09-07 | 459d? | finish no earlier than 2012-09-07 | R4 | 3672h | 3672h | 26 | 36.101; 36.104; 36.133; 36.141; 36.307; new generic 36.850 | Rel-11 | 50 | Issam | CA | LTE_CA_B4_B17-Core | AT&T | marc.grant@att.com | LTE_CA_B4_B17-Core | RP-121024 |
| 6495 | 2157.3.2.2 | Perf. part: LTE Advanced Carrier Aggregation of Band 4 and Band 17 | 521d? | 2010-12-17 A | 2012-12-07 A | 100% | 2010-12-17 | 2012-12-07 | 521d? | finish no earlier than 2012-12-07 | R4 | 4168h | 4168h | 26 | 36.101; 36.104; 36.133; 36.307 | Rel-11 | 50 | Issam | CA | LTE_CA_B4_B17-Perf | AT&T | marc.grant@att.com | LTE_CA_B4_B17-Perf | RP-121595 |
| 6496 | 2157.3.3 | **LTE Advanced Carrier Aggregation of Band 4 and Band 13** | 754.12d? | 2010-12-10 A | 2012-12-07 A | 100% | 2010-12-10 | 2012-12-07 | 528d? |  | R4 | 12040h | 12040h | 26 | LTE | Rel-11 | 50 | Issam | CA | LTE_CA_B4_B13 | Ericsson | christian.bergljung@ericsson.com | LTE_CA_B4_B13 |  |
| 6497 | 2157.3.3.1 | Core part: LTE Advanced Carrier Aggregation of Band 4 and Band 13 | 456d? | 2010-12-10 A | 2012-09-07 A | 100% | 2010-12-10 | 2012-09-07 | 456d? | finish no earlier than 2012-09-07 | R4 | 3648h | 3648h | 26 | 36.101; 36.104; 36.133; 36.307; new generic 36.850 | Rel-11 | 50 | Issam | CA | LTE_CA_B4_B13-Core | Ericsson | christian.bergljung@ericsson.com | LTE_CA_B4_B13-Core | RP-121026 |
| 6498 | 2157.3.3.2 | Perf. part: LTE Advanced Carrier Aggregation of Band 4 and Band 13 | 521d? | 2010-12-21 A | 2012-12-07 A | 100% | 2010-12-21 | 2012-12-07 | 521d? | finish no earlier than 2012-12-07 | R4 | 4168h | 4168h | 26 | 36.101; 36.133; 36.141 | Rel-11 | 50 | Issam | CA | LTE_CA_B4_B13-Perf | Ericsson | christian.bergljung@ericsson.com | LTE_CA_B4_B13-Perf | RP-121594 |
| 6499 | 2157.3.4 | **LTE Advanced Carrier Aggregation of Band 4 and Band 12** | 648.38d? | 2011-03-22 A | 2012-12-07 A | 100% | 2011-03-22 | 2012-12-07 | 456d? |  | R4; R2 | 18200h | 18200h | 26 | LTE | Rel-11 | 51 | Issam | CA | LTE_CA_B4_B12 | Leap Wireless | Bill Chandler (bchandler@cricketcommunications.com) | LTE_CA_B4_B12 |  |
| 6500 | 2157.3.4.1 | Core part: LTE Advanced Carrier Aggregation of Band 4 and Band 12 | 456d? | 2011-03-22 A | 2012-12-07 A | 100% | 2011-03-22 | 2012-12-07 | 456d? | finish no earlier than 2012-12-07 | R4; R2 | 7296h | 7296h | 26 | 36.101; 36.104; 36.307; new generic 36.850 | Rel-11 | 51 | Issam | CA | LTE_CA_B4_B12-Core | Leap Wireless | Bill Chandler (bchandler@cricketcommunications.com) | LTE_CA_B4_B12-Core | RP-121592 |
| 6501 | 2157.3.4.2 | Perf. part: LTE Advanced Carrier Aggregation of Band 4 and Band 12 | 451d? | 2011-03-29 A | 2012-12-07 A | 100% | 2011-03-29 | 2012-12-07 | 451d? | finish no earlier than 2012-12-07 | R4 | 3608h | 3608h | 26 | 36.133; 36.141 | Rel-11 | 51 | Issam | CA | LTE_CA_B4_B12-Perf | Leap Wireless | Bill Chandler (bchandler@cricketcommunications.com) | LTE_CA_B4_B12-Perf | RP-121593 |
| 6502 | 2157.3.5 | **LTE Advanced Carrier Aggregation of Band 5 and Band 12** | 648.38d? | 2011-03-22 A | 2012-12-07 A | 100% | 2011-03-22 | 2012-12-07 | 456d? |  | R4; R2 | 18200h | 18200h | 26 | LTE | Rel-11 | 51 | Issam | CA | LTE_CA_B5_B12 | US Cellular | sebastian.thalanany@uscellular.com | LTE_CA_B5_B12 |  |
| 6503 | 2157.3.5.1 | Core part: LTE Advanced Carrier Aggregation of Band 5 and Band 12 | 456d? | 2011-03-22 A | 2012-12-07 A | 100% | 2011-03-22 | 2012-12-07 | 456d? | finish no earlier than 2012-12-07 | R4; R2 | 7296h | 7296h | 26 | 36.101; 36.104; 36.133; 36.141; 36.307; new generic 36.850 | Rel-11 | 51 | Issam | CA | LTE_CA_B5_B12-Core | US Cellular | sebastian.thalanany@uscellular.com | LTE_CA_B5_B12-Core | RP-121596 |
| 6504 | 2157.3.5.2 | Perf. part: LTE Advanced Carrier Aggregation of Band 5 and Band 12 | 451d? | 2011-03-25 A | 2012-12-07 A | 100% | 2011-03-25 | 2012-12-07 | 451d? | finish no earlier than 2012-12-07 | R4 | 3608h | 3608h | 26 | 36.101; 36.104; 36.133; 36.307 | Rel-11 | 51 | Issam | CA | LTE_CA_B5_B12-Perf | US Cellular | sebastian.thalanany@uscellular.com | LTE_CA_B5_B12-Perf | RP-121597 |
| 6505 | 2157.3.6 | **LTE Advanced Carrier Aggregation of Band 7 and Band 20** | 554.38d? | 2011-03-22 A | 2012-09-07 A | 100% | 2011-03-22 | 2012-09-07 | 389d? |  | R4 | 9288h | 9288h | 26 | LTE | Rel-11 | 51 | Issam | CA | LTE_CA_B7_B20 | Huawei | Steven Chen | LTE_CA_B7_B20 |  |
| 6506 | 2157.3.6.1 | Core part: LTE Advanced Carrier Aggregation of Band 7 and Band 20 | 386d? | 2011-03-22 A | 2012-09-07 A | 100% | 2011-03-22 | 2012-09-07 | 386d? | finish no earlier than 2012-09-07 | R4 | 3088h | 3088h | 26 | 36.101; 36.104; 36.307; new generic 36.850 | Rel-11 | 51 | Issam | CA | LTE_CA_B7_B20-Core | Huawei | Steven Chen | LTE_CA_B7_B20-Core | RP-121032 |
| 6507 | 2157.3.6.2 | Perf. part: LTE Advanced Carrier Aggregation of Band 7 and Band 20 | 386d? | 2011-03-25 A | 2012-09-07 A | 100% | 2011-03-25 | 2012-09-07 | 386d? | finish no earlier than 2012-09-07 | R4 | 3088h | 3088h | 26 | 36.133; 36.141 | Rel-11 | 51 | Issam | CA | LTE_CA_B7_B20-Perf | Huawei | Steven Chen | LTE_CA_B7_B20-Perf | RP-121033 |
| 6508 | 2157.3.7 | **LTE Advanced Carrier Aggregation of Band 2 and Band 17** | 647.38d? | 2011-03-23 A | 2012-12-07 A | 100% | 2011-03-23 | 2012-12-07 | 455d? |  | R4 | 10336h | 10336h | 26 | LTE | Rel-11 | 51 | Issam | CA | LTE_CA_B2_B17 | AT&T | marc.grant@att.com | LTE_CA_B2_B17 |  |
| 6509 | 2157.3.7.1 | Core part: LTE Advanced Carrier Aggregation of Band 2 and Band 17 | 386d? | 2011-03-23 A | 2012-09-07 A | 100% | 2011-03-23 | 2012-09-07 | 386d? | finish no earlier than 2012-09-07 | R4 | 3088h | 3088h | 26 | 36.101; 36.104; 36.133; 36.141; 36.307; new generic 36.850 | Rel-11 | 51 | Issam | CA | LTE_CA_B2_B17-Core | AT&T | marc.grant@att.com | LTE_CA_B2_B17-Core | RP-121034 |
| 6510 | 2157.3.7.2 | Perf. part: LTE Advanced Carrier Aggregation of Band 2 and Band 17 | 451d? | 2011-03-25 A | 2012-12-07 A | 100% | 2011-03-25 | 2012-12-07 | 451d? | finish no earlier than 2012-12-07 | R4 | 3608h | 3608h | 26 | 36.101; 36.104; 36.133; 36.307 | Rel-11 | 51 | Issam | CA | LTE_CA_B2_B17-Perf | AT&T | marc.grant@att.com | LTE_CA_B2_B17-Perf | RP-121585 |
| 6511 | 2157.3.8 | **LTE Advanced Carrier Aggregation of Band 4 and Band 5** | 647.38d? | 2011-03-23 A | 2012-12-07 A | 100% | 2011-03-23 | 2012-12-07 | 455d? |  | R4 | 10856h | 10856h | 26 | LTE | Rel-11 | 51 | Issam | CA | LTE_CA_B4_B5 | AT&T | marc.grant@att.com | LTE_CA_B4_B5 |  |
| 6512 | 2157.3.8.1 | Core part: LTE Advanced Carrier Aggregation of Band 4 and Band 5 | 451d? | 2011-03-23 A | 2012-12-07 A | 100% | 2011-03-23 | 2012-12-07 | 451d? | finish no earlier than 2012-12-07 | R4 | 3608h | 3608h | 26 | 36.101; 36.104; 36.133; 36.141; 36.307; new generic 36.850 | Rel-11 | 51 | Issam | CA | LTE_CA_B4_B5-Core | AT&T | marc.grant@att.com | LTE_CA_B4_B5-Core | RP-121757 |
| 6513 | 2157.3.8.2 | Perf. part: LTE Advanced Carrier Aggregation of Band 4 and Band 5 | 451d? | 2011-03-25 A | 2012-12-07 A | 100% | 2011-03-25 | 2012-12-07 | 451d? | finish no earlier than 2012-12-07 | R4 | 3608h | 3608h | 26 | 36.101; 36.104; 36.133; 36.307 | Rel-11 | 51 | Issam | CA | LTE_CA_B4_B5-Perf | AT&T | marc.grant@att.com | LTE_CA_B4_B5-Perf | RP-121589 |

Notes:
- 6489: LTE_CA_Rel-11
- 6490: RP#57 completed. In Europe Band 3,7,20 are interesting for LTE and LTE-Advanced deployment. Different CA combinations for these bands are of high priority for Region 1
- 6491: RP#57 completed. RP#59 new generic TR 36.850v100 for Information and Approval
- 6492: RP#57 completed
- 6493: Stage 3. RP#57 Core completed. RP#58 Perf completed
- 6494: RP#57 completed. RP#59 new generic TR 36.850v100 for Information and Approval
- 6495: RP#58 completed
- 6496: Stage 3. RP#57 Core completed. RP#58 Perf completed
- 6497: RP#57 completed
- 6498: RP#58 completed
- 6499: Stage 3. RP#58 completed
- 6500: RP#58 completed. RP#59 new generic TR 36.850v100 for Information and Approval
- 6501: RP#58 completed
- 6502: Stage 3. RP#58 completed
- 6503: RP#58 completed. RP#59 new generic TR 36.850v100 for Information and Approval
- 6504: RP#58 completed
- 6505: Stage 3. RP#57 completed
- 6506: RP#57 completed. RP#59 new generic TR 36.850v100 for Information and Approval
- 6507: RP#57 completed
- 6508: Stage 3. RP#57 Core completed. RP#58 Perf completed
- 6509: RP#57 completed. RP#59 new generic TR 36.850v100 for Information and Approval
- 6510: RP#58 completed
- 6511: Stage 3. RP#58 completed
- 6512: RP#58 completed. RP#59 new generic TR 36.850v100 for Information and Approval
- 6513: RP#58 completed

| ID | WBS | Task | Duration | Start | Finish | Complete | Baseline start | Baseline finish | Baseline duration | Constraint | Resources | Work | Actual work | Acronym | PCG approved | WI rapporteur name | WI rapporteur e-mail | Release | TSG approved | MCC resp | Special Focus Doc | Acronym_3GU_Export | Status Report |
| --- | --- | --- | --- | --- | --- | --- | --- | --- | --- | --- | --- | --- | --- | --- | --- | --- | --- | --- | --- | --- | --- | --- | --- |
| 6514 | 2157.3.9 | **LTE Advanced Carrier Aggregation of Band 5 and Band 17** | 647.38d? | 2011-03-23 A | 2012-12-07 A | 100% | 2011-03-23 | 2012-12-07 | 455d? |  | R4 | 10856h | 10856h | LTE_CA_B5_B17 | 26 | AT&T | marc.grant@att.com | Rel-11 | 51 | Issam | CA | LTE_CA_B5_B17 |  |
| 6515 | 2157.3.9.1 | Core part: LTE Advanced Carrier Aggregation of Band 5 and Band 17 | 451d? | 2011-03-23 A | 2012-12-07 A | 100% | 2011-03-23 | 2012-12-07 | 451d? | finish no earlier than 2012-12-07 | R4 | 3608h | 3608h | LTE_CA_B5_B17-Core | 26 | AT&T | marc.grant@att.com | Rel-11 | 51 | Issam | CA | LTE_CA_B5_B17-Core | RP-121598 |
| 6516 | 2157.3.9.2 | Perf. part: LTE Advanced Carrier Aggregation of Band 5 and Band 17 | 451d? | 2011-03-25 A | 2012-12-07 A | 100% | 2011-03-25 | 2012-12-07 | 451d? | finish no earlier than 2012-12-07 | R4 | 3608h | 3608h | LTE_CA_B5_B17-Perf | 26 | AT&T | marc.grant@att.com | Rel-11 | 51 | Issam | CA | LTE_CA_B5_B17-Perf | RP-121599 |
| 6517 | 2157.3.10 | **LTE Advanced Carrier Aggregation of Band 3 and Band 20** | 367.12d? | 2011-09-19 A | 2012-09-07 A | 100% | 2011-09-19 | 2012-09-07 | 258d? |  | R4 | 6168h | 6168h | LTE_CA_B3_B20 | 27 | Vodafone | tim.frost@vodafone.com | Rel-11 | 53 | Issam | CA | LTE_CA_B3_B20 |  |
| 6518 | 2157.3.10.1 | Core part: LTE Advanced Carrier Aggregation of Band 3 and Band 20 | 256d? | 2011-09-19 A | 2012-09-07 A | 100% | 2011-09-19 | 2012-09-07 | 256d? | finish no earlier than 2012-09-07 | R4 | 2048h | 2048h | LTE_CA_B3_B20-Core | 27 | Vodafone | tim.frost@vodafone.com | Rel-11 | 53 | Issam | CA | LTE_CA_B3_B20-Core | RP-121046 |
| 6519 | 2157.3.10.2 | Perf. part: LTE Advanced Carrier Aggregation of Band 3 and Band 20 | 257d? | 2011-09-20 A | 2012-09-07 A | 100% | 2011-09-20 | 2012-09-07 | 257d? | finish no earlier than 2012-09-07 | R4 | 2056h | 2056h | LTE_CA_B3_B20-Perf | 27 | Vodafone | tim.frost@vodafone.com | Rel-11 | 53 | Issam | CA | LTE_CA_B3_B20-Perf | RP-121047 |
| 6520 | 2157.3.11 | **LTE Advanced Carrier Aggregation of Band 8 and Band 20** | 461.12d? | 2011-09-19 A | 2012-12-07 A | 100% | 2011-09-19 | 2012-12-07 | 325d? |  | R4 | 7752h | 7752h | LTE_CA_B8_B20 | 27 | Vodafone | Luis.Anaya@vodafone.com | Rel-11 | 53 | Issam | CA | LTE_CA_B8_B20 |  |
| 6521 | 2157.3.11.1 | Core part: LTE Advanced Carrier Aggregation of Band 8 and Band 20 | 323d? | 2011-09-19 A | 2012-12-07 A | 100% | 2011-09-19 | 2012-12-07 | 323d? | finish no earlier than 2012-12-07 | R4 | 2584h | 2584h | LTE_CA_B8_B20-Core | 27 | Vodafone | Luis.Anaya@vodafone.com | Rel-11 | 53 | Issam | CA | LTE_CA_B8_B20-Core | RP-121600 |
| 6522 | 2157.3.11.2 | Perf. part: LTE Advanced Carrier Aggregation of Band 8 and Band 20 | 321d? | 2011-09-23 A | 2012-12-07 A | 100% | 2011-09-23 | 2012-12-07 | 321d? | finish no earlier than 2012-12-07 | R4 | 2568h | 2568h | LTE_CA_B8_B20-Perf | 27 | Vodafone | Luis.Anaya@vodafone.com | Rel-11 | 53 | Issam | CA | LTE_CA_B8_B20-Perf | RP-121601 |
| 6523 | 2157.3.12 | **LTE Advanced Carrier Aggregation of Band 3 and Band 5** | 367.12d? | 2011-09-19 A | 2012-09-07 A | 100% | 2011-09-19 | 2012-09-07 | 258d? |  | R4 | 6160h | 6160h | LTE_CA_B3_B5 | 27 | SK Telecom | Haesung Park | Rel-11 | 53 | Issam | CA | LTE_CA_B3_B5 |  |
| 6524 | 2157.3.12.1 | Core part: LTE Advanced Carrier Aggregation of Band 3 and Band 5 | 256d? | 2011-09-19 A | 2012-09-07 A | 100% | 2011-09-19 | 2012-09-07 | 256d? | finish no earlier than 2012-09-07 | R4 | 2048h | 2048h | LTE_CA_B3_B5-Core | 27 | SK Telecom | Haesung Park | Rel-11 | 53 | Issam | CA | LTE_CA_B3_B5-Core | RP-121042 |
| 6525 | 2157.3.12.2 | Perf. part: LTE Advanced Carrier Aggregation of Band 3 and Band 5 | 256d? | 2011-09-21 A | 2012-09-07 A | 100% | 2011-09-21 | 2012-09-07 | 256d? | finish no earlier than 2012-09-07 | R4 | 2048h | 2048h | LTE_CA_B3_B5-Perf | 27 | SK Telecom | Haesung Park | Rel-11 | 53 | Issam | CA | LTE_CA_B3_B5-Perf | RP-121043 |
| 6526 | 2157.3.13 | **LTE Advanced Carrier Aggregation of Band 4 and Band 7** | 461.12d? | 2011-09-19 A | 2012-12-07 A | 100% | 2011-09-19 | 2012-12-07 | 325d? |  | R4 | 7744h | 7744h | LTE_CA_B4_B7 | 27 | Rogers Wireless | takwing.wan@rci.rogers.com | Rel-11 | 53 | Issam | CA | LTE_CA_B4_B7 |  |
| 6527 | 2157.3.13.1 | Core part: LTE Advanced Carrier Aggregation of Band 4 and Band 7 | 322d? | 2011-09-19 A | 2012-12-07 A | 100% | 2011-09-19 | 2012-12-07 | 322d? | finish no earlier than 2012-12-07 | R4 | 2576h | 2576h | LTE_CA_B4_B7-Core | 27 | Rogers Wireless | takwing.wan@rci.rogers.com | Rel-11 | 53 | Issam | CA | LTE_CA_B4_B7-Core | RP-121590 |
| 6528 | 2157.3.13.2 | Perf. part: LTE Advanced Carrier Aggregation of Band 4 and Band 7 | 321d? | 2011-09-23 A | 2012-12-07 A | 100% | 2011-09-23 | 2012-12-07 | 321d? | finish no earlier than 2012-12-07 | R4 | 2568h | 2568h | LTE_CA_B4_B7-Perf | 27 | Rogers Wireless | takwing.wan@rci.rogers.com | Rel-11 | 53 | Issam | CA | LTE_CA_B4_B7-Perf | RP-121591 |
| 6529 | 2157.3.14 | **LTE Advanced Carrier Aggregation of Band 11 and Band 18** | 377.5d? | 2011-12-09 A | 2012-12-07 A | 100% | 2011-12-09 | 2012-12-07 | 265d? |  | R4; R2 | 10568h | 10568h | LTE_CA_B11_B18 | 28 | KDDI | Masaaki Obara (ms-obara@kddi.com) | Rel-11 | 54 | Issam | CA | LTE_CA_B11_B18 |  |
| 6530 | 2157.3.14.1 | Core part: LTE Advanced Carrier Aggregation of Band 11 and Band 18 | 265d? | 2011-12-09 A | 2012-12-07 A | 100% | 2011-12-09 | 2012-12-07 | 265d? | finish no earlier than 2012-12-07 | R4; R2 | 4240h | 4240h | LTE_CA_B11_B18-Core | 28 | KDDI | Masaaki Obara (ms-obara@kddi.com) | Rel-11 | 54 | Issam | CA | LTE_CA_B11_B18-Core | RP-121602 |
| 6531 | 2157.3.14.2 | Perf. part: LTE Advanced Carrier Aggregation of Band 11 and Band 18 | 261d? | 2011-12-15 A | 2012-12-07 A | 100% | 2011-12-15 | 2012-12-07 | 261d? | finish no earlier than 2012-12-07 | R4 | 2088h | 2088h | LTE_CA_B11_B18-Perf | 28 | KDDI | Masaaki Obara (ms-obara@kddi.com) | Rel-11 | 54 | Issam | CA | LTE_CA_B11_B18-Perf | RP-121603 |
| 6532 | 2157.3.15 | **LTE Advanced Carrier Aggregation of Band 1 and Band 18** | 283.5d? | 2011-12-09 A | 2012-09-07 A | 100% | 2011-12-09 | 2012-09-07 | 198d? |  | R4; R2 | 7904h | 7904h | LTE_CA_B1_B18 | 28 | KDDI | Masaaki Obara (ms-obara@kddi.com) | Rel-11 | 54 | Issam | CA | LTE_CA_B1_B18 |  |
| 6533 | 2157.3.15.1 | Core part: LTE Advanced Carrier Aggregation of Band 1 and Band 18 | 198d? | 2011-12-09 A | 2012-09-07 A | 100% | 2011-12-09 | 2012-09-07 | 198d? | finish no earlier than 2012-09-07 | R4; R2 | 3168h | 3168h | LTE_CA_B1_B18-Core | 28 | KDDI | Masaaki Obara (ms-obara@kddi.com) | Rel-11 | 54 | Issam | CA | LTE_CA_B1_B18-Core | RP-121052 |
| 6534 | 2157.3.15.2 | Perf. part: LTE Advanced Carrier Aggregation of Band 1 and Band 18 | 196d? | 2011-12-13 A | 2012-09-07 A | 100% | 2011-12-13 | 2012-09-07 | 196d? | finish no earlier than 2012-12-07 | R4 | 1568h | 1568h | LTE_CA_B1_B18-Perf | 28 | KDDI | Masaaki Obara (ms-obara@kddi.com) | Rel-11 | 54 | Issam | CA | LTE_CA_B1_B18-Perf | RP-121053 |
| 6535 | 2157.3.16 | **LTE Advanced Carrier Aggregation of Band 1 and Band 19** | 280.25d? | 2011-12-12 A | 2012-09-07 A | 100% | 2011-12-12 | 2012-09-07 | 197d? |  | R4; R2 | 6432h | 6432h | LTE_CA_B1_B19 | 28 | NTT DoCoMo | Hiromasa Umeda (umedah@nttdocomo.co.jp) | Rel-11 | 54 | Issam | CA | LTE_CA_B1_B19 |  |
| 6536 | 2157.3.16.1 | Core part: LTE Advanced Carrier Aggregation of Band 1 and Band 19 | 137d? | 2012-03-05 A | 2012-09-07 A | 100% | 2012-03-05 | 2012-09-07 | 137d? | finish no earlier than 2012-09-07 | R4; R2 | 2192h | 2192h | LTE_CA_B1_B19-Core | 28 | NTT DoCoMo | Hiromasa Umeda (umedah@nttdocomo.co.jp) | Rel-11 | 54 | Issam | CA | LTE_CA_B1_B19-Core | RP-120552 |
| 6537 | 2157.3.16.2 | Perf. part: LTE Advanced Carrier Aggregation of Band 1 and Band 19 | 136d? | 2011-12-12 A | 2012-06-15 A | 100% | 2011-12-12 | 2012-06-15 | 136d? | finish no earlier than 2012-12-07 | R4 | 1088h | 1088h | LTE_CA_B1_B19-Perf | 28 | NTT DoCoMo | Hiromasa Umeda (umedah@nttdocomo.co.jp) | Rel-11 | 54 | Issam | CA | LTE_CA_B1_B19-Perf | RP-120553 |

Notes:
- 6514: Stage 3. RP#58 completed / Impacted TSs and TRs: LTE
- 6515: RP#58 completed. RP#59 new generic TR 36.850v100 for Information and Approval / Impacted TSs and TRs: 36.101; 36.104; 36.133; 36.141; 36.307; new generic 36.850
- 6516: RP#58 completed / Impacted TSs and TRs: 36.101; 36.104; 36.133; 36.141; 36.307
- 6517: Stage 3. RP#57 completed / Impacted TSs and TRs: LTE
- 6518: RP#57 completed. RP#59 new generic TR 36.850v100 for Information and Approval / Impacted TSs and TRs: 36.101; 36.104; 36.133; 36.307; new generic 36.850
- 6519: RP#57 completed / Impacted TSs and TRs: 36.101; 36.104; 36.133; 36.141; 36.307
- 6520: Stage 3. RP#58 completed / Impacted TSs and TRs: LTE
- 6521: RP#58 completed. RP#59 new generic TR 36.850v100 for Information and Approval / Impacted TSs and TRs: 36.101; 36.104; 36.307; new generic 36.850
- 6522: RP#58 completed / Impacted TSs and TRs: 36.101; 36.104; 36.133; 36.141
- 6523: Stage 3. RP#57 completed / Impacted TSs and TRs: LTE
- 6524: RP#57 completed. RP#59 new generic TR 36.850v100 for Information and Approval / Impacted TSs and TRs: 36.101; 36.104; 36.133; 36.307; new generic 36.850
- 6525: RP#57 completed / Impacted TSs and TRs: 36.133; 36.141
- 6526: Stage 3. RP#58 completed / Impacted TSs and TRs: LTE
- 6527: RP#58 completed. RP#59 new generic TR 36.850v100 for Information and Approval / Impacted TSs and TRs: 36.101; 36.104; 36.133; 36.141; 36.307; 37.104; new generic 36.850
- 6528: RP#58 completed / Impacted TSs and TRs: 36.101; 36.104; 36.133; 36.141; 36.307
- 6529: Stage 3. RP#58 completed / Impacted TSs and TRs: LTE
- 6530: RP#58 completed. RP#59 new generic TR 36.850v100 for Information and Approval / Impacted TSs and TRs: 36.101; 36.104; 36.307; new generic 36.850
- 6531: RP#58 completed / Impacted TSs and TRs: 36.133
- 6532: Stage 3. RP#57 completed / Impacted TSs and TRs: LTE
- 6533: RP#57 completed. RP#59 new generic TR 36.850v100 for Information and Approval / Impacted TSs and TRs: 36.101; 36.104; 36.307; new generic 36.850
- 6534: RP#57 completed / Impacted TSs and TRs: 36.133; 36.141
- 6535: Stage 3. RP#56 completed. Updated WID RP-111765=>RP-120866 / Impacted TSs and TRs: LTE
- 6536: RP#56 completed. RP#59 new generic TR 36.850v100 for Information and Approval / Impacted TSs and TRs: 36.101; 36.104; 36.133; 36.307; new generic 36.850
- 6537: RP#56 completed / Impacted TSs and TRs: 36.133; 36.141

| ID | WBS | Task | Duration | Start | Finish | Complete | Baseline start | Baseline finish | Baseline duration | Constraint | Resources | Work | Actual work | Acronym | PCG approved | WI rapporteur name | Release | TSG approved | MCC resp | Special Focus Doc | Acronym_3GU_Export | Status Report |
| --- | --- | --- | --- | --- | --- | --- | --- | --- | --- | --- | --- | --- | --- | --- | --- | --- | --- | --- | --- | --- | --- | --- |
| 6538 | 2157.3.17 | **LTE Advanced Carrier Aggregation of Band 1 and Band 21** | 377.5d? | 2011-12-09 A | 2012-12-07 A | 100% | 2011-12-09 | 2012-12-07 | 265d? |  | R4; R2 | 9496h | 9496h | LTE_CA_B1_B21 | 28 | NTT DoCoMo | Rel-11 | 54 | Issam | CA | LTE_CA_B1_B21 |  |
| 6539 | 2157.3.17.1 | Core part: LTE Advanced Carrier Aggregation of Band 1 and Band 21 | 198d? | 2011-12-09 A | 2012-09-07 A | 100% | 2011-12-09 | 2012-09-07 | 198d? | finish no earlier than 2012-09-07 | R4; R2 | 3168h | 3168h | LTE_CA_B1_B21-Core | 28 | NTT DoCoMo | Rel-11 | 54 | Issam | CA | LTE_CA_B1_B21-Core | RP-121054 |
| 6540 | 2157.3.17.2 | Perf. part: LTE Advanced Carrier Aggregation of Band 1 and Band 21 | 263d? | 2011-12-13 A | 2012-12-07 A | 100% | 2011-12-13 | 2012-12-07 | 263d? | finish no earlier than 2012-12-07 | R4 | 2088h | 2088h | LTE_CA_B1_B21-Perf | 28 | NTT DoCoMo | Rel-11 | 54 | Issam | CA | LTE_CA_B1_B21-Perf | RP-121055 |
| 6541 | 2157.3.18 | **LTE Advanced Carrier Aggregation of Band 3 and Band 8** | 287.25d? | 2012-03-05 A | 2012-12-07 A | 100% | 2012-03-05 | 2012-12-07 | 204d? |  | R4 | 4864h | 4864h | LTE_CA_B3_B8 | 28 | KT | Rel-11 | 55 | Issam | CA | LTE_CA_B3_B8 |  |
| 6542 | 2157.3.18.1 | Core part: LTE Advanced Carrier Aggregation of Band 3 and Band 8 | 201d? | 2012-03-05 A | 2012-12-07 A | 100% | 2012-03-05 | 2012-12-07 | 201d? | finish no earlier than 2012-12-07 | R4 | 1608h | 1608h | LTE_CA_B3_B8-Core | 28 | KT | Rel-11 | 55 | Issam | CA | LTE_CA_B3_B8-Core | RP-121586 |
| 6543 | 2157.3.18.2 | Perf. part: LTE Advanced Carrier Aggregation of Band 3 and Band 8 | 203d? | 2012-03-06 A | 2012-12-07 A | 100% | 2012-03-06 | 2012-12-07 | 203d? | finish no earlier than 2012-12-07 | R4 | 1624h | 1624h | LTE_CA_B3_B8-Perf | 28 | KT | Rel-11 | 55 | Issam | CA | LTE_CA_B3_B8-Perf | RP-121587 |
| 6544 | 2157.4 | **Rel-11 intra-band Carrier Aggregation** | 474.62d? | 2011-06-07 A | 2012-09-07 A | 100% | 2011-06-07 | 2012-09-07 | 334d? |  | RP | 18864h | 18864h |  | 30 |  | Rel-11 | 58 |  | CA |  |  |
| 6545 | 2157.4.1 | **LTE Advanced Carrier Aggregation in Band 38** | 474.62d? | 2011-06-07 A | 2012-09-07 A | 100% | 2011-06-07 | 2012-09-07 | 334d? |  | R4 | 7976h | 7976h | LTE_CA_B38 | 27 | Huawei | Rel-11 | 52 | Issam | CA | LTE_CA_B38 |  |
| 6546 | 2157.4.1.1 | Core part: LTE Advanced Carrier Aggregation in Band 38 | 331d? | 2011-06-07 A | 2012-09-07 A | 100% | 2011-06-07 | 2012-09-07 | 331d? | finish no earlier than 2012-09-07 | R4 | 2648h | 2648h | LTE_CA_B38-Core | 27 | Huawei | Rel-11 | 52 | Issam | CA | LTE_CA_B38-Core | RP-121060 |
| 6547 | 2157.4.1.2 | Perf. part: LTE Advanced Carrier Aggregation in Band 38 | 333d? | 2011-06-08 A | 2012-09-07 A | 100% | 2011-06-08 | 2012-09-07 | 333d? | finish no earlier than 2012-09-07 | R4 | 2656h | 2656h | LTE_CA_B38-Perf | 27 | Huawei | Rel-11 | 52 | Issam | CA | LTE_CA_B38-Perf | RP-121061 |
| 6548 | 2157.4.2 | **LTE Advanced Carrier Aggregation in Band 41** | 279.12d? | 2011-06-07 A | 2012-03-02 A | 100% | 2011-06-07 | 2012-03-02 | 197d? |  | R4 | 4720h | 4720h | LTE_CA_B41 | 27 | Clearwire | Rel-11 | 52 | Issam | CA | LTE_CA_B41 |  |
| 6549 | 2157.4.2.1 | Core part: LTE Advanced Carrier Aggregation in Band 41 | 196d? | 2011-06-07 A | 2012-03-02 A | 100% | 2011-06-07 | 2012-03-02 | 196d? | finish no earlier than 2012-02-23 | R4 | 1568h | 1568h | LTE_CA_B41-Core | 27 | Clearwire | Rel-11 | 52 | Issam | CA | LTE_CA_B41-Core | RP-120126 |
| 6550 | 2157.4.2.2 | Perf. part: LTE Advanced Carrier Aggregation in Band 41 | 197d? | 2011-06-07 A | 2012-03-02 A | 100% | 2011-06-07 | 2012-03-02 | 197d? | finish no earlier than 2012-03-02 | R4 | 1576h | 1576h | LTE_CA_B41-Perf | 27 | Clearwire | Rel-11 | 52 | Issam | CA | LTE_CA_B41-Perf | RP-120127 |
| 6551 | 2157.4.3 | **LTE Advanced Carrier Aggregation in Band 7** | 367.12d? | 2011-09-19 A | 2012-09-07 A | 100% | 2011-09-19 | 2012-09-07 | 258d? |  | R4 | 6168h | 6168h | LTE_CA_B7 | 27 | China Unicom | Rel-11 | 53 | Issam | CA | LTE_CA_B7 |  |
| 6552 | 2157.4.3.1 | Core part: LTE Advanced Carrier Aggregation in Band 7 | 256d? | 2011-09-19 A | 2012-09-07 A | 100% | 2011-09-19 | 2012-09-07 | 256d? | finish no earlier than 2012-09-07 | R4 | 2048h | 2048h | LTE_CA_B7-Core | 27 | China Unicom | Rel-11 | 53 | Issam | CA | LTE_CA_B7-Core | RP-121062 |
| 6553 | 2157.4.3.2 | Perf. part: LTE Advanced Carrier Aggregation in Band 7 | 257d? | 2011-09-20 A | 2012-09-07 A | 100% | 2011-09-20 | 2012-09-07 | 257d? | finish no earlier than 2012-09-07 | R4 | 2056h | 2056h | LTE_CA_B7-Perf | 27 | China Unicom | Rel-11 | 53 | Issam | CA | LTE_CA_B7-Perf | RP-121063 |
| 6554 | 2158 | **UE Over The Air (Antenna) conformance testing methodology - Laptop mounted equipment Free Space test** | 2644.12d? | 2009-09-18 A | 2016-09-15 A | 100% | 2009-09-18 | 2014-12-05 | 1374d? |  | R4; R5 | 45192h | 45192h | UEAnt_FSTest | 23 | CATR | Rel-11 | 45 | Issam |  | UEAnt_FSTest |  |
| 6555 | 2158.1 | Core part: UE Over The Air (Antenna) conformance testing methodology - Laptop mounted equipment Free Space test | 583d? | 2009-09-18 A | 2011-12-09 A | 100% | 2009-09-18 | 2011-12-09 | 583d? | finish no earlier than 2011-12-09 | R4 | 4664h | 4664h | UEAnt_FSTest-Core | 23 | CATR | Rel-11 | 45 | Issam |  | UEAnt_FSTest-Core | RP-111456 |
| 6556 | 2158.2 | Test part: UE Over The Air (Antenna) conformance testing methodology - Laptop mounted equipment Free Space test | 1388d? | 2011-06-15 A | 2016-09-15 A | 100% | 2011-06-07 | 2014-12-05 | 926d? | finish no earlier than 2016-09-15 | R5 | 11056h | 11056h | UEAnt_FSTest-UEConTest | 27 | ZTE | Rel-11 | 52 | Ingbert |  | UEAnt_FSTest-UEConTest | RP-151187 |
| 6557 | 2159 | **Eight carrier HSDPA** | 842.13d? | 2010-09-15 A | 2012-12-07 A | 100% | 2010-09-15 | 2012-12-07 | 589d? |  | R1; R2; R3; R4 | 37768h | 37768h | 8C_HSDPA | 26 | Ericsson | Rel-11 | 50 | Patrick |  | 8C_HSDPA |  |
| 6558 | 2159.1 | Core part: Eight carrier HSDPA | 461d? | 2010-09-15 A | 2012-06-15 A | 100% | 2010-09-15 | 2012-06-15 | 461d? | finish no earlier than 2012-06-15 | R1; R2; R3; R4 | 14752h | 14752h | 8C_HSDPA-Core | 26 | Ericsson | Rel-11 | 50 | Patrick |  | 8C_HSDPA-Core | RP-120971 |
| 6559 | 2159.2 | Perf. part: Eight carrier HSDPA | 523d? | 2010-12-15 A | 2012-12-07 A | 100% | 2010-12-15 | 2012-12-07 | 523d? | finish no earlier than 2012-12-07 | R4 | 4168h | 4168h | 8C_HSDPA-Perf | 26 | Ericsson | Rel-11 | 50 | Issam |  | 8C_HSDPA-Perf | RP-120972 |
| 6560 | 2160 | **UE demodulation performance requirements under multiple-cell scenario for 1.28Mcps TDD** | 464.62d? | 2010-12-10 A | 2012-03-02 A | 100% | 2010-12-10 | 2012-03-02 | 324d? |  | R4; R5 | 7760h | 7760h | LCR_TDD_UE_demod_mc | 26 | China Mobile | Rel-11 | 50 | Issam |  | LCR_TDD_UE_demod_mc |  |
| 6561 | 2160.1 | Perf. part: UE demodulation performance requirements under multiple-cell scenario for 1.28Mcps TDD | 201d? | 2010-12-10 A | 2011-09-16 A | 100% | 2010-12-10 | 2011-09-16 | 201d? | finish no earlier than 2011-09-16 | R4 | 1608h | 1608h | LCR_TDD_UE_demod_mc-Perf | 26 | China Mobile | Rel-11 | 50 | Issam |  | LCR_TDD_UE_demod_mc-Perf | RP-110996 |
| 6562 | 2160.2 | Test part: UE demodulation performance requirements under multiple-cell scenario for 1.28Mcps TDD | 121d? | 2011-09-19 A | 2012-03-02 A | 100% | 2011-09-19 | 2012-03-02 | 121d? | finish no earlier than 2012-02-23 | R5 | 968h | 968h | LCR_TDD_UE_demod_mc-UEConTest | 27 | China Mobile | Rel-11 | 53 | Ingbert |  | LCR_TDD_UE_demod_mc-UEConTest | RP-120052 |

Notes:
- 6538: Stage 3. RP#57 completed. Updated WID RP-111764=>RP-121173 / Impacted TSs and TRs: LTE / WI rapporteur e-mail: Hiromasa Umeda (umedah@nttdocomo.co.jp)
- 6539: RP#57 completed. RP#59 new generic TR 36.850v100 for Information and Approval / Impacted TSs and TRs: 36.101; 36.104; 36.133; 36.307; new generic 36.850 / WI rapporteur e-mail: Hiromasa Umeda (umedah@nttdocomo.co.jp)
- 6540: RP#57 completed / Impacted TSs and TRs: 36.133; 36.141 / WI rapporteur e-mail: Hiromasa Umeda (umedah@nttdocomo.co.jp)
- 6541: Stage 3. RP#58 completed / Impacted TSs and TRs: LTE / WI rapporteur e-mail: Chungwoo HWANG (cwhwang@kt.com)
- 6542: RP#58 completed. RP#59 new generic TR 36.850v100 for Information and Approval / Impacted TSs and TRs: 36.101; 36.104; 36.133; 36.307; new generic 36.850 / WI rapporteur e-mail: Chungwoo HWANG (cwhwang@kt.com)
- 6543: RP#58 completed / Impacted TSs and TRs: 36.133; 36.141 / WI rapporteur e-mail: Chungwoo HWANG (cwhwang@kt.com)
- 6544: LTE_CA_Rel-11 / Impacted TSs and TRs: LTE
- 6545: Stage 3. RP#57 completed. WI only covers intra-band contiguous and not non-contiguous aspects / Impacted TSs and TRs: LTE / WI rapporteur e-mail: ronnie.zhang@huawei.com
- 6546: RP#57 completed. TR 36.830 v100 for Information & Approval / Impacted TSs and TRs: 36.101; 36.104; 36.133; 36.141; 36.307; 37.104; 37.141; new 36.833-1-38 [instead of 36.830] / WI rapporteur e-mail: ronnie.zhang@huawei.com
- 6547: RP#57 completed / Impacted TSs and TRs: 36.101; 36.104; 36.133; 36.141; 36.307; 37.104; 37.141 / WI rapporteur e-mail: ronnie.zhang@huawei.com
- 6548: RP#55 completed. WI only covers intra-band contiguous and not non-contiguous aspects. / Impacted TSs and TRs: LTE / WI rapporteur e-mail: michael.hart@clearwire.com
- 6549: RP#55 completed. Updated WID RP-110673=>RP-120249. TR 36.827 v100 for Information + Approval / Impacted TSs and TRs: 36.101; 36.104; 36.133; 36.141; 36.307; 37.104; new 36.833-1-41 [instead of 36.827] / WI rapporteur e-mail: michael.hart@clearwire.com
- 6550: RP#55 completed / Impacted TSs and TRs: 36.101; 36.104; 36.133; 36.141; 36.307 / WI rapporteur e-mail: michael.hart@clearwire.com
- 6551: Stage 3. RP#57 completed. Updated WID RP-111356=>RP-121193. WI only covers intra-band contiguous and not non-contiguous aspects / Impacted TSs and TRs: LTE / WI rapporteur e-mail: Zhangchao Ma (mazc@chinaunicom.cn), Zhonghao Zhang (zhangzh306@chinaunicom.cn)
- 6552: RP#57 completed. TR 36.831 v100 for Information & Approval / Impacted TSs and TRs: 36.101; 36.104; 36.133; 36.141; 36.307; 37.104; 37.141; new 36.833-1-07 [instead of 36.831] / WI rapporteur e-mail: Zhangchao Ma (mazc@chinaunicom.cn), Zhonghao Zhang (zhangzh306@chinaunicom.cn)
- 6553: RP#57 completed / Impacted TSs and TRs: 36.101; 36.104; 36.133; 36.141; 36.307; 37.104; 37.141 / WI rapporteur e-mail: Zhangchao Ma (mazc@chinaunicom.cn), Zhonghao Zhang (zhangzh306@chinaunicom.cn)
- 6554: - / Impacted TSs and TRs: UTRA / WI rapporteur e-mail: Guo Lin (guolin@emcite.com)
- 6555: RP#54 completed / Impacted TSs and TRs: 25.144; 25.914; 34.114 / WI rapporteur e-mail: Guo Lin (guolin@emcite.com)
- 6556: 1st Apr 15: CD:Mon 15/06/15->Wed 15/06/16 1st Apr 15: Stat Rep: RP-141846->RP-150068 03/07/15: Stat Rep: RP-150068->RP-150603 29/09/15: Stat Rep: RP-150603->RP-151187 / Impacted TSs and TRs: 34.114 / WI rapporteur e-mail: carolyn.tayl@zte.com.cn
- 6557: Stage 3 / Impacted TSs and TRs: UTRA / WI rapporteur e-mail: johan.hultell@ericsson.com
- 6558: RP#57 completed / Impacted TSs and TRs: 25.101; 25.104; 25.133; 25.211; 25.212; 25.213; 25.214; 25.215; 25.308; 25.331; 25.423; 25.433; 26.306 / WI rapporteur e-mail: johan.hultell@ericsson.com
- 6559: RP#57 completed / Impacted TSs and TRs: 25.101; 25.104; 25.133; 25.141 / WI rapporteur e-mail: johan.hultell@ericsson.com
- 6560: Stage 3 / Impacted TSs and TRs: UTRA / WI rapporteur e-mail: Li Nan (linan@chinamobile.com)
- 6561: RP#53 completed. TR 25.873v100 for Approval / Impacted TSs and TRs: 25.102; new 25.873 / WI rapporteur e-mail: Li Nan (linan@chinamobile.com)
- 6562: RP#55 completed / Impacted TSs and TRs: 34.108; 34.122 / WI rapporteur e-mail: Ma Shuai (mashuai@chinamobile.com)

| ID | WBS | Task | Duration | Start | Finish | Complete | Baseline start | Baseline finish | Baseline duration | Constraint | Resources | Work | Actual work | Acronym | PCG approved | WI rapporteur name | WI rapporteur e-mail | Release | TSG approved | MCC resp | Acronym_3GU_Export | Status Report |
| --- | --- | --- | --- | --- | --- | --- | --- | --- | --- | --- | --- | --- | --- | --- | --- | --- | --- | --- | --- | --- | --- | --- |
| 6563 | 2161 | **Uplink Transmit Diversity for HSPA** | 1326.12d? | 2010-12-10 A | 2014-06-13 A | 100% | 2010-12-10 | 2014-06-13 | 929d? |  | R1; R4; R2; R3; R5 | 83568.3h | 83568.3h | HSPA_UL_TxDiv | 26 | Huawei | zongjie.wang@huawei.com | Rel-11 | 50 | Patrick | HSPA_UL_TxDiv |  |
| 6564 | 2161.1 | Core part: Uplink Transmit Diversity for HSPA - Closed Loop | 528d? | 2010-12-10 A | 2012-12-07 A | 100% | 2010-12-10 | 2012-12-07 | 528d? | finish no earlier than 2012-12-07 | R1; R4; R2; R3 | 16896h | 16896h | HSPA_UL_TxDiv-CL-Core | 26 | Huawei | zongjie.wang@huawei.com | Rel-11 | 50 | Patrick | HSPA_UL_TxDiv-CL-Core | RP-121542 |
| 6565 | 2161.2 | Perf. part: Uplink Transmit Diversity for HSPA - Closed Loop | 721d? | 2010-12-14 A | 2013-09-06 A | 100% | 2010-12-14 | 2013-09-06 | 721d? | finish no earlier than 2013-09-06 | R4 | 5760.31h | 5760.31h | HSPA_UL_TxDiv-CL-Perf | 26 | Huawei | zongjie.wang@huawei.com | Rel-11 | 50 | Issam | HSPA_UL_TxDiv-CL-Perf | RP-130477 |
| 6566 | 2161.3 | Core part: Uplink Transmit Diversity for HSPA - Open Loop | 528d? | 2010-12-10 A | 2012-12-07 A | 100% | 2010-12-10 | 2012-12-07 | 528d? | finish no earlier than 2012-12-07 | R4; R1; R2; R3 | 16896h | 16896h | HSPA_UL_TxDiv-OL-Core | 26 | Huawei | zongjie.wang@huawei.com | Rel-11 | 50 | Patrick | HSPA_UL_TxDiv-OL-Core | RP-121544 |
| 6567 | 2161.4 | Perf. part: Uplink Transmit Diversity for HSPA - Open Loop | 521d? | 2010-12-14 A | 2012-12-07 A | 100% | 2010-12-14 | 2012-12-07 | 521d? | finish no earlier than 2012-12-07 | R4 | 4168h | 4168h | HSPA_UL_TxDiv-OL-Perf | 26 | Huawei | zongjie.wang@huawei.com | Rel-11 | 50 | Issam | HSPA_UL_TxDiv-OL-Perf | RP-121545 |
| 6568 | 2161.5 | Test part: Uplink Transmit Diversity for HSPA | 336d? | 2013-03-04 A | 2014-06-13 A | 100% | 2013-03-04 | 2014-06-13 | 336d? | finish no earlier than 2014-06-13 | R5 | 2688h | 2688h | HSPA_UL_TxDiv-UEConTest | 30 | Qualcomm | Shubhang Vora (svora@qti.qualcomm.com) | Rel-11 | 59 | Ingbert | HSPA_UL_TxDiv-UEConTest | RP-140767 |
| 6569 | 2162 | **Introduction of New Configuration for 4C-HSDPA** | 467.5d? | 2011-03-22 A | 2012-06-15 A | 100% | 2011-03-22 | 2012-06-15 | 328d? |  | R4; R2 | 10928h | 10928h | 4C_HSDPA_Config | 26 | Telus Communications | jorge.delrio@telus.com | Rel-11 | 51 | Issam | 4C_HSDPA_Config |  |
| 6570 | 2162.1 | Core part: Introduction of New Configuration for 4C-HSDPA | 192d? | 2011-03-22 A | 2011-12-09 A | 100% | 2011-03-22 | 2011-12-09 | 192d? | finish no earlier than 2011-12-09 | R4; R2 | 3072h | 3072h | 4C_HSDPA_Config-Core | 26 | Telus Communications | jorge.delrio@telus.com | Rel-11 | 51 | Issam | 4C_HSDPA_Config-Core | RP-111463 |
| 6571 | 2162.2 | Perf. part: Introduction of New Configuration for 4C-HSDPA | 326d? | 2011-03-24 A | 2012-06-15 A | 100% | 2011-03-24 | 2012-06-15 | 326d? | finish no earlier than 2012-06-15 | R4 | 2608h | 2608h | 4C_HSDPA_Config-Perf | 26 | Telus Communications | jorge.delrio@telus.com | Rel-11 | 51 | Issam | 4C_HSDPA_Config-Perf | RP-120475 |
| 6572 | 2163 | **Non-contiguous 4C-HSDPA operation** | 734.25d? | 2011-03-23 A | 2013-03-01 A | 100% | 2011-03-23 | 2013-03-01 | 516d? |  | R4; R2; R3 | 24360h | 24360h | NC_4C_HSDPA | 26 | Ericsson | muhammad.kazmi@ericsson.com | Rel-11 | 51 | Issam | NC_4C_HSDPA |  |
| 6573 | 2163.1 | Core part: Non-contiguous 4C-HSDPA operation | 328d? | 2011-06-15 A | 2012-09-07 A | 100% | 2011-06-15 | 2012-09-07 | 328d? | finish no earlier than 2012-09-07 | R4; R2; R3 | 7872h | 7872h | NC_4C_HSDPA-Core | 26 | Ericsson | muhammad.kazmi@ericsson.com | Rel-11 | 51 | Issam | NC_4C_HSDPA-Core | RP-120842 |
| 6574 | 2163.2 | Perf. part: Non-contiguous 4C-HSDPA operation | 513d? | 2011-03-23 A | 2013-03-01 A | 100% | 2011-03-23 | 2013-03-01 | 513d? | finish no earlier than 2013-03-01 | R4 | 4104h | 4104h | NC_4C_HSDPA-Perf | 26 | Ericsson | muhammad.kazmi@ericsson.com | Rel-11 | 51 | Issam | NC_4C_HSDPA-Perf | RP-130049 |
| 6575 | 2164 | **Further Enhancements to CELL_FACH** | 1507d? | 2011-03-18 A | 2015-03-13 A | 100% | 2011-03-18 | 2014-09-12 | 924d? |  | R1; R2; R3; R4; R5 | 66320h | 66320h | Cell_FACH_enh | 26 | Qualcomm | Ravi Agarwal | Rel-11 | 51 | Patrick | Cell_FACH_enh |  |
| 6576 | 2164.1 | Core part: Further Enhancements to CELL_FACH | 458d? | 2011-03-18 A | 2012-12-07 A | 100% | 2011-03-18 | 2012-12-07 | 458d? | finish no earlier than 2012-12-07 | R2; R1; R3; R4 | 14656h | 14656h | Cell_FACH_enh-Core | 26 | Qualcomm | Ravi Agarwal | Rel-11 | 51 | Yong-Jun | Cell_FACH_enh-Core | RP-121547 |
| 6577 | 2164.2 | Perf. part: Further Enhancements to CELL_FACH | 717d? | 2011-03-24 A | 2013-12-06 A | 100% | 2011-03-24 | 2013-12-06 | 717d? | finish no earlier than 2013-12-06 | R4 | 5728h | 5728h | Cell_FACH_enh-Perf | 26 | Qualcomm | Heechoon Lee (heechoon@qti.qualcomm.com) | Rel-11 | 51 | Issam | Cell_FACH_enh-Perf | RP-131459 |
| 6578 | 2164.3 | Test part: Further Enhancements to CELL_FACH | 457d? | 2013-06-15 A | 2015-03-13 A | 100% | 2013-06-18 | 2014-09-12 | 327d? | finish no earlier than 2015-03-15 | R5 | 3656h | 3656h | Cell_FACH_enh-UEConTest | 31 | Ericsson | leif.mattisson@ericsson.com | Rel-11 | 60 | Ingbert | Cell_FACH_enh-UEConTest | RP-150132 |
| 6579 | 2165 | **HSDPA Multiflow Data Transmission** | 1315.5d? | 2011-09-19 A | 2015-03-13 A | 100% | 2011-09-19 | 2014-12-05 | 851d? |  | R2; R1; R3; R4; R5 | 54136h | 54136h | HSDPA_MFTX | 27 | Nokia Siemens Networks | Alexander Sayenko | Rel-11 | 53 | Yong-Jun | HSDPA_MFTX |  |
| 6580 | 2165.1 | Core part: HSDPA Multiflow Data Transmission | 325d? | 2011-09-19 A | 2012-12-07 A | 100% | 2011-09-19 | 2012-12-07 | 325d? | finish no earlier than 2012-12-07 | R2; R1; R3; R4 | 10400h | 10400h | HSDPA_MFTX-Core | 27 | Nokia Siemens Networks | Alexander Sayenko | Rel-11 | 53 | Yong-Jun | HSDPA_MFTX-Core | RP-121551 |
| 6581 | 2165.2 | Perf. part: HSDPA Multiflow Data Transmission | 519d? | 2011-09-20 A | 2013-09-06 A | 100% | 2011-09-20 | 2013-09-06 | 519d? | finish no earlier than 2013-09-06 | R4 | 4152h | 4152h | HSDPA_MFTX-Perf | 27 | Nokia Siemens Networks | kamil.bechta@nsn.com | Rel-11 | 53 | Issam | HSDPA_MFTX-Perf | RP-130959 |
| 6582 | 2165.3 | Test part: HSDPA Multiflow Data Transmission | 328d? | 2013-12-15 A | 2015-03-13 A | 100% | 2013-12-06 | 2014-12-05 | 262d? | finish no earlier than 2015-03-15 | R5 | 2624h | 2624h | HSDPA_MFTX-UEConTest | 32 | Qualcomm | Shubhang Vora (svora@qti.qualcomm.com) | Rel-11 | 62 | Ingbert | HSDPA_MFTX-UEConTest | RP-150126 |
| 6583 | 2166 | **Four Branch MIMO transmission for HSDPA** | 837.5d? | 2011-09-19 A | 2013-12-06 A | 100% | 2011-09-19 | 2013-12-06 | 590d? |  | R1; R2; R3; R4 | 33968h | 33968h | 4Tx_HSDPA | 27 | Ericsson | johan.hultell@ericsson.com | Rel-11 | 53 | Patrick | 4Tx_HSDPA |  |
| 6584 | 2166.1 | Core part: Four Branch MIMO transmission for HSDPA | 325d? | 2011-09-19 A | 2012-12-07 A | 100% | 2011-09-19 | 2012-12-07 | 325d? | finish no earlier than 2012-12-07 | R1; R2; R3; R4 | 10400h | 10400h | 4Tx_HSDPA-Core | 27 | Ericsson | johan.hultell@ericsson.com | Rel-11 | 53 | Patrick | 4Tx_HSDPA-Core | RP-121549 |
| 6585 | 2166.2 | Perf. part: Four Branch MIMO transmission for HSDPA | 586d? | 2011-09-21 A | 2013-12-06 A | 100% | 2011-09-21 | 2013-12-06 | 586d? | finish no earlier than 2013-12-06 | R4 | 4688h | 4688h | 4Tx_HSDPA-Perf | 27 | Ericsson | johan.hultell@ericsson.com | Rel-11 | 53 | Issam | 4Tx_HSDPA-Perf | RP-131460 |
| 6586 | 2167 | **MIMO with 64QAM for HSUPA** | 659.75d? | 2011-12-09 A | 2013-09-06 A | 100% | 2011-12-09 | 2013-09-06 | 464d? |  | R1; R2; R3; R4 | 26984h | 26984h | MIMO_64QAM_HSUPA | 28 | Nokia Siemens Networks | Karri Ranta-aho | Rel-11 | 54 | Patrick | MIMO_64QAM_HSUPA |  |
| 6587 | 2167.1 | Core part: MIMO with 64QAM for HSUPA | 265d? | 2011-12-09 A | 2012-12-07 A | 100% | 2011-12-09 | 2012-12-07 | 265d? | finish no earlier than 2012-12-07 | R1; R2; R3; R4 | 8480h | 8480h | MIMO_64QAM_HSUPA-Core | 28 | Nokia Siemens Networks | Karri Ranta-aho | Rel-11 | 54 | Patrick | MIMO_64QAM_HSUPA-Core | RP-121554 |
| 6588 | 2167.2 | Perf. part: MIMO with 64QAM for HSUPA | 457d? | 2011-12-13 A | 2013-09-06 A | 100% | 2011-12-13 | 2013-09-06 | 457d? | finish no earlier than 2013-09-06 | R4 | 3656h | 3656h | MIMO_64QAM_HSUPA-Perf | 28 | Nokia Siemens Networks | kamil.bechta@nsn.com | Rel-11 | 54 | Issam | MIMO_64QAM_HSUPA-Perf | RP-130960 |

Notes:
- 6563: Stage 2/3 / Impacted TSs and TRs: UTRA
- 6564: RP#58 completed / Impacted TSs and TRs: 25.101; 25.104; 25.133; 25.211; 25.212; 25.213; 25.214; 25.215; 25.306; 25.319; 25.321; 25.331; 25.423; 25.433
- 6565: RP#61 completed / Impacted TSs and TRs: 25.101; 25.104; 25.133; 25.141
- 6566: RP#58 completed / Impacted TSs and TRs: 25.101; 25.133; 25.306; 25.319; 25.321; 25.331; 25.423; 25.433
- 6567: RP#58 completed / Impacted TSs and TRs: 25.101; 25.133
- 6568: RP#64 completed / Impacted TSs and TRs: 34.121-1; 34.121-2; 34.123-1; 34.123-2; 34.123-3
- 6569: - / Impacted TSs and TRs: UTRA
- 6570: RP#54 completed. RP#62 existing TS 25.317 replaced by new TS 25.327 / Impacted TSs and TRs: 25.101; 25.104; 25.141; 25.317 replaced by new 25.327
- 6571: RP#56 completed. RP#62 existing TS 25.317 replaced by new TS 25.327 / Impacted TSs and TRs: 25.101; 25.104; 25.141; 25.317 replaced by new 25.327
- 6572: - / Impacted TSs and TRs: UTRA
- 6573: RP#56 completed / Impacted TSs and TRs: 25.101; 25.104; 25.133; 25.331; 25.423; 25.433
- 6574: RP#59 completed / Impacted TSs and TRs: 25.101; 25.104; 25.133; 25.141
- 6575: - / Impacted TSs and TRs: UTRA
- 6576: RP#58 completed / Impacted TSs and TRs: 25.101; 25.104; 25.133; 25.211; 25.212; 25.213; 25.214; 25.306; 25.308; 25.319; 25.321; 25.331; 25.423; 25.433
- 6577: RP#62 completed / Impacted TSs and TRs: 25.101; 25.104; 25.133; 25.141
- 6578: ¦Stat Rep: RP-141164->RP-141770 1st Apr 15: Compl:92%->100% 1st Apr 15: Stat Rep: RP-141770->RP-150132 / Impacted TSs and TRs: 34.108; 34.121-1; 34.121-2; 34.123-1; 34.123-2; 34.123-3; 36.508; 36.523-1; 36.523-2; 36.523-3
- 6579: Stage 2,3 / Impacted TSs and TRs: UTRA
- 6580: RP#58 completed / Impacted TSs and TRs: 25.101; 25.104; 25.133; 25.211; 25.212; 25.214; 25.306; 25.308; 25.321; 25.331; 25.423; 25.433
- 6581: RP#61 completed / Impacted TSs and TRs: 25.101; 25.104; 25.133; 25.141
- 6582: ¦Stat Rep: RP-141136->RP-141961 1st Apr 15: Compl:90%->100% 1st Apr 15: Stat Rep: RP-141961->RP-150126 / Impacted TSs and TRs: 34.108; 34.121-1; 34.121-2; 34.123-1; 34.123-2; 34.123-3
- 6583: Stage 3 / Impacted TSs and TRs: UTRA
- 6584: RP#58 completed / Impacted TSs and TRs: 25.101; 25.104; 25.133; 25.211; 25.212; 25.213; 25.214; 25.215; 25.308; 25.331; 25.423; 25.433; 26.306
- 6585: RP#62 completed / Impacted TSs and TRs: 25.101; 25.104; 25.133; 25.141
- 6586: Specified UE and BS performance requirements for uplink MIMO together with QPSK and 16QAM modulations for E-DCH/HSUPA. 64QAM is for future releases / Impacted TSs and TRs: UTRA
- 6587: RP#58 completed / Impacted TSs and TRs: 25.101; 25.104; 25.133; 25.211; 25.212; 25.213; 25.214; 25.215; 25.308; 25.321; 25.331; 25.423; 25.433; 26.306
- 6588: RP#61 completed / Impacted TSs and TRs: 25.101; 25.104; 25.133; 25.141

| ID | WBS | Task | Type | Duration | Start | Finish | Complete | Baseline start | Baseline finish | Baseline duration | Constraint | Resources | Work | Actual work | Acronym | PCG approved | Impacted TSs and TRs | WI rapporteur name | Release | TSG approved | MCC resp | Acronym_3GU_Export | Status Report | Special Focus Doc | PCG stopped | TSG stopped |
| --- | --- | --- | --- | --- | --- | --- | --- | --- | --- | --- | --- | --- | --- | --- | --- | --- | --- | --- | --- | --- | --- | --- | --- | --- | --- | --- |
| 6589 | 2168 | **HSDPA Dual-Band Multi-Carrier combinations** |  | 283.5d? | 2011-12-09 A | 2012-09-07 A | 100% | 2011-12-09 | 2012-09-07 | 198d? |  | R4; R2 | 7920h | 7920h | HSDPA_DB_MC | 28 | UTRA | Ericsson | Rel-11 | 54 | Issam | HSDPA_DB_MC |  |  |  |  |
| 6590 | 2168.1 | Core part: HSDPA Dual-Band Multi-Carrier combinations |  | 198d? | 2011-12-09 A | 2012-09-07 A | 100% | 2011-12-09 | 2012-09-07 | 198d? | finish no earlier than 2012-09-07 | R4; R2 | 3168h | 3168h | HSDPA_DB_MC-Core | 28 | 25.101; 25.104; 25.141; 25.317 replaced by new 25.327 | Ericsson | Rel-11 | 54 | Issam | HSDPA_DB_MC-Core | RP-120987 |  |  |  |
| 6591 | 2168.2 | Perf. part: HSDPA Dual-Band Multi-Carrier combinations |  | 198d? | 2011-12-09 A | 2012-09-07 A | 100% | 2011-12-09 | 2012-09-07 | 198d? | finish no earlier than 2012-09-07 | R4 | 1584h | 1584h | HSDPA_DB_MC-Perf | 28 | 25.101; 25.104; 25.141 | Ericsson | Rel-11 | 54 | Issam | HSDPA_DB_MC-Perf | RP-120988 |  |  |  |
| 6592 | 2169 | Split TTCN Test Models for IMS testing in TS 34.229-3 |  | 201d? | 2013-12-09 A | 2014-09-12 A | 100% | 2013-12-09 | 2014-09-12 | 201d? | finish no earlier than 2014-09-12 | R5 | 1608h | 1608h | IMS-CCR_Test2 | 32 | 34.229-3; New 34.229-4 | Spirent | Rel-11 | 62 | Ingbert | IMS-CCR_Test2 | RP-141155 |  |  |  |
| 6593 | 2170 | (Small) Technical Enhancements and Improvements for Rel-11 |  | 595d? | 2010-06-18 A | 2012-09-20 A | 100% | 2010-06-18 | 2012-09-20 | 595d? | finish no earlier than 2012-09-20 | SP; CP; RP; GP | 19040h | 19040h | TEI11 | 25 |  |  | Rel-11 | 48 | All | TEI11 |  |  |  |  |
| 6594 | 2171 | Test - (Small) Technical Enhancements and Improvements for Rel-11 |  | 397d? | 2012-06-15 A | 2013-12-11 A | 100% | 2012-06-15 | 2013-12-11 | 397d? | finish no earlier than 2013-12-11 | R5; G3new | 6352h | 6352h | TEI11_Test | 29 |  |  | Rel-11 | 56 | Ingbert | TEI11_Test |  |  |  |  |
| 6595 | 2172 | (IETF) (Small) Technical Enhancements and Improvements for Rel-11 (RFC 7077) |  | 333d? | 2012-09-07 A | 2013-12-06 A | 100% | 2012-09-07 | 2013-12-06 | 333d? | finish no earlier than 2013-11-28 | C4-IETF | 2632.95h | 2632.95h | TEI11_IETF | 29 | RFC 7077 (was draft-ietf-netext-update-notifications) | Lionel Morand | Rel-11 | 57 | Kimmo | TEI11_IETF |  |  |  |  |
| 6596 | 2173 | Release 11 Studies | milestone | 0d? | 2009-12-10 A | 2009-12-10 A | 100% | 2009-12-10 | 2012-09-14 | 727d? | finish no earlier than 2012-12-07 | SP; CP; GP; RP |  |  |  |  |  |  | Rel-11 |  | All |  |  |  |  |  |
| 6597 | 2174 | Study on IMS based Peer-to-Peer Content Distribution Services |  | 195d? | 2009-09-11 A | 2010-06-10 A | 100% | 2009-05-12 | 2010-06-10 | 284d? | finish no earlier than 2010-06-10 | S1; S2 | 3120h | 3120h | FS_IMS_P2P | 23 | 22.906 | China Mobile | Rel-11 | 45 | Alain | FS_IMS_P2P |  |  |  |  |
| 6598 | 2175 | Study on Non Voice Emergency Services |  | 467d? | 2009-12-10 A | 2011-09-21 A | 100% | 2009-12-10 | 2011-09-21 | 467d? | finish no earlier than 2011-09-21 | S1 | 3720h | 3720h | FS_NOVES | 24 | 22.871 | Qualcomm | Rel-11 | 46 | Alain | FS_NOVES |  |  |  |  |
| 6599 | 2176 | Study on Support for 3GPP Voice Interworking with Enterprise IP-PBX |  | 130d? | 2010-09-23 A | 2011-03-23 A | 100% | 2010-09-23 | 2011-03-23 | 130d? | finish no earlier than 2011-02-21 | S1; S2 | 2080h | 2080h | FS_VINE | 25 | 22.809 | Tatara Systems | Rel-11 | 48 | Alain | FS_VINE |  |  |  |  |
| 6600 | 2177 | Study on IMS Network-Independent Public User Identities |  | 185d? | 2010-09-23 A | 2011-06-08 A | 100% | 2010-09-23 | 2011-06-08 | 185d? | finish no earlier than 2011-06-08 | S1 | 1480h | 1480h | FS_INIPUI | 25 | 22.894 | Vodafone | Rel-11 | 49 | Alain | FS_INIPUI |  |  |  |  |
| 6601 | 2178 | Study on IMS Evolution |  | 849d? | 2008-09-18 A | 2011-12-14 A | 100% | 2008-09-18 | 2011-12-14 | 849d? | finish no earlier than 2011-12-07 | S2 | 6784h | 6784h | FS_eIMS | 21 | 23.812 | China Mobile | Rel-11 | 41 | Maurice | FS_eIMS |  |  |  |  |
| 6602 | 2179 | Study on Policy solutions and enhancements |  | 521d? | 2009-06-12 A | 2011-06-10 A | 100% | 2000-01-03 | 2002-01-03 | 525d? | finish no earlier than 2011-06-10 | S2; S1 | 8336h | 8336h | FS_PP | 23 | 23.813 | AT&T | Rel-11 | 44 | Maurice | FS_PP |  |  |  |  |
| 6603 | 2180 | Study on IPv6 Migration |  | 525d? | 2009-06-04 A | 2011-06-08 A | 100% | 2009-06-04 | 2011-06-08 | 525d? | finish no earlier than 2011-06-08 | S2 | 4200h | 4200h | FS_IP6M | 23 | 23.975 | China Mobile | Rel-11 | 44 | Maurice | FS_IP6M |  |  |  |  |
| 6604 | 2181 | Study on Single Radio Voice Call Continuity from UTRAN/GERAN to E-UTRAN/HSPA |  | 528d? | 2009-12-10 A | 2011-12-14 A | 100% | 2009-12-10 | 2011-12-14 | 528d? | finish no earlier than 2011-09-21 | S2 | 4208h | 4208h | FS_rSRVCC | 24 | 23.885 | Orange | Rel-11 | 46 | Maurice | FS_rSRVCC |  |  |  |  |
| 6605 | 2182 | Study on Roaming Architecture for Voice over IMS with Local Breakout |  | 276.12d? | 2011-03-23 A | 2011-12-14 A | 100% | 2011-03-23 | 2011-12-14 | 194d? | finish no earlier than 2011-12-07 | S2 | 1535.79h | 1535.79h | FS_RAVEL | 26 | 23.850 | Deutsche Telekom | Rel-11 | 51 | Maurice | FS_RAVEL |  |  |  |  |
| 6606 | 2183 | Study on UTRAN key management enhancements |  | 1102d? | 2007-12-20 A | 2012-03-07 A | 100% | 2007-12-20 | 2012-03-07 | 1102d? | finish no earlier than 2012-02-20 | S3 | 8808.12h | 8808.12h | FS_UKM | 21 | 33.859 | Ericsson | Rel-11 | 38 | Mirko | FS_UKM |  |  |  |  |
| 6607 | 2184 | Study on Single Sign On (SSO) Application Security for IMS - based on SIP Digest |  | 532d? | 2010-06-10 A | 2012-06-20 A | 100% | 2010-06-10 | 2012-06-20 | 532d? | finish no earlier than 2012-06-20 | S3 | 4247.09h | 4247.09h | FS_SSO_APS | 25 | 33.914 converted to 33.804 | Nokia | Rel-11 | 48 | Mirko | FS_SSO_APS |  |  |  |  |
| 6608 | 2185 | Study on Mobile 3D Video Coding |  | 273d? | 2011-06-08 A | 2012-06-20 A | 100% | 2011-06-08 | 2012-06-20 | 273d? | finish no earlier than 2012-06-20 | S4 | 2168h | 2168h | FS_M3DVC | 27 | 26.905 | Orange | Rel-11 | 52 | Paolo | FS_M3DVC |  |  |  |  |
| 6609 | 2186 | Study on Management of Converged Networks |  | 591d? | 2010-06-10 A | 2012-09-12 A | 100% | 2010-06-10 | 2012-09-12 | 591d? | finish no earlier than 2012-09-12 | S5 | 4720h | 4720h | FS_ManCon | 25 | 32.833 | Nokia Siemens Networks | Rel-11 | 48 | Mirko | FS_ManCon |  |  |  |  |
| 6610 | 2187 | Study on User Data Convergence (UDC) information model handling and provisioning: Example Use Cases |  | 321d? | 2010-09-23 A | 2011-12-14 A | 100% | 2010-09-23 | 2011-12-14 | 321d? | finish no earlier than 2011-12-14 | S5 | 2560h | 2560h | FS_UDC_AppUseCase | 25 | 32.901 | Alcatel-Lucent | Rel-11 | 49 | Mirko | FS_UDC_AppUseCase |  |  |  |  |
| 6611 | 2188 | Study on OAM aspects of inter-RAT Energy Saving |  | 194d? | 2011-03-23 A | 2011-12-14 A | 100% | 2011-03-23 | 2011-12-14 | 194d? | start no earlier than 2011-03-23 | S5 | 1528h | 1528h | FS_OAM_ES_iRAT | 26 | 32.834 | Nokia Siemens Networks | Rel-11 | 51 | Mirko | FS_OAM_ES_iRAT |  | SON |  |  |
| 6612 | 2189 | Study on impacts on UE-Core Network signalling from Energy Saving |  | 261d? | 2010-06-04 A | 2011-06-03 A | 100% | 2010-06-04 | 2011-06-03 | 261d? | finish no earlier than 2011-06-03 | C1 | 2088h | 2088h | FS_UE-CN_ES | 25 | 24.826 | NEC | Rel-11 | 48 | Frederic | FS_UE-CN_ES |  |  |  |  |
| 6613 | 2190 | Study on EPC Nodes Restoration |  | 588d? | 2010-09-17 A | 2012-12-07 A | 100% | 2010-09-17 | 2012-12-07 | 588d? | finish no earlier than 2012-12-07 | C4 | 4664h | 4664h | FS_EPC_NR | 25 | 23.857 | ZTE | Rel-11 | 49 | Kimmo | FS_EPC_NR |  |  |  |  |
| 6614 | 2191 | Study on Signal Precoding enhancements for EGPRS2 DL |  | 394d? | 2010-09-03 A | 2012-03-02 A | 100% | 2010-09-03 | 2012-03-02 | 394d? | finish no earlier than 2012-03-02 | G1; G2 | 6304h | 6304h | FS_SPEED | 25 | GERAN 45.860 | Ericsson | Rel-11 | 46 | Paolo | FS_SPEED |  |  |  |  |
| 6615 | 2192 | Study on Coordinated Multi-Point operation for LTE |  | 203d? | 2010-12-10 A | 2011-09-16 A | 100% | 2010-12-10 | 2011-09-16 | 203d? | finish no earlier than 2011-09-16 | R1; R2; R3 | 4872h | 4872h | FS_CoMP_LTE | 24 | LTE 36.819 | Samsung | Rel-11 | 47 | Patrick | FS_CoMP_LTE | RP-111343 |  |  |  |
| 6616 | 2193 | Study on Signalling and procedure for interference avoidance for in-device coexistence |  | 338d? | 2010-06-04 A | 2011-09-16 A | 100% | 2010-06-04 | 2011-09-16 | 338d? | finish no earlier than 2011-09-16 | R2; R4 | 5408h | 5408h | FS_SPIA_IDC | 25 | LTE 36.816 | China Mobile | Rel-11 | 48 | Yong-Jun | FS_SPIA_IDC | RP-111057 |  |  |  |
| 6617 | 2194 | Study on HetNet mobility enhancements for LTE |  | 391d? | 2011-03-18 A | 2012-09-07 A | 100% | 2011-03-18 | 2012-09-07 | 391d? | finish no earlier than 2012-09-07 | R2; R1; R3; R4 | 12512h | 12512h | FS_HetNet_eMOB_LTE | 26 | LTE 36.839 | Alcatel-Lucent | Rel-11 | 51 | Yong-Jun | FS_HetNet_eMOB_LTE | RP-121085 |  |  |  |
| 6618 | 2195 | Study on further Downlink MIMO enhancements for LTE-Advanced |  | 193d? | 2011-03-18 A | 2011-12-09 A | 100% | 2011-03-18 | 2011-12-09 | 193d? | finish no earlier than 2011-12-09 | R1 | 1544h | 1544h | FS_LTE_eDL_MIMO_enh | 26 | LTE 36.871 | Alcatel-Lucent | Rel-11 | 51 | Patrick | FS_LTE_eDL_MIMO_enh | RP-111550 |  |  |  |
| 6619 | 2196 | Study on Further Enhancements to LTE TDD for DL-UL Interference Management and Traffic Adaptation |  | 328d? | 2011-03-22 A | 2012-06-15 A | 100% | 2011-03-22 | 2012-06-15 | 328d? | finish no earlier than 2012-06-15 | R1; R4 | 5248h | 5248h | FS_LTE_TDD_eIMTA | 26 | LTE 36.828 | CATT | Rel-11 | 51 | Patrick | FS_LTE_TDD_eIMTA | RP-120587 | Small cell |  |  |
| 6620 | 2197 | Study on LTE Coverage Enhancements |  | 197d? | 2011-09-19 A | 2012-06-15 A | 100% | 2011-09-19 | 2012-06-15 | 197d? | finish no earlier than 2012-06-15 | R1; R2 | 3152h | 3152h | FS_Cov_Enh_LTE | 27 | LTE 36.824 | China Telecom | Rel-11 | 53 | Patrick | FS_Cov_Enh_LTE | RP-120589 |  |  |  |
| 6621 | 2198 | Study on Enhanced performance requirement for LTE UE |  | 121d? | 2011-09-19 A | 2012-03-02 A | 100% | 2011-09-19 | 2012-03-02 | 121d? | finish no earlier than 2012-03-02 | R4; R1 | 1936h | 1936h | FS_enh_perf_UE_LTE | 27 | LTE 36.829 | NTT DoCoMo | Rel-11 | 53 | Issam | FS_enh_perf_UE_LTE | RP-120167 |  |  |  |
| 6622 | 2199 | Study on Measurements of radio performances for LTE terminals - Total Radiated Power (TRP) and Total Radiated Sensitivity (TRS) test methodology |  | 136d? | 2012-03-05 A | 2012-09-07 A | 100% | 2012-03-05 | 2012-09-07 | 136d? | finish no earlier than 2012-09-07 | R4 | 1088h | 1088h | FS_LTE_OTA | 28 | LTE 25.914; New 37.902 | CATR | Rel-11 | 55 | Issam | FS_LTE_OTA | RP-121083 |  |  |  |
| 6623 | 2200 | Study on Measurement of Radiated Performance for MIMO and multi-antenna reception for HSPA and LTE terminals |  | 712.8d? | 2009-03-06 A | 2012-03-02 A | 100% | 2009-03-06 | 2012-03-02 | 712.8d? | finish no earlier than 2012-03-02 | R4 | 5702.4h | 5702.4h | FS_HSPA_LTE_measRP_MIMO_multi-antenna | 22 | UTRA; LTE 37.976 | Vodafone | Rel-11 | 43 | Issam | FS_HSPA_LTE_measRP_MIMO_multi-antenna | RP-120154 |  |  |  |
| 6624 | 2201 | Study on Extending 850 MHz |  | 860d? | 2009-05-30 A | 2012-09-07 A | 100% | 2009-05-30 | 2012-09-07 | 860d? | finish no earlier than 2012-09-07 | R4 | 6880h | 6880h | FS_e850 | 23 | UTRA; LTE 37.806 | Ericsson | Rel-11 | 44 | Issam | FS_e850 | RP-121080 |  |  |  |
| 6625 | 2202 | Study on RAN improvements for Machine-Type Communications |  | 523d? | 2009-09-18 A | 2011-09-16 A | 100% | 2009-09-18 | 2011-09-16 | 523d? | finish no earlier than 2011-09-16 | R2; R1; R3; R4 | 16736h | 16736h | FS_NIMTC_RAN | 23 | UTRA; LTE 37.868 | Huawei | Rel-11 | 45 | Yong-Jun | FS_NIMTC_RAN | RP-111052 | MTC, M2M |  |  |
| 6626 | 2203 | Study on UE Application Layer Data Throughput Performance |  | 264d? | 2010-09-16 A | 2011-09-16 A | 100% | 2010-09-16 | 2011-09-16 | 264d? | finish no earlier than 2011-09-16 | R5; R4 | 4224h | 4224h | FS_UE_App_Data_Perf | 26 | UTRA; LTE 37.901 | Spirent | Rel-11 | 50 | Ingbert | FS_UE_App_Data_Perf | RP-111543 |  |  |  |
| 6627 | 2204 | Study on further enhancements for HNB and HeNB |  | 330d? | 2011-03-18 A | 2012-06-15 A | 100% | 2011-03-18 | 2012-06-15 | 330d? | finish no earlier than 2012-06-15 | R3; R2 | 5280h | 5280h | FS_EHNB_enh | 26 | UTRA; LTE 37.803 | Alcatel-Lucent | Rel-11 | 51 | Juha | FS_EHNB_enh | RP-120579 | HNB |  |  |
| 6628 | 2205 | Study on Interference analysis between 800~900 MHz bands |  | 326d? | 2011-03-23 A | 2012-06-15 A | 100% | 2011-03-23 | 2012-06-15 | 326d? | finish no earlier than 2012-06-15 | R4 | 2608h | 2608h | FS_B800_B900_Interf_LTE | 26 | UTRA; LTE impac37.804 | LG Uplus | Rel-11 | 51 | Issam | FS_B800_B900_Interf_LTE | RP-120586 |  |  |  |
| 6629 | 2206 | Study on UMTS/LTE in 900 MHz band (Japan, Korea) |  | 272d? | 2011-06-07 A | 2012-06-15 A | 100% | 2011-06-07 | 2012-06-15 | 272d? | finish no earlier than 2012-06-15 | R4 | 2176h | 2176h | FS_UTRA_LTE_900MHz | 27 | UTRA; LTE 37.804 | NTT DoCoMo | Rel-11 | 52 | Issam | FS_UTRA_LTE_900MHz | RP-120580 |  |  |  |
| 6630 | 2207 | Study on Uplink MIMO |  | 203d? | 2010-12-10 A | 2011-09-16 A | 100% | 2010-12-10 | 2011-09-16 | 203d? | finish no earlier than 2011-09-16 | R1 | 1624h | 1624h | FS_UTRA_UL_MIMO | 26 | UTRA 25.871 | Qualcomm | Rel-11 | 50 | Patrick | FS_UTRA_UL_MIMO | RP-111048 |  |  |  |
| 6631 | 2208 | Study on HSDPA Multipoint Transmission |  | 203d? | 2010-12-10 A | 2011-09-16 A | 100% | 2010-12-10 | 2011-09-16 | 203d? | finish no earlier than 2011-09-16 | R1; R2; R3 | 4872h | 4872h | FS_HSDPA_MP_TX | 26 | UTRA 25.872 | Nokia Siemens Networks | Rel-11 | 50 | Patrick | FS_HSDPA_MP_TX | RP-111049 |  |  |  |
| 6632 | 2209 | Study on UE Over The Air (OTA) test method with Head and Hand Phantoms |  | 258d? | 2011-09-19 A | 2012-09-07 A | 100% | 2011-09-19 | 2012-09-07 | 258d? | finish no earlier than 2012-09-07 | R4; R5 | 4128h | 4128h | FS_OTA_phantoms_UTRA | 27 | UTRA 25.914 | Nokia | Rel-11 | 53 | Issam | FS_OTA_phantoms_UTRA | RP-121078 |  |  |  |
| 6633 | 2210 | Study on HSPA feedback and signalling efficiency enhancements for LCR TDD |  | 199d? | 2011-12-07 A | 2012-09-07 A | 100% | 2011-12-07 | 2012-09-07 | 199d? | finish no earlier than 2012-09-07 | R1 | 1584h | 1584h | FS_LCRTDD_HSPAenh | 28 | UTRA 25.874 | TD Tech | Rel-11 | 54 | Patrick | FS_LCRTDD_HSPAenh | RP-121079 |  |  |  |
| 6634 | 2211 | Deleted - Study on Enhanced Uplink Transmission for LTE |  | 328d? | 2011-03-22 A | 2012-06-15 A | 100% | 2011-03-22 | 2012-06-15 | 328d? | finish no earlier than 2012-06-15 | R1 | 2624h | 2624h | FS_eUL_TX_LTE | 26 | LTE 36.8xy | Huawei | Rel-11 | 51 | Patrick | FS_eUL_TX_LTE | RP-120585 |  | PCG-29 | RP-56 |
| 6635 | 2212 | --- RELEASE 10 --- |  | 728d? | 2008-12-11 A | 2011-09-21 A | 100% | 2008-12-11 | 2011-09-21 | 728d? | finish no earlier than 2011-09-21 | CP; GP; RP; SP | 23296h | 23296h |  |  |  |  | Rel-10 |  |  |  |  |  |  |  |

Notes:
- 6589: Stage 3 / WI rapporteur e-mail: muhammad.kazmi@ericsson.com
- 6590: RP#57 completed. RP#62 existing TS 25.317 replaced by new TS 25.327 / WI rapporteur e-mail: muhammad.kazmi@ericsson.com
- 6591: RP#57 completed / WI rapporteur e-mail: muhammad.kazmi@ericsson.com
- 6592: SP#65 completed. TS 34.229-4 for Approval. Split out of old TS 34.229-3 a new TS 34.229-4 / WI rapporteur e-mail: richard.catmur@spirent.com
- 6593: SP#50 EU-Alert is introduced under Public Warning System in parallel with the already existing ETWS and CMAS. SA1 22.268 CR#9r1 adds EU-ALERT specific requirements & CT1 23.041 CRs#
- 6594: -
- 6595: CP#62 completed / WI rapporteur e-mail: Lionel Morand
- 6596: -
- 6597: SP#48 completed. 3/3/15: start date corrected (was 05/09) / WI rapporteur e-mail: Li Gang (ligangyf@chinamobile.com)
- 6598: SP#53 completed. Spin-off Feature UID_500030 Non Voice Emergency Services (NOVES) / WI rapporteur e-mail: dwilliams@qualcomm.com
- 6599: SP#51 completed. Support Interworking between 3GPP networks and Enterprise environments to provide enterprise voice services via 3GPP mobile devices / WI rapporteur e-mail: Phillip Brown (pbrown@tatarasystems.com)
- 6600: SP#52 completed / WI rapporteur e-mail: mona.mustapha@vodafone.com
- 6601: SP#54 completed / WI rapporteur e-mail: Li Gang (ligangyf@chinamobile.com), Yu Qing (yuqing@chinamobile.com)
- 6602: SP#52 completed. 3/3/15: start and finish dates corrected (was start on Jan-00, ends on Jan-02) / WI rapporteur e-mail: farooq.bari@att.com
- 6603: SP#52 completed / WI rapporteur e-mail: Li Lianyuan (lilianyuan@chinamobile.com), Liu Hong (liuhongyfw@chinamobile.com)
- 6604: SP#54 completed. Study on "reverse direction" from UTRAN/GERAN to E-UTRAN/HSPA (Rel-8 SRVCC was in the other direction E-UTRAN/HSPA to GERAN/UTRAN) / WI rapporteur e-mail: delphin.barankanira@orange-ftgroup.com
- 6605: SP#54 completed. Linked to Rel-11 OSCAR (Optimized Service Charging and Allocation of ResourcES in CP-150IMS whilst Roaming) UID_490032. Related to LBO/home routing decision / WI rapporteur e-mail: michele.zarri@telekom.com
- 6606: SP#55 completed / WI rapporteur e-mail: karl.norrman@ericsson.com
- 6607: SP#56 completed. SP#55 TR 33.914v200 approved (converted 33.804). Study reuse of non-UICC credentials (in particular SIP Digest) to provide security for access to applications. Provide reference material for IMS based non-UICC based SSO to applications / WI rapporteur e-mail: Silke.Holtmanns@nokia.com
- 6608: SP#56 completed. Extends Rel-10 work on 3D video formats UID_480044 Improved Video Coding Support for PSS and MBMS / WI rapporteur e-mail: gilles.teniou@orange-ftgroup.com
- 6609: SP#57 completed. TR 32.833v200 for Approval / WI rapporteur e-mail: Jörg Schmidt (J.Schmidt@nsn.com)
- 6610: SP#54 completed / WI rapporteur e-mail: Nick Mazzarella (njmazzarella@alcatel-lucent.com)
- 6611: SP#54 completed. Triggered by Rel-10 UID_430044 TR 32.826 Study on Energy Savings Management (FS_OAM_ESM) and UID_470037 OAM aspects of Energy Saving in Radio Networks (OAM-ES) / WI rapporteur e-mail: clemens.suerbaum@nsn.com
- 6612: CP#52 completed. Linked to SA5 UID_430044 (FS_OAM-ESM) & UID_470037 (OAM-ES), RAN3 UID_470015 (FS_Energy_LTE), RAN1 UID_460016 (FS_Energy_UMTS) / WI rapporteur e-mail: gottfried.punz@nw.neclab.eu
- 6613: CP#58 completed. Continue work in Rel-11 especially to cover handling of Idle mode Signalling Reduction (ISR). Linked to SA2 UID_490036 Study on Core Network Overload solutions / WI rapporteur e-mail: lu.fei1@zte.com.cn
- 6614: GP#53 completed (03/12). GP#46 approved WID. / WI rapporteur e-mail: marten.sundberg@ericsson.com
- 6615: RP#53 completed / WI rapporteur e-mail: bruno.clerckx@samsung.com
- 6616: RP#53 completed. Studied coexistence scenario of LTE and Industrial, Scientific and Medical (ISM) Radio within the same device working in adjacent frequencies / WI rapporteur e-mail: Zhenping Hu (huzhenping@chinamobile.com)
- 6617: RP#57 completed. TR 36.839 v100 for Information & Approval / WI rapporteur e-mail: sudeep.palat@alcatel-lucent.com
- 6618: RP#54 completed / WI rapporteur e-mail: federico.boccardi@alcatel-lucent.com
- 6619: RP#56 completed. TR 36.828 for Information and Approval / WI rapporteur e-mail: Zukang Shen (shenzukang@catt.cn)
- 6620: RP#56 completed. TR 36.824 v200 for Approval / WI rapporteur e-mail: Peng Chen (chenpeng@ctbri.com.cn)
- 6621: RP#55 completed. TR 36.829 v100 for Information + Approval / WI rapporteur e-mail: Yuta Sagae
- 6622: RP#57 completed / WI rapporteur e-mail: Xudong An (anxudong@emcite.com)
- 6623: RP#55 completed. TR 37.976 v200 for Approval / WI rapporteur e-mail: Tim.frost@vodafone.com
- 6624: RP#57 completed. TR 37.806 v200 for Approval / WI rapporteur e-mail: christian.bergljung@ericsson.com
- 6625: RP#53 completed. TR 37.868v100 for Approval (No WID change: RAN overload only). Triggered by TR 22.868 Study on Facilitating Machine to Machine Communication in GSM and UMTS (M2M) UID_7027 and Rel-10 NIMTC UID_410030 / WI rapporteur e-mail: Jeff Gao (gaoyq@huawei.com)
- 6626: RP#54 completed / WI rapporteur e-mail: ron.borsato@spirent.com
- 6627: RP#56 completed. TR 37.803 v200 for Approval / WI rapporteur e-mail: Martin.Warner@alcatel-lucent.com
- 6628: RP#56 completed. Impacts TR 37.804 Study on UMTS/LTE in 900 MHz band (Japan, Korea) UID_520018 / WI rapporteur e-mail: Koo Yeon Sang (yskoo@lguplus.co.kr)
- 6629: RP#56 completed. Updated WID RP-111751=>RP-120617. TR 37.804 v100 for Information and Approval. Linked to Study on Interference analysis between 800~900 MHz bands UID_510038 / WI rapporteur e-mail: Masahiro Fujii (fujiima@nttdocomo.co.jp)
- 6630: RP#53 completed (1-step Approval) / WI rapporteur e-mail: Sharad Sambhwani
- 6631: RP#53 completed / WI rapporteur e-mail: karri.ranta-aho@nsn.com
- 6632: RP#57 completed / WI rapporteur e-mail: petri.j.vasenkari@nokia.com
- 6633: RP#57 completed. TR 25.874 v100 for Information & Approval / WI rapporteur e-mail: limei.wei@td-tech.com
- 6634: RP#56 stopped. RP-120856 discussion: most content moved to Rel-11 Coordinated Multi-Point Operation for LTE Uplink (COMP_LTE_UL) and RAN1 has no time to look at it / WI rapporteur e-mail: Yongxing Zhou
- 6635: -

| ID | WBS | Task | Duration | Start | Finish | Complete | Baseline start | Baseline finish | Baseline duration | Constraint | Resources | Work | Actual work | Acronym | PCG approved | WI rapporteur name | WI rapporteur e-mail | Release | TSG approved | MCC resp | Special Focus Doc | Acronym_3GU_Export | PCG stopped | TSG stopped | Status Report |
| --- | --- | --- | --- | --- | --- | --- | --- | --- | --- | --- | --- | --- | --- | --- | --- | --- | --- | --- | --- | --- | --- | --- | --- | --- | --- |
| 6636 | 2213 | **Enhancements for Multimedia Priority Service** | 1897.12d? | 2006-03-13 A | 2011-03-18 A | 100% | 2006-03-13 | 2011-03-18 | 1311d? |  | S1; S2; C4; C3; C1 | 72120h | 72120h | eMPS | 21 | Telcordia | jgarraha@telcordia.com | Rel-10 | 39 | Alain | Public Safety (I-A) | eMPS |  |  |  |
| 6637 | 2213.1 | Stage 1 on enhancements for Multimedia Priority Service | 584d? | 2006-03-13 A | 2008-06-05 A | 100% | 2006-03-13 | 2008-06-05 | 584d? | start no earlier than 2006-03-12 | S1 | 4672h | 4672h | ePRIOR-St1 | 21 | Telcordia | jgarraha@telcordia.com | Rel-10 | 39 | Alain | Public Safety (I-A) | ePRIOR |  |  |  |
| 6638 | 2213.2 | **Stage 2 on enhancements for Multimedia Priority Service** | 298.25d? | 2009-12-10 A | 2010-09-23 A | 100% | 2009-12-10 | 2010-09-23 | 206d? |  | S2 | 6592h | 6592h | ePRIOR-St2 | 24 | Telcordia, NTT DoCoMo | Vijay Varma, Katsutoshi Nishida | Rel-10 | 46 | Maurice | Public Safety (I-A) |  |  |  |  |
| 6639 | 2213.2.1 | Stage 2 on eMPS for CSFB | 206d? | 2009-12-10 A | 2010-09-23 A | 100% | 2009-12-10 | 2010-09-23 | 206d? | finish no earlier than 2010-09-24 | S2 | 1648h | 1648h | ePRIOR-St2 | 24 | Telcordia, NTT DoCoMo | Vijay Varma, Katsutoshi Nishida | Rel-10 | 46 | Maurice | Public Safety (I-A) |  |  |  |  |
| 6640 | 2213.2.2 | Stage 2 on eMPS for EPS Bearer Service | 206d? | 2009-12-10 A | 2010-09-23 A | 100% | 2009-12-10 | 2010-09-23 | 206d? | finish no earlier than 2010-12-09 | S2 | 1648h | 1648h | ePRIOR-St2 | 24 | Telcordia, NTT DoCoMo | Vijay Varma, Katsutoshi Nishida | Rel-10 | 46 | Maurice | Public Safety (I-A) |  |  |  |  |
| 6641 | 2213.2.3 | Stage 2 on eMPS for IMS Aspects | 206d? | 2009-12-10 A | 2010-09-23 A | 100% | 2009-12-10 | 2010-09-23 | 206d? | finish no earlier than 2010-12-09 | S2 | 1648h | 1648h | ePRIOR-St2 | 24 | Telcordia, NTT DoCoMo | Vijay Varma, Katsutoshi Nishida | Rel-10 | 46 | Maurice | Public Safety (I-A) |  |  |  |  |
| 6642 | 2213.3 | Deleted - TR 23.854 on Stage 2 on enhancements for Multimedia Priority Service | 266d? | 2009-12-10 A | 2010-12-16 A | 100% | 2009-12-10 | 2010-12-16 | 266d? | finish no earlier than 2011-03-17 | S2 | 2128h | 2128h |  | 24 | Telcordia, NTT DoCoMo | Vijay Varma, Katsutoshi Nishida | Rel-10 | 46 | Maurice | Public Safety (I-A) |  | PCG-27 | SP-50 |  |
| 6643 | 2213.4 | **Stage 3 on enhancements for Multimedia Priority Service** | 189.5d? | 2010-09-17 A | 2011-03-18 A | 100% | 2010-09-17 | 2011-03-18 | 131d? |  | C4; C3; C1 | 6288h | 6288h | eMPS-CN | 25 | Ericsson | Philip.hodges@ericsson.com | Rel-10 | 49 | Kimmo | Public Safety (I-A) | eMPS-CN |  |  |  |
| 6644 | 2213.4.1 | CT4 part on Stage 3 on enhancements for Multimedia Priority Service | 131d? | 2010-09-17 A | 2011-03-18 A | 100% | 2010-09-17 | 2011-03-18 | 131d? | start no earlier than 2010-09-17 | C4 | 1048h | 1048h | eMPS-CN | 25 | Ericsson | Philip.hodges@ericsson.com | Rel-10 | 49 | Kimmo | Public Safety (I-A) |  |  |  |  |
| 6645 | 2213.4.2 | CT3 part on Stage 3 on enhancements for Multimedia Priority Service | 131d? | 2010-09-17 A | 2011-03-18 A | 100% | 2010-09-17 | 2011-03-18 | 131d? | start no earlier than 2010-09-17 | C3 | 1048h | 1048h | eMPS-CN | 25 | Ericsson | Philip.hodges@ericsson.com | Rel-10 | 49 | Adrian | Public Safety (I-A) |  |  |  |  |
| 6646 | 2213.4.3 | CT1 part on Stage 3 on enhancements for Multimedia Priority Service | 131d? | 2010-09-17 A | 2011-03-18 A | 100% | 2010-09-17 | 2011-03-18 | 131d? | start no earlier than 2010-09-17 | C1 | 1048h | 1048h | eMPS-CN | 25 | Ericsson | Philip.hodges@ericsson.com | Rel-10 | 49 | Frederic | Public Safety (I-A) |  |  |  |  |
| 6647 | 2214 | **Network Improvements for Machine-Type Communications** | 1957.88d? | 2008-09-18 A | 2013-11-22 A | 100% | 2008-09-18 | 2013-11-22 | 1365d? |  | S1; S2; S5; C1; C4; C6; G2; R2; R3; R5; G3new | 149017h | 149017h | NIMTC | 21 | KPN | toon.norp@tno.nl | Rel-10 | 41 | Alain | MTC, M2M | NIMTC |  |  |  |
| 6648 | 2214.1 | Stage 1 for Network Improvements for Machine-Type Communications | 397d? | 2008-09-18 A | 2010-03-25 A | 100% | 2008-09-18 | 2010-03-25 | 397d? | finish no earlier than 2009-12-10 | S1 | 3176h | 3176h | NIMTC | 21 | KPN | toon.norp@tno.nl | Rel-10 | 41 | Alain | MTC, M2M |  |  |  |  |
| 6649 | 2214.2 | Deleted - TR on Stage 2 for Network Improvements for Machine-Type Communications | 321d? | 2009-09-24 A | 2010-12-16 A | 100% | 2009-09-24 | 2010-12-16 | 321d? | finish no earlier than 2010-11-30 | S2 | 2568h | 2568h | NIMTC | 23 | Samsung | erik.guttman@partner.samsung.com | Rel-10 | 45 | Maurice | MTC, M2M |  | PCG-26 | SP-50 |  |
| 6650 | 2214.3 | Stage 2 for Network Improvements for Machine-Type Communications | 19d? | 2010-08-30 A | 2010-09-23 A | 100% | 2010-08-30 | 2010-09-23 | 19d? | finish no earlier than 2010-09-17 | S2 | 152h | 152h | NIMTC | 23 | Samsung | erik.guttman@partner.samsung.com | Rel-10 | 45 | Maurice | MTC, M2M |  |  |  |  |
| 6651 | 2214.4 | Deleted - Security for Network Improvements for Machine-Type Communications | 193.15d? | 2009-12-10 A | 2010-09-23 A | 100% | 2009-12-10 | 2010-09-23 | 193.15d? | finish no earlier than 2010-09-23 | S3 | 1545.2h | 1545.2h | NIMTC | 24 | Samsung | Rajavelsamy R (rajvel@samsung.com) | Rel-10 | 46 | Mirko | MTC, M2M |  | PCG-25 | SP-49 |  |
| 6652 | 2214.5 | Charging for Network Improvements for Machine-Type Communication | 3d? | 2011-03-21 A | 2011-03-23 A | 100% | 2011-03-21 | 2011-03-23 | 3d? | start no earlier than 2011-03-21 | S5 | 24h | 24h | NIMTC-CH | 26 | Ericsson | patrik.teppo@@ericsson.com | Rel-10 | 51 | Mirko | MTC, M2M | NIMTC-CH |  |  |  |
| 6653 | 2214.6 | **CN part of Stage 3 for Network Improvements for Machine-Type Communications** | 378d? | 2010-06-04 A | 2011-06-03 A | 100% | 2010-06-04 | 2011-06-03 | 261d? |  | C1; C4; C6 | 12976h | 12976h | NIMTC-CN | 25 | Ericsson | mikael.wass@ericsson.com | Rel-10 | 48 | Frederic | MTC, M2M | NIMTC-CN |  |  |  |
| 6654 | 2214.6.1 | CT1 part of Stage 3 for Network Improvements for Machine-Type Communications | 261d? | 2010-06-04 A | 2011-06-03 A | 100% | 2010-06-04 | 2011-06-03 | 261d? | finish no earlier than 2011-06-03 | C1 | 2088h | 2088h | NIMTC-CN | 25 | Ericsson | mikael.wass@ericsson.com | Rel-10 | 48 | Frederic | MTC, M2M |  |  |  |  |
| 6655 | 2214.6.2 | Deleted - CT3 part of Stage 3 for Network Improvements for Machine-Type Communications | 261d? | 2010-06-04 A | 2011-06-03 A | 100% | 2010-06-04 | 2011-06-03 | 261d? | finish no earlier than 2010-12-10 | C3 | 2088h | 2088h | NIMTC-CN | 25 | Ericsson | mikael.wass@ericsson.com | Rel-10 | 48 | Adrian | MTC, M2M |  | PCG-27 | CP-52 |  |
| 6656 | 2214.6.3 | CT4 part of Stage 3 for Network Improvements for Machine-Type Communications | 261d? | 2010-06-04 A | 2011-06-03 A | 100% | 2010-06-04 | 2011-06-03 | 261d? | finish no earlier than 2011-03-18 | C4 | 2088h | 2088h | NIMTC-CN | 25 | Ericsson | mikael.wass@ericsson.com | Rel-10 | 48 | Kimmo | MTC, M2M |  |  |  |  |
| 6657 | 2214.6.4 | CT6 part of Stage 3 for Network Improvements for Machine-Type Communications | 56d? | 2011-03-18 A | 2011-06-03 A | 100% | 2011-03-18 | 2011-06-03 | 56d? | finish no earlier than 2011-06-03 | C6 | 448h | 448h | NIMTC-CN | 26 | Sagem-Orga | heiko.kruse@sagem-orga.com | Rel-10 | 51 | Xavier | MTC, M2M |  |  |  |  |
| 6658 | 2214.7 | GERAN part of Network Improvements for Machine-Type Communications (Stage 3) | 261d? | 2010-09-03 A | 2011-09-02 A | 100% | 2010-09-03 | 2011-09-02 | 261d? | finish no earlier than 2011-09-02 | G2 | 2088h | 2088h | NIMTC | 25 | Vodafone, Ericsson | leo.patanapongpibul@vodafone.com, john.diachina@ericsson.com | Rel-10 | 47 | Gert | MTC, M2M |  |  |  |  |
| 6659 | 2214.8 | MS Conformance Test Aspects for GERAN - Network Improvements for Machine-Type Communications | 333d? | 2012-08-27 A | 2013-11-22 A | 100% | 2012-08-27 | 2013-11-22 | 333d? | finish no earlier than 2013-11-22 | G3new | 2656h | 2656h | NIMTC_GERAN-MSTest | 29 | ST-Ericsson | hakan.e.grunditz@stericsson.com | Rel-10 | 55 | Ingbert | MTC, M2M | NIMTC_GERAN-MSTest |  |  |  |
| 6660 | 2214.9 | RAN mechanisms to avoid CN overload due to Machine-Type Communications | 131d? | 2010-09-17 A | 2011-03-18 A | 100% | 2010-09-17 | 2011-03-18 | 131d? | finish no earlier than 2011-03-18 | R2; R3 | 2096h | 2096h | NIMTC-RAN_overload | 25 | Huawei | Jeff Gao (gaoyq@huawei.com) | Rel-10 | 49 | Yong-Jun | MTC, M2M | NIMTC-RAN_overload |  |  | RP-110063 |
| 6661 | 2214.10 | UE Conformance Test Aspects - Network Improvements for Machine-Type Communications | 202d? | 2012-09-11 A | 2013-06-14 A | 100% | 2012-09-11 | 2013-06-14 | 202d? | finish no earlier than 2013-06-14 | R5 | 1616h | 1616h | NIMTC-UEConTest | 29 | Ericsson | calle.hagenfeldt@ericsson.com | Rel-10 | 57 | Ingbert | MTC, M2M | NIMTC-UEConTest |  |  | RP-130465 |

Notes:
- 6636: CP#51 completed. SP#49 moved Stage 1 from Rel-9 & Completed Stage 2. SP#40 Stage 1 completed. Continuation of Rel-8 Feature PRIOR (UID_340044)
- 6637: 22/01: acronym modified / Impacted TSs and TRs: 22.153; 22.278
- 6638: 22/01: acronym modified
- 6639: 22/01: acronym modified / Impacted TSs and TRs: 23.002; 23.203; 23.221; 23.228; 23.272; 23.401
- 6640: 22/01: acronym modified / Impacted TSs and TRs: 23.002; 23.203; 23.221; 23.228; 23.272; 23.401
- 6641: 22/01: acronym modified / Impacted TSs and TRs: 23.002; 23.203; 23.221; 23.228; 23.272; 23.401
- 6642: SP#49 TR 23.854 v100 for Information. SP#50 moved to Rel-11 SRVCC aspect of enhancements for Multimedia Priority Service UID_480135 (place holder for solution alternatives and agreed functions to be reflected in affected existing TS) / Impacted TSs and TRs: new 23.854
- 6643: CP#51 completed / Impacted TSs and TRs: Stage 3
- 6644: CP#51 completed / Impacted TSs and TRs: 23.008; 29.002; 29.228; 29.229; 29.272; 29.274; 29.277; 29.328; 29.329
- 6645: CP#51 completed / Impacted TSs and TRs: 29.212; 29.213; 29.214
- 6646: CP#51 completed / Impacted TSs and TRs: 24.008; 24.229; 24.301
- 6647: Triggered by Rel-8 UID_7027 Study on Facilitating Machine to Machine Communication in GSM and UMTS (FS_M2M) TR 22.868
- 6648: SP#47 completed / Impacted TSs and TRs: 22.011; New 22.368
- 6649: SP#50 updated WID SP-090832=>SP-100863 (TR 23.888 not submitted for approval to conclude Rel-10 NIMTC as it will continue to serve as basis for Rel-11 SIMTC work item) / Impacted TSs and TRs: New 23.888
- 6650: SP#49 completed / Impacted TSs and TRs: 23.060; 23.236; 23.401
- 6651: SP#49 stopped (activity transferred to Rel-11 Feature SIMTC under UID_490028 "TR on Security aspects of Machine-Type Communications". / Impacted TSs and TRs: New 33.868
- 6652: SP#51 completed / Impacted TSs and TRs: 32.251; 32.298; 32.299
- 6653: CP#52 completed / Impacted TSs and TRs: Stage 3
- 6654: CP#52 completed / Impacted TSs and TRs: 23.122; 24.008; 24.301; New 24.368
- 6655: CP#52 stopped (SA2 decided to move impact from CT3 to CT4). Updated WID CP-110147=>CP-110442 (no CT3 impact) / Impacted TSs and TRs: 29.212; 29.213; 29.215
- 6656: CP#52 completed / Impacted TSs and TRs: 23.003; 23.008; 29.002; 29.060; 29.230; 29.272; 29.274; 29.275; 29.282
- 6657: CP#52 completed / Impacted TSs and TRs: 31.102
- 6658: GP#51 completed. GP#47 approved WID / Impacted TSs and TRs: 44.018; 44.060
- 6659: GP#60 completed. GP#55 approved WID. Testing for CT1 part of Stage 3 for NIMTC UID_480105, GERAN part of NIMTC (Stage 3) UID_490003 / Impacted TSs and TRs: 51.010-1; 51.010-2
- 6660: RP#51 completed / Impacted TSs and TRs: UTRA; LTE 25.331; 25.413; 36.331; 36.413
- 6661: RP#60 completed. Testing for CT1 part of Stage 3 UID_480105, RAN mechanisms to avoid CN overload due to MTC UID_490024 / Impacted TSs and TRs: 34.123-1; 34.123-2; 34.123-3; 36.523-1; 36.523-2; 36.523-3

| ID | WBS | Task | Duration | Start | Finish | Complete | Baseline start | Baseline finish | Baseline duration | Constraint | Resources | Work | Actual work | Acronym | PCG approved | WI rapporteur name | Release | TSG approved | MCC resp | Acronym_3GU_Export | Special Focus Doc |
| --- | --- | --- | --- | --- | --- | --- | --- | --- | --- | --- | --- | --- | --- | --- | --- | --- | --- | --- | --- | --- | --- |
| 6662 | 2215 | **Multi Access PDN Connectivity** | 762.12d? | 2009-03-13 A | 2011-03-18 A | 100% | 2009-03-13 | 2011-03-18 | 527d? |  | S2; C4; C1; C3 | 23680h | 23680h | MAPCON | 22 | Telecom Italia | Rel-10 | 43 | Maurice | MAPCON |  |
| 6663 | 2215.1 | Stage 2 for Multi Access PDN Connectivity | 401d? | 2009-03-13 A | 2010-09-23 A | 100% | 2009-03-13 | 2010-09-23 | 401d? |  | S2 | 3208h | 3208h | MAPCON | 22 | Telecom Italia | Rel-10 | 43 | Maurice |  |  |
| 6664 | 2215.2 | **CT aspects of Multi Access PDN Connectivity** | 128.25d? | 2010-11-15 A | 2011-03-18 A | 100% | 2010-11-15 | 2011-03-18 | 90d? |  | C4; C1; C3 | 3608h | 3608h | MAPCON-St3 | 26 | ZTE | Rel-10 | 50 | Kimmo | MAPCON-St3 |  |
| 6665 | 2215.2.1 | CT4 aspects of Multi Access PDN Connectivity | 20d? | 2010-11-15 A | 2010-12-10 A | 100% | 2010-11-15 | 2010-12-10 | 20d? | start no earlier than 2010-12-10 | C4 | 160h | 160h | MAPCON-St3 | 26 | ZTE | Rel-10 | 50 | Kimmo |  |  |
| 6666 | 2215.2.2 | CT1 aspects of Multi Access PDN Connectivity | 71d? | 2010-12-10 A | 2011-03-18 A | 100% | 2010-12-10 | 2011-03-18 | 71d? | start no earlier than 2010-12-10 | C1 | 568h | 568h | MAPCON-St3 | 26 | ZTE | Rel-10 | 50 | Frederic |  |  |
| 6667 | 2215.2.3 | CT3 aspects of Multi Access PDN Connectivity | 90d? | 2010-11-15 A | 2011-03-18 A | 100% | 2010-11-15 | 2011-03-18 | 90d? | finish no earlier than 2011-03-18 | C3 | 720h | 720h | MAPCON-St3 | 26 | ZTE | Rel-10 | 50 | Adrian |  |  |
| 6668 | 2216 | **IMS Service Continuity – Inter Device Transfer enhancements** | 1327.88d? | 2009-06-04 A | 2012-12-07 A | 100% | 2009-06-04 | 2012-12-07 | 924d? |  | S1; S2; C1; IETF | 41168h | 41168h | IMS_SC_eIDT | 23 | Huawei | Rel-10 | 44 | Alain | IMS_SC_eIDT |  |
| 6669 | 2216.1 | Stage 1 - IMS Service Continuity – Inter Device Transfer enhancements | 305.5d? | 2009-06-04 A | 2010-03-25 A | 100% | 2009-06-04 | 2010-03-25 | 211d? | finish no earlier than 2010-03-25 | S1 | 1688h | 1688h | IMS_SC_eIDT | 23 | Huawei | Rel-10 | 44 | Alain |  |  |
| 6670 | 2216.2 | Stage 2 - IMS Inter-UE Transfer enhancements | 261d? | 2009-09-24 A | 2010-09-23 A | 100% | 2009-09-24 | 2010-09-23 | 261d? | finish no earlier than 2010-09-23 | S2 | 2088h | 2088h | IMS_SC_eIDT | 23 | Huawei | Rel-10 | 45 | Maurice |  |  |
| 6671 | 2216.3 | Stage 3 - IMS Inter-UE Transfer enhancements | 261d? | 2010-03-19 A | 2011-03-18 A | 100% | 2010-03-19 | 2011-03-18 | 261d? | start no earlier than 2010-03-19 | C1 | 2088h | 2088h | IMS_SC_eIDT | 24 | Huawei | Rel-10 | 47 | Frederic |  |  |
| 6672 | 2216.4 | (IETF) Stage 3 - IMS Inter-UE Transfer enhancements | 717d? | 2010-03-19 A | 2012-12-07 A | 100% | 2010-03-19 | 2012-12-07 | 717d? | finish no earlier than 2012-12-04 | C1-IETF | 5736h | 5736h | IMS_SC_eIDT | 27 | christer.holmberg@ericsson.com | Rel-10 | 52 | Frederic |  |  |
| 6673 | 2217 | **IP-Short-Message-Gateway enhancements for CPM-SMS Interworking** | 371.75d? | 2009-09-24 A | 2010-09-17 A | 100% | 2009-09-24 | 2010-09-17 | 257d? |  | S1; S2; C3 | 9904.8h | 9904.8h | CPM-SMS | 23 | China Mobile | Rel-10 | 45 | Alain | CPM-SMS |  |
| 6674 | 2217.1 | Stage 1 for CPM-SMS | 131d? | 2009-09-24 A | 2010-03-25 A | 100% | 2009-09-24 | 2010-03-25 | 131d? | finish no earlier than 2010-03-25 | S1 | 1048h | 1048h | CPM-SMS | 23 | China Mobile | Rel-10 | 45 | Alain |  |  |
| 6675 | 2217.2 | Stage 2 for CPM-SMS | 130.1d? | 2009-09-24 A | 2010-03-25 A | 100% | 2009-09-24 | 2010-03-25 | 130.1d? | finish no earlier than 2010-03-25 | S2 | 1040.8h | 1040.8h | CPM-SMS | 23 | Orange | Rel-10 | 45 | Maurice |  |  |
| 6676 | 2217.3 | Stage 3 for IP-Short-Message-Gateway enhancements for CPM-SMS Interworking | 206d? | 2009-12-04 A | 2010-09-17 A | 100% | 2009-12-04 | 2010-09-17 | 206d? | finish no earlier than 2010-09-17 | C3 | 1648h | 1648h | CPM-SMS | 24 | Ericsson | Rel-10 | 46 | Adrian |  |  |
| 6677 | 2218 | **Completion of Communications on Not Logged-in** | 560.25d? | 2009-09-24 A | 2011-03-18 A | 100% | 2009-09-24 | 2011-03-18 | 387d? |  | S1; C1; C3 | 11992h | 11992h | CCNL | 23 | Deutsche Telekom | Rel-10 | 45 | Alain | CCNL |  |
| 6678 | 2218.1 | Stage 1 for Completion of Communications on Not Logged-in | 1d? | 2009-09-24 A | 2009-09-24 A | 100% | 2009-09-24 | 2009-09-24 | 1d? | start no earlier than 2009-09-24 | S1 | 8h | 8h | CCNL | 23 | Deutsche Telekom | Rel-10 | 45 | Alain |  |  |
| 6679 | 2218.2 | CT1 part of Stage 3 for Completion of Communications on Not Logged-in | 261d? | 2010-03-19 A | 2011-03-18 A | 100% | 2010-03-19 | 2011-03-18 | 261d? | finish no earlier than 2011-03-18 | C1 | 2088h | 2088h | CCNL | 24 | Deutsche Telekom | Rel-10 | 47 | Frederic |  |  |
| 6680 | 2218.3 | CT3 part of Stage 3 for Completion of Communications on Not Logged-in | 76d? | 2010-06-04 A | 2010-09-17 A | 100% | 2010-06-04 | 2010-09-17 | 76d? | finish no earlier than 2010-09-17 | C3 | 608h | 608h | CCNL | 25 | Deutsche Telekom | Rel-10 | 48 | Adrian |  |  |
| 6681 | 2219 | **Local IP Access and Selected Internet IP Traffic Offload** | 565.5d? | 2009-09-24 A | 2011-03-23 A | 100% | 2009-09-24 | 2011-03-23 | 390d? |  | S2; S1; S3; S5; C4; C1 | 66128h | 66128h | LIPA_SIPTO | 23 | Huawei, China Mobile | Rel-10 | 45 | Maurice | LIPA_SIPTO | HNB |
| 6682 | 2219.1 | Stage 1 for Local IP Access and Selected Internet IP Traffic Offload | 131d? | 2009-09-24 A | 2010-03-25 A | 100% | 2009-09-24 | 2010-03-25 | 131d? | finish no earlier than 2010-03-25 | S1 | 1048h | 1048h | LIPA_SIPTO | 23 | Huawei, China Mobile | Rel-10 | 45 | Alain |  | HNB |
| 6683 | 2219.2 | TR on Local IP Access and Selected Internet IP Traffic Offload | 387d? | 2009-09-24 A | 2011-03-18 A | 100% | 2009-09-24 | 2011-03-18 | 387d? | finish no earlier than 2011-03-18 | S2 | 3096h | 3096h | LIPA_SIPTO | 23 | Huawei, China Mobile | Rel-10 | 45 | Maurice |  | HNB |
| 6684 | 2219.3 | Security for Local IP Access and Selected Internet IP Traffic Offload | 261d? | 2009-09-24 A | 2010-09-23 A | 100% | 2009-09-24 | 2010-09-23 | 261d? | finish no earlier than 2010-09-23 | S3 | 2088h | 2088h | LIPA_SIPTO | 23 | Huawei, Qualcomm | Rel-10 | 45 | Mirko |  | HNB |
| 6685 | 2219.4 | OAM&P for Local IP Access and Selected Internet IP Traffic Offload | 390d? | 2009-09-24 A | 2011-03-23 A | 100% | 2009-09-24 | 2011-03-23 | 390d? | finish no earlier than 2011-03-23 | S5 | 3120h | 3120h | LIPA_SIPTO | 23 | Huawei, China Mobile | Rel-10 | 45 | Mirko |  | HNB |
| 6686 | 2219.5 | Charging for Local IP Access and Selected Internet IP Traffic Offload | 335d? | 2009-12-10 A | 2011-03-23 A | 100% | 2009-12-10 | 2011-03-23 | 335d? | finish no earlier than 2011-03-23 | S5 | 2680h | 2680h | LIPA_SIPTO | 24 | Huawei, China Mobile | Rel-10 | 46 | Mirko |  | HNB |

Notes:
- 6662: CP#51 completed. SP#49 Stage 2 completed. Triggered by TR 23.861 UID_410043 FS_MAPIM. Stage 1 in Rel-9 22.278 (6.2 - IP session control) / WI rapporteur e-mail: ivano.guardini@telecomitalia.it
- 6663: SP#49 completed. Triggered by TR 23.861 UID_410043 FS_MAPIM. Stage 1 in Rel-9 22.278 (6.2 - IP session control) / Impacted TSs and TRs: 23.237; 23.401; 23.402 / WI rapporteur e-mail: ivano.guardini@telecomitalia.it
- 6664: CP#51 completed / WI rapporteur e-mail: Xingyue (Joy) Zhou (zhou.xingyue@zte.com.cn)
- 6665: CP#50 completed / Impacted TSs and TRs: 29.273; 29.272; 29.002; 23.008 / WI rapporteur e-mail: Xingyue (Joy) Zhou (zhou.xingyue@zte.com.cn)
- 6666: CP#51 completed / Impacted TSs and TRs: 24.302; 24.312 / WI rapporteur e-mail: Xingyue (Joy) Zhou (zhou.xingyue@zte.com.cn)
- 6667: CP#51 completed / Impacted TSs and TRs: 29.215 / WI rapporteur e-mail: Xingyue (Joy) Zhou (zhou.xingyue@zte.com.cn)
- 6668: CP#51 completed. SP#47 Stage 1 completed. Rel-9 set Inter-Device Transfer requirements UID_410033 (IMS_SCC-IDT). Adds IDT scenarios and requirements / WI rapporteur e-mail: Amar Deol (adeol@huawei.com)
- 6669: SP#47 completed / Impacted TSs and TRs: 22.228 / WI rapporteur e-mail: Amar Deol (adeol@huawei.com)
- 6670: SP#49 completed / Impacted TSs and TRs: 23.237; 23.292; new 23.831 / WI rapporteur e-mail: Lee Valerius (lvalerius@huawei.com)
- 6671: CP#51 completed. WID updated CP-100334=>CP-110285 / Impacted TSs and TRs: 24.216; 24.229; 24.237; new (24.837; 24.337) / WI rapporteur e-mail: georg.mayer@huawei.com
- 6672: CP#58 completed / Impacted TSs and TRs: RFC 6809 (was draft-ietf-sipcore-proxy-feature) / WI rapporteur e-mail: christer.holmberg@ericsson.com
- 6673: CP#49 completed. SP#47 Stage 1 completed. IP-SM-GW enhancements for interworking with OMA CPM / WI rapporteur e-mail: Qing Huang (huangqing@chinamobile.com)
- 6674: SP#47 completed. External requirements (Stage 1 in OMA-RD-CPM-V1_0-20090310-C) / Impacted TSs and TRs: 22.340 / WI rapporteur e-mail: Qing Huang
- 6675: SP#47 completed / Impacted TSs and TRs: 23.204; new 23.824 / WI rapporteur e-mail: antoine.mouquet@orange-ftgroup.com
- 6676: CP#49 completed. Linked to Rel-8 UID_340031 Service-Level Interworking for Messaging Services (MESSIW) 23.204 / Impacted TSs and TRs: 29.311 / WI rapporteur e-mail: Jan Holm
- 6677: CP#51 completed. SP#45 Stage 1 completed / WI rapporteur e-mail: Kurt Bischinger
- 6678: SP#45 completed / Impacted TSs and TRs: 22.173 CR#0056r1 / WI rapporteur e-mail: Kurt Bischinger
- 6679: CP#51 completed / Impacted TSs and TRs: 24.173; 24.642 / WI rapporteur e-mail: martin.huelsemann@telekom.de
- 6680: CP#49 completed / Impacted TSs and TRs: 29.165 / WI rapporteur e-mail: martin.huelsemann@telekom.de
- 6681: TSG#51 completed. Updated WID SP-100696=>SP-110131. SP#49 Stage 2 & Security completed. UID_400035 Enhanced Home NodeB/eNodeB (EHNB) formerly covered Local IP Access to Internet and Local access to Home Network from the Home NodeB/eNodeB / WI rapporteur e-mail: patrice.hede@huawei.com, Tao Sun (suntao@chinamobile.com)
- 6682: SP#47 completed / Impacted TSs and TRs: 22.101; 22.220 / WI rapporteur e-mail: Amar Deol (adeolf@huawei.com), Gang Li (ligangyf@chinamobile.com)
- 6683: SP#51 completed. TR 23.829 for Approval / Impacted TSs and TRs: New 23.829 / WI rapporteur e-mail: patrice.hede@huawei.com, Tao Sun (suntao@chinamobile.com)
- 6684: SP#49 completed / Impacted TSs and TRs: 33.102; 33.107; 33.108; 33.320; 33.401 / WI rapporteur e-mail: Marcus Wong (mwong@huawei.com), Brian Rosenberg (bmr@qualcomm.com)
- 6685: SP#51 completed. Updated WID SP-100696=>SP-110131 / Impacted TSs and TRs: 32.581; 32.582; 32.584; 32.591; 32.592; 32.642; 32.646; 32.772; 32.782 / WI rapporteur e-mail: Zou Lan (zlan@huawei.com), Chen Gang (chengang@chinamobile.com)
- 6686: SP#51 completed. Updated WID SP-100696=>SP-110131 / Impacted TSs and TRs: 32.251 / WI rapporteur e-mail: shan.mingjun@huawei.com, Ai Chen (chenai@chinamobile.com)

| ID | WBS | Task | Duration | Start | Finish | Complete | Baseline start | Baseline finish | Baseline duration | Constraint | Resources | Work | Actual work | Acronym | PCG approved | WI rapporteur name | WI rapporteur e-mail | Release | TSG approved | MCC resp | Special Focus Doc | Acronym_3GU_Export |
| --- | --- | --- | --- | --- | --- | --- | --- | --- | --- | --- | --- | --- | --- | --- | --- | --- | --- | --- | --- | --- | --- | --- |
| 6687 | 2219.6 | **Stage 2/3 for Local IP Access** | 560.25d? | 2009-09-24 A | 2011-03-18 A | 100% | 2009-09-24 | 2011-03-18 | 387d? |  | S2; C4; C1 | 17968h | 17968h | LIPA | 23 | Huawei, China Mobile | patrice.hede@huawei.com, Tao Sun (suntao@chinamobile.com) | Rel-10 | 45 | Maurice | HNB | LIPA |
| 6688 | 2219.6.1 | Stage 2 for Local IP Access | 261d? | 2009-09-24 A | 2010-09-23 A | 100% | 2009-09-24 | 2010-09-23 | 261d? | finish no earlier than 2010-08-10 | S2 | 2088h | 2088h | LIPA | 23 | Huawei, China Mobile | patrice.hede@huawei.com, Tao Sun (suntao@chinamobile.com) | Rel-10 | 45 | Maurice | HNB |  |
| 6689 | 2219.6.2 | **Stage 3 for Local IP Access** | 298.25d? | 2010-06-04 A | 2011-03-18 A | 100% | 2010-06-04 | 2011-03-18 | 206d? |  | C4; C1 | 6592h | 6592h | LIPA | 25 | China Mobile | Zhang Hao (zhanghao@chinamobile.com) | Rel-10 | 48 | Kimmo | HNB |  |
| 6690 | 2219.6.2.1 | CT4 part of Stage 3 for Local IP Access | 206d? | 2010-06-04 A | 2011-03-18 A | 100% | 2010-06-04 | 2011-03-18 | 206d? | finish no earlier than 2011-03-18 | C4 | 1648h | 1648h | LIPA | 25 | China Mobile | Zhang Hao (zhanghao@chinamobile.com) | Rel-10 | 48 | Kimmo | HNB |  |
| 6691 | 2219.6.2.2 | CT1 part of Stage 3 for Local IP Access | 206d? | 2010-06-04 A | 2011-03-18 A | 100% | 2010-06-04 | 2011-03-18 | 206d? | finish no earlier than 2011-03-18 | C1 | 1648h | 1648h | LIPA | 25 | China Mobile | Zhang Hao (zhanghao@chinamobile.com) | Rel-10 | 48 | Frederic | HNB |  |
| 6692 | 2219.7 | **Stage 2/3 for SIPTO for macro networks** | 560.25d? | 2009-09-24 A | 2011-03-18 A | 100% | 2009-09-24 | 2011-03-18 | 387d? |  | S2; C4; C1 | 17408h | 17408h | SIPTO | 23 | Huawei, China Mobile | patrice.hede@huawei.com, Tao Sun (suntao@chinamobile.com) | Rel-10 | 45 | Maurice | HNB | SIPTO |
| 6693 | 2219.7.1 | Stage 2 for SIPTO for macro networks | 261d? | 2009-09-24 A | 2010-09-23 A | 100% | 2009-09-24 | 2010-09-23 | 261d? | finish no earlier than 2010-09-23 | S2 | 2088h | 2088h | SIPTO | 23 | Huawei, China Mobile | patrice.hede@huawei.com, Tao Sun (suntao@chinamobile.com) | Rel-10 | 45 | Maurice | HNB |  |
| 6694 | 2219.7.2 | **Stage 3 for SIPTO for macro networks** | 298.25d? | 2010-06-04 A | 2011-03-18 A | 100% | 2010-06-04 | 2011-03-18 | 206d? |  | C4; C1 | 6032h | 6032h | SIPTO | 25 | Huawei | Caixia Qi (qcxmay@huawei.com) | Rel-10 | 48 | Kimmo | HNB |  |
| 6695 | 2219.7.2.1 | CT4 part of Stage 3 for SIPTO for macro networks | 206d? | 2010-06-04 A | 2011-03-18 A | 100% | 2010-06-04 | 2011-03-18 | 206d? | finish no earlier than 2011-03-18 | C4 | 1648h | 1648h | SIPTO | 25 | Huawei | Caixia Qi (qcxmay@huawei.com) | Rel-10 | 48 | Kimmo | HNB |  |
| 6696 | 2219.7.2.2 | CT1 part of Stage 3 for SIPTO for macro networks | 136d? | 2010-06-04 A | 2010-12-10 A | 100% | 2010-06-04 | 2010-12-10 | 136d? | finish no earlier than 2011-03-18 | C1 | 1088h | 1088h | SIPTO | 25 | Huawei | Caixia Qi (qcxmay@huawei.com) | Rel-10 | 48 | Frederic | HNB |  |
| 6697 | 2220 | **IP Flow Mobility and seamless WLAN offload** | 565.5d? | 2009-09-24 A | 2011-03-23 A | 100% | 2009-09-24 | 2011-03-23 | 390d? |  | S2; S1; S5; C1; C3 | 26808h | 26808h | IFOM | 23 | Qualcomm | Gerardo Giaretta (gerardo@qualcomm.com) | Rel-10 | 45 | Maurice | WLAN | IFOM |
| 6698 | 2220.1 | Stage 1 for IP Flow Mobility and seamless WLAN offload | 56d? | 2009-09-24 A | 2009-12-10 A | 100% | 2009-09-24 | 2009-12-10 | 56d? | finish no earlier than 2009-12-10 | S1 | 448h | 448h | IFOM | 23 | Qualcomm | David Williams (dwilliam@qualcomm.com) | Rel-10 | 45 | Alain | WLAN |  |
| 6699 | 2220.2 | Stage 2 for IP Flow Mobility and seamless WLAN offload | 261d? | 2009-09-24 A | 2010-09-23 A | 100% | 2009-09-24 | 2010-09-23 | 261d? | finish no earlier than 2010-09-23 | S2 | 2088h | 2088h | IFOM | 23 | Qualcomm | Gerardo Giaretta (gerardo@qualcomm.com) | Rel-10 | 45 | Maurice | WLAN |  |
| 6700 | 2220.3 | Charging for IP Flow Mobility and seamless WLAN offload | 260d? | 2010-03-25 A | 2011-03-23 A | 100% | 2010-03-25 | 2011-03-23 | 260d? | finish no earlier than 2011-03-23 | S5 | 2080h | 2080h | IFOM | 24 | Alcatel-Lucent | maryse.gardella@alcatel-lucent.com | Rel-10 | 47 | Mirko | WLAN |  |
| 6701 | 2220.4 | **Stage 3 for IP Flow Mobility and seamless WLAN offload** | 298.25d? | 2010-06-04 A | 2011-03-18 A | 100% | 2010-06-04 | 2011-03-18 | 206d? |  | C1; C3 | 6592h | 6592h | IFOM-CT | 25 | Qualcomm | Patrick Stupar (pstupar@qualcomm.com) | Rel-10 | 48 | Frederic | WLAN | IFOM-CT |
| 6702 | 2220.4.1 | CT1 part of Stage 3 for IP Flow Mobility and seamless WLAN offload | 206d? | 2010-06-04 A | 2011-03-18 A | 100% | 2010-06-04 | 2011-03-18 | 206d? | finish no earlier than 2011-03-18 | C1 | 1648h | 1648h | IFOM-CT | 25 | Qualcomm | Patrick Stupar (pstupar@qualcomm.com) | Rel-10 | 48 | Frederic | WLAN |  |
| 6703 | 2220.4.2 | CT3 part of Stage 3 for IP Flow Mobility and seamless WLAN offload | 206d? | 2010-06-04 A | 2011-03-18 A | 100% | 2010-06-04 | 2011-03-18 | 206d? | finish no earlier than 2011-03-18 | C3 | 1648h | 1648h | IFOM-CT | 25 | Qualcomm | Patrick Stupar (pstupar@qualcomm.com) | Rel-10 | 48 | Adrian | WLAN |  |
| 6704 | 2221 | **Enabling Coder Selection and Rate Adaptation for UTRAN and E-UTRAN for Load Adaptive Applications** | 1190.78d? | 2009-07-15 A | 2012-09-07 A | 100% | 2009-07-15 | 2012-09-07 | 827.4d? |  | S2; S4; C4; C3; C1; IETF | 85939.2h | 85939.2h | ECSRA_LAA | 23 | Qualcomm | AC Mahendran (ac@qualcomm.com) | Rel-10 | 45 | Maurice |  | ECSRA_LAA |
| 6705 | 2221.1 | TR on Enabling Coder Selection and Rate Adaptation for UTRAN and E-UTRAN for Load Adaptive Applications | 186d? | 2010-01-07 A | 2010-09-23 A | 100% | 2010-01-07 | 2010-09-23 | 186d? | finish no earlier than 2010-09-23 | S2; S4 | 2976h | 2976h | ECSRA_LAA | 23 | Qualcomm | AC Mahendran (ac@qualcomm.com) | Rel-10 | 45 | Maurice |  |  |
| 6706 | 2221.2 | SA4 review of TR on Enabling Coder Selection and Rate Adaptation for UTRAN and E-UTRAN for Load Adaptive Applications | 320d? | 2009-09-24 A | 2010-12-15 A | 100% | 2009-09-24 | 2010-12-15 | 320d? | finish no earlier than 2010-12-15 | S4 | 2560h | 2560h | ECSRA_LAA | 23 | Qualcomm | AC Mahendran (ac@qualcomm.com) | Rel-10 | 45 | Paolo |  |  |
| 6707 | 2221.3 | Stage 2 for Enabling Coder Selection and Rate Adaptation for UTRAN and E-UTRAN for Load Adaptive Applications | 261d? | 2009-09-24 A | 2010-09-23 A | 100% | 2009-09-24 | 2010-09-23 | 261d? | finish no earlier than 2010-09-23 | S2 | 2088h | 2088h | ECSRA_LAA | 23 | Qualcomm | AC Mahendran (ac@qualcomm.com) | Rel-10 | 45 | Maurice |  |  |
| 6708 | 2221.4 | SA4 aspects of Enabling Coder Selection and Rate Adaptation for UTRAN and E-UTRAN for Load Adaptive Applications | 130d? | 2010-09-23 A | 2011-03-23 A | 100% | 2010-09-23 | 2011-03-23 | 130d? | finish no earlier than 2011-03-23 | S4 | 1040h | 1040h | ECSRA_LAA | 25 | Qualcomm | AC Mahendran (ac@qualcomm.com) | Rel-10 | 49 | Paolo |  |  |
| 6709 | 2221.5 | **CN aspects of Enabling Coder Selection and Rate Adaptation for UTRAN and E-UTRAN for Load Adaptive Applications** | 1190.78d? | 2009-07-15 A | 2012-09-07 A | 100% | 2009-07-15 | 2012-09-07 | 827.4d? |  | C4; C3; C1 | 37560h | 37560h | ECSRA_LAA-CN | 25 | Ericsson | philip.hodges@ericsson.com | Rel-10 | 49 | Kimmo |  | ECSRA_LAA-CN |
| 6710 | 2221.5.1 | CT4 part of CN aspects of Enabling Coder Selection and Rate Adaptation for UTRAN and E-UTRAN for Load Adaptive Applications | 186d? | 2010-09-17 A | 2011-06-03 A | 100% | 2010-09-17 | 2011-06-03 | 186d? | start no earlier than 2010-09-17 | C4 | 1488h | 1488h | ECSRA_LAA-CN | 25 | Ericsson | philip.hodges@ericsson.com | Rel-10 | 49 | Kimmo |  |  |
| 6711 | 2221.5.2 | (IETF) CT3, CT4 part of CN aspects of Enabling Coder Selection and Rate Adaptation for UTRAN and E-UTRAN for Load Adaptive Applications | 827.4d? | 2009-07-15 A | 2012-09-07 A | 100% | 2009-07-15 | 2012-09-07 | 827.4d? | finish no earlier than 2012-09-07 | C3-IETF; C4-IETF | 13238.4h | 13238.4h | ECSRA_LAA-CN | 27 | Lionel Morand |  | Rel-10 | 53 | Adrian |  |  |
| 6712 | 2221.5.3 | CT3 part of CN aspects of Enabling Coder Selection and Rate Adaptation for UTRAN and E-UTRAN for Load Adaptive Applications | 186d? | 2010-09-17 A | 2011-06-03 A | 100% | 2010-09-17 | 2011-06-03 | 186d? | finish no earlier than 2011-06-03 | C3 | 1488h | 1488h | ECSRA_LAA-CN | 25 | Ericsson | philip.hodges@ericsson.com | Rel-10 | 49 | Adrian |  |  |
| 6713 | 2221.5.4 | CT1 part of CN aspects of Enabling Coder Selection and Rate Adaptation for UTRAN and E-UTRAN for Load Adaptive Applications | 186d? | 2010-09-17 A | 2011-06-03 A | 100% | 2010-09-17 | 2011-06-03 | 186d? | start no earlier than 2010-09-17 | C1 | 1488h | 1488h | ECSRA_LAA-CN | 25 | Ericsson | philip.hodges@ericsson.com | Rel-10 | 49 | Frederic |  |  |

Notes:
- 6687: -
- 6688: SP#49 completed (has impacts to RAN) / Impacted TSs and TRs: 23.060; 23.401
- 6689: CP#51 completed
- 6690: CP#51 completed / Impacted TSs and TRs: 23.008; 23.015; 29.002; 29.060; 29.272; 29.274; 29.281; 29.303
- 6691: CP#51 completed / Impacted TSs and TRs: 24.008; 24.301
- 6692: -
- 6693: SP#49 completed (SIPTO GW selection for wild card APN and for GERAN. Serving-GW selection for SIPTO. Corrections and Clarifications of the SIPTO procedure) / Impacted TSs and TRs: 23.060; 23.401
- 6694: CP#51 completed. Updated WID CP-100419=>CP-110091
- 6695: CP#51 completed. Updated WID CP-100419=>CP-110091 / Impacted TSs and TRs: 23.003; 23.008; 29.002; 29.272; 29.303
- 6696: CP#50 completed / Impacted TSs and TRs: 24.008; 24.301
- 6697: SP#51 completed. Triggered by Rel-10 TR 23.861 (UID_410043 Study on Multi Access PDN connectivity and IP flow mobility - MAPIM)
- 6698: SP#46 completed / Impacted TSs and TRs: 22.278
- 6699: SP#49 completed / Impacted TSs and TRs: 23.203; 23.402; new 23.261
- 6700: SP#51 completed / Impacted TSs and TRs: 32.240; 32.251; 32.252; 32.298; 32.299
- 6701: CP#51 completed / Impacted TSs and TRs: Stage 3
- 6702: CP#51 completed / Impacted TSs and TRs: 24.008; 24.301; 24.302; 24.303; 24.312; 24.327
- 6703: CP#51 completed / Impacted TSs and TRs: 29.212; 29.213; 29.214; 29.215
- 6704: CP#52 completed. Triggered by Rel-9 UID_440013 Vocoder rate adaptation for LTE / Impacted TSs and TRs: UTRA; LTE
- 6705: SP#48 completed / Impacted TSs and TRs: new 23.860
- 6706: SP#50 completed / Impacted TSs and TRs: new 23.860
- 6707: SP#49 completed / Impacted TSs and TRs: 23.060; 23.203; 23.228; 23.401
- 6708: SP#51 completed / Impacted TSs and TRs: 26.114
- 6709: CP#52 completed / Impacted TSs and TRs: Stage 2/3
- 6710: CP#52 completed / Impacted TSs and TRs: 23.334; 29.334; 29.238; 23.333; 29.333; 29.232; 29.332
- 6711: CP#57 completed / Impacted TSs and TRs: RFC 6679 (was draft-ietf-avtcore-ecn-for-rtp)
- 6712: CP#52 completed / Impacted TSs and TRs: 29.162; 29.163; 29.213; 29.235; 29.292
- 6713: CP#52 completed / Impacted TSs and TRs: 24.229

| ID | WBS | Task | Type | Duration | Start | Finish | Complete | Baseline start | Baseline finish | Baseline duration | Constraint | Resources | Work | Actual work | Acronym | PCG approved | Impacted TSs and TRs | WI rapporteur name | WI rapporteur e-mail | Release | TSG approved | MCC resp | Special Focus Doc | Acronym_3GU_Export | PCG stopped | TSG stopped |
| --- | --- | --- | --- | --- | --- | --- | --- | --- | --- | --- | --- | --- | --- | --- | --- | --- | --- | --- | --- | --- | --- | --- | --- | --- | --- | --- |
| 6714 | 2222 | **Extended H(e)NB features** |  | 675.12d? | 2008-12-11 A | 2010-09-23 A | 100% | 2008-12-11 | 2010-09-23 | 467d? |  | S1; S2; S3 | 15552h | 15552h | EHNBF | 23 | UTRA; LTE | NEC | joerg.swetina@neclab.eu | Rel-10 | 45 | Alain | HNB | EHNBF |  |  |
| 6715 | 2222.1 | Stage 1 of Extended H(e)NB features |  | 131d? | 2009-09-24 A | 2010-03-25 A | 100% | 2009-09-24 | 2010-03-25 | 131d? | finish no earlier than 2010-03-25 | S1 | 1048h | 1048h | EHNBF | 23 | 22.220 | NEC | joerg.swetina@neclab.eu | Rel-10 | 45 | Alain | HNB |  |  |  |
| 6716 | 2222.2 | IMS aspects of Architecture for Home NodeB |  | 336d? | 2008-12-11 A | 2010-03-25 A | 100% | 2008-12-11 | 2010-03-25 | 336d? | finish no earlier than 2010-03-25 | S2 | 2688h | 2688h | EHNB-IMS | 22 | New 23.832 | Alcatel-Lucent | Nicolas Drevon | Rel-10 | 42 | Maurice | HNB | EHNB-IMS |  |  |
| 6717 | 2222.3 | Extended H(e)NB Security features (Stage 2) |  | 76d? | 2010-06-10 A | 2010-09-23 A | 100% | 2010-06-10 | 2010-09-23 | 76d? | finish no earlier than 2010-09-23 | S3 | 608h | 608h | EHNBF-Sec | 25 | 33.320 | Huawei | Marcus Wong (mwong@huawei.com) | Rel-10 | 48 | Mirko | HNB | EHNBF-Sec |  |  |
| 6718 | 2223 | **Optimal Media Routing** |  | 455.75d? | 2010-03-25 A | 2011-06-08 A | 100% | 2010-03-25 | 2011-06-08 | 314d? |  | S2; S5; C3; C1 | 22696h | 22696h | OMR | 24 |  | Alcatel-Lucent | andy.bennett@alcatel-lucent.com | Rel-10 | 46 | Maurice |  | OMR |  |  |
| 6719 | 2223.1 | Stage 2 for Optimal Media Routing | milestone | 0d? | 2010-03-25 A | 2010-03-25 A | 100% | 2010-03-25 | 2010-03-25 | 0d? |  | S2 |  |  | OMR | 24 | 23.228 | Alcatel-Lucent | andy.bennett@alcatel-lucent.com | Rel-10 | 46 | Maurice |  |  |  |  |
| 6720 | 2223.2 | **Stage 3 for Optimal Media Routing** |  | 378d? | 2010-06-04 A | 2011-06-03 A | 100% | 2010-06-04 | 2011-06-03 | 261d? |  | C3; C1; C4 | 11648h | 11648h | OMR | 25 |  | Alcatel-Lucent | jim.calme@alcatel-lucent.com | Rel-10 | 48 | Adrian |  |  |  |  |
| 6721 | 2223.2.1 | CT3 part of Stage 3 for Optimal Media Routeing |  | 261d? | 2010-06-04 A | 2011-06-03 A | 100% | 2010-06-04 | 2011-06-03 | 261d? | finish no earlier than 2011-06-03 | C3 | 2088h | 2088h | OMR | 25 | 29.162; 29.163; 29.165; 29.235; new 29.079 | Alcatel-Lucent | jim.calme@alcatel-lucent.com | Rel-10 | 48 | Adrian |  |  |  |  |
| 6722 | 2223.2.2 | CT1 part of Stage 3 for Optimal Media Routeing |  | 206d? | 2010-06-04 A | 2011-03-18 A | 100% | 2010-06-04 | 2011-03-18 | 206d? | finish no earlier than 2011-03-18 | C1 | 1648h | 1648h | OMR | 25 | 24.229 | Alcatel-Lucent | jim.calme@alcatel-lucent.com | Rel-10 | 48 | Frederic |  |  |  |  |
| 6723 | 2223.2.3 | Deleted - CT4 part of Stage 3 for Optimal Media Routeing |  | 206d? | 2010-06-04 A | 2011-03-18 A | 100% | 2010-06-04 | 2011-03-18 | 206d? | finish no earlier than 2011-03-18 | C4 | 1648h | 1648h | OMR | 25 |  | Alcatel-Lucent | jim.calme@alcatel-lucent.com | Rel-10 | 48 | Kimmo |  |  | PCG-26 | CP-51 |
| 6724 | 2223.3 | Charging for Optimal Media Routing |  | 125d? | 2010-12-16 A | 2011-06-08 A | 100% | 2010-12-16 | 2011-06-08 | 125d? | finish no earlier than 2011-06-08 | S5 | 1000h | 1000h | OMR | 26 | 32.260; 32.298; 32.299 | Alcatel-Lucent | maryse.gardella@alcatel-lucent.com | Rel-10 | 50 | Mirko |  |  |  |  |
| 6725 | 2224 | **IMS Emergency Session Enhancements** |  | 451.5d? | 2010-03-25 A | 2011-06-03 A | 100% | 2010-03-25 | 2011-06-03 | 312d? |  | S1; S2; C1 | 9552h | 9552h | IESE | 24 |  | Deutsche Telekom, T-Mobile | michele.zarri@t-mobile.co.uk | Rel-10 | 47 | Maurice | Public Safety (I-A) | IESE |  |  |
| 6726 | 2224.1 | Stage 1 for IMS Emergency Session Enhancements |  | 1d? | 2010-03-25 A | 2010-03-25 A | 100% | 2010-03-25 | 2010-03-25 | 1d? | start no earlier than 2010-03-25 | S1 | 8h | 8h | IESE | 24 | 22.101 CR#0343 | Deutsche Telekom, T-Mobile | Kurt Bischinger | Rel-10 | 47 | Alain | Public Safety (I-A) |  |  |  |
| 6727 | 2224.2 | Stage 2 for IMS Emergency Session Enhancements |  | 131d? | 2010-03-25 A | 2010-09-23 A | 100% | 2010-03-25 | 2010-09-23 | 131d? | finish no earlier than 2010-09-23 | S2 | 1048h | 1048h | IESE | 24 | 23.167 | Deutsche Telekom, T-Mobile | michele.zarri@t-mobile.co.uk | Rel-10 | 47 | Maurice | Public Safety (I-A) |  |  |  |
| 6728 | 2224.3 | Stage 3 for IMS Emergency Session Enhancements |  | 126d? | 2010-12-10 A | 2011-06-03 A | 100% | 2010-12-10 | 2011-06-03 | 126d? | finish no earlier than 2011-06-03 | C1 | 1008h | 1008h | IESE | 26 | 24.229 | Deutsche Telekom | reinhard.lauster@t-mobile.at | Rel-10 | 50 | Frederic | Public Safety (I-A) |  |  |  |
| 6729 | 2225 | **S2b Mobility based on GTP** |  | 292d? | 2010-06-10 A | 2011-03-18 A | 100% | 2010-06-10 | 2011-03-18 | 202d? |  | S2; C4; C3; C1 | 12800h | 12800h | SMOG | 25 |  | Alcatel-Lucent | bruno.landais@alcatel-lucent.com | Rel-10 | 48 | Maurice | WLAN | SMOG |  |  |
| 6730 | 2225.1 | Stage 2 for S2b Mobility based on GTP |  | 76d? | 2010-06-10 A | 2010-09-23 A | 100% | 2010-06-10 | 2010-09-23 | 76d? | finish no earlier than 2010-09-23 | S2 | 608h | 608h | SMOG | 25 | 23.002; 23.203; 23.402 | Alcatel-Lucent | bruno.landais@alcatel-lucent.com | Rel-10 | 48 | Maurice | WLAN |  |  |  |
| 6731 | 2225.2 | **Stage 3 for S2b Mobility based on GTP** |  | 189.5d? | 2010-09-17 A | 2011-03-18 A | 100% | 2010-09-17 | 2011-03-18 | 131d? |  | C4; C3; C1 | 5728h | 5728h | SMOG-St3 | 25 |  | Alcatel-Lucent | bruno.landais@alcatel-lucent.com | Rel-10 | 49 | Kimmo | WLAN | SMOG-St3 |  |  |
| 6732 | 2225.2.1 | CT4 part of Stage 3 for S2b Mobility based on GTP |  | 131d? | 2010-09-17 A | 2011-03-18 A | 100% | 2010-09-17 | 2011-03-18 | 131d? | finish no earlier than 2011-03-18 | C4 | 1048h | 1048h | SMOG-St3 | 25 | 23.003; 23.007; 23.008; 29.273; 29.274; 29.281; 29.303 | Alcatel-Lucent | bruno.landais@alcatel-lucent.com | Rel-10 | 49 | Kimmo | WLAN |  |  |  |
| 6733 | 2225.2.2 | CT3 part of Stage 3 for S2b Mobility based on GTP |  | 131d? | 2010-09-17 A | 2011-03-18 A | 100% | 2010-09-17 | 2011-03-18 | 131d? | finish no earlier than 2011-03-18 | C3 | 1048h | 1048h | SMOG-St3 | 25 | 29.212; 29.213; 29.215 | Alcatel-Lucent | bruno.landais@alcatel-lucent.com | Rel-10 | 49 | Adrian | WLAN |  |  |  |
| 6734 | 2225.2.3 | CT1 part of Stage 3 for S2b Mobility based on GTP |  | 61d? | 2010-09-17 A | 2010-12-10 A | 100% | 2010-09-17 | 2010-12-10 | 61d? | finish no earlier than 2010-12-10 | C1 | 488h | 488h | SMOG-St3 | 25 | 24.302 | Alcatel-Lucent | bruno.landais@alcatel-lucent.com | Rel-10 | 49 | Frederic | WLAN |  |  |  |
| 6735 | 2226 | **Policy Enhancements for Sponsored Connectivity and Coherent Access to Policy related Databases** |  | 162.65d? | 2010-10-12 A | 2011-03-18 A | 100% | 2010-10-12 | 2011-03-18 | 113.15d? |  | S2; C3 | 2378.4h | 2378.4h | PEST | 26 |  | Qualcomm | AC Mahendran (ac@qualcomm.com) | Rel-10 | 50 | Maurice |  | PEST |  |  |
| 6736 | 2226.1 | Stage 2 for Policy Enhancements for Sponsored Connectivity and Coherent Access to Policy related Databases | milestone | 0d? | 2010-10-12 A | 2010-10-12 A | 100% | 2010-10-12 | 2010-12-15 | 0d? | finish no earlier than 2010-12-15 | S2 |  |  | PEST | 26 | 23.002; 23.203 | Qualcomm | AC Mahendran (ac@qualcomm.com) | Rel-10 | 50 | Maurice |  |  |  |  |
| 6737 | 2226.2 | CT3 aspects of Policy Enhancements for Sponsored Connectivity and Coherent Access to Policy related Databases |  | 71d? | 2010-12-10 A | 2011-03-18 A | 100% | 2010-12-10 | 2011-03-18 | 71d? | finish no earlier than 2011-03-18 | C3 | 568h | 568h | PEST-CT3 | 26 | 29.212; 29.213; 29.214; 29.215 | ZTE | zhou.xiaoyun@zte.com.cn | Rel-10 | 50 | Adrian |  | PEST-CT3 |  |  |

Notes:
- 6714: SP#49 completed. Adds extensions to Rel-9 functionality in UID_400035 Enhanced Home NodeB / eNodeB (EHNB)
- 6715: SP#47 completed
- 6716: SP#47 completed. Chosen solution has no normative impacts
- 6717: SP#49 completed
- 6718: CP#52 completed. SP#47 Stage 2 completed. Triggered by TR 23.894 (UID_370050 Study on System enhancements for the use of IMS servicES in CP-150local breakout)
- 6719: SP#47 completed
- 6720: CP#51 completion 03/11=>06/11. WID updated CP-100327=>CP-110134
- 6721: CP#52 completed
- 6722: CP#51 completed. WID updated CP-100327=>CP-110134
- 6723: CP#51 stopped (CT4 specs not impacted). WID updated CP-100327=>CP-110134
- 6724: SP#52 completed. Stage 3: Linked to CT3 TS 29.079 OMR within the IMS¦Stage 3 (UID_480110)
- 6725: CP#52 completed. SP#49 completed. Source of external requirements: ETSI TISPAN TS 181.019 (Business Communication Requirements)
- 6726: SP#47 completed
- 6727: SP#49 completed
- 6728: CP#52 completed
- 6729: CP#51 completed. SP#49 Stage 2 completed. Related to Rel-10 UID_470049 Study on S2b mobility based on GTP (TR23.834), UID_350027 SAE for support for non-3GPP accesses. Stage1 in Rel-8 UID_320022 Reqs for evolution of 3GPP system architecture (AIPN-SAE)
- 6730: SP#49 completed
- 6731: CP#51 Stage 3 completed
- 6732: CP#51 completed
- 6733: CP#51 completed
- 6734: CP#50 completed
- 6735: CP#51 completed. SP#50 Stage 2 completed. Triggered by the SA1,SA2 Rel-10 TR 23.813 Study on Policy solutions and enhancements (FS_PP) UID_440047. Provides Video Call seamless service continuity for 3G/LTE terminal user
- 6736: SP#51 updated WID SP-100702=>SP-110196. SP#49 work completed as SA2 CRs approved under TEI10 (SP-10557)
- 6737: CP#51 completed

| ID | WBS | Task | Duration | Start | Finish | Complete | Baseline start | Baseline finish | Baseline duration | Constraint | Resources | Work | Actual work | Acronym | PCG approved | WI rapporteur name | WI rapporteur e-mail | Release | TSG approved | MCC resp | Acronym_3GU_Export | PCG stopped | TSG stopped |
| --- | --- | --- | --- | --- | --- | --- | --- | --- | --- | --- | --- | --- | --- | --- | --- | --- | --- | --- | --- | --- | --- | --- | --- |
| 6738 | 2227 | **Lawful Interception in the 3GPP Rel-10** | 456.75d? | 2010-03-25 A | 2011-06-08 A | 100% | 2010-03-25 | 2011-06-08 | 315d? |  | S3 | 20480h | 20480h | LI10 | 24 | PIDS, BT | Koen Jaspers (k.b.jaspers@minjus.nl), alex.leadbeater@bt.com | Rel-10 | 47 | Mirko | LI10 |  |  |
| 6739 | 2227.1 | LI for CAT (Customer Alerting Tones) | 315d? | 2010-03-25 A | 2011-06-08 A | 100% | 2010-03-25 | 2011-06-08 | 315d? | finish no earlier than 2011-03-23 | S3 | 2520h | 2520h | LI10 | 24 | PIDS, BT | Koen Jaspers (k.b.jaspers@minjus.nl), alex.leadbeater@bt.com | Rel-10 | 47 | Mirko |  |  |  |
| 6740 | 2227.2 | LI for CRS (Customized Ringing Signal) | 315d? | 2010-03-25 A | 2011-06-08 A | 100% | 2010-03-25 | 2011-06-08 | 315d? | finish no earlier than 2011-03-23 | S3 | 2520h | 2520h | LI10 | 24 | PIDS, BT | Koen Jaspers (k.b.jaspers@minjus.nl), alex.leadbeater@bt.com | Rel-10 | 47 | Mirko |  |  |  |
| 6741 | 2227.3 | LI for EPS enhancements | 315d? | 2010-03-25 A | 2011-06-08 A | 100% | 2010-03-25 | 2011-06-08 | 315d? | finish no earlier than 2011-03-23 | S3 | 2520h | 2520h | LI10 | 24 | PIDS, BT | Koen Jaspers (k.b.jaspers@minjus.nl), alex.leadbeater@bt.com | Rel-10 | 47 | Mirko |  |  |  |
| 6742 | 2227.4 | LI for VCC (Voice Call Continuity) | 260d? | 2010-03-25 A | 2011-03-23 A | 100% | 2010-03-25 | 2011-03-23 | 260d? | finish no earlier than 2011-03-23 | S3 | 2080h | 2080h | LI10 | 24 | PIDS, BT | Koen Jaspers (k.b.jaspers@minjus.nl), alex.leadbeater@bt.com | Rel-10 | 47 | Mirko |  |  |  |
| 6743 | 2227.5 | LI for MEDIASEC (IMS Media security) | 260d? | 2010-03-25 A | 2011-03-23 A | 100% | 2010-03-25 | 2011-03-23 | 260d? | finish no earlier than 2011-03-23 | S3 | 2080h | 2080h | LI10 | 24 | PIDS, BT | Koen Jaspers (k.b.jaspers@minjus.nl), alex.leadbeater@bt.com | Rel-10 | 47 | Mirko |  |  |  |
| 6744 | 2227.6 | LI for H(e)NB also with Local IP Access and Selected IP Traffic Offload (LIPA, SIPTO) | 260d? | 2010-03-25 A | 2011-03-23 A | 100% | 2010-03-25 | 2011-03-23 | 260d? | finish no earlier than 2011-03-23 | S3 | 2080h | 2080h | LI10 | 24 | PIDS, BT | Koen Jaspers (k.b.jaspers@minjus.nl), alex.leadbeater@bt.com | Rel-10 | 47 | Mirko |  |  |  |
| 6745 | 2227.7 | LI for MBMS enhancements | 260d? | 2010-03-25 A | 2011-03-23 A | 100% | 2010-03-25 | 2011-03-23 | 260d? | finish no earlier than 2011-03-23 | S3 | 2080h | 2080h | LI10 | 24 | PIDS, BT | Koen Jaspers (k.b.jaspers@minjus.nl), alex.leadbeater@bt.com | Rel-10 | 47 | Mirko |  |  |  |
| 6746 | 2227.8 | LI for LCLS (Local Call Local Switch) | 260d? | 2010-03-25 A | 2011-03-23 A | 100% | 2010-03-25 | 2011-03-23 | 260d? | finish no earlier than 2011-03-23 | S3 | 2080h | 2080h | LI10 | 24 | PIDS, BT | Koen Jaspers (k.b.jaspers@minjus.nl), alex.leadbeater@bt.com | Rel-10 | 47 | Mirko |  |  |  |
| 6747 | 2228 | Optimization of IMS based PSS and MBMS User Service | 260d? | 2010-03-25 A | 2011-03-23 A | 100% | 2010-03-25 | 2011-03-23 | 260d? | finish no earlier than 2011-03-23 | S4 | 2080h | 2080h | OPT_IMS_PSS_MBMS_US | 24 | Ericsson | markus.kampmann@ericsson.com | Rel-10 | 47 | Paolo | OPT_IMS_PSS_MBMS_US |  |  |
| 6748 | 2229 | **HTTP-based Streaming and Download Services** | 565.25d? | 2010-03-25 A | 2011-09-21 A | 100% | 2010-03-25 | 2011-09-21 | 392d? |  | S4; IETF | 10468.8h | 10468.8h | HTTP_SDS | 24 | Qualcomm | Thomas Stockhammer (c_tstock@qualcomm.com) | Rel-10 | 47 | Paolo | HTTP_SDS |  |  |
| 6749 | 2229.1 | HTTP-based Streaming and Download Services in 3GPP | 315d? | 2010-03-25 A | 2011-06-08 A | 100% | 2010-03-25 | 2011-06-08 | 315d? | finish no earlier than 2011-05-26 | S4 | 2520h | 2520h | HTTP_SDS | 24 | Qualcomm | Thomas Stockhammer (c_tstock@qualcomm.com) | Rel-10 | 47 | Paolo |  |  |  |
| 6750 | 2229.2 | (IETF) HTTP-based Streaming and Download Services in 3GPP | 211.6d? | 2010-03-25 A | 2011-09-21 A | 100% | 2010-03-25 | 2011-09-21 | 211.6d? | start no earlier than 2010-03-25 | S4-IETF | 1676.8h | 1676.8h | HTTP_SDS | 27 |  |  | Rel-10 | 52 | Paolo |  |  |  |
| 6751 | 2230 | PSS and MBMS enhancements | 205d? | 2010-06-10 A | 2011-03-23 A | 100% | 2010-06-10 | 2011-03-23 | 205d? | finish no earlier than 2011-03-23 | S4 | 1640h | 1640h | MBS_Enh | 25 | Ericsson | Markus.Kampmann@ericsson.com | Rel-10 | 48 | Paolo | MBS_Enh |  |  |
| 6752 | 2231 | Enhancements and Addition of Audio Tests to 26.131 and 26.132 | 260d? | 2010-06-10 A | 2011-06-08 A | 100% | 2010-06-10 | 2011-06-08 | 260d? | finish no earlier than 2011-06-08 | S4 | 2080h | 2080h | EAAT | 25 | Vodafone | ramin.afchar@vodafone.com | Rel-10 | 48 | Paolo | EAAT |  |  |
| 6753 | 2232 | Video Coding Enhancements in MTSI | 3d? | 2011-03-21 A | 2011-03-23 A | 100% | 2011-03-21 | 2011-03-23 | 3d? | start no earlier than 2011-03-21 | S4 | 24h | 24h | VCEM | 26 | Ericsson | frederic.gabin@ericsson.com | Rel-10 | 51 | Paolo | VCEM |  |  |
| 6754 | 2233 | **Rel-10 Operations, Administration, Maintenance and Provisioning (OAM&P)** | 674d? | 2009-12-10 A | 2011-09-21 A | 100% | 2009-12-10 | 2011-09-21 | 467d? |  | S5; C4 | 54144h | 54144h | OAM10 | 24 |  |  | Rel-10 | 46 | Mirko | OAM10 |  |  |
| 6755 | 2233.1 | **Rel-10 Network Infrastructure Management** | 674d? | 2009-12-10 A | 2011-09-21 A | 100% | 2009-12-10 | 2011-09-21 | 467d? |  | S5 | 14592h | 14592h | OAM10-NIM | 24 |  |  | Rel-10 | 46 | Mirko | OAM10-NIM |  |  |
| 6756 | 2233.1.1 | Common RAT Network Resource Model (NRM) | 390d? | 2009-12-10 A | 2011-06-08 A | 100% | 2009-12-10 | 2011-06-08 | 390d? | finish no earlier than 2011-06-08 | S5 | 3120h | 3120h | RAT_NRM_common | 24 | Ericsson | robert.petersen@ericsson.com | Rel-10 | 46 | Mirko | RAT_NRM_common |  |  |
| 6757 | 2233.1.2 | IRP Solution Set specification organisation improvements | 260d? | 2010-03-25 A | 2011-03-23 A | 100% | 2010-03-25 | 2011-03-23 | 260d? | finish no earlier than 2011-03-23 | S5 | 2080h | 2080h | OAM-IRP-SS | 24 | Nokia Siemens Networks, Huawei | Jörg Schmidt (J.Schmidt@nsn.com), Lan Zou (zlan@huawei.com) | Rel-10 | 47 | Mirko | OAM-IRP-SS |  |  |
| 6758 | 2233.1.3 | Deleted - Service Oriented Architecture (SOA) for IRP continuation from Rel-9 | 260d? | 2010-03-25 A | 2011-03-23 A | 100% | 2010-03-25 | 2011-03-23 | 260d? | finish no earlier than 2011-06-08 | S5 | 2080h | 2080h | OAM-SOA-IRP | 24 | Nokia Siemens Networks, Ericsson | Jörg Schmidt (J.Schmidt@NSN.com), edwin.tse@ericsson.com | Rel-10 | 47 | Mirko | OAM-SOA-IRP | PCG-26 | SP-51 |
| 6759 | 2233.1.4 | IRP Overview, Profiles & Usage Guide | 260d? | 2010-06-10 A | 2011-06-08 A | 100% | 2010-06-10 | 2011-06-08 | 260d? | finish no earlier than 2011-06-08 | S5 | 2080h | 2080h | OAM-NIM-IRP_OPU | 25 | Nokia Siemens Networks | Jörg Schmidt (J.Schmidt@NSN.com) | Rel-10 | 48 | Mirko | OAM-NIM-IRP_OPU |  |  |
| 6760 | 2233.1.5 | Alarm Correlation and Root Cause Analysis | 133d? | 2011-03-23 A | 2011-09-21 A | 100% | 2011-03-23 | 2011-09-21 | 133d? | finish no earlier than 2011-09-21 | S5 | 1048h | 1048h | OAM-AC-RCA | 26 | Ericsson | brendan.hassett@ericsson.com | Rel-10 | 51 | Mirko | OAM-AC-RCA |  |  |
| 6761 | 2233.1.6 | Inventory Management Network Resource Model enhancements | 56d? | 2011-03-23 A | 2011-06-08 A | 100% | 2011-03-23 | 2011-06-08 | 56d? | start no earlier than 2011-03-23 | S5 | 448h | 448h | OAM-IM-NMR | 26 | Nokia Siemens Networks | olaf.pollakowski@nsn.com | Rel-10 | 51 | Mirko | OAM-IM-NMR |  |  |

Notes:
- 6738: SP#52 completed / Impacted TSs and TRs: 33.106 (LI requirements); 33.107 (LI architecture and functions); 33.108 (Handover interface for LI)
- 6739: SP#52 completed / Impacted TSs and TRs: 33.106; 33.107; 33.108
- 6740: SP#52 completed / Impacted TSs and TRs: 33.106; 33.107; 33.108
- 6741: SP#52 completed / Impacted TSs and TRs: 33.106; 33.107; 33.108
- 6742: SP#51 completed / Impacted TSs and TRs: 33.106; 33.107; 33.108
- 6743: SP#51 completed / Impacted TSs and TRs: 33.106; 33.107; 33.108
- 6744: SP#51 completed / Impacted TSs and TRs: 33.106; 33.107; 33.108
- 6745: SP#51 completed / Impacted TSs and TRs: 33.106; 33.107; 33.108
- 6746: SP#51 completed / Impacted TSs and TRs: 33.106; 33.107; 33.108
- 6747: SP#51 completed. Work to enhance UID_430046 Rel-9 IMS_PSS_MBMS_US_EXT / Impacted TSs and TRs: 26.237
- 6748: SP#52 completed. Work to enhance UID_430038 Rel-9 PSS and MBMS extensions
- 6749: SP#52 completed / Impacted TSs and TRs: 26.234; 26.244; 26.346; new 26.247
- 6750: SP#53/IETF#81: Draft not included in 3GPP documentation. Dec.14: IETF RFC added / Impacted TSs and TRs: RFC 6381 (was draft-gellens-mime-bucket-bis)
- 6751: SP#51 completed. Linked to Rel-9 Feature UID_430038 PSS and MBMS extensions (PMA-MBS_Ext). / Impacted TSs and TRs: 26.234; 26.346
- 6752: SP#52 completed. Reduce fragmentation in acoustic testing (3GPP SA4, ETSI STQ, GCF CAG, CTIA) & Review existing acoustic tests to determine need for new spec / Impacted TSs and TRs: 26.131; 26.132
- 6753: SP#51 completed. Linked to Rel-7 UID_7040 Multimedia Telephony Service for IMS - Media handling and interaction in MTSI (MTSI-MHI) / Impacted TSs and TRs: 26.114
- 6754: OAM10 is an umbrella Feature also for OAM&P related TEI10 type of changes that are not part of any other dedicated feature/WI / Impacted TSs and TRs: 30.820
- 6755: umbrella BB
- 6756: SP#52 completed. Share equipment btw several RATs (RET,TMA,repeaters) to reduce costs. With existing modelling is difficult to see that several cells are affected when an antenna tilt is changed etc / Impacted TSs and TRs: 32.616; 32.642; 32.646; 32.652; 32.656; 32.762; 32.766 new (32.791; 32.792; 32.796)
- 6757: SP#51 completed / Impacted TSs and TRs: 32.153; new (32.111-6.32.126.32.176.32.306.32.316.32.326.32.336.32.346.32.356.32.366.32.376.32.386.32.396.32.416.32.446.32.506/26/36.32.606.32.616.32.626.32.636.32.646.32.656.32.666.32.676.32.696.32.716.32.726.32.736.32.746.32.756.32.766.32.776.32.786)
- 6758: SP#51 work stopped (Reason: lack of progress). Continuation of Rel-9 UID_440065 SOA for IRP (covering SOA Architecture & SOA-supporting Solution Set) to address SOA conforming Registration & Discovery capabilities / Impacted TSs and TRs: 32.101; 32.150
- 6759: SP#52 completed. Updated WID SP-100777=>SP-110277 / Impacted TSs and TRs: new 32.103
- 6760: SP#53 completed. Triggered by Rel-10 TR 32.832 Study on Alarm Correlation and Alarm Root Cause Analysis UID_480045 & TR 32.829 Study on Harmonization of 3GPP Alarm IRP and TMF Interface Program Fault Management UID_460038 / Impacted TSs and TRs: 32.111-1; 32.111-2; 32.111-6
- 6761: SP#52 completed. Inventory NRM specified in Rel-6 is mainly hardware related. Rel-10 TR 32.828 recommends extending the scope of inventory NRM. Additionally, NGMN Top OPE Recs, v1.0 sets inventory enhancements as one of top 10 priority items / Impacted TSs and TRs: 32.690; 32.691; 32.692; 32.696

| ID | WBS | Task | Duration | Start | Finish | Complete | Baseline start | Baseline finish | Baseline duration | Constraint | Resources | Work | Actual work | Acronym | PCG approved | Release | TSG approved | MCC resp | Special Focus Doc | Acronym_3GU_Export | WI rapporteur name |
| --- | --- | --- | --- | --- | --- | --- | --- | --- | --- | --- | --- | --- | --- | --- | --- | --- | --- | --- | --- | --- | --- |
| 6762 | 2233.2 | **Rel-10 Self-Organizing Networks (SON) - OAM aspects** | 565.5d? | 2009-12-10 A | 2011-06-08 A | 100% | 2009-12-10 | 2011-06-08 | 390d? |  | S5 | 11000h | 11000h | OAM10-SON | 24 | Rel-10 | 46 | Mirko | SON | OAM10-SON |  |
| 6763 | 2233.2.1 | SON Self-optimization management continuation | 390d? | 2009-12-10 A | 2011-06-08 A | 100% | 2009-12-10 | 2011-06-08 | 390d? | finish no earlier than 2011-03-23 | S5 | 3120h | 3120h | LTE-SON-OAM_SO | 24 | Rel-10 | 46 | Mirko | SON | LTE-SON-OAM_SO | Huawei |
| 6764 | 2233.2.2 | SON Self-healing management | 335d? | 2009-12-10 A | 2011-03-23 A | 100% | 2009-12-10 | 2011-03-23 | 335d? | finish no earlier than 2011-03-23 | S5 | 2680h | 2680h | LTE-SON-OAM_SH | 24 | Rel-10 | 46 | Mirko | SON | LTE-SON-OAM_SH | ZTE |
| 6765 | 2233.2.3 | OAM aspects of Energy Saving in Radio Networks | 260d? | 2010-03-25 A | 2011-03-23 A | 100% | 2010-03-25 | 2011-03-23 | 260d? | finish no earlier than 2011-03-23 | S5 | 2080h | 2080h | OAM-ES | 24 | Rel-10 | 47 | Mirko | SON | OAM-ES | Nokia Siemens Networks |
| 6766 | 2233.3 | Rel-10 Subscription Management (SuM) evolution | 260d? | 2010-03-25 A | 2011-03-23 A | 100% | 2010-03-25 | 2011-03-23 | 260d? | finish no earlier than 2011-03-23 | S5 | 2080h | 2080h | OAM10-SuM | 24 | Rel-10 | 47 | Mirko |  | OAM10-SuM | Ericsson |
| 6767 | 2233.4 | **Rel-10 Performance Management** | 456.75d? | 2010-03-25 A | 2011-06-08 A | 100% | 2010-03-25 | 2011-06-08 | 315d? |  | S5; C4 | 19000h | 19000h |  | 24 | Rel-10 | 47 | Mirko |  |  |  |
| 6768 | 2233.4.1 | Key Performance Indicators (KPIs) for IMS | 260d? | 2010-03-25 A | 2011-03-23 A | 100% | 2010-03-25 | 2011-03-23 | 260d? | finish no earlier than 2011-03-23 | S5 | 2080h | 2080h | OAM-PM-KPI_IMS | 24 | Rel-10 | 47 | Mirko |  | OAM-PM-KPI_IMS | China Mobile |
| 6769 | 2233.4.2 | Key Performance Indicators (KPIs) for EPC | 260d? | 2010-03-25 A | 2011-03-23 A | 100% | 2010-03-25 | 2011-03-23 | 260d? | finish no earlier than 2011-03-23 | S5 | 2080h | 2080h | OAM-PM-KPI_EPC | 24 | Rel-10 | 47 | Mirko |  | OAM-PM-KPI_EPC | China Mobile |
| 6770 | 2233.4.3 | **Management of UE based network performance measurements** | 456.75d? | 2010-03-25 A | 2011-06-08 A | 100% | 2010-03-25 | 2011-06-08 | 315d? |  | S5; C4 | 7720h | 7720h | OAM-PM-UE | 24 | Rel-10 | 47 | Mirko |  | OAM-PM-UE | Huawei, Nokia Siemens Networks, Ericsson |
| 6771 | 2233.4.3.1 | SA5 aspects of Management of UE based network performance measurements | 315d? | 2010-03-25 A | 2011-06-08 A | 100% | 2010-03-25 | 2011-06-08 | 315d? | finish no earlier than 2011-06-08 | S5 | 2520h | 2520h |  | 24 | Rel-10 | 47 | Mirko |  |  | Huawei, Nokia Siemens Networks, Ericsson |
| 6772 | 2233.4.3.2 | CN aspects of Management of UE based network performance measurements | 20d? | 2011-02-21 A | 2011-03-18 A | 100% | 2011-02-21 | 2011-03-18 | 20d? | start no earlier than 2011-02-21 | C4 | 160h | 160h |  | 26 | Rel-10 | 51 | Kimmo |  |  | Nokia Siemens Networks |
| 6773 | 2233.4.4 | 3G HNB and LTE HeNB Subsystem performance measurements | 260d? | 2010-03-25 A | 2011-03-23 A | 100% | 2010-03-25 | 2011-03-23 | 260d? | finish no earlier than 2011-03-23 | S5 | 2080h | 2080h | OAM-PM-HeNS | 24 | Rel-10 | 47 | Mirko | HNB | OAM-PM-HeNS | China Mobile |
| 6774 | 2234 | **Rel-10 Charging Management small Enhancements** | 681.5d? | 2009-06-04 A | 2011-03-23 A | 100% | 2009-06-04 | 2011-03-23 | 470d? |  | S5 | 7520h | 7520h | CH10 | 24 | Rel-10 | 47 | Mirko | WLAN | CH10 |  |
| 6775 | 2234.1 | IWLAN mobility charging | 470d? | 2009-06-04 A | 2011-03-23 A | 100% | 2009-06-04 | 2011-03-23 | 470d? | finish no earlier than 2011-03-23 | S5 | 3760h | 3760h | eIWLAN_Mob | 23 | Rel-10 | 44 | Mirko | WLAN | eIWLAN_Mob | Orange |
| 6776 | 2235 | **Advice of Charge (AoC) service support enhancements** | 451.5d? | 2010-03-25 A | 2011-06-03 A | 100% | 2010-03-25 | 2011-06-03 | 312d? |  | S5; C1 | 8560h | 8560h | eAoC | 24 | Rel-10 | 47 | Mirko |  | eAoC | Deutsche Telekom |
| 6777 | 2235.1 | SA5 part - AoC enhancements | 260d? | 2010-03-25 A | 2011-03-23 A | 100% | 2010-03-25 | 2011-03-23 | 260d? | finish no earlier than 2011-03-23 | S5 | 2080h | 2080h | eAoC | 24 | Rel-10 | 47 | Mirko |  |  | Deutsche Telekom |
| 6778 | 2235.2 | CT1 part - AoC enhancements (Stage 3) | 186d? | 2010-09-17 A | 2011-06-03 A | 100% | 2010-09-17 | 2011-06-03 | 186d? | finish no earlier than 2011-06-03 | C1 | 1488h | 1488h | eAoC | 25 | Rel-10 | 49 | Frederic |  |  | Deutsche Telekom |
| 6779 | 2236 | IMS Stage 3 IETF Protocol Alignment - phase 4 | 261d? | 2010-03-19 A | 2011-03-18 A | 100% | 2010-03-19 | 2011-03-18 | 261d? | finish no earlier than 2011-03-18 | C1 | 2088h | 2088h | IMSProtoc4 | 24 | Rel-10 | 47 | Frederic |  | IMSProtoc4 | Alcatel-Lucent |
| 6780 | 2237 | Enhanced User Data Convergence (UDC) Model | 206d? | 2010-06-04 A | 2011-03-18 A | 100% | 2010-06-04 | 2011-03-18 | 206d? | finish no earlier than 2011-03-18 | C4 | 1648h | 1648h | eUDC | 25 | Rel-10 | 48 | Kimmo |  | eUDC | China Mobile |
| 6781 | 2238 | **Further improvements of II-NNI Stage 3 based on operational feedback and evolution of other specifications** | 1036.75d? | 2010-06-04 A | 2013-03-01 A | 100% | 2010-06-04 | 2013-03-01 | 724d? |  | C3 | 10625.9h | 10625.9h | II-NNI2 | 25 | Rel-10 | 48 | Adrian |  | II-NNI2 | Orange |
| 6782 | 2238.1 | Further improvements of II-NNI Stage 3 | 206d? | 2010-06-04 A | 2011-03-18 A | 100% | 2010-06-04 | 2011-03-18 | 206d? | start no earlier than 2010-06-04 | C3 | 1648h | 1648h | II-NNI2 | 25 | Rel-10 | 48 | Adrian |  |  | Orange |
| 6783 | 2238.2 | (IETF) Further improvements of II-NNI Stage 3 (RFC 6794) | 230d? | 2012-04-20 A | 2013-03-01 A | 100% | 2012-04-20 | 2013-03-01 | 230d? | finish no earlier than 2013-03-01 | C3-IETF | 1832h | 1832h | II-NNI2 | 29 | Rel-10 | 56 | Adrian |  |  | Lionel Morand |
| 6784 | 2238.3 | (IETF) Further improvements of II-NNI Stage 3 (RFC 6809) | 170d? | 2012-04-20 A | 2012-12-07 A | 100% | 2012-04-20 | 2012-12-07 | 170d? | finish no earlier than 2012-12-04 | C3-IETF | 1353.89h | 1353.89h | II-NNI2 | 29 | Rel-10 | 56 | Adrian |  |  | christer.holmberg@ericsson.com |
| 6785 | 2239 | AT Commands for IMS-configuration | 298.25d? | 2010-06-04 A | 2011-03-18 A | 100% | 2010-06-04 | 2011-03-18 | 206d? |  | C1 | 1648h | 1648h | AT_IMS | 25 | Rel-10 | 48 | Frederic |  | AT_IMS | Ericsson |
| 6786 | 2240 | AT Commands for USIM Application Toolkit (USAT) | 189.5d? | 2010-09-17 A | 2011-03-18 A | 100% | 2010-09-17 | 2011-03-18 | 131d? |  | C1 | 52.4h | 52.4h | AT_UICC | 25 | Rel-10 | 49 | Frederic |  | AT_UICC | ST-Ericsson |
| 6787 | 2241 | Communication Control for IMS by USIM (Stage 3) | 131d? | 2010-09-17 A | 2011-03-18 A | 100% | 2010-09-17 | 2011-03-18 | 131d? | start no earlier than 2010-09-17 | C6 | 1048h | 1048h | CC_IMS_USIM | 25 | Rel-10 | 49 | Xavier |  | CC_IMS_USIM | Gemalto |
| 6788 | 2242 | Dynamic view of SIP message for Inter-IMS Network to Network Interface (II-NNI) (Stage 3) | 126d? | 2010-12-10 A | 2011-06-03 A | 100% | 2010-12-10 | 2011-06-03 | 126d? | finish no earlier than 2011-06-03 | C3 | 1008h | 1008h | NNI_DV | 26 | Rel-10 | 50 | Adrian |  | NNI_DV | NTT |
| 6789 | 2243 | Introduction of Smart Card Web Server launch functionality | 71d? | 2010-12-10 A | 2011-03-18 A | 100% | 2010-12-10 | 2011-03-18 | 71d? | finish no earlier than 2011-03-18 | C6 | 568h | 568h | SCWS_L | 26 | Rel-10 | 50 | Xavier |  | SCWS_L | Telecom Italia |
| 6790 | 2244 | USAT using AT Commands | 71d? | 2010-12-10 A | 2011-03-18 A | 100% | 2010-12-10 | 2011-03-18 | 71d? | finish no earlier than 2011-03-18 | C6 | 568h | 568h | USAT_AT | 26 | Rel-10 | 50 | Xavier |  | USAT_AT | Giesecke & Devrient |

Notes:
- 6762: umbrella BB
- 6763: SP#52 completed. Cont'd Rel-9 SON self-optimization management UID_390007 / Impacted TSs and TRs: 32.425; 32.521; 32.522; 32.526; 32.762; 32.766 / WI rapporteur e-mail: Lan Zou (zlan@huawei.com)
- 6764: SP#51 completed. WID updated SP-100776=>SP-110150. Work moved to Rel-10 after split of the Rel-9 UID_390007 SON self-optimization (removed Self-Healing handling) / Impacted TSs and TRs: 32.522; 32.526; 32.762; 32.766; new 32.541 / WI rapporteur e-mail: zhu.weihong@zte.com.cn
- 6765: SP#51 completed. WID updated SP-100226=>SP-110128. Triggered by Rel-10 TR 32.826 Study on Telecommunication Management¦Energy Savings Management (FS_OAM_ESM) UID_430044 / Impacted TSs and TRs: 32.425; 32.522; 32.526; 32.626; 32.762; 32.766; new 32.551 / WI rapporteur e-mail: clemens.suerbaum@nsn.com
- 6766: SP#51 completed / Impacted TSs and TRs: 32.172; 32.175; 32.176 / WI rapporteur e-mail: leo.yang@ericsson.com
- 6767: umbrella BB
- 6768: SP#51 completed / Impacted TSs and TRs: new 32.454 / WI rapporteur e-mail: Li Jian (lijian@chinamobile.com), Liang Shuangchun (liangshuangchun@cmdi.chinamobile.com)
- 6769: SP#51 completed / Impacted TSs and TRs: new 32.455 / WI rapporteur e-mail: Li Jian (lijian@chinamobile.com), Liang Shuangchun (liangshuangchun@cmdi.chinamobile.com)
- 6770: SP#52 completed. Stage 2/3. Linked to UID_460003 Minimization of drive tests for E-UTRAN and UTRAN (MDT_UMTSLTE) / WI rapporteur e-mail: Zou Lan (zlan@huawei.com), gyula.bodog@nsn.com, ulf.hubinette@ericsson.com
- 6771: SP#52 completed / Impacted TSs and TRs: 32.421; 32.422; 32.423; 32.441; 32.442; 32.446 / WI rapporteur e-mail: Zou Lan (zlan@huawei.com), gyula.bodog@nsn.com, ulf.hubinette@ericsson.com
- 6772: CP#51 completed under the SA5 WI code / Impacted TSs and TRs: 23.008 (CR#0330); 29.002 (CR#1007); 29.230 (CR#0207); 29.272 (CR#0329) / WI rapporteur e-mail: ulrich.wiehe@nsn.com
- 6773: SP#51 completed / Impacted TSs and TRs: 32.582; 32.592; new (32.452; 32.453) / WI rapporteur e-mail: Chen Gang (chengang@chinamobile.com)
- 6774: CH10 is an umbrella Feature also for OAM&P related TEI10 type of changes that are not part of any other dedicated feature/WI / Impacted TSs and TRs: 30.820
- 6775: SP#51 completed. RAT differentiation for charging. Completes Rel-8 Feature IWLAN_Mob UID_370049 Mobility between 3GPP-WLAN Interworking and 3GPP Systems. Cooperation with CT1,CT3 on affected protocols / Impacted TSs and TRs: 32.240; 32.252; 32.298; 32.299 / WI rapporteur e-mail: Jean-Luc Garcia (jl.garcia@orange-ftgroup.com)
- 6776: CP#52 completed. SP#51 completed SA5. Continuation of Rel-8 BB UID_80042: Advice of Charge (AoC) support in IMS Charging (IMSTSS). Stage 2/3 work / WI rapporteur e-mail: matthias.seibel@telekom.de
- 6777: SP#51 completed. SA1 Stage 1 in 22.115 / Impacted TSs and TRs: 32.275; 32.280; 32.298; 32.299 / WI rapporteur e-mail: matthias.seibel@telekom.de
- 6778: CP#52 completed. SA1 Stage 1 in 22.115, 22.173, 22.024. Add mobile-specific CAI format and volume charging elements. Extensions to existing AoC XML / Impacted TSs and TRs: 24.647 / WI rapporteur e-mail: reinhard.lauster@t-mobile.at
- 6779: CP#51 completed. Ensure protocol alignment between 3GPP Stage 3 IMS work and IETF. Review capabilities provided in SIP by IETF and document whether these capabilities are supported in the IM CN Subsystem or not / Impacted TSs and TRs: 23.218; 24.229; 24.930 / WI rapporteur e-mail: keith.drage@alcatel-lucent.com
- 6780: CP#51 completed. Specify CRUD (Create/Read/Update/Delete) operations based on SOAP protocol, which may be used by the applications having no high real-time requirement to the data access operations / Impacted TSs and TRs: 29.335 / WI rapporteur e-mail: Lan Sizhong (lansizhong@chinamobile.com)
- 6781: Improvements of Rel-9 Feature UID_440027 Operational description of the Inter-IMS Network to Network Interface (II-NNI) / WI rapporteur e-mail: beata.dobrowolska@orange-ftgroup.com
- 6782: CP#51 completed / Impacted TSs and TRs: 29.165 / WI rapporteur e-mail: beata.dobrowolska@orange-ftgroup.com
- 6783: CP#59 completed AUTH 48 RFC-to-be-6794 / Impacted TSs and TRs: RFC 6794 (was draft-ietf-sip-session-policy-framework) / WI rapporteur e-mail: Lionel Morand
- 6784: CP#58 completed / Impacted TSs and TRs: RFC 6809 (was draft-ietf-sipcore-proxy-feature) / WI rapporteur e-mail: Christer Holmberg
- 6785: CP#51 completed. Specify 1) IMS-related AT-commands to configure MT and 2) IMS-related unsolicited response codes from MT to present to end-user / Impacted TSs and TRs: 27.007 / WI rapporteur e-mail: atle.monrad@ericsson.com
- 6786: CP#51 completed / Impacted TSs and TRs: 27.007 / WI rapporteur e-mail: magnus.mk.karlsson@stericsson.com
- 6787: CP#51 completed. Stage 1 in TS 22.038 USAT service description. Linked to CT6's UID_1273 Rel-5 BB Provisioning of IP-based multimedia services (24.229, 31.103) and UID_390021 Rel-8 BB CT6 aspects of SAE (31.102, 31.111) / Impacted TSs and TRs: 31.102; 31.103; 31.111 / WI rapporteur e-mail: Denis.Lheriteau@gemalto.com
- 6788: CP#52 completed. Linked to CT3 Rel-10 Feature UID_480014 Further improvements of II-NNI Stage 3 based on operational feedback and evolution of other specifications (II-NNI2) / Impacted TSs and TRs: 29.165 / WI rapporteur e-mail: arai.kenjiro@lab.ntt.co.jp
- 6789: CP#51 completed. Define a solution which allows enabling to launch Smart Card Web Server servicES in CP-150an easy and simple manner / Impacted TSs and TRs: 31.102 / WI rapporteur e-mail: davide.pratone@telecomitalia.it
- 6790: CP#51 completed. Stage 3 based on SA1 22.038CR#37r1 (Make USAT proactive capability reqs applicable to ME as a whole without regard to any particular configuration¦e.g. a modem connected to an external display) / Impacted TSs and TRs: Stage 3 31.102; 31.111 / WI rapporteur e-mail: enric.fort@gi-de.com

| ID | WBS | Task | Type | Duration | Start | Finish | Complete | Baseline start | Baseline finish | Baseline duration | Constraint | Resources | Work | Actual work | Acronym | PCG approved | WI rapporteur name | WI rapporteur e-mail | Release | TSG approved | MCC resp | Acronym_3GU_Export | Status Report | Special Focus Doc | PCG stopped | TSG stopped |
| --- | --- | --- | --- | --- | --- | --- | --- | --- | --- | --- | --- | --- | --- | --- | --- | --- | --- | --- | --- | --- | --- | --- | --- | --- | --- | --- |
| 6791 | 2245 | **Single Radio Voice Call Continuity (SRVCC) enhancements (Stage 3)** |  | 754.12d? | 2010-12-10 A | 2012-12-07 A | 100% | 2010-12-10 | 2012-12-07 | 528d? |  | C1; C4; IETF | 17295.4h | 17295.4h | eSRVCC | 26 | China Mobile | Jiang Y (jiangyi@chinamobile.com) | Rel-10 | 50 | Frederic | eSRVCC |  |  |  |  |
| 6792 | 2245.1 | CT1 part of Stage 3 for SRVCC enhancements |  | 71d? | 2010-12-10 A | 2011-03-18 A | 100% | 2010-12-10 | 2011-03-18 | 71d? | finish no earlier than 2011-03-18 | C1 | 568h | 568h | eSRVCC | 26 | China Mobile | Jiang Y (jiangyi@chinamobile.com) | Rel-10 | 50 | Frederic |  |  |  |  |  |
| 6793 | 2245.2 | CT4 part of Stage 3 for SRVCC enhancements |  | 71d? | 2010-12-10 A | 2011-03-18 A | 100% | 2010-12-10 | 2011-03-18 | 71d? | finish no earlier than 2011-03-18 | C4 | 568h | 568h | eSRVCC | 26 | China Mobile | Jiang Y (jiangyi@chinamobile.com) | Rel-10 | 50 | Kimmo |  |  |  |  |  |
| 6794 | 2245.3 | (IETF) CT1 part of Stage 3 for SRVCC enhancements (RFC 6809) |  | 436.8d? | 2010-12-10 A | 2012-12-07 A | 100% | 2010-12-10 | 2012-12-07 | 436.8d? | finish no earlier than 2013-03-01 | C1-IETF | 3487.38h | 3487.38h | eSRVCC | 27 | christer.holmberg@ericsson.com | christer.holmberg@ericsson.com | Rel-10 | 52 | Frederic |  |  |  |  |  |
| 6795 | 2246 | **Single Radio Voice Call Continuity (SRVCC) in alerting phase (Stage 3)** |  | 841d? | 2010-12-10 A | 2013-03-01 A | 100% | 2010-12-10 | 2013-03-01 | 589d? |  | C1; R5 | 11440h | 11440h | aSRVCC | 26 | ZTE | li.shitao@zte.com.cn | Rel-10 | 50 | Frederic | aSRVCC |  |  |  |  |
| 6796 | 2246.1 | CT aspects of Single Radio Voice Call Continuity (SRVCC) in alerting phase (Stage 3) |  | 126d? | 2010-12-10 A | 2011-06-03 A | 100% | 2010-12-10 | 2011-06-03 | 126d? | finish no earlier than 2011-06-03 | C1 | 1008h | 1008h | aSRVCC | 26 | ZTE | li.shitao@zte.com.cn | Rel-10 | 50 | Frederic |  |  |  |  |  |
| 6797 | 2246.2 | Conformance test aspects SRVCC in alerting phase |  | 126d? | 2012-09-11 A | 2013-03-01 A | 100% | 2012-09-11 | 2013-03-01 | 126d? | finish no earlier than 2013-03-01 | R5 | 1008h | 1008h | aSRVCC-UEConTest | 29 | NTT DoCoMo | Takao.Shimizu.rp@nttdocomo.com | Rel-10 | 57 | Ingbert | aSRVCC-UEConTest | RP-130042 |  |  |  |
| 6798 | 2247 | **PCRF failure and restoration** |  | 102.5d? | 2010-12-10 A | 2011-03-18 A | 100% | 2010-12-10 | 2011-03-18 | 71d? |  | C4; C3 | 2130h | 2130h | PCRF_FR | 26 | NEC | Toshiyuki Tamura (tamurato@aj.jp.nec.com) | Rel-10 | 50 | Kimmo | PCRF_FR |  |  |  |  |
| 6799 | 2247.1 | CT4 part of PCRF failure and restoration |  | 71d? | 2010-12-10 A | 2011-03-18 A | 100% | 2010-12-10 | 2011-03-18 | 71d? | finish no earlier than 2011-03-18 | C4 | 568h | 568h | PCRF_FR | 26 | NEC | Toshiyuki Tamura (tamurato@aj.jp.nec.com) | Rel-10 | 50 | Kimmo |  |  |  |  |  |
| 6800 | 2247.2 | CT3 part of PCRF failure and restoration |  | 53.25d? | 2010-12-10 A | 2011-03-18 A | 100% | 2010-12-10 | 2011-03-18 | 53.25d? | start no earlier than 2010-12-10 | C3 | 426h | 426h | PCRF_FR | 26 | NEC | Toshiyuki Tamura (tamurato@aj.jp.nec.com) | Rel-10 | 50 | Adrian |  |  |  |  |  |
| 6801 | 2248 | Formalization of WLAN Files | milestone | 0d? | 2011-02-23 A | 2011-02-23 A | 100% | 2011-02-23 | 2011-03-18 | 0d? | start no earlier than 2011-03-16 | C1 |  |  | FoWF | 26 | Deutsche Telekom | dieter.jacobsohn@telekom.de | Rel-10 | 51 | Frederic | FoWF |  | WLAN |  |  |
| 6802 | 2249 | CS and IMS Interworking for CAT service - Early Session model |  | 58d? | 2011-03-16 A | 2011-06-03 A | 100% | 2011-03-16 | 2011-06-03 | 58d? |  | C3 | 464h | 464h | CIIC_ES | 26 | ZTE | li.shitao@zte.com.cn | Rel-10 | 51 | Adrian | CIIC_ES |  |  |  |  |
| 6803 | 2250 | EPC Node Restoration without Idle mode Signalling Reduction (ISR) activated |  | 3d? | 2011-03-16 A | 2011-03-18 A | 100% | 2011-03-16 | 2011-03-18 | 3d? | finish no earlier than 2011-03-18 | C4 | 24h | 24h | EPC_NR | 26 | Alcatel-Lucent | bruno.landais@alcatel-lucent.com | Rel-10 | 51 | Kimmo | EPC_NR |  |  |  |  |
| 6804 | 2251 | EPC Node Restoration with Idle mode Signalling Reduction (ISR) activated |  | 58d? | 2011-03-16 A | 2011-06-03 A | 100% | 2011-03-16 | 2011-06-03 | 58d? | finish no earlier than 2011-03-18 | C4 | 464h | 464h | EPC_NR_ISR | 26 | NEC | Toshiyuki Tamura (tamurato@aj.jp.nec.com) | Rel-10 | 51 | Kimmo | EPC_NR_ISR |  |  |  |  |
| 6805 | 2252 | Mobile Terminating Roaming Forwarding with pre-paging |  | 58d? | 2011-03-16 A | 2011-06-03 A | 100% | 2011-03-16 | 2011-06-03 | 58d? | finish no earlier than 2011-03-18 | C4 | 464h | 464h | MTRF | 26 | Ericsson | philip.hodges@ericsson.com | Rel-10 | 51 | Kimmo | MTRF |  |  |  |  |
| 6806 | 2253 | **UICC access to IMS Specification** |  | 82.75d? | 2011-03-16 A | 2011-06-03 A | 100% | 2011-03-16 | 2011-06-03 | 58d? |  | C6; C1 | 1416h | 1416h | IMS-UICC-S | 26 | Gemalto | Denis.Lheriteau@gemalto.com | Rel-10 | 51 | Xavier | IMS-UICC-S |  |  |  |  |
| 6807 | 2253.1 | CT6 part of UICC access to IMS Specification |  | 3d? | 2011-03-16 A | 2011-03-18 A | 100% | 2011-03-16 | 2011-03-18 | 3d? | start no earlier than 2011-03-16 | C6 | 24h | 24h | IMS-UICC-S | 26 | Gemalto | Denis.Lheriteau@gemalto.com | Rel-10 | 51 | Xavier |  |  |  |  |  |
| 6808 | 2253.2 | CT1 part of UICC access to IMS Specification |  | 58d? | 2011-03-16 A | 2011-06-03 A | 100% | 2011-03-16 | 2011-06-03 | 58d? | start no earlier than 2011-03-16 | C1 | 464h | 464h | IMS-UICC-S | 26 | Gemalto | Denis.Lheriteau@gemalto.com | Rel-10 | 51 | Frederic |  |  |  |  |  |
| 6809 | 2254 | Deleted - Testing for Terminal support of Rel-10 USIM, ISIM and USAT features |  | 463d? | 2012-03-05 A | 2013-12-03 A | 100% | 2012-03-05 | 2013-12-03 | 463d? | finish no earlier than 2013-06-14 | C6 | 3704h | 3704h | USIM_R10_Test | 28 | Gemalto | Denis.Praca@gemalto.com | Rel-10 | 55 | Xavier | USIM_R10_Test |  |  | PCG-32 | CP-62 |
| 6810 | 2255 | **CN aspects of Local Call Local Switch** |  | 682.38d? | 2009-05-29 A | 2011-03-18 A | 100% | 2009-05-29 | 2011-03-18 | 472d? |  | C4 | 13008h | 13008h | LCLS-CN | 23 | Vodafone | David.Hutton@vodafone.com | Rel-10 | 44 | Kimmo | LCLS-CN |  |  |  |  |
| 6811 | 2255.1 | TR on CN aspects of Local Call Local Switch |  | 341d? | 2009-05-29 A | 2010-09-16 A | 100% | 2009-05-29 | 2010-09-16 | 341d? | finish no earlier than 2010-09-17 | C4 | 2728h | 2728h | LCLS-CN | 23 | Vodafone | David.Hutton@vodafone.com | Rel-10 | 44 | Kimmo |  |  |  |  |  |
| 6812 | 2255.2 | Stage 2/3 for CN aspects of Local Call Local Switch |  | 131d? | 2010-09-17 A | 2011-03-18 A | 100% | 2010-09-17 | 2011-03-18 | 131d? | finish no earlier than 2011-03-18 | C4 | 1048h | 1048h | LCLS-CN | 25 | Vodafone | David.Hutton@vodafone.com | Rel-10 | 49 | Kimmo |  |  |  |  |  |
| 6813 | 2255.3 | Deleted - CT3 aspects of Local Call Local Switch |  | 341d? | 2009-05-29 A | 2010-09-16 A | 100% | 2009-05-29 | 2010-09-16 | 341d? | finish no earlier than 2010-09-17 | C3 | 2728h | 2728h | LCLS-CN | 23 | Vodafone | David.Hutton@vodafone.com | Rel-10 | 44 | Adrian |  |  |  | PCG-25 | CP-49 |
| 6814 | 2255.4 | Deleted - CT1 aspects of Local Call Local Switch |  | 341d? | 2009-05-29 A | 2010-09-16 A | 100% | 2009-05-29 | 2010-09-16 | 341d? | finish no earlier than 2010-09-17 | C1 | 2728h | 2728h | LCLS-CN | 23 | Vodafone | David.Hutton@vodafone.com | Rel-10 | 44 | Frederic |  |  |  | PCG-25 | CP-49 |
| 6815 | 2256 | Local Call Local Switch | milestone | 0d? | 2007-05-07 A | 2007-05-07 A | 100% | 2007-05-07 | 2011-05-20 | 1055.8d? |  | GP; G2 |  |  | LCLS | 22 | Huawei | wang_zhixi@huawei.com | Rel-10 | 41 | Paolo | LCLS |  |  |  |  |

Notes:
- 6791: Triggered by SA2 TR 23.856 Study on Single Radio Voice Call Continuity enhancements (FS_eSRVCC) UID_440049
- 6792: CP#51 completed / Impacted TSs and TRs: 24.229; 24.237
- 6793: CP#51 completed / Impacted TSs and TRs: 23.003; 23.008; 29.002; 29.230; 29.272; 29.305; 29.328; 29.329
- 6794: CP#58 completed / Impacted TSs and TRs: RFC 6809 (was draft-ietf-sipcore-proxy-feature)
- 6795: Builds on Rel-8 UID_390057 (IMS-Cont) TS 23.216 Stage 2. Provide Stage 3 for SRVCC PS-CS transfer of a call in alerting phase. Stage 2 TEI10 in TS 23.237 (6.3.2.1.4c/d, 6.3.2.1.7a/b)
- 6796: CP#52 completed / Impacted TSs and TRs: 24.008; 24.237
- 6797: RP#59 completed / Impacted TSs and TRs: 36.523-1; 36.523-2; 36.523-3; 34.229-1; 34.229-2; 34.229-3
- 6798: CP#51 completed. Triggered by CT3 TR 29.816 Study on Policy and Charging Rules Function (PCRF) failure and restoration (FS_PCRF-FR) UID_450013 / Impacted TSs and TRs: Stage 2/3 work
- 6799: CP#51 completed / Impacted TSs and TRs: Stage 2 23.007; Stage 3 29.230
- 6800: CP#51 completed / Impacted TSs and TRs: Stage 3 29.212; 29.213; 29.214; 29.215
- 6801: CP#51 completed. TS 24.235 for Info+Approval. Define the ME files as specified in 24.234 in OMA Device Management structure / Impacted TSs and TRs: Stage 3: 24.234; New 24.235
- 6802: CP#52 completed. Stage 1 in Rel-8 TS 22.182 Customized Alerting Tones (CAT) service. Stage 3 TS 24.182 defines 3 impl models: Gateway, Forking, Early Session. Specify missing CAT service interworking procedures btw CS & IMS networks / Impacted TSs and TRs: Stage 3 29.163; 29.235; 29.292
- 6803: CP#51 completed. Triggered by DRAFT TR 23.857 Study on EPC Nodes Restoration (FS_EPC_NR) UID_490014 / Impacted TSs and TRs: Stage 2/3: 23.007; 29.274
- 6804: CP#52 completed. Triggered by DRAFT TR 23.857 Study on EPC Nodes Restoration (FS_EPC_NR) UID_490014 / Impacted TSs and TRs: Stage 2/3: 23.007; 29.274
- 6805: CP#52 completed. Provides Stage 2/3 alternative solution to Mobile Terminating Roaming Retry to solve roaming events during paging, in particular to support CSFB. Hence, no new Stage 1 requirements exist / Impacted TSs and TRs: Stage 2/3: 23.012; 23.018; 23.116; 29.002
- 6806: CP#52 completed. Triggered by Rel-10 TR 31.828 Study on UICC access to IMS (FS_IMS-UICC) UID_480017. Specify mechanism in UICC and ME to make use of IMS functionality implemented in ME for case a) an ISIM is present b) no ISIM is present in UICC
- 6807: CP#51 completed / Impacted TSs and TRs: 31.102; 31.103; 31.111
- 6808: CP#52 completed / Impacted TSs and TRs: 24.229
- 6809: CP#62 stopped (at 70% completion 06/13). Testing for New featurES in CP-150Rel-10 specifications for USIM, ISIM applications and USIM Application Toolkit (USAT) in TS 31.102, 31.103, 31.111 / Impacted TSs and TRs: 31.121; 31.124; New 31.ABC (Conformance Testing of specific features)
- 6810: CP#51 completed / Impacted TSs and TRs: GERAN Stage 2/3
- 6811: CP#49 completed / Impacted TSs and TRs: new 23.889
- 6812: CP#51 completed / Impacted TSs and TRs: 23.003; 23.009; 23.205; 23.231; 29.002; 29.205; 29.232; new 23.284
- 6813: CP#49 stopped. Result of study TR 23.889: no CT3 specification impact
- 6814: CP#49 stopped. Result of study TR 23.889: no CT1 specification impact
- 6815: GP#50 completed. GP#41 WID approved / Impacted TSs and TRs: GERAN Stage 3: 48.008; 48.103

| ID | WBS | Task | Duration | Start | Finish | Complete | Baseline start | Baseline finish | Baseline duration | Constraint | Resources | Work | Actual work | Acronym | PCG approved | WI rapporteur name | Release | TSG approved | MCC resp | Acronym_3GU_Export | Status Report | Special Focus Doc |
| --- | --- | --- | --- | --- | --- | --- | --- | --- | --- | --- | --- | --- | --- | --- | --- | --- | --- | --- | --- | --- | --- | --- |
| 6816 | 2257 | **Tightened Link Level Performance Requirements for Single Antenna MS** | 942.5d? | 2010-09-03 A | 2013-03-01 A | 100% | 2010-09-03 | 2013-03-01 | 659d? |  | G1; G2; C1; G3new | 30856h | 30856h | TIGHTER | 25 | Renesas Mobile | Rel-10 | 46 | Paolo | TIGHTER |  |  |
| 6817 | 2257.1 | CT1 part for TIGHTER | 196d? | 2010-09-03 A | 2011-06-03 A | 100% | 2010-09-03 | 2011-06-03 | 196d? | finish no earlier than 2011-06-03 | C1 | 1568h | 1568h | TIGHTER | 25 | Renesas Mobile | Rel-10 | 46 | Frederic |  |  |  |
| 6818 | 2257.2 | TIGHTER Performance Requirements | 186d? | 2010-09-03 A | 2011-05-20 A | 100% | 2010-09-03 | 2011-05-20 | 186d? | finish no earlier than 2011-05-20 | G1; G2 | 2976h | 2976h | TIGHTER | 25 | Renesas Mobile | Rel-10 | 46 | Paolo |  |  |  |
| 6819 | 2257.3 | TIGHTER Testing | 654d? | 2010-09-08 A | 2013-03-01 A | 100% | 2010-09-08 | 2013-03-01 | 654d? | finish no earlier than 2013-03-01 | G3new | 5224h | 5224h | TIGHTER | 25 | Renesas Mobile | Rel-10 | 46 | Ingbert |  |  |  |
| 6820 | 2258 | **Support of Multi-Operator Core Network by GERAN** | 298.25d? | 2010-05-21 A | 2011-03-04 A | 100% | 2010-05-21 | 2011-03-04 | 206d? |  | G2; S2; C1 | 8392h | 8392h | MOCN-GERAN | 25 | Alcatel-Lucent | Rel-10 | 47 | Gert | MOCN-GERAN |  |  |
| 6821 | 2258.1 | Stage 2 for Support of Multi-Operator Core Network by GERAN | 150d? | 2010-05-21 A | 2010-12-16 A | 100% | 2010-05-21 | 2010-12-16 | 150d? | finish no earlier than 2010-12-15 | S2 | 1200h | 1200h | MOCN-GERAN | 25 | Alcatel-Lucent | Rel-10 | 47 | Maurice |  |  |  |
| 6822 | 2258.2 | CT1 part of Stage 3 for Support of Multi-Operator Core Network by GERAN | 146d? | 2010-05-21 A | 2010-12-10 A | 100% | 2010-05-21 | 2010-12-10 | 146d? | finish no earlier than 2010-12-10 | C1 | 1168h | 1168h | MOCN-GERAN | 25 | Alcatel-Lucent | Rel-10 | 47 | Frederic |  |  |  |
| 6823 | 2258.3 | GERAN2 part of Stage 3 for Support of Multi-Operator Core Network by GERAN | 135d? | 2010-08-30 A | 2011-03-04 A | 100% | 2010-08-30 | 2011-03-04 | 135d? | finish no earlier than 2011-03-04 | G2 | 1080h | 1080h | MOCN-GERAN | 25 | Alcatel-Lucent | Rel-10 | 47 | Gert |  |  |  |
| 6824 | 2259 | **Enhancements of Iur-g interface** | 283.75d? | 2010-09-03 A | 2011-06-03 A | 100% | 2010-09-03 | 2011-06-03 | 196d? |  | G2; R3 | 5752h | 5752h | eIurg | 25 | China Mobile, ZTE | Rel-10 | 47 | Gert | eIurg |  |  |
| 6825 | 2259.1 | GERAN part for Enhancements of Iur-g interface (Stage 2/3) | 131d? | 2010-09-03 A | 2011-03-04 A | 100% | 2010-09-03 | 2011-03-04 | 131d? | finish no earlier than 2011-03-04 | G2 | 1048h | 1048h | eIurg-GERAN | 25 | China Mobile, ZTE | Rel-10 | 47 | Gert | eIurg-GERAN |  |  |
| 6826 | 2259.2 | Core part: Enhancements of Iur-g interface (Stage 2/3) | 196d? | 2010-09-03 A | 2011-06-03 A | 100% | 2010-09-03 | 2011-06-03 | 196d? | finish no earlier than 2011-06-03 | R3 | 1568h | 1568h | eIurg-RAN | 25 | ZTE | Rel-10 | 49 | Juha | eIurg-RAN | RP-110526 |  |
| 6827 | 2260 | 1.28 Mcps TDD Repeater | 599d? | 2007-12-04 A | 2010-03-19 A | 100% | 2007-12-04 | 2010-03-19 | 599d? | finish no earlier than 2010-03-19 | R4 | 4792h | 4792h | RANimp-Repeaters1.28TDD | 21 | RITT | Rel-10 | 38 | Issam | RANimp-Repeaters1.28TDD | RP-100039 |  |
| 6828 | 2261 | 1.28 Mcps TDD Multi-carrier HSUPA | 321d? | 2009-09-18 A | 2010-12-10 A | 100% | 2009-09-18 | 2010-12-10 | 321d? | finish no earlier than 2010-12-10 | R1; R2; R3; R4 | 10272h | 10272h | TDD_MC_HSUPA | 23 | CATR | Rel-10 | 45 | Patrick | TDD_MC_HSUPA | RP-101079 |  |
| 6829 | 2262 | **1.28 Mcps TDD Home NodeB RF requirements** | 385.25d? | 2009-12-04 A | 2010-12-10 A | 100% | 2009-12-04 | 2010-12-10 | 266d? |  | R4 | 5304h | 5304h | HNB_LCRTDD_RF | 24 | TD Tech | Rel-10 | 46 | Issam | HNB_LCRTDD_RF |  | HNB |
| 6830 | 2262.1 | Core part: 1.28Mcps TDD Home NodeB RF requirements | 131d? | 2009-12-04 A | 2010-06-04 A | 100% | 2009-12-04 | 2010-06-04 | 131d? | finish no earlier than 2010-12-10 | R4 | 1048h | 1048h | HNB_LCRTDD_RF-Core | 24 | TD Tech | Rel-10 | 46 | Issam | HNB_LCRTDD_RF-Core | RP-100446 | HNB |
| 6831 | 2262.2 | Perf. part: 1.28Mcps TDD Home NodeB RF requirements | 266d? | 2009-12-04 A | 2010-12-10 A | 100% | 2009-12-04 | 2010-12-10 | 266d? | finish no earlier than 2010-12-10 | R4 | 2128h | 2128h | HNB_LCRTDD_RF-Perf | 24 | TD Tech | Rel-10 | 46 | Issam | HNB_LCRTDD_RF-Perf | RP-101081 | HNB |
| 6832 | 2263 | **Multi-User Multiple-Input and Multiple-Output (MU-MIMO) for 1.28Mcps TDD** | 457.75d? | 2010-03-19 A | 2011-06-03 A | 100% | 2010-03-19 | 2011-06-03 | 316d? |  | R1; R2; R3; R4 | 17224h | 17224h | MUMIMO_LCR_TDD | 24 | CATT | Rel-10 | 47 | Patrick | MUMIMO_LCR_TDD |  |  |
| 6833 | 2263.1 | Core part: MU-MIMO for 1.28Mcps TDD | 191d? | 2010-03-19 A | 2010-12-10 A | 100% | 2010-03-19 | 2010-12-10 | 191d? | finish no earlier than 2010-12-10 | R1; R2; R3 | 4584h | 4584h | MUMIMO_LCR_TDD-Core | 24 | CATT | Rel-10 | 47 | Patrick | MUMIMO_LCR_TDD-Core | RP-101085 |  |
| 6834 | 2263.2 | Perf. part: MU-MIMO for 1.28Mcps TDD | 316d? | 2010-03-19 A | 2011-06-03 A | 100% | 2010-03-19 | 2011-06-03 | 316d? | finish no earlier than 2011-06-03 | R4 | 2528h | 2528h | MUMIMO_LCR_TDD-Perf | 24 | CATT | Rel-10 | 47 | Issam | MUMIMO_LCR_TDD-Perf | RP-110520 |  |
| 6835 | 2264 | **AGNSS Minimum Performance for UTRAN** | 754.75d? | 2009-09-18 A | 2011-09-16 A | 100% | 2009-09-18 | 2011-09-16 | 523d? |  | R4; R5 | 13624h | 13624h | AGNSSPerf_UTRAN | 23 | Thales | Rel-10 | 45 | Issam | AGNSSPerf_UTRAN |  |  |
| 6836 | 2264.1 | AGNSS Minimum Performance Specification Development | 321d? | 2009-09-18 A | 2010-12-10 A | 100% | 2009-09-18 | 2010-12-10 | 321d? | finish no earlier than 2010-12-10 | R4 | 2568h | 2568h | AGNSSPerf_UTRAN | 23 | Thales | Rel-10 | 45 | Issam | AGNSSPerf_UTRAN | RP-101078 |  |
| 6837 | 2264.2 | AGNSS test case development for UMTS | 336d? | 2010-06-04 A | 2011-09-16 A | 100% | 2010-06-04 | 2011-09-16 | 336d? | finish no earlier than 2011-09-16 | R5 | 2688h | 2688h | AGNSSPerf_UTRAN | 25 | Thales | Rel-10 | 48 | Ingbert | AGNSSPerf_UTRAN | RP-110979 |  |
| 6838 | 2265 | **Inclusion of RF Pattern Matching Technologies as positioning method in the UTRAN** | 486.75d? | 2009-12-04 A | 2011-03-18 A | 100% | 2009-12-04 | 2011-03-18 | 336d? |  | R2; R3 | 10752h | 10752h | LCS_UMTS_RFPMT | 24 | Polaris Wireless | Rel-10 | 46 | Yong-Jun | LCS_UMTS_RFPMT | RP-110048 |  |
| 6839 | 2265.1 | Core part: Inclusion of RF Pattern Matching Technologies as positioning method in the UTRAN | 336d? | 2009-12-04 A | 2011-03-18 A | 100% | 2009-12-04 | 2011-03-18 | 336d? | finish no earlier than 2011-03-18 | R2; R3 | 5376h | 5376h | LCS_UMTS_RFPMT-Core | 24 | Polaris Wireless | Rel-10 | 46 | Yong-Jun | LCS_UMTS_RFPMT-Core | RP-110048 |  |

Notes:
- 6816: GP#46 approved WID / Impacted TSs and TRs: GERAN / WI rapporteur e-mail: carsten.juncker@renesasmobile.com
- 6817: CP#52 completed / Impacted TSs and TRs: 24.008 / WI rapporteur e-mail: marko.niemi@renesasmobile.com
- 6818: GP#50 completed / Impacted TSs and TRs: 45.005; 45.015 / WI rapporteur e-mail: carsten.juncker@renesasmobile.com
- 6819: GP#57 completed / Impacted TSs and TRs: 51.010 / WI rapporteur e-mail: carsten.juncker@renesasmobile.com
- 6820: GP#47 approved WID. 900 MHz spectrum re-farming to other RATs lead operators to reduce GSM capacity and therefore share their GSM networks. Hence the need for the most suitable (GE)RAN sharing method / Impacted TSs and TRs: GERAN / WI rapporteur e-mail: michel.robert@alcatel-lucent.com
- 6821: SP#50 completed / Impacted TSs and TRs: 23.251 / WI rapporteur e-mail: michel.robert@alcatel-lucent.com
- 6822: CP#50 completed / Impacted TSs and TRs: 24.008 CR#1644 / WI rapporteur e-mail: michel.robert@alcatel-lucent.com
- 6823: GP#49 completed / Impacted TSs and TRs: 48.008 CR#0325; 48.018 CR#0303 / WI rapporteur e-mail: michel.robert@alcatel-lucent.com
- 6824: GP#47 approved WID / Impacted TSs and TRs: GERAN.UTRA / WI rapporteur e-mail: Ms Juan Deng (dengjuan@chinamobile.com), Xinhui Wang (wangxinhui@zte.com.cn)
- 6825: GP#49 completed. GP#48 updated WID GP-101659=>GP-101758 (restricting the scope to GERAN BSC and TD-SCDMA RNC only). GP#47 approved WID / Impacted TSs and TRs: 43.130; 48.008 / WI rapporteur e-mail: Ms Juan Deng (dengjuan@chinamobile.com), Xinhui Wang (wangxinhui@zte.com.cn)
- 6826: RP#52 completed / Impacted TSs and TRs: UTRA Stage 2 (25.401; 25.420); Stage 3 (25.423) / WI rapporteur e-mail: Liu Junqiang (liu.junqiang@zte.com.cn)
- 6827: RP#47 completed / Impacted TSs and TRs: UTRA 25.113; New 25.116; 25.153 (testing) / WI rapporteur e-mail: qinyan@chinattl.com
- 6828: RP#50 completed / Impacted TSs and TRs: UTRA 25.102; 25.105; 25.123; 25.221; 25.222; 25.223; 25.224; 25.225; 25.306; 25.319; 25.321; 25.331; 25.423; 25.427; 25.433 / WI rapporteur e-mail: Aihui Song (songaihui@mail.ritt.com.cn)
- 6829: RP#50 completed. Triggered by FS_RAN-HNBLCRTDD UID_410016 Study on 1.28 Mcps TDD Home NodeB (TR 25.866) / Impacted TSs and TRs: UTRA / WI rapporteur e-mail: Li Rong (lirong@td-tech.com)
- 6830: RP#48 completed / Impacted TSs and TRs: 25.105 / WI rapporteur e-mail: Li Rong (lirong@td-tech.com)
- 6831: RP#50 completed. TR 25.968 v100 for Approval / Impacted TSs and TRs: 25.142; new 25.968 / WI rapporteur e-mail: Li Rong (lirong@td-tech.com)
- 6832: RP#52 completed / Impacted TSs and TRs: UTRA / WI rapporteur e-mail: Yanping Xing (xingyanping@datangmobile.cn)
- 6833: RP#50 completed / Impacted TSs and TRs: 25.221; 25.222; 25.224; 25.306; 25.308; 25.319; 25.331; 25.423; 25.425; 25.433; 25.435 / WI rapporteur e-mail: Yanping Xing (xingyanping@datangmobile.cn)
- 6834: RP#52 completed / Impacted TSs and TRs: 25.102; 25.105; 25.142 / WI rapporteur e-mail: Sanjun Feng (fengsanjun@datangmobile.cn)
- 6835: RP#53 completed. Triggered by Rel-7 UID_20050 (GNSS in UTRAN) and Rel-8 UID_400051 (Support for Additional NSS). Linked to GERAN Rel-9 UID_38002 (AGNSS Performances and Testing Procedures) / Impacted TSs and TRs: UTRA / WI rapporteur e-mail: Michel.monnerat@thalesaleniaspace.com
- 6836: RP#50 completed / Impacted TSs and TRs: new 25.172 / WI rapporteur e-mail: Michel.monnerat@thalesaleniaspace.com
- 6837: RP#53 completed / Impacted TSs and TRs: 34.108; 34.109; 34.123-1; 34.123-2; 34.123-3; 36.37.571-5; new 34.172 / WI rapporteur e-mail: Michel.monnerat@thalesaleniaspace.com
- 6838: RP#51 completed. Triggered by Study UID_380079 Evaluation of the inclusion of Path Loss Based Technology in the UTRAN (25.907) / Impacted TSs and TRs: UTRA / WI rapporteur e-mail: Norman Shaw (nshaw@polariswireless.com)
- 6839: RP#51 completed / Impacted TSs and TRs: 25.305; 25.453 / WI rapporteur e-mail: Norman Shaw (nshaw@polariswireless.com)

| ID | WBS | Task | Duration | Start | Finish | Complete | Baseline start | Baseline finish | Baseline duration | Constraint | Resources | Work | Actual work | Acronym | PCG approved | WI rapporteur name | WI rapporteur e-mail | Release | TSG approved | MCC resp | Acronym_3GU_Export | Status Report | PCG stopped | TSG stopped | Special Focus Doc |
| --- | --- | --- | --- | --- | --- | --- | --- | --- | --- | --- | --- | --- | --- | --- | --- | --- | --- | --- | --- | --- | --- | --- | --- | --- | --- |
| 6840 | 2266 | **Four carrier HSDPA** | 1420.62d? | 2009-12-04 A | 2013-09-06 A | 100% | 2009-12-04 | 2013-09-06 | 992d? |  | R1; R2; R3; R4; R5 | 57872h | 57872h | 4C_HSDPA | 24 | Qualcomm | Arjun Bharadwaj (arjunb@qualcomm.com) | Rel-10 | 46 | Patrick | 4C_HSDPA |  |  |  |  |
| 6841 | 2266.1 | Core part: Four carrier HSDPA | 336d? | 2009-12-04 A | 2011-03-18 A | 100% | 2009-12-04 | 2011-03-18 | 336d? | finish no earlier than 2011-03-18 | R1; R2; R3; R4 | 10752h | 10752h | 4C_HSDPA-Core | 24 | Qualcomm | Arjun Bharadwaj (arjunb@qualcomm.com) | Rel-10 | 46 | Patrick | 4C_HSDPA-Core | RP-110046 |  |  |  |
| 6842 | 2266.2 | Perf. part: Four carrier HSDPA | 466d? | 2009-12-04 A | 2011-09-16 A | 100% | 2009-12-04 | 2011-09-16 | 466d? | finish no earlier than 2011-09-16 | R4 | 3728h | 3728h | 4C_HSDPA-Perf | 24 | Qualcomm | Arjun Bharadwaj (arjunb@qualcomm.com) | Rel-10 | 46 | Issam | 4C_HSDPA-Perf | RP-110986 |  |  |  |
| 6843 | 2266.3 | Test part: Four carrier HSDPA | 464d? | 2011-12-02 A | 2013-09-06 A | 100% | 2011-12-02 | 2013-09-06 | 464d? | finish no earlier than 2013-09-06 | R5 | 3712h | 3712h | 4C_HSDPA-UEConTest | 28 | Qualcomm | Shubhang Vora (svora@qualcomm.com) | Rel-10 | 54 | Ingbert | 4C_HSDPA-UEConTest | RP-130940 |  |  |  |
| 6844 | 2267 | **Performance Requirements for two-antenna 1.28Mcps TDD Type 1 and Type 2 UE receiver** | 457.75d? | 2010-03-19 A | 2011-06-03 A | 100% | 2010-03-19 | 2011-06-03 | 316d? |  | R4 | 5504h | 5504h | 2ant_UE_LCR_TDD | 24 | TD Tech | dafei.wang@td-tech.com | Rel-10 | 47 | Issam | 2ant_UE_LCR_TDD |  |  |  |  |
| 6845 | 2267.1 | Core part: Performance Requirements for two-antenna 1.28Mcps TDD Type 1 and Type 2 UE receiver | 56d? | 2010-03-19 A | 2010-06-04 A | 100% | 2010-03-19 | 2010-06-04 | 56d? | finish no earlier than 2010-06-04 | R4 | 448h | 448h | 2ant_UE_LCR_TDD-Core | 24 | TD Tech | dafei.wang@td-tech.com | Rel-10 | 47 | Issam | 2ant_UE_LCR_TDD-Core | RP-100454 |  |  |  |
| 6846 | 2267.2 | Perf. part: Performance Requirements for two-antenna 1.28Mcps TDD Type 1 and Type 2 UE receiver | 316d? | 2010-03-19 A | 2011-06-03 A | 100% | 2010-03-19 | 2011-06-03 | 316d? | finish no earlier than 2011-06-03 | R4 | 2528h | 2528h | 2ant_UE_LCR_TDD-Perf | 24 | TD Tech | dafei.wang@td-tech.com | Rel-10 | 47 | Issam | 2ant_UE_LCR_TDD-Perf | RP-110521 |  |  |  |
| 6847 | 2268 | **Automatic Neighbour Relation (ANR) for UTRAN** | 949.88d? | 2010-06-04 A | 2012-12-07 A | 100% | 2010-06-04 | 2012-12-07 | 663d? |  | R3; R2; R5 | 22672h | 22672h | ANR_UTRAN | 25 | ZTE | Zhai.hengxing@zte.com.cn | Rel-10 | 48 | Juha | ANR_UTRAN |  |  |  |  |
| 6848 | 2268.1 | Core part: Automatic Neighbour Relation (ANR) for UTRAN | 261d? | 2010-06-04 A | 2011-06-03 A | 100% | 2010-06-04 | 2011-06-03 | 261d? | finish no earlier than 2011-06-03 | R3; R2 | 4176h | 4176h | ANR_UTRAN-Core | 25 | ZTE | Zhai.hengxing@zte.com.cn | Rel-10 | 48 | Juha | ANR_UTRAN-Core | RP-110522 |  |  |  |
| 6849 | 2268.2 | Test part: Automatic Neighbour Relation (ANR) for UTRAN | 323d? | 2011-09-19 A | 2012-12-07 A | 100% | 2011-09-19 | 2012-12-07 | 323d? | finish no earlier than 2012-12-07 | R5 | 2584h | 2584h | ANR_UTRAN-UEConTest | 27 | Ericsson | leif.mattisson@ericsson.com | Rel-10 | 53 | Ingbert | ANR_UTRAN-UEConTest | RP-121529 |  |  |  |
| 6850 | 2269 | **Support of New Band Combinations for Dual-Band Dual Cell HSDPA** | 378d? | 2010-06-04 A | 2011-06-03 A | 100% | 2010-06-04 | 2011-06-03 | 261d? |  | R4; R2 | 9568h | 9568h | DB_DC_HSDPA | 25 | AT&T | Vince Spatafora (vs5785@att.com) | Rel-10 | 48 | Issam | DB_DC_HSDPA |  |  |  |  |
| 6851 | 2269.1 | Core part: Support of New Band Combinations for Dual-Band Dual Cell HSDPA | 261d? | 2010-06-04 A | 2011-06-03 A | 100% | 2010-06-04 | 2011-06-03 | 261d? | finish no earlier than 2011-06-03 | R4; R2 | 4176h | 4176h | DB_DC_HSDPA-Core | 25 | AT&T | Vince Spatafora (vs5785@att.com) | Rel-10 | 48 | Issam | DB_DC_HSDPA-Core | RP-110523 |  |  |  |
| 6852 | 2269.2 | Deleted - Perf. part: Support of New Band Combinations for Dual-Band Dual Cell HSDPA | 76d? | 2010-06-04 A | 2010-09-17 A | 100% | 2010-06-04 | 2010-09-17 | 76d? | finish no earlier than 2010-09-17 | R4; R2 | 1216h | 1216h | DB_DC_HSDPA-Perf | 25 | AT&T | Vince Spatafora (vs5785@att.com) | Rel-10 | 48 | Issam | DB_DC_HSDPA-Perf | RP-100759 | PCG-25 | RP-49 |  |
| 6853 | 2270 | **MIMO operation with non-MIMO coexistence in HSDPA** | 660.38d? | 2010-06-04 A | 2012-03-02 A | 100% | 2010-06-04 | 2012-03-02 | 459d? |  | R4; R5 | 12936h | 12936h | MIMO_HSDPA | 25 | Qualcomm | Heechoon Lee | Rel-10 | 48 | Issam | MIMO_HSDPA |  |  |  |  |
| 6854 | 2270.1 | Core part: MIMO operation with non-MIMO coexistence in HSDPA | 186d? | 2010-09-17 A | 2011-06-03 A | 100% | 2010-09-17 | 2011-06-03 | 186d? | finish no earlier than 2011-06-03 | R4 | 1488h | 1488h | MIMO_HSDPA-Core | 25 | Qualcomm | Heechoon Lee | Rel-10 | 49 | Issam | MIMO_HSDPA-Core | RP-110524 |  |  |  |
| 6855 | 2270.2 | Perf. part: MIMO operation with non-MIMO coexistence in HSDPA | 261d? | 2010-06-04 A | 2011-06-03 A | 100% | 2010-06-04 | 2011-06-03 | 261d? | finish no earlier than 2011-06-03 | R4 | 2088h | 2088h | MIMO_HSDPA-Perf | 25 | Qualcomm | Heechoon Lee | Rel-10 | 48 | Issam | MIMO_HSDPA-Perf | RP-110525 |  |  |  |
| 6856 | 2270.3 | Test part: MIMO operation with non-MIMO coexistence in HSDPA | 252d? | 2011-03-18 A | 2012-03-02 A | 100% | 2011-03-18 | 2012-03-02 | 252d? | finish no earlier than 2012-03-02 | R5 | 2016h | 2016h | MIMO_HSDPA-UEConTest | 26 | Qualcomm | Shubhang Vora (svora@qualcomm.com) | Rel-10 | 51 | Ingbert | MIMO_HSDPA-UEConTest | RP-120042 |  |  |  |
| 6857 | 2271 | Interfrequency detected set measurements for UMTS | 61d? | 2010-09-17 A | 2010-12-10 A | 100% | 2010-09-17 | 2010-12-10 | 61d? | finish no earlier than 2010-12-10 | R2; R4 | 976h | 976h | Interf_dset_meas_UMTS | 25 | Nokia | Chris.callender@nokia.com | Rel-10 | 49 | Yong-Jun | Interf_dset_meas_UMTS | RP-101093 |  |  |  |
| 6858 | 2272 | **Carrier Aggregation for LTE** | 1138.38d? | 2009-12-04 A | 2012-12-07 A | 100% | 2009-12-04 | 2012-12-07 | 793d? |  | R1; R2; R3; R4; R5 | 51024h | 51024h | LTE_CA | 24 | Nokia | Asbjorn.grovlen@nokia.com | Rel-10 | 46 | Patrick | LTE_CA |  |  |  | CA |
| 6859 | 2272.1 | Core part: Carrier Aggregation for LTE | 391d? | 2009-12-04 A | 2011-06-03 A | 100% | 2009-12-04 | 2011-06-03 | 391d? | finish no earlier than 2011-06-03 | R1; R2; R3; R4 | 12512h | 12512h | LTE_CA-Core | 24 | Nokia | lars.e.lindh@nokia.com | Rel-10 | 46 | Patrick | LTE_CA-Core | RP-110535 |  |  | CA |
| 6860 | 2272.2 | Perf. part: Carrier Aggregation for LTE | 528d? | 2009-12-04 A | 2011-12-09 A | 100% | 2009-12-04 | 2011-12-09 | 528d? | finish no earlier than 2011-12-09 | R4 | 4224h | 4224h | LTE_CA-Perf | 24 | Nokia | lars.e.lindh@nokia.com | Rel-10 | 46 | Issam | LTE_CA-Perf | RP-111452 |  |  | CA |
| 6861 | 2272.3 | Test part: Carrier Aggregation for LTE | 321d? | 2011-09-19 A | 2012-12-07 A | 100% | 2011-09-19 | 2012-12-07 | 321d? | finish no earlier than 2012-12-07 | R5 | 2568h | 2568h | LTE_CA-UEConTest | 27 | Nokia | jussi.kuusisto@nokia.com | Rel-10 | 53 | Ingbert | LTE_CA-UEConTest | RP-121528 |  |  | CA |
| 6862 | 2273 | **Enhanced Downlink Multiple Antenna Transmission for LTE** | 1333.88d? | 2009-12-04 A | 2013-06-14 A | 100% | 2009-12-04 | 2013-06-14 | 930d? |  | R1; R2; R4; R5 | 44624h | 44624h | LTE_eDL_MIMO | 24 | NTT DoCoMo | Hidekazu Taoka (taoka@nttdocomo.com) | Rel-10 | 46 | Patrick | LTE_eDL_MIMO |  |  |  |  |
| 6863 | 2273.1 | Core part: Enhanced Downlink Multiple Antenna Transmission for LTE | 336d? | 2009-12-04 A | 2011-03-18 A | 100% | 2009-12-04 | 2011-03-18 | 336d? | finish no earlier than 2011-03-18 | R1; R2; R4 | 8064h | 8064h | LTE_eDL_MIMO-Core | 24 | NTT DoCoMo | Hidekazu Taoka (taoka@nttdocomo.com) | Rel-10 | 46 | Patrick | LTE_eDL_MIMO-Core | RP-110067 |  |  |  |
| 6864 | 2273.2 | Perf. part: Enhanced Downlink Multiple Antenna Transmission for LTE | 589d? | 2009-12-04 A | 2012-03-02 A | 100% | 2009-12-04 | 2012-03-02 | 589d? | finish no earlier than 2012-03-02 | R4 | 4712h | 4712h | LTE_eDL_MIMO-Perf | 24 | NTT DoCoMo | Hidekazu Taoka (taoka@nttdocomo.com) | Rel-10 | 46 | Issam | LTE_eDL_MIMO-Perf | RP-120053 |  |  |  |
| 6865 | 2273.3 | Test part: Enhanced Downlink Multiple Antenna Transmission for LTE | 261d? | 2012-06-18 A | 2013-06-14 A | 100% | 2012-06-18 | 2013-06-14 | 261d? | finish no earlier than 2013-06-14 | R5 | 2088h | 2088h | LTE_eDL_MIMO-UEConTest | 29 | ZTE | Carolyn Taylor (carolyn.tayl@zte.com.cn) | Rel-10 | 56 | Ingbert | LTE_eDL_MIMO-UEConTest | RP-130464 |  |  |  |

Notes:
- 6840: RP#53 completed / Impacted TSs and TRs: UTRA
- 6841: RP#51 completed. RP#52 TR 25.864 v200 for Approval / Impacted TSs and TRs: 25.101; 25.104; 25.133; 25.211; 25.212; 25.213; 25.214; 25.215; 25.308; 25.331; 25.423; 25.433; 26.306; new 25.864
- 6842: RP#53 completed / Impacted TSs and TRs: 25.101; 25.104; 25.133; 25.141
- 6843: RP#61 completed / Impacted TSs and TRs: 34.108; 34.121-1; 34.121-2; 34.123-1; 34.123-2; 34.123-3
- 6844: Stage 3. RP#52 completed / Impacted TSs and TRs: UTRA
- 6845: RP#48 completed / Impacted TSs and TRs: 25.102
- 6846: RP#52 completed / Impacted TSs and TRs: 25.102
- 6847: RP#52 Core completed. Automatic Neighbour Relation (ANR) function for UTRAN relieves operators from the burden of manually managing the Neighbour cell Relations (NRs) / Impacted TSs and TRs: UTRA
- 6848: RP#52 completed / Impacted TSs and TRs: 25.331; 25.413; 25.423; new 25.484 (Stage 2)
- 6849: RP#58 completed / Impacted TSs and TRs: 34.108; 34.123-1; 34.123-2; 34.123-3
- 6850: RP#52 completed. Rel-9 Dual-Band Dual-Cell HSDPA (UID_430015 Support for different bands for Dual-Cell HSDPA) has one combination per region in principle. This work adds additional combinations: Band I and XI (Region 3) and Band II and V (Region 2) / Impacted TSs and TRs: UTRA
- 6851: RP#52 completed. RP#62 existing TS 25.317 replaced by new TS 25.327 / Impacted TSs and TRs: 25.101; 25.104; 25.141; 25.317 replaced by new 25.327
- 6852: RP#49 stopped (Reason: no need for Performance work) / Impacted TSs and TRs: 25.101; 25.104; 25.141; 25.317
- 6853: RP#52 completed. RP#49 updated WID RP-100687=>RP-100993 (changed Title: MIMO Testing in HSDPA => MIMO operation with non-MIMO coexistence in HSDPA) / Impacted TSs and TRs: UTRA
- 6854: RP#52 completed / Impacted TSs and TRs: 25.104
- 6855: RP#52 completed / Impacted TSs and TRs: 25.101; 25.141
- 6856: RP#55 completed / Impacted TSs and TRs: 34.108; 34.121-1; 34.121-2; 34.123-1; 34.123-2; 34.123-3
- 6857: RP#50 completed / Impacted TSs and TRs: UTRA 25.133; 25.331
- 6858: - / Impacted TSs and TRs: LTE
- 6859: RP#52 completed. RP#56 new RAN4 TR (36.807, 36.808) v200 for Approval / Impacted TSs and TRs: 36.101; 36.104; 36.133; 36.211; 36.212; 36.213; 36.300; 36.302; 36.306; 36.321; 36.331; 36.413; 36.423; 37.104; new RAN4 (36.807; 36.808)
- 6860: RP#54 completed / Impacted TSs and TRs: 36.101; 36.104; 36.133; 36.141; 37.141
- 6861: RP#58 completed / Impacted TSs and TRs: 36.508; 36.521-1; 36.521-2; 36.521-3; 36.523-1; 36.523-2; 36.523-3; 37.571-1; 37.571-3; 37.571-5
- 6862: - / Impacted TSs and TRs: LTE
- 6863: RP#51 completed. RP#56 new RAN4 TR 36.807 v200 for Approval / Impacted TSs and TRs: 36.101; 36.104; 36.133; 36.201; 36.211; 36.212; 36.213; 36.300; 36.306; 36.321; 36.331; new RAN4 36.807
- 6864: RP#55 completed / Impacted TSs and TRs: 36.101; 36.104; 36.133; 36.141
- 6865: RP#60 completed. Testing for 36.101, 36.133 / Impacted TSs and TRs: 36.508; 36.521-1; 36.521-2

| ID | WBS | Task | Duration | Start | Finish | Complete | Baseline start | Baseline finish | Baseline duration | Constraint | Resources | Work | Actual work | Acronym | PCG approved | WI rapporteur name | WI rapporteur e-mail | Release | TSG approved | MCC resp | Acronym_3GU_Export | Status Report | PCG stopped | TSG stopped |
| --- | --- | --- | --- | --- | --- | --- | --- | --- | --- | --- | --- | --- | --- | --- | --- | --- | --- | --- | --- | --- | --- | --- | --- | --- |
| 6866 | 2274 | **Uplink Multiple Antenna Transmission for LTE** | 4977.25d? | 2000-01-03 A | 2013-03-01 A | 100% | 2000-01-03 | 2013-03-01 | 3445d? |  | R1; R2; R4; R5 | 125976h | 125976h | LTE_UL_MIMO | 24 | Huawei | Mattias.wennstrom@huawei.com | Rel-10 | 46 | Patrick | LTE_UL_MIMO |  |  |  |
| 6867 | 2274.1 | Core part: UL multiple antenna transmission for LTE | 391d? | 2000-01-03 A | 2001-06-29 A | 100% | 2000-01-03 | 2001-06-29 | 391d? |  | R1; R2; R4 | 9384h | 9384h | LTE_UL_MIMO-Core | 24 | Huawei | Mattias.wennstrom@huawei.com | Rel-10 | 46 | Patrick | LTE_UL_MIMO-Core | RP-110537 |  |  |
| 6868 | 2274.2 | Perf. part: UL multiple antenna transmission for LTE | 466d? | 2009-12-04 A | 2011-09-16 A | 100% | 2009-12-04 | 2011-09-16 | 466d? | finish no earlier than 2011-09-16 | R4 | 3728h | 3728h | LTE_UL_MIMO-Perf | 24 | Huawei | Mattias.wennstrom@huawei.com | Rel-10 | 46 | Issam | LTE_UL_MIMO-Perf | RP-110992 |  |  |
| 6869 | 2274.3 | Test part: UL multiple antenna transmission for LTE | 328d? | 2011-12-02 A | 2013-03-01 A | 100% | 2011-12-02 | 2013-03-01 | 328d? | finish no earlier than 2013-03-01 | R5 | 2624h | 2624h | LTE_UL_MIMO-UEConTest | 28 | Huawei | Zhang Xin (suzanna.zhang@huawei.com) | Rel-10 | 54 | Ingbert | LTE_UL_MIMO-UEConTest | RP-130038 |  |  |
| 6870 | 2275 | **Relays for LTE** | 571.75d? | 2009-12-04 A | 2011-06-08 A | 100% | 2009-12-04 | 2011-06-08 | 394d? |  | R1; R2; R4; S2; S3; C4; C6 | 36856h | 36856h | LTE_Relay | 24 | Ericsson | christian.hoymann@ericsson.com | Rel-10 | 46 | Patrick | LTE_Relay |  |  |  |
| 6871 | 2275.1 | Core part: Relays for LTE | 391d? | 2009-12-04 A | 2011-06-03 A | 100% | 2009-12-04 | 2011-06-03 | 391d? | finish no earlier than 2011-06-03 | R1; R2; R4 | 9384h | 9384h | LTE_Relay-Core | 24 | Ericsson | christian.hoymann@ericsson.com | Rel-10 | 46 | Patrick | LTE_Relay-Core | RP-110540 |  |  |
| 6872 | 2275.2 | Deleted - Perf. part: Relays for LTE | 391d? | 2009-12-04 A | 2011-06-03 A | 100% | 2009-12-04 | 2011-06-03 | 391d? | finish no earlier than 2011-09-16 | R4 | 3128h | 3128h | LTE_Relay-Perf | 24 | Ericsson | christian.hoymann@ericsson.com | Rel-10 | 46 | Issam | LTE_Relay-Perf | RP-110541 | PCG-27 | RP-52 |
| 6873 | 2275.3 | Stage 2 for Relays for LTE | 3d? | 2011-06-06 A | 2011-06-08 A | 100% | 2011-06-06 | 2011-06-08 | 3d? | start no earlier than 2011-06-06 | S2 | 24h | 24h | LTE_Relay | 27 | Vodafone | chris.pudney@vodafone.com | Rel-10 | 52 | Maurice | LTE_Relay |  |  |  |
| 6874 | 2275.4 | **LTE Relay Nodes Security** | 100.5d? | 2010-12-16 A | 2011-03-22 A | 100% | 2010-12-16 | 2011-03-22 | 69d? |  | S3; C6 | 2232h | 2232h | LTE_Relay-Sec | 26 | Qualcomm | Adrian Escott (aescott@qualcomm.com) | Rel-10 | 50 | Mirko | LTE_Relay-Sec |  |  |  |
| 6875 | 2275.4.1 | TR on LTE Relay Nodes Security | 69d? | 2010-12-16 A | 2011-03-22 A | 100% | 2010-12-16 | 2011-03-22 | 69d? | finish no earlier than 2011-03-23 | S3 | 552h | 552h | LTE_Relay-Sec | 26 | Qualcomm | Adrian Escott (aescott@qualcomm.com) | Rel-10 | 50 | Mirko |  |  |  |  |
| 6876 | 2275.4.2 | Security for LTE Relay Nodes (Stage 2) | 69d? | 2010-12-16 A | 2011-03-22 A | 100% | 2010-12-16 | 2011-03-22 | 69d? | finish no earlier than 2011-03-23 | S3 | 552h | 552h | LTE_Relay-Sec | 26 | Qualcomm | Adrian Escott (aescott@qualcomm.com) | Rel-10 | 50 | Mirko |  |  |  |  |
| 6877 | 2275.4.3 | CT6 aspects of LTE Relay Node Security | 3d? | 2011-03-16 A | 2011-03-18 A | 100% | 2011-03-16 | 2011-03-18 | 3d? | start no earlier than 2011-03-16 | C6 | 24h | 24h | LTE_Relay-Sec | 26 | n/a | n/a | Rel-10 | 51 | Xavier |  |  |  |  |
| 6878 | 2275.5 | Core Network Impacts for Relay Nodes | 3d? | 2011-03-16 A | 2011-03-18 A | 100% | 2011-03-16 | 2011-03-18 | 3d? | finish no earlier than 2011-03-18 | C4 | 24h | 24h | LTE_Relay-CN | 26 | Vodafone | David.Hutton@vodafone.com | Rel-10 | 51 | Kimmo | LTE_Relay-CN |  |  |  |
| 6879 | 2276 | **Enhanced Inter-Cell Interference Control (ICIC) for non-Carrier Aggregation (CA) based deployments of heterogeneous networks for LTE** | 1601.62d? | 2010-03-19 A | 2014-06-13 A | 100% | 2010-03-19 | 2014-06-13 | 1119d? |  | R1; R2; R3; R4; R5 | 64384h | 64384h | eICIC_LTE | 24 | China Mobile | Xiaodong XU (xuxiaodong@chinamobile.com) | Rel-10 | 47 | Patrick | eICIC_LTE |  |  |  |
| 6880 | 2276.1 | Core part: Enhanced Inter-Cell Interference Control (ICIC) for non-Carrier Aggregation (CA) based deployments of heterogeneous networks for LTE | 316d? | 2010-03-19 A | 2011-06-03 A | 100% | 2010-03-19 | 2011-06-03 | 316d? | finish no earlier than 2011-06-03 | R1; R2; R3; R4 | 10112h | 10112h | eICIC_LTE-Core | 24 | China Mobile | Xiaodong XU (xuxiaodong@chinamobile.com) | Rel-10 | 47 | Patrick | eICIC_LTE-Core | RP-110543 |  |  |
| 6881 | 2276.2 | Perf. part: Enhanced Inter-Cell Interference Control (ICIC) for non-Carrier Aggregation (CA) based deployments of heterogeneous networks for LTE | 589d? | 2010-03-19 A | 2012-06-15 A | 100% | 2010-03-19 | 2012-06-15 | 589d? | finish no earlier than 2012-06-15 | R4 | 4712h | 4712h | eICIC_LTE-Perf | 24 | China Mobile | Xiaodong XU (xuxiaodong@chinamobile.com) | Rel-10 | 47 | Issam | eICIC_LTE-Perf | RP-120461 |  |  |
| 6882 | 2276.3 | Test part: Enhanced Inter-Cell Interference Control (ICIC) for non-Carrier Aggregation (CA) based deployments of heterogeneous networks for LTE | 600d? | 2012-03-05 A | 2014-06-13 A | 100% | 2012-03-05 | 2014-06-13 | 600d? | finish no earlier than 2014-06-13 | R5 | 4800h | 4800h | eICIC_LTE-UEConTest | 28 | Qualcomm | Anjali Mishra (ajha@qualcomm.com) | Rel-10 | 55 | Ingbert | eICIC_LTE-UEConTest | RP-140766 |  |  |
| 6883 | 2277 | **LTE TDD in 2600MHz for US** | 276.5d? | 2010-03-19 A | 2010-12-10 A | 100% | 2010-03-19 | 2010-12-10 | 191d? |  | R4; R2; R3; R5 | 11344h | 11344h | LTE_TDD_2600_US | 24 | Clearwire | michael.hart@clearwire.com | Rel-10 | 47 | Issam | LTE_TDD_2600_US |  |  |  |
| 6884 | 2277.1 | Core part: LTE TDD in 2600MHz for US | 129d? | 2010-03-19 A | 2010-09-15 A | 100% | 2010-03-19 | 2010-09-17 | 131d? | finish no earlier than 2010-09-17 | R4; R2; R3 | 3096h | 3096h | LTE_TDD_2600_US-Core | 24 | Clearwire | michael.hart@clearwire.com | Rel-10 | 47 | Issam | LTE_TDD_2600_US-Core | RP-100782 |  |  |
| 6885 | 2277.2 | Perf. part: LTE TDD in 2600MHz for US | 131d? | 2010-03-19 A | 2010-09-17 A | 100% | 2010-03-19 | 2010-09-17 | 131d? | finish no earlier than 2010-09-17 | R4 | 1048h | 1048h | LTE_TDD_2600_US-Perf | 24 | Clearwire | michael.hart@clearwire.com | Rel-10 | 47 | Issam | LTE_TDD_2600_US-Perf | RP-100783 |  |  |
| 6886 | 2277.3 | UE conformance test part: LTE TDD in 2600MHz for US | 136d? | 2010-06-04 A | 2010-12-10 A | 100% | 2010-06-04 | 2010-12-10 | 136d? | finish no earlier than 2010-12-10 | R5 | 1088h | 1088h | LTE_TDD_2600_US-UEConTest | 25 | Clearwire | michael.hart@clearwire.com | Rel-10 | 48 | Ingbert | LTE_TDD_2600_US-UEConTest | RP-101071 |  |  |
| 6887 | 2278 | **Adding 2 GHz band LTE FDD (Band 23) for Ancillary Terrestrial Component (ATC) of Mobile Satellite Service (MSS) in North America** | 653.12d? | 2010-03-19 A | 2011-12-09 A | 100% | 2010-03-19 | 2011-12-09 | 454d? |  | R2; R4; R5 | 19568h | 19568h | S_Band_LTE_ATC_MSS | 24 | DBSD | Mariam.Sorond@ico.com | Rel-10 | 47 | Yong-Jun | S_Band_LTE_ATC_MSS |  |  |  |
| 6888 | 2278.1 | Core part: Adding 2 GHz band LTE FDD (Band 23) for ATC of MSS in North America | 316d? | 2010-03-19 A | 2011-06-03 A | 100% | 2010-03-19 | 2011-06-03 | 316d? | finish no earlier than 2011-06-03 | R4; R2 | 5056h | 5056h | S_Band_LTE_ATC_MSS-Core | 24 | DBSD | Mariam.Sorond@ico.com | Rel-10 | 47 | Issam | S_Band_LTE_ATC_MSS-Core | RP-110545 |  |  |
| 6889 | 2278.2 | Perf. part: Adding 2 GHz band LTE FDD (Band 23) for ATC of MSS in North America | 316d? | 2010-03-19 A | 2011-06-03 A | 100% | 2010-03-19 | 2011-06-03 | 316d? | finish no earlier than 2011-06-03 | R4 | 2528h | 2528h | S_Band_LTE_ATC_MSS-Perf | 24 | DBSD | Mariam.Sorond@ico.com | Rel-10 | 47 | Issam | S_Band_LTE_ATC_MSS-Perf | RP-110546 |  |  |
| 6890 | 2278.3 | Test part: Adding 2 GHz band LTE FDD (Band 23) for ATC of MSS in North America | 137d? | 2011-06-07 A | 2011-12-09 A | 100% | 2011-06-07 | 2011-12-09 | 137d? | finish no earlier than 2011-12-09 | R5 | 1088h | 1088h | S_Band_LTE_ATC_MSS-UEConTest | 27 | DBSD | Mariam.Sorond@ico.com | Rel-10 | 52 | Ingbert | S_Band_LTE_ATC_MSS-UEConTest | RP-111444 |  |  |

Notes:
- 6866: - / Impacted TSs and TRs: LTE
- 6867: RP#52 completed. TR 36.817 v110 for Approval. RP#56 new TR 36.807 v200 for Approval / Impacted TSs and TRs: 36.101; 36.104; 36.133; 36.201; 36.211; 36.212; 36.213; 36.300; 36.306; 36.321; 36.331; new RAN4 (36.807; 36.817)
- 6868: RP#53 completed / Impacted TSs and TRs: 36.101; 36.104; 36.133; 36.141; 36.817
- 6869: RP#59 completed / Impacted TSs and TRs: 36.508; 36.521-1; 36.521-2; 36.521-3; 36.523-1; 36.523-2; 36.523-3
- 6870: RP#52 completed (open RAN4 Core & Perf parts moved to new Rel-11) / Impacted TSs and TRs: LTE
- 6871: RP#52 completed. Updated WID RP-101417=>RP-101911 (contains only Core part completed in Rel-10). Open RAN4 Core & Perf parts moved to new Rel-11 / Impacted TSs and TRs: 36.201; 36.211; 36.212; 36.213; 36.300; 36.321; 36.323; 36.331; New RAN1 36.216
- 6872: RP#52 stopped at 30% (no CRs so far) . Transferred completely to Rel-11 together with remaining core part / Impacted TSs and TRs: 36.133; New 36.117 (E-UTRA Relay conformance testing)
- 6873: SP#52 SP-110338 (S2-85/S2-112851) 23.401 Cat F CR#2128 Completion of Relay procedure overview / Impacted TSs and TRs: 23.401
- 6874: -
- 6875: SP#51 completed / Impacted TSs and TRs: 33.816
- 6876: SP#51 completed (impacting Stage 3 in CT and RAN) / Impacted TSs and TRs: 33.401 (CR#0437.0438); CT1 24.301; CT4 (29.272; 29.274); CT6 31.102; RAN2 (36.331; 36.323); RAN3 36.413
- 6877: CP#51 completed / Impacted TSs and TRs: 31.101; 31.102
- 6878: CP#51 completed / Impacted TSs and TRs: 23.003; 23.008; 29.303; 29.230; 29.272
- 6879: RP#56 completed / Impacted TSs and TRs: LTE
- 6880: RP#52 completed / Impacted TSs and TRs: 36.101; 36.133; 36.201; 36.211; 36.212; 36.213; 36.214; 36.300; 36.321; 36.331; 36.413; 36.423
- 6881: RP#56 completed / Impacted TSs and TRs: 36.101; 36.133
- 6882: RP#64 completed / Impacted TSs and TRs: 36.508; 36.521-1; 36.521-2; 36.521-3; 36.523-1; 36.523-2; 36.523-3
- 6883: RP#50 Testing completed. RP#49 Core+Perf completed / Impacted TSs and TRs: LTE
- 6884: RP#49 completed 1st Apr 15: CD:Fri 17/09/10->Wed 15/09/10 / Impacted TSs and TRs: 25.461; 25.466; 36.101; 36.104; 36.113; 36.124; 36.133; 36.141; 36.307; 36.331; 37.104; 37.113; 37.141; new 36.812
- 6885: RP#49 completed / Impacted TSs and TRs: 36.101; 36.104; 36.133; 36.141; 36.307; 37.104; 37.141; new 36.812
- 6886: RP#50 completed / Impacted TSs and TRs: 36.508; 36.521-1; 36.521-2; 36.521-3; 36.523-1; 36.523-2; 36.523-3
- 6887: RP#52 completed. Updated WID RP-101401=>RP-110775 (changed in Title "LTE" to "LTE FDD (Band 23)" / Impacted TSs and TRs: LTE
- 6888: RP#52 completed / Impacted TSs and TRs: 25.101; 25.104; 25.141; 25.461; 25.466; 36.101; 36.104; 36.113; 36.124; 36.133; 36.307; 37.104; 37.141; new 36.811
- 6889: RP#52 completed / Impacted TSs and TRs: 36.101; 36.104; 36.113; 36.124; 36.133; 36.141; 36.307; 36.811
- 6890: RP#54 completed / Impacted TSs and TRs: 36.508; 36.521-1; 36.521-2; 36.521-3; 36.523-1; 36.523-2; 36.523-3

| ID | WBS | Task | Duration | Start | Finish | Complete | Baseline start | Baseline finish | Baseline duration | Constraint | Resources | Work | Actual work | Acronym | PCG approved | WI rapporteur name | WI rapporteur e-mail | Release | TSG approved | MCC resp | Acronym_3GU_Export | Status Report | Special Focus Doc |
| --- | --- | --- | --- | --- | --- | --- | --- | --- | --- | --- | --- | --- | --- | --- | --- | --- | --- | --- | --- | --- | --- | --- | --- |
| 6891 | 2279 | **Adding L-Band (Band 24) LTE for Ancillary Terrestrial Component (ATC) of Mobile Satellite Service (MSS) in North America** | 667.75d? | 2009-12-11 A | 2011-09-16 A | 100% | 2009-12-11 | 2011-09-16 | 463d? |  | R4; R2; R5 | 18864h | 18864h | L_Band_LTE_ATC_MSS | 24 | LightSquared | Eric.Jacks@lightsquared.com, Maqbool.Aliani@lightsquared.com | Rel-10 | 47 | Issam | L_Band_LTE_ATC_MSS |  |  |
| 6892 | 2279.1 | Core part: Adding L-Band (Band 24) LTE for ATC of MSS in North America | 261d? | 2009-12-11 A | 2010-12-10 A | 100% | 2009-12-11 | 2010-12-10 | 261d? | finish no earlier than 2010-12-10 | R4; R2 | 4176h | 4176h | L_Band_LTE_ATC_MSS-Core | 24 | LightSquared | Eric.Jacks@lightsquared.com, Maqbool.Aliani@lightsquared.com | Rel-10 | 47 | Issam | L_Band_LTE_ATC_MSS-Core | RP-101117 |  |
| 6893 | 2279.2 | Perf. part: Adding L-Band (Band 24) LTE for ATC of MSS in North America | 316d? | 2010-03-19 A | 2011-06-03 A | 100% | 2010-03-19 | 2011-06-03 | 316d? | finish no earlier than 2011-06-03 | R4 | 2528h | 2528h | L_Band_LTE_ATC_MSS-Perf | 24 | LightSquared | Eric.Jacks@lightsquared.com, Maqbool.Aliani@lightsquared.com | Rel-10 | 47 | Issam | L_Band_LTE_ATC_MSS-Perf | RP-110548 |  |
| 6894 | 2279.3 | Test part: Adding L-Band (Band 24) LTE for ATC of MSS in North America | 131d? | 2011-03-18 A | 2011-09-16 A | 100% | 2011-03-18 | 2011-09-16 | 131d? | finish no earlier than 2011-09-16 | R5 | 1048h | 1048h | L_Band_LTE_ATC_MSS-UEConTest | 26 | LightSquared | masoud.olfat@lightsquared.com | Rel-10 | 51 | Ingbert | L_Band_LTE_ATC_MSS-UEConTest | RP-110980 |  |
| 6895 | 2280 | **LTE Self Optimizing Networks (SON) enhancements** | 457.75d? | 2010-03-19 A | 2011-06-03 A | 100% | 2010-03-19 | 2011-06-03 | 316d? |  | R3; R2; R4 | 15168h | 15168h | SONenh_LTE | 24 | Nokia Siemens Networks | krzysztof.kordybach@nsn.com | Rel-10 | 47 | Juha | SONenh_LTE |  | SON |
| 6896 | 2280.1 | Core part: LTE Self Optimizing Networks (SON) enhancements | 316d? | 2010-03-19 A | 2011-06-03 A | 100% | 2010-03-19 | 2011-06-03 | 316d? | finish no earlier than 2011-06-03 | R3; R2; R4 | 7584h | 7584h | SONenh_LTE-Core | 24 | Nokia Siemens Networks | krzysztof.kordybach@nsn.com | Rel-10 | 47 | Juha | SONenh_LTE-Core | RP-110547 | SON |
| 6897 | 2281 | **Further enhancements to MBMS for LTE** | 660.38d? | 2010-06-04 A | 2012-03-02 A | 100% | 2010-06-04 | 2012-03-02 | 459d? |  | R2; R3; R5 | 14840h | 14840h | MBMS_LTE_enh | 25 | Huawei | Ms Zhao Junhui (zhaojh@huawei.com) | Rel-10 | 48 | Yong-Jun | MBMS_LTE_enh |  |  |
| 6898 | 2281.1 | Core part: Further enhancements to MBMS for LTE | 206d? | 2010-06-04 A | 2011-03-18 A | 100% | 2010-06-04 | 2011-03-18 | 206d? | finish no earlier than 2011-03-18 | R2; R3 | 3296h | 3296h | MBMS_LTE_enh-Core | 25 | Huawei | Ms Zhao Junhui (zhaojh@huawei.com) | Rel-10 | 48 | Yong-Jun | MBMS_LTE_enh-Core | RP-110083 |  |
| 6899 | 2281.2 | Test part: Further enhancements to MBMS for LTE | 66d? | 2011-12-02 A | 2012-03-02 A | 100% | 2011-12-02 | 2012-03-02 | 66d? | finish no earlier than 2012-03-02 | R5 | 528h | 528h | MBMS_LTE_enh-UEConTest | 28 | Huawei | Zhang Xin (suzanna.zhang@huawei.com) | Rel-10 | 54 | Ingbert | MBMS_LTE_enh-UEConTest | RP-120049 |  |
| 6900 | 2282 | **UMTS/LTE 3500 MHz** | 2095d? | 2007-11-30 A | 2013-06-14 A | 100% | 2007-11-30 | 2013-06-14 | 1456d? |  | R4; R2; R3; R5 | 87360h | 87360h | RInImp8-UMTSLTE3500 | 21 | Ericsson | johan.skold@ericsson.com | Rel-10 | 38 | Issam | RInImp8-UMTSLTE3500 |  |  |
| 6901 | 2282.1 | Core part: UMTS/LTE 3500 MHz | 994d? | 2007-11-30 A | 2011-09-16 A | 100% | 2007-11-30 | 2011-09-16 | 994d? | finish no earlier than 2011-09-16 | R4; R2; R3 | 23856h | 23856h | RInImp8-UMTSLTE3500 | 21 | Ericsson | johan.skold@ericsson.com | Rel-10 | 38 | Issam | RInImp8-UMTSLTE3500 | RP-110987 |  |
| 6902 | 2282.2 | Conformance Test Aspects – LTE 3500 | 1189d? | 2008-12-05 A | 2013-06-14 A | 100% | 2008-12-05 | 2013-06-14 | 1189d? | finish no earlier than 2013-06-14 | R5 | 9512h | 9512h | LTE-UEConTest_LTE3500 | 22 | Ericsson | fredrik.sundstrom@ericsson.com | Rel-10 | 42 | Ingbert | LTE-UEConTest_LTE3500 | RP-130461 |  |
| 6903 | 2282.3 | Conformance Test Aspects – UMTS 3500 | 925d? | 2008-12-05 A | 2012-06-15 A | 100% | 2008-12-05 | 2012-06-15 | 925d? | finish no earlier than 2012-06-15 | R5 | 7400h | 7400h | RInImp-UEConTest_UMTS3500 | 22 | Ericsson | fredrik.sundstrom@ericsson.com | Rel-10 | 42 | Ingbert | RInImp-UEConTest_UMTS3500 | RP-120450 |  |
| 6904 | 2283 | **Minimization of Drive Tests for E-UTRAN and UTRAN** | 1225.25d? | 2009-12-04 A | 2013-03-01 A | 100% | 2009-12-04 | 2013-03-01 | 854d? |  | R2; R4; R3; R5 | 39784h | 39784h | MDT_UMTSLTE | 24 | Nokia Siemens Networks | malgorzata.tomala@nsn.com | Rel-10 | 46 | Yong-Jun | MDT_UMTSLTE |  |  |
| 6905 | 2283.1 | Core part: Minimization of Drive Tests for E-UTRAN and UTRAN | 391d? | 2009-12-04 A | 2011-06-03 A | 100% | 2009-12-04 | 2011-06-03 | 391d? | finish no earlier than 2011-06-03 | R2; R4; R3 | 9384h | 9384h | MDT_UMTSLTE-Core | 24 | Nokia Siemens Networks | malgorzata.tomala@nsn.com | Rel-10 | 46 | Yong-Jun | MDT_UMTSLTE-Core | RP-110528 |  |
| 6906 | 2283.2 | Test part: Minimization of Drive Tests for E-UTRAN | 384d? | 2011-09-19 A | 2013-03-01 A | 100% | 2011-09-19 | 2013-03-01 | 384d? | finish no earlier than 2013-03-01 | R5 | 3072h | 3072h | MDT_UMTSLTE-UEConTest | 27 | Ericsson | leif.mattisson@ericsson.com | Rel-10 | 53 | Ingbert | MDT_UMTSLTE-UEConTest | RP-130036 |  |
| 6907 | 2284 | **HNB and HeNB Mobility Enhancements** | 1029.62d? | 2010-03-19 A | 2012-12-07 A | 100% | 2010-03-19 | 2012-12-07 | 718d? |  | R3; R2; R5 | 23016h | 23016h | HNB_HENB_mob_enh | 24 | Alcatel-Lucent | Martin,Warner@alcatel-lucent.com | Rel-10 | 47 | Juha | HNB_HENB_mob_enh |  | HNB |
| 6908 | 2284.1 | Core part: HNB and HeNB Mobility Enhancements | 261d? | 2010-03-19 A | 2011-03-18 A | 100% | 2010-03-19 | 2011-03-18 | 261d? | start no earlier than 2010-03-19 | R3; R2 | 4176h | 4176h | HNB_HENB_mob_enh-Core | 24 | Alcatel-Lucent | Martin.Warner@alcatel-lucent.com | Rel-10 | 47 | Juha | HNB_HENB_mob_enh-Core | RP-110058 | HNB |
| 6909 | 2284.2 | Test part: HeNB Mobility Enhancements | 201d? | 2012-03-05 A | 2012-12-07 A | 100% | 2012-03-05 | 2012-12-07 | 201d? | finish no earlier than 2012-12-07 | R5 | 1608h | 1608h | HNB_HENB_mob_enh-UEConTest_LTE | 28 | Qualcomm | Anjali Mishra (ajha@qualcom.com) | Rel-10 | 55 | Ingbert | HNB_HENB_mob_enh-UEConTest_LTE | RP-121533 | HNB |
| 6910 | 2285 | **Expanded 1900 MHz Band for UTRA and LTE** | 855.88d? | 2010-06-04 A | 2012-09-07 A | 100% | 2010-06-04 | 2012-09-07 | 596d? |  | R4; R2; R5 | 25312h | 25312h | E1900 | 25 | Sprint | nick.j.baustert@sprint.com | Rel-10 | 48 | Issam | E1900 |  |  |
| 6911 | 2285.1 | Core part: Expanded 1900 MHz Band for UTRA and LTE | 261d? | 2010-06-04 A | 2011-06-03 A | 100% | 2010-06-04 | 2011-06-03 | 261d? | finish no earlier than 2011-06-03 | R4; R2 | 4176h | 4176h | E1900-Core | 25 | Sprint | nick.j.baustert@sprint.com | Rel-10 | 48 | Issam | E1900-Core | RP-110529 |  |
| 6912 | 2285.2 | Perf. part: Expanded 1900 MHz Band for UTRA and LTE | 261d? | 2010-06-04 A | 2011-06-03 A | 100% | 2010-06-04 | 2011-06-03 | 261d? | finish no earlier than 2011-06-03 | R4; R2 | 4176h | 4176h | E1900-Perf | 25 | Sprint | nick.j.baustert@sprint.com | Rel-10 | 48 | Issam | E1900-Perf | RP-110530 |  |
| 6913 | 2285.3 | Test part: Expanded 1900 MHz Band for UTRA and LTE | 333d? | 2011-06-07 A | 2012-09-07 A | 100% | 2011-06-07 | 2012-09-07 | 333d? | finish no earlier than 2012-09-07 | R5 | 2656h | 2656h | E1900-UEConTest | 27 | Sprint | nick.j.baustert@sprint.com | Rel-10 | 52 | Ingbert | E1900-UEConTest | RP-120957 |  |
| 6914 | 2286 | **Multi-Standard Radio Base Station RF requirements for non-contiguous spectrum deployments** | 558.88d? | 2010-06-04 A | 2011-11-25 A | 100% | 2010-06-04 | 2011-11-25 | 389d? |  | R4; G1 | 16160h | 16160h | MSR_NC | 25 | Ericsson | johan.skold@ericsson.com | Rel-10 | 48 | Issam | MSR_NC |  |  |
| 6915 | 2286.1 | Core part: Multi-Standard Radio BS RF requirements for non-contiguous spectrum deployments | 261d? | 2010-06-04 A | 2011-06-03 A | 100% | 2010-06-04 | 2011-06-03 | 261d? | finish no earlier than 2011-06-03 | R4 | 2088h | 2088h | MSR_NC-Core | 25 | Ericsson | johan.skold@ericsson.com | Rel-10 | 48 | Issam | MSR_NC-Core | RP-110531 |  |
| 6916 | 2286.2 | Perf. part: Multi-Standard Radio BS RF requirements for non-contiguous spectrum deployments | 336d? | 2010-06-04 A | 2011-09-16 A | 100% | 2010-06-04 | 2011-09-16 | 336d? | finish no earlier than 2011-09-16 | R4 | 2688h | 2688h | MSR_NC-Perf | 25 | Ericsson | johan.skold@ericsson.com | Rel-10 | 48 | Issam | MSR_NC-Perf | RP-110988 |  |

Notes:
- 6891: RP#53 completed / Impacted TSs and TRs: LTE
- 6892: RP#51 completed / Impacted TSs and TRs: 25.101; 25.104; 25.141; 25.461; 25.466; 34.124; 36.101; 36.104; 36.113; 36.124; 36.133; 36.307; 37.104; 37.141; new RAN4 36.813
- 6893: RP#52 completed / Impacted TSs and TRs: 34.121-1; 36.101; 36.104; 36.113; 36.124; 36.133; 36.141; 36.307; 36.521-1; 36.813
- 6894: RP#53 completed / Impacted TSs and TRs: 36.508; 36.521-1; 36.521-2; 36.521-3; 36.523-2
- 6895: RP#52 completed / Impacted TSs and TRs: LTE
- 6896: RP#52 completed (Stage 1,2,3) / Impacted TSs and TRs: 36.300; 36.331; 36.413; 36.423
- 6897: RP#51 completed. SA2 decided not to support MBR>GBR in Rel-10 MBMS. For SA2, MBR=GBR in Rel-10 MBMS. Hence RAN removed enabling statistical multiplexing gains for variable bit rate services in Objectives / Impacted TSs and TRs: LTE
- 6898: RP#51 completed / Impacted TSs and TRs: 25.446; 36.300; 36.321; 36.322; 36.323; 36.331; 36.440; 36.441; 36.442; 36.443; 36.444; 36.445
- 6899: RP#55 completed / Impacted TSs and TRs: 36.508; 36.523-1; 36.523-2; 36.523-3
- 6900: - / Impacted TSs and TRs: UTRA; LTE
- 6901: RP#53 completed. TR 37.801v200 for Approval / Impacted TSs and TRs: 25.101; 25.104; 25.113; 25.133; 25.141; 25.307; 25.307; 25.331; 25.461; 25.463; 34.124; 36.101; 36.104; 36.113; 36.141; 36.331; new 37.801
- 6902: RP#60 completed / Impacted TSs and TRs: 36.508; 36.521-1; 36.521-2; 36.521-3
- 6903: RP#56 completed / Impacted TSs and TRs: 34.108; 34.121-1; 34.121-2
- 6904: Triggered by UID_430021 TR 36.805 (Study on Minimization of drive-tests in NGN) / Impacted TSs and TRs: UTRA; LTE
- 6905: RP#52 completed / Impacted TSs and TRs: 25.133; 25.215; 25.304; 25.331; 25.423; 36.133; 36.214; 36.300; 36.304; 36.331; 36.413; 36.423; new 37.320 (Stage 2)
- 6906: RP#59 completed. Testing for LTE only / Impacted TSs and TRs: LTE 34.108; 34.109; 34.123-1; 34.123-2; 34.123-3; 36.508; 36.509; 36.523-1; 36.523-2; 36.523-3
- 6907: - / Impacted TSs and TRs: UTRA; LTE
- 6908: RP#51 completed / Impacted TSs and TRs: 25.413; 25.467; 25.469; 36.300; 36.413; 36.423; new 25.471
- 6909: RP#58 completed / Impacted TSs and TRs: 34.108; 34.123-1; 34.123-2; 34.123-3; 36.508; 36.523-1; 36.523-2; 36.523-3
- 6910: Expand UTRA and E-UTRA band 2 to include frequencies between 1910 1915 MHz and 1990-1995 MHz (US FCC allocation) / Impacted TSs and TRs: UTRA; LTE
- 6911: RP#52 completed / Impacted TSs and TRs: 25.101; 25.104; 25.113; 25.133; 25.141; 25.461; 25.466; 36.101; 36.104; 36.113; 36.124; 36.133; 36.141; 36.307; 36.331; new 36.818
- 6912: RP#52 completed / Impacted TSs and TRs: 25.101; 25.104; 25.113; 25.133; 25.141; 25.461; 25.466; 36.101; 36.104; 36.113; 36.124; 36.133; 36.141; 36.307; 36.331; new 36.818
- 6913: RP#57 completed / Impacted TSs and TRs: 34.108; 34.121-1; 34.121-2; 34.123-1; 34.123-2; 34.123-3; 36.508; 36.521-1; 36.521-2; 36.521-3; 36.523-1; 36.523-2; 36.523-3
- 6914: - / Impacted TSs and TRs: UTRA; LTE; GERAN
- 6915: RP#52 completed / Impacted TSs and TRs: 25.104; 36.104; 37.104; new 37.802
- 6916: RP#53 completed / Impacted TSs and TRs: 25.141; 36.141; 37.141; 37.802

| ID | WBS | Task | Type | Duration | Start | Finish | Complete | Baseline start | Baseline finish | Baseline duration | Constraint | Resources | Work | Actual work | Acronym | PCG approved | WI rapporteur name | WI rapporteur e-mail | Release | TSG approved | MCC resp | Acronym_3GU_Export | Impacted TSs and TRs | PCG stopped | TSG stopped | Status Report | Special Focus Doc |
| --- | --- | --- | --- | --- | --- | --- | --- | --- | --- | --- | --- | --- | --- | --- | --- | --- | --- | --- | --- | --- | --- | --- | --- | --- | --- | --- | --- |
| 6917 | 2286.3 | **GERAN part: Multi-Standard Radio BS RF requirements for non-contiguous spectrum deployments** |  | 464.62d? | 2010-09-03 A | 2011-11-25 A | 100% | 2010-09-03 | 2011-11-25 | 324d? |  | G1 | 5160h | 5160h | MSR_NC-GERAN | 25 | Ericsson | mats.y.samuelsson@ericsson.com | Rel-10 | 47 | Paolo | MSR_NC-GERAN |  |  |  |  |  |
| 6918 | 2286.3.1 | GERAN Core part: Multi-Standard Radio BS RF requirements for non-contiguous spectrum deployments |  | 261d? | 2010-09-03 A | 2011-09-02 A | 100% | 2010-09-03 | 2011-09-02 | 261d? | finish no earlier than 2011-09-02 | G1 | 2088h | 2088h | MSR_NC-GERAN | 25 | Ericsson | mats.y.samuelsson@ericsson.com | Rel-10 | 47 | Paolo |  | 45.005 |  |  |  |  |
| 6919 | 2286.3.2 | GERAN BS Test part: Multi-Standard Radio BS RF requirements for non-contiguous spectrum deployments |  | 62d? | 2011-09-02 A | 2011-11-25 A | 100% | 2011-09-02 | 2011-11-25 | 62d? | finish no earlier than 2011-11-25 | G1 | 496h | 496h | MSR_NC-GERAN | 28 | Ericsson | mats.y.samuelsson@ericsson.com | Rel-10 | 52 | Paolo |  | 51.021 |  |  |  |  |
| 6920 | 2287 | (Small) Technical Enhancements and Improvements for Rel-10 |  | 470d? | 2009-06-04 A | 2011-03-23 A | 100% | 2009-06-04 | 2011-03-23 | 470d? | finish no earlier than 2011-03-23 | SP; CP; RP; GP | 15040h | 15040h | TEI10 | 23 |  |  | Rel-10 | 44 |  | TEI10 |  |  |  |  |  |
| 6921 | 2288 | (IETF) (Small) Technical Enhancements and Improvements for Rel-10 (draft-atarius-dispatch-meid-urn) --> RFC8464 |  | 1244d? | 2009-06-04 A | 2014-12-04 A | 100% | 2009-06-04 | 2014-12-05 | 1242d? | finish no earlier than 2014-12-09 | C1-IETF | 9952h | 9952h | TEI10_IETF | 27 | Andrew Allen | Andrew Allen | Rel-10 | 52 | Frederic | TEI10_IETF | draft-atarius-dispatch-meid-urn |  |  |  |  |
| 6922 | 2289 | (IETF) (Small) Technical Enhancements and Improvements for Rel-10 (RFC6275) |  | 562d? | 2009-06-04 A | 2011-07-29 A | 100% | 2009-06-04 | 2011-07-29 | 562d? | finish no earlier than 2011-07-29 | C1-IETF | 4496h | 4496h | TEI10_IETF1 | 27 |  |  | Rel-10 | 53 | Frederic | TEI10_IETF1 | RFC 6275 (was draft-ietf-mext-rfc3775bis) |  |  |  |  |
| 6923 | 2290 | Test - (Small) Technical Enhancements and Improvements for Rel-10 |  | 271d? | 2011-12-01 A | 2012-12-07 A | 100% | 2011-12-01 | 2012-12-07 | 271d? | finish no earlier than 2012-12-07 | R5; G3new | 4336h | 4336h | TEI10_Test | 28 | n/a |  | Rel-10 | 54 | Ingbert | TEI10_Test |  |  |  |  |  |
| 6924 | 2291 | **Deleted - Registration in Densely-populated area (RED)** |  | 960.88d? | 2007-03-12 A | 2009-09-24 A | 100% | 2007-03-12 | 2009-09-24 | 665d? |  | S1 | 9544h | 9544h | RED | 18 | NTT DoCoMo | tanakai@nttdocomo.co.jp | Rel-10 | 35 | Alain | RED |  | PCG-24 | SP-46 |  |  |
| 6925 | 2291.1 | Deleted - Stage 1 for RED |  | 4d? | 2007-03-12 A | 2007-03-15 A | 100% | 2007-03-12 | 2007-03-15 | 4d? | start no earlier than 2007-03-12 | S1 | 32h | 32h | RED | 19 | NTT DoCoMo | takakurat@s1.nttdocomo.co.jp | Rel-10 | 37 | Alain |  | 22.101 CR#0207 | PCG-24 | SP-46 |  |  |
| 6926 | 2291.2 | Deleted - Stage 2 for RED |  | 524d? | 2007-09-25 A | 2009-09-24 A | 100% | 2007-09-25 | 2009-09-24 | 524d? | finish no earlier than 2009-09-24 | S2 | 4192h | 4192h | RED | 19 | NTT DoCoMo | tanakai@nttdocomo.co.jp | Rel-10 | 37 | Maurice |  | draft 23.880 withdrawn; 23.002; 23.060; 23.221; 23.236 | PCG-23 | SP-45 |  |  |
| 6927 | 2292 | **Deleted - Network Selection for non-3GPP Access** |  | 681.38d? | 2007-12-07 A | 2009-09-24 A | 100% | 2007-12-07 | 2009-09-24 | 471d? |  | S1; C6 | 15072h | 15072h | N3GtoNSP | 21 | Telefónica O2 | chris.friel@O2.com | Rel-10 | 38 | Alain | N3GtoNSP |  | PCG-23 | SP-45 |  |  |
| 6928 | 2292.1 | Deleted - Stage 1 for N3GtoNSP |  | 471d? | 2007-12-07 A | 2009-09-24 A | 100% | 2007-12-07 | 2009-09-24 | 471d? | finish no earlier than 2009-12-10 | S1 | 3768h | 3768h | N3GtoNSP | 21 | Telefónica O2 | chris.friel@O2.com | Rel-10 | 38 | Alain |  | 22.011 | PCG-23 | SP-45 |  |  |
| 6929 | 2292.2 | Deleted - CT6 issues for N3GtoNSP |  | 471d? | 2007-12-07 A | 2009-09-24 A | 100% | 2007-12-07 | 2009-09-24 | 471d? | finish no earlier than 2009-12-04 | C6 | 3768h | 3768h | N3GtoNSP | 21 | Telefónica O2 | chris.friel@O2.com | Rel-10 | 38 | Xavier |  | 36.300 | PCG-23 | CP-45 |  |  |
| 6930 | 2293 | **Deleted - GTP-based S8 chaining** |  | 486.62d? | 2008-12-11 A | 2010-03-25 A | 100% | 2008-12-11 | 2010-03-25 | 337d? |  | S2 | 5392h | 5392h | GTPchaining | 22 | Huawei | Haining Wang (wanghaining@huawei.com) | Rel-10 | 42 | Maurice | GTPchaining |  | PCG-24 | SP-47 |  |  |
| 6931 | 2293.1 | Deleted - Stage 2 for GTPchaining |  | 337d? | 2008-12-11 A | 2010-03-25 A | 100% | 2008-12-11 | 2010-03-25 | 337d? | finish no earlier than 2010-03-25 | S2 | 2696h | 2696h | GTPchaining | 22 | Huawei | Haining Wang (wanghaining@huawei.com) | Rel-10 | 42 | Maurice |  | 23.402 | PCG-24 | SP-47 |  |  |
| 6932 | 2294 | Deleted - UTRAN 2 ms TTI uplink range improvement |  | 272d? | 2009-03-06 A | 2010-03-19 A | 100% | 2009-03-06 | 2010-03-19 | 272d? | finish no earlier than 2010-03-19 | R1; R2; R3; R4 | 8704h | 8704h | RANimp-2mTTI_ULimp | 22 | Nokia Siemens Networks | Karri Ranta-aho (karri.ranta-aho@nsn.com) | Rel-10 | 43 | Patrick | RANimp-2mTTI_ULimp | 25.133; 25.212; 25.214; 25.321; 25.331 | PCG-24 | RP-47 | RP-100040 |  |
| 6933 | 2295 | Deleted - Enhanced Home NodeB / eNodeB continuation of Rel-9 |  | 486.62d? | 2008-12-11 A | 2010-03-25 A | 100% | 2008-12-11 | 2010-03-25 | 337d? |  | S2 | 2696h | 2696h | eEHNB | 23 | Alcatel-Lucent | Nicolas Drevon | Rel-10 | 44 | Maurice | eEHNB |  | PCG-24 | SP-47 |  | HNB |
| 6934 | 2296 | **Deleted - Fixed Wireless Customer-Premises Equipment (CPE) RF Requirements** |  | 566.5d? | 2009-12-04 A | 2011-06-03 A | 100% | 2009-12-04 | 2011-06-03 | 391d? |  | R4; R5 | 12512h | 12512h | FW_CPE_RF | 24 | Verizon Wireless | zheng.zhao@verizonwireless.com | Rel-10 | 46 | Issam | FW_CPE_RF | LTE | PCG-27 | RP-52 |  |  |
| 6935 | 2296.1 | Deleted - Core part: Fixed Wireless Customer-Premises Equipment (CPE) RF Requirements |  | 391d? | 2009-12-04 A | 2011-06-03 A | 100% | 2009-12-04 | 2011-06-03 | 391d? | finish no earlier than 2011-06-03 | R4 | 3128h | 3128h | FW_CPE_RF-Core | 24 | Verizon Wireless | zheng.zhao@verizonwireless.com | Rel-10 | 46 | Issam | FW_CPE_RF-Core | 36.101 | PCG-27 | RP-52 | RP-110539 |  |
| 6936 | 2296.2 | Deleted - Test part: Fixed Wireless Customer-Premises Equipment (CPE) RF Requirements |  | 391d? | 2009-12-04 A | 2011-06-03 A | 100% | 2009-12-04 | 2011-06-03 | 391d? | finish no earlier than 2011-06-03 | R5 | 3128h | 3128h | FW_CPE_RF-UEConTest | 24 | Verizon Wireless | zheng.zhao@verizonwireless.com | Rel-10 | 46 | Ingbert | FW_CPE_RF-UEConTest | 36.521-1 | PCG-27 | RP-52 | RP-110504 |  |
| 6937 | 2297 | **Deleted - Latency reductions for LTE** |  | 385.25d? | 2009-12-04 A | 2010-12-10 A | 100% | 2009-12-04 | 2010-12-10 | 266d? |  | R2; R1 | 8512h | 8512h | LTE_LATRED | 24 | Ericsson | henrik.enbuske@ericsson.com | Rel-10 | 46 | Yong-Jun | LTE_LATRED | LTE | PCG-26 | RP-50 |  |  |
| 6938 | 2297.1 | Deleted - Core part: Latency reductions for LTE |  | 266d? | 2009-12-04 A | 2010-12-10 A | 100% | 2009-12-04 | 2010-12-10 | 266d? | finish no earlier than 2010-12-10 | R2; R1 | 4256h | 4256h | LTE_LATRED-Core | 24 | Ericsson | henrik.enbuske@ericsson.com | Rel-10 | 46 | Yong-Jun | LTE_LATRED-Core | 36.213; 36.300; 36.306; 36.321; 36.331 | PCG-26 | RP-50 | RP-101112 |  |
| 6939 | 2298 | **Deleted - Enhanced Interference Management for Home NodeBs** |  | 189.5d? | 2010-03-19 A | 2010-09-17 A | 100% | 2010-03-19 | 2010-09-17 | 131d? |  | R3 | 2096h | 2096h | HNB_IM | 24 | Qualcomm | Andrei Radulescu (aradules@qualcomm.com) | Rel-10 | 47 | Juha | HNB_IM | UTRA | PCG-25 | RP-49 | RP-100754 | HNB |
| 6940 | 2298.1 | Deleted - Core part: Enhanced Interference Management for Home NodeBs |  | 131d? | 2010-03-19 A | 2010-09-17 A | 100% | 2010-03-19 | 2010-09-17 | 131d? | finish no earlier than 2010-09-17 | R3 | 1048h | 1048h | HNB_IM-Core | 24 | Qualcomm | Andrei Radulescu (aradules@qualcomm.com) | Rel-10 | 47 | Juha | HNB_IM-Core | 25.413; 25.467; 25.469 | PCG-25 | RP-49 | RP-100754 | HNB |
| 6941 | 2299 | Release 10 Studies | milestone | 0d? | 2009-03-12 A | 2009-03-12 A | 100% | 2009-03-12 | 2011-03-23 | 531d? | finish no earlier than 2011-03-23 | CP; GP; RP; SP |  |  |  |  |  |  | Rel-10 |  |  |  |  |  |  |  |  |

Notes:
- 6917: -
- 6918: GP#51 completed. GP#47 approved WID
- 6919: GP#52 completed
- 6920: -
- 6921: Not completed internet-draft, waiting for draft-montemurro to complete; 26/6/19: 75%->100; 23/4/20: 100%->100
- 6922: SP#53/IETF#81: RFC 6275 completed
- 6923: -
- 6924: SP#35 Stage 1 completed. SP#45 Stage 2 work stopped. SP#46 work stopped/abandoned
- 6925: SP#35 completed. SP#46 work stopped/abandoned
- 6926: SP#45 Stage 2 work stopped
- 6927: SP#45 work stopped/abandoned
- 6928: SP#45 work stopped/abandoned
- 6929: SP#45 work stopped/abandoned
- 6930: SP#47 work stopped (depending on ongoing related CT4 work). Stage 1 in UID_320022 Rel-8 Requirements for evolution of the 3GPP system architecture (AIPN-SAE): 22.278, 22.011, 22.246
- 6931: SP#47 work stopped
- 6932: RP#47 work stopped/abandoned (no CR approved). Cell sets the TTI (Transmission Time Interval) to 2 ms
- 6933: SP#47 deleted (SA2 work moved under SA1 UID_450053). SP#44 Umbrella Feature created to host WIs moved out of Rel-9 (SA2 UID_420034 on IMS aspects of Architecture for Home NodeB)
- 6934: RP#52 work stopped (lack of contributions). Add new power classES in CP-150E-UTRAN UL to allow CPE type applications to be operated at higher max output power
- 6935: RP#52 work stopped at 55% (lack of contributions)
- 6936: RP#52 work stopped (lack of contributions)
- 6937: RP#50 work stopped (RP-101266)
- 6938: RP#50 work stopped (RP-101266)
- 6939: RP#49 stopped (no further standardization needed). Ensure that Enhanced Interference Management methods identified in Rel-9 for HNBs do not fail in deployments with a large penetration of CSG-aware UEs
- 6940: RP#49 stopped (no further standardization needed)
- 6941: -

| ID | WBS | Task | Type | Duration | Start | Finish | Complete | Baseline start | Baseline finish | Baseline duration | Constraint | Resources | Work | Actual work | Acronym | PCG approved | Impacted TSs and TRs | WI rapporteur name | Release | TSG approved | MCC resp | Acronym_3GU_Export | Status Report | PCG stopped | TSG stopped |
| --- | --- | --- | --- | --- | --- | --- | --- | --- | --- | --- | --- | --- | --- | --- | --- | --- | --- | --- | --- | --- | --- | --- | --- | --- | --- |
| 6942 | 2300 | **Study on enhanced voice service requirements for the Evolved Packet System (EPS)** |  | 968.12d? | 2007-09-03 A | 2010-03-25 A | 100% | 2007-09-03 | 2010-03-25 | 670d? |  | S1; S4 | 18744h | 18744h | FS_EV_EPS | 19 | 22.813 | France Telecom | Rel-10 | 37 | Alain | FS_EV_EPS |  |  |  |
| 6943 | 2300.1 | Use cases definition and service and system requirements |  | 334d? | 2007-09-03 A | 2008-12-11 A | 100% | 2007-09-03 | 2008-12-11 | 334d? | finish no earlier than 2008-12-11 | S1 | 2672h | 2672h | FS_EV_EPS-S1 | 19 | 22.813 | France Telecom | Rel-10 | 37 | Alain | FS_EV_EPS-S1 |  |  |  |
| 6944 | 2300.2 | Codec specific part of FS_EV_EPS |  | 669d? | 2007-09-03 A | 2010-03-25 A | 100% | 2007-09-03 | 2010-03-25 | 669d? | finish no earlier than 2010-03-25 | S4 | 5352h | 5352h | FS_EV_EPS-S4 | 19 | 22.813 | Ericsson | Rel-10 | 37 | Paolo | FS_EV_EPS-S4 |  |  |  |
| 6945 | 2301 | Study on advanced requirements for IP interconnect |  | 528d? | 2007-12-04 A | 2009-12-10 A | 100% | 2007-12-04 | 2009-12-10 | 528d? | finish no earlier than 2009-12-10 | S1 | 4224h | 4224h | FS_IPXS | 21 | 22.893 | Telefónica O2 | Rel-10 | 38 | Alain | FS_IPXS |  |  |  |
| 6946 | 2302 | Study on Personal Broadcast Service |  | 397d? | 2008-09-18 A | 2010-03-25 A | 100% | 2008-09-18 | 2010-03-25 | 397d? | finish no earlier than 2010-03-25 | S1 | 3168h | 3168h | FS_PBS | 21 | 22.947 | ETRI | Rel-10 | 41 | Alain | FS_PBS |  |  |  |
| 6947 | 2303 | Study on LCS support in SAE for non-3GPP accesses |  | 397d? | 2008-09-18 A | 2010-03-25 A | 100% | 2008-09-18 | 2010-03-25 | 397d? | finish no earlier than 2010-03-25 | S1 | 3168h | 3168h | FS_LCS_n3GPP | 21 | 22.814 | SK Telecom | Rel-10 | 41 | Alain | FS_LCS_n3GPP |  |  |  |
| 6948 | 2304 | Study on Haptic Services |  | 272d? | 2009-03-12 A | 2010-03-25 A | 100% | 2009-03-12 | 2010-03-25 | 272d? | finish no earlier than 2010-03-25 | S1 | 2168h | 2168h | FS_Haptics | 22 | 22.987 | SK Telecom | Rel-10 | 43 | Alain | FS_Haptics |  |  |  |
| 6949 | 2305 | Study on System enhancements for the use of IMS services in Local BreakOut and Optimal Routing of Media |  | 575d? | 2007-10-01 A | 2009-12-10 A | 100% | 2007-10-01 | 2009-12-10 | 575d? | finish no earlier than 2009-12-10 | S2 | 4600h | 4600h | FS_IMS_LBO_ORM | 19 | 23.894 | Telecom Italia, BT | Rel-10 | 37 | Maurice | FS_IMS_LBO_ORM |  |  |  |
| 6950 | 2306 | Study on Intra Domain Connection of RAN Nodes to Multiple CN Nodes |  | 533d? | 2008-03-12 A | 2010-03-25 A | 100% | 2008-03-12 | 2010-03-25 | 533d? | finish no earlier than 2010-03-25 | S2 | 4264h | 4264h | FS_IDC | 21 | 23.924 (was 23.823) | China Mobile | Rel-10 | 39 | Maurice | FS_IDC |  |  |  |
| 6951 | 2307 | Study on Single Radio Voice Call Continuity enhancements |  | 341d? | 2009-06-04 A | 2010-09-23 A | 100% | 2009-06-04 | 2010-09-23 | 341d? | finish no earlier than 2010-09-23 | S2 | 2728h | 2728h | FS_eSRVCC | 23 | 23.856 | China Mobile | Rel-10 | 44 | Maurice | FS_eSRVCC |  |  |  |
| 6952 | 2308 | Study on Single Radio Video Call Continuity for 3G-CS |  | 131d? | 2010-03-25 A | 2010-09-23 A | 100% | 2010-03-25 | 2010-09-23 | 131d? | finish no earlier than 2010-09-23 | S2 | 1048h | 1048h | FS_vSRVCC | 24 | 23.886 | Samsung | Rel-10 | 47 | Maurice | FS_vSRVCC |  |  |  |
| 6953 | 2309 | Study on S2b Mobility based on GTP |  | 56d? | 2010-03-25 A | 2010-06-10 A | 100% | 2010-03-25 | 2010-06-10 | 56d? | finish no earlier than 2010-06-07 | S2 | 448h | 448h | FS_SMOG | 24 | 23.834 | Alcatel-Lucent | Rel-10 | 47 | Maurice | FS_SMOG |  |  |  |
| 6954 | 2310 | Study on Surround Sound codec extension for PSS and MBMS |  | 530d? | 2009-03-12 A | 2011-03-23 A | 100% | 2009-03-12 | 2011-03-23 | 530d? | finish no earlier than 2011-03-23 | S4 | 4240h | 4240h | FS_SS_PSS_MBMS | 22 | 26.950 | Fraunhofer Gesellschaft | Rel-10 | 43 | Paolo | FS_SS_PSS_MBMS |  |  |  |
| 6955 | 2311 | Study on Improved Video Coding Support |  | 205d? | 2010-06-10 A | 2011-03-23 A | 100% | 2010-06-10 | 2011-03-23 | 205d? | finish no earlier than 2011-03-23 | S4 | 1640h | 1640h | FS_IVCS | 25 | 26.904 | Nokia, ETRI | Rel-10 | 48 | Paolo | FS_IVCS |  |  |  |
| 6956 | 2312 | Study on Rc Reference Point Functionalities and Message Flows |  | 397d? | 2008-09-18 A | 2010-03-25 A | 100% | 2008-09-18 | 2010-03-25 | 397d? | finish no earlier than 2010-03-23 | S5 | 3170.08h | 3170.08h | FS_OAM_Rc | 21 | 32.825 | Huawei | Rel-10 | 41 | Mirko | FS_OAM_Rc |  |  |  |
| 6957 | 2313 | Study on Telecommunication Management; Energy Savings Management |  | 271d? | 2009-03-12 A | 2010-03-25 A | 100% | 2009-03-12 | 2010-03-25 | 271d? | finish no earlier than 2010-03-25 | S5 | 2168h | 2168h | FS_OAM_ESM | 22 | 32.826 | Orange, Vodafone | Rel-10 | 43 | Mirko | FS_OAM_ESM |  |  |  |
| 6958 | 2314 | Study on Integration of Device Management Information with Itf-N |  | 211d? | 2009-06-04 A | 2010-03-25 A | 100% | 2009-06-04 | 2010-03-25 | 211d? | finish no earlier than 2010-03-25 | S5 | 1688h | 1688h | FS_IDMI_Itf-N | 23 | 32.827 | Motorola | Rel-10 | 44 | Mirko | FS_IDMI_Itf-N |  |  |  |
| 6959 | 2315 | Study on Alignment of 3GPP Generic NRM IRP and TMF Shared Information Data (SID) model |  | 335d? | 2009-12-10 A | 2011-03-23 A | 100% | 2009-12-10 | 2011-03-23 | 335d? | finish no earlier than 2011-03-23 | S5 | 2680h | 2680h | FS_3GNRM_TMFSID | 24 | 32.828 | Nokia Siemens Networks | Rel-10 | 46 | Mirko | FS_3GNRM_TMFSID |  |  |  |
| 6960 | 2316 | Study on Harmonization of 3GPP Alarm IRP and TMF Interface Program (TIP) Fault Management |  | 335d? | 2009-12-10 A | 2011-03-23 A | 100% | 2009-12-10 | 2011-03-23 | 335d? | finish no earlier than 2011-03-23 | S5 | 2680h | 2680h | FS_3G_TMF_FM | 24 | 32.829 | Nokia Siemens Networks, Alcatel-Lucent | Rel-10 | 46 | Mirko | FS_3G_TMF_FM |  |  |  |
| 6961 | 2317 | Study on Alarm Correlation and Alarm Root Cause Analysis |  | 205d? | 2010-06-10 A | 2011-03-23 A | 100% | 2010-06-10 | 2011-03-23 | 205d? | finish no earlier than 2011-03-23 | S5 | 1640h | 1640h | FS_AC_ARCA | 25 | 32.832 | Ericsson | Rel-10 | 48 | Mirko | FS_AC_ARCA |  |  |  |
| 6962 | 2318 | Study on Alignment of 3GPP PM IRP and TMF Interface Program (TIP) PM |  | 205d? | 2010-06-10 A | 2011-03-23 A | 100% | 2010-06-10 | 2011-03-23 | 205d? | finish no earlier than 2011-03-23 | S5 | 1640h | 1640h | FS_3G_TMF_PM | 25 | 32.831 | Alcatel-Lucent | Rel-10 | 48 | Mirko | FS_3G_TMF_PM |  |  |  |
| 6963 | 2319 | Study on Policy and Charging Rules Function (PCRF) failure and restoration |  | 261d? | 2009-08-18 A | 2010-09-17 A | 100% | 2009-08-18 | 2010-09-17 | 261d? | finish no earlier than 2010-09-17 | C3 | 2088h | 2088h | FS_PCRF-FR | 23 | 29.816 | NEC | Rel-10 | 45 | Adrian | FS_PCRF-FR |  |  |  |
| 6964 | 2320 | Study on User Data Convergence (UDC) evolution |  | 206d? | 2010-06-04 A | 2011-03-18 A | 100% | 2010-06-04 | 2011-03-18 | 206d? | finish no earlier than 2011-03-18 | C4 | 1648h | 1648h | FS_UDCe | 25 | 23.845 | Alcatel-Lucent | Rel-10 | 48 | Kimmo | FS_UDCe |  |  |  |
| 6965 | 2321 | Study on UICC access to IMS |  | 206d? | 2010-06-04 A | 2011-03-18 A | 100% | 2010-06-04 | 2011-03-18 | 206d? | finish no earlier than 2011-03-18 | C6 | 1648h | 1648h | FS_IMS-UICC | 25 | 31.828 | Gemalto | Rel-10 | 48 | Xavier | FS_IMS-UICC |  |  |  |
| 6966 | 2322 | Study on Uplink Tx Diversity for HSPA |  | 208.4d? | 2009-08-18 A | 2010-06-04 A | 100% | 2009-08-18 | 2010-06-04 | 208.4d? | finish no earlier than 2010-06-04 | R4 | 1667.2h | 1667.2h | FS_UL-TxDiv-HSPA | 23 | UTRA 25.863 | Qualcomm | Rel-10 | 45 | Issam | FS_UL-TxDiv-HSPA | RP-100499 |  |  |
| 6967 | 2323 | Study on Solutions for Energy Saving within UTRA Node B |  | 206d? | 2009-12-04 A | 2010-09-17 A | 100% | 2009-12-04 | 2010-09-17 | 206d? | finish no earlier than 2010-09-17 | R1; R3 | 3296h | 3296h | FS_Energy_UMTS | 24 | UTRA 25.927 | Vodafone | Rel-10 | 46 | Patrick | FS_Energy_UMTS | RP-100796 |  |  |
| 6968 | 2324 | Study on Potential solutions for energy saving for E-UTRAN |  | 348.75d? | 2010-02-02 A | 2011-06-03 A | 100% | 2010-02-02 | 2011-06-03 | 348.75d? | finish no earlier than 2011-06-03 | R3; R2 | 5580h | 5580h | FS_Energy_LTE | 24 | LTE 36.927 | China Mobile | Rel-10 | 47 | Juha | FS_Energy_LTE | RP-110597 |  |  |
| 6969 | 2325 | Study on Improvements of distributed antenna for 1.28Mcps TDD |  | 200.55d? | 2010-03-05 A | 2010-12-10 A | 100% | 2010-03-05 | 2010-12-10 | 200.55d? | finish no earlier than 2010-12-10 | R1; R2; R3 | 4813.2h | 4813.2h | FS_distr_ant_LCR_TDD | 24 | UTRA 25.865 | ZTE | Rel-10 | 47 | Patrick | FS_distr_ant_LCR_TDD | RP-101287 |  |  |
| 6970 | 2326 | Deleted - Study on Unauthenticated PS Emergency Calls |  | 471d? | 2008-06-05 A | 2010-03-25 A | 100% | 2008-06-05 | 2010-03-25 | 471d? | finish no earlier than 2010-03-25 | S1 | 3768h | 3768h | FS_UAPSEC | 21 | 22.984 | Nokia Siemens Networks | Rel-10 | 40 | Alain | FS_UAPSEC |  | PCG-24 | SP-47 |
| 6971 | 2327 | Deleted - Study on enhancements to IMS border functions for IMS Interconnection of services |  | 586d? | 2008-09-18 A | 2010-12-15 A | 100% | 2008-09-18 | 2010-12-15 | 586d? | finish no earlier than 2010-12-15 | S2 | 4688h | 4688h | FS_eIMS_IBCF | 21 | 23.848 | Starent Networks | Rel-10 | 41 | Maurice | FS_eIMS_IBCF |  | PCG-26 | SP-50 |
| 6972 | 2328 | Deleted - Study on EPC Charging enhancement |  | 211d? | 2009-06-04 A | 2010-03-25 A | 100% | 2009-06-04 | 2010-03-25 | 211d? | finish no earlier than 2010-03-25 | S5 | 1688h | 1688h | FS_EPCcharg | 23 |  | Nokia Siemens Networks | Rel-10 | 44 | Mirko | FS_EPCcharg |  | PCG-24 | SP-47 |
| 6973 | 2329 | Deleted - Study on Interworking Proxy between GTP based and PMIP based interfaces |  | 186d? | 2009-09-18 A | 2010-06-04 A | 100% | 2009-09-18 | 2010-06-04 | 186d? | finish no earlier than 2010-06-04 | C4 | 1488h | 1488h | FS_GTP-MIP-IW | 23 | 29.875 | NTT DoCoMo | Rel-10 | 45 | Kimmo | FS_GTP-MIP-IW |  | PCG-25 | CP-48 |
| 6974 | 2330 | --- RELEASE 9 --- | milestone | 0d? | 2000-01-01 A | 2000-01-01 A | 100% | 2000-01-01 | 2000-01-01 | 0d? |  | CP; GP; RP; SP |  |  |  |  |  |  | Rel-9 |  |  |  |  |  |  |

Notes:
- 6942: SP#47 completed. TR 22.813-100 for Approval. Spin-off Feature UID_470030 Codec for Enhanced Voice Services / WI rapporteur e-mail: philippe.lottin@orange.com
- 6943: SP#47 completed. TR 22.813-100 for Approval / WI rapporteur e-mail: philippe.lottin@orange.com
- 6944: SP#47 completed. TR 22.813-100 for Approval / WI rapporteur e-mail: stefan.bruhn@ericson.com
- 6945: SP#46 completed. Linked to Rel-8 Feature UID_380060 IP Interconnection of Services (IPinterc). Spin-off Feature Rel-11 UID_470051 Advanced IP Interconnection of Services / WI rapporteur e-mail: chris.friel@O2.com
- 6946: SP#47 completed / WI rapporteur e-mail: Jaihyung Cho
- 6947: SP#47 completed / WI rapporteur e-mail: jinhan.song@sktelecom.com
- 6948: SP#47 completed. Covers Mobile/Fixed/Cordless/etc terminals. Haptic (human-machine tactile communication) extend service offering & richness of user experience beyond current visual & auditory senses / WI rapporteur e-mail: jinhan.song@sktelecom.com
- 6949: SP#46 completed. Spin-off Feature UID_460028 Optimal Media Routeing (OMR). Linked to Study on Multimedia Session Continuity UID_350051, Study on Centralized IMS Service Control UID_330012, IMS inter-operator service interconnection interface UID_360011 / WI rapporteur e-mail: mario.madella@telecomitalia.it, victor.kueh@bt.com
- 6950: SP#47 completed. Concluded no further normative work expected. Linked to 23.236 / WI rapporteur e-mail: LIU HONG (liuhongyfw@chinamobile.com)
- 6951: SP#49 completed (Conclusion: select the SIP anchoring based solution for normative work CR (TEI10) introducing and completing stage-2). Analyzed performance of Rel-8 SRVCC solution from E-UTRAN/HSPA to UTRAN/GERAN / WI rapporteur e-mail: Hou zhiqiang (houzhiqiang@chinamobile.com), Jiang Yi (jiangyi@chinamobile.com)
- 6952: SP#49 completed. TR 23.886v100 for Approval. Related to Rel-8 UID_350030 Single Radio Voice Call Continuity for 3GPP (SAES-SRVCC). Study how to provide Video Call seamless service continuity for 3G/LTE terminal user / WI rapporteur e-mail: Haris Zisimopoulos (haris.z@samsung.com)
- 6953: SP#48 completed. Triggered by Rel-8 UID_350027 SAE for support for non-3GPP accesses. Nature of relationship: S2b one of the interfaces defined for non-3GPP accesses support in EPS. Stage 1 in Rel-8 UID_320022 (AIPN-SAE) 22.278,22.101 / WI rapporteur e-mail: bruno.landais@alcatel-lucent.com
- 6954: SP#51 completed. Extend Rel-8 UID_34043 (Extending PSS and MBMS User Services for optimized Mobile TV) / WI rapporteur e-mail: jan.plogsties@iis.franhofer.de
- 6955: SP#51 completed. Extends Rel-9 Improved Video Support for PSS and MBMS (UID_430039) / WI rapporteur e-mail: imed.bouazizi@nokia.com, jaihyung@etri.re.kr
- 6956: SP#47 completed / WI rapporteur e-mail: shan.mingjun@huawei.com
- 6957: SP#47 completed. Study result might impact Feature UID_420011 Self Organising Networks (SON) / WI rapporteur e-mail: Jean-Michel Cornilly (Orange)
- 6958: SP#47 completed / WI rapporteur e-mail: Yizhi Yao (yzyao@motorola.com)
- 6959: SP#51 completed / WI rapporteur e-mail: olaf.pollakowski@nsn.com
- 6960: SP#51 completed / WI rapporteur e-mail: olaf.pollakowski@nsn.com, Padma.Sudarsan@alcatel-lucent.com
- 6961: SP#51 completed / WI rapporteur e-mail: edwin.tse@ericsson.com
- 6962: SP#51 completed / WI rapporteur e-mail: Padma.Sudarsan@alcatel-lucent.com
- 6963: CP#49 completed / WI rapporteur e-mail: gottfried.punz@nw.neclab.eu
- 6964: CP#51 completed. Study UDC evolution from FeaturES in CP-150Rel-9 UID_400034 and Rel-10 UID_480011 UDC Data Model / WI rapporteur e-mail: jean-jacques.trottin@alcatel-lucent.com
- 6965: CP#51 completed / WI rapporteur e-mail: Denis.Lheriteau@gemalto.com
- 6966: RP#48 completed / WI rapporteur e-mail: Heechoon Lee (heechoon@qualcomm.com)
- 6967: RP#49 completed. Based on ETSI EE TS 102 706. / WI rapporteur e-mail: Prakash.bhat@vodafone.com
- 6968: RP#52 completed / WI rapporteur e-mail: Yang Ning (yangning@chinamobile.com)
- 6969: RP#50 completed. TR 25.865 v101 for Approval / WI rapporteur e-mail: huang.he4@zte.com.cn
- 6970: SP#47 work stopped/abandoned / WI rapporteur e-mail: Juergen.Merkel@nsn.com
- 6971: SP#50 work stopped. Additional work may be addressed as part of the Rel-11 Feature UID_470051 Advanced IP Interconnection of Services (IPXS) / WI rapporteur e-mail: Rajat Ghai (rghai@starentnetworks.com)
- 6972: SP#47 work stopped. Issue covered by Rel-10 UID_460039 Charging for LIPA_SIPTO and UID_4700xy Charging for IFOM / WI rapporteur e-mail: Gerald.Goermer@nsn.com
- 6973: CP#48 work stopped/abandoned / WI rapporteur e-mail: takaaki.matsuura.sp@s1.nttdocomo.com
- 6974: -

| ID | WBS | Task | Duration | Start | Finish | Complete | Baseline start | Baseline finish | Baseline duration | Constraint | Resources | Work | Actual work | Acronym | PCG approved | WI rapporteur name | WI rapporteur e-mail | Release | TSG approved | MCC resp | Special Focus Doc | Acronym_3GU_Export | Status Report |
| --- | --- | --- | --- | --- | --- | --- | --- | --- | --- | --- | --- | --- | --- | --- | --- | --- | --- | --- | --- | --- | --- | --- | --- |
| 6975 | 2331 | **Enhanced Home NodeB / eNodeB** | 1328.25d? | 2008-06-05 A | 2011-12-09 A | 100% | 2008-06-05 | 2011-12-09 | 921d? |  | S1; S2; S3; S5; C1; C6; R2; R3; R4; R5; GP | 113136h | 113136h | EHNB | 21 | T-Mobile | michael.kurz@t-mobile.at | Rel-9 | 40 | Alain | HNB | EHNB |  |
| 6976 | 2331.1 | Stage 1 for EHNB | 261d? | 2008-06-05 A | 2009-06-04 A | 100% | 2008-06-05 | 2009-06-04 | 261d? | finish no earlier than 2009-06-04 | S1 | 2088h | 2088h | EHNB | 21 | T-Mobile | michael.kurz@t-mobile.at | Rel-9 | 40 | Alain | HNB |  |  |
| 6977 | 2331.2 | Architecture aspects of EHNB | 266d? | 2008-09-18 A | 2009-09-24 A | 100% | 2008-09-18 | 2009-09-24 | 266d? | finish no earlier than 2009-09-22 | S2 | 2128h | 2128h | EHNB | 21 | T-Mobile | sebastian.speicher@telekom.de | Rel-9 | 41 | Maurice | HNB |  |  |
| 6978 | 2331.3 | Security aspects of Enhanced Home NodeB / eNodeB | 262d? | 2008-12-11 A | 2009-12-10 A | 100% | 2008-12-11 | 2009-12-10 | 262d? | finish no earlier than 2009-12-10 | S3 | 2096h | 2096h | EHNB-Sec | 22 | Huawei | Marcus Wong (mwong@huawei.com) | Rel-9 | 42 | Mirko | HNB | EHNB-Sec |  |
| 6979 | 2331.4 | CT1 aspects - Support of Home NB and Home eNB enhancements | 321d? | 2009-09-18 A | 2010-12-10 A | 100% | 2009-09-18 | 2010-12-10 | 321d? | finish no earlier than 2010-12-10 | C1 | 2568h | 2568h | EHNB-CT1 | 23 | Qualcomm | Ramachandran Subramanian (rsubrama@qualcomm.com) | Rel-9 | 45 | Frederic | HNB | EHNB-CT1 |  |
| 6980 | 2331.5 | CT6 aspects - Support of Home NB and Home eNB enhancements | 131d? | 2009-09-18 A | 2010-03-19 A | 100% | 2009-09-18 | 2010-03-19 | 131d? | finish no earlier than 2010-03-19 | C6 | 1048h | 1048h | EHNB-CT6 | 23 | Qualcomm | Ramachandran Subramanian (rsubrama@qualcomm.com) | Rel-9 | 45 | Xavier | HNB | EHNB-CT6 |  |
| 6981 | 2331.6 | 3G HNB Gateway and LTE HeNB Gateway OAM&P | 336d? | 2008-12-11 A | 2010-03-25 A | 100% | 2008-12-11 | 2010-03-25 | 336d? | finish no earlier than 2010-03-25 | S5 | 2688h | 2688h | HNB-OAM_GW | 22 | China Mobile | GangChen (chengang@chinamobile.com) | Rel-9 | 42 | Mirko | HNB | HNB-OAM_GW |  |
| 6982 | 2331.7 | 3G HNB and LTE HeNB OAM&P Type 1 Interface | 272d? | 2009-03-12 A | 2010-03-25 A | 100% | 2009-03-12 | 2010-03-25 | 272d? | finish no earlier than 2010-03-25 | S5 | 2168h | 2168h | HNB_eHNB-OAM_Type1 | 22 | Huawei | Zou Lan (zlan@huawei.com) | Rel-9 | 43 | Mirko | HNB | HNB_eHNB-OAM_Type1 |  |
| 6983 | 2331.8 | 3G HNB and LTE HeNB OAM&P Type 2 Interface | 225d? | 2009-05-15 A | 2010-03-25 A | 100% | 2009-05-15 | 2010-03-25 | 225d? | finish no earlier than 2010-03-25 | S5 | 1800h | 1800h | HNB_eHNB-OAM_Type2 | 23 | Ericsson | edwin.tse@ericsson.com | Rel-9 | 44 | Mirko | HNB | HNB_eHNB-OAM_Type2 |  |
| 6984 | 2331.9 | LTE FDD Home eNodeB RF Requirements | 336d? | 2008-12-05 A | 2010-03-19 A | 100% | 2008-12-05 | 2010-03-19 | 336d? | finish no earlier than 2010-03-19 | R4 | 2688h | 2688h | HeNB-RF_FDD | 22 | Motorola | Ying Cai (yingcai@motorola.com) | Rel-9 | 42 | Issam | HNB | HeNB-RF_FDD | RP-100035 |
| 6985 | 2331.10 | LTE TDD Home eNodeB RF Requirements | 271d? | 2009-03-06 A | 2010-03-19 A | 100% | 2009-03-06 | 2010-03-19 | 271d? | finish no earlier than 2010-03-19 | R4 | 2168h | 2168h | HeNB-RF_TDD | 22 | China Mobile | Nan Li (linan@chinamobile.com) | Rel-9 | 43 | Issam | HNB | HeNB-RF_TDD | RP-100036 |
| 6986 | 2331.11 | Home NB and Home eNB enhancements - RAN3 aspects | 197d? | 2009-03-06 A | 2009-12-04 A | 100% | 2009-03-06 | 2009-12-04 | 197d? | finish no earlier than 2009-12-04 | R3 | 1576h | 1576h | EHNB-RAN3 | 22 | Alcatel-Lucent | Martin Warner (mw15@alcatel-lucent.com) | Rel-9 | 43 | Juha | HNB | EHNB-RAN3 | RP-091050 |
| 6987 | 2331.12 | Home NB and Home eNB enhancements - RAN2 aspects | 271d? | 2009-03-06 A | 2010-03-19 A | 100% | 2009-03-06 | 2010-03-19 | 271d? | finish no earlier than 2010-03-19 | R2 | 2168h | 2168h | EHNB-RAN2 | 22 | Huawei | Yang Xudong (yangxudong@huawei.com) | Rel-9 | 43 | Yong-Jun | HNB | EHNB-RAN2 | RP-100037 |
| 6988 | 2331.13 | Conformance Test Aspects – Home NB enhancements for FDD | 322d? | 2010-09-17 A | 2011-12-09 A | 100% | 2010-09-17 | 2011-12-09 | 322d? | finish no earlier than 2011-12-09 | R5 | 2568h | 2568h | EHNB-UTRA_FDD_UEConTest | 25 | Huawei | trica_li@huawei.com | Rel-9 | 49 | Ingbert | HNB | EHNB-UTRA_FDD_UEConTest | RP-111679 |
| 6989 | 2331.14 | Conformance Test Aspects – Home eNB enhancements | 201d? | 2010-12-10 A | 2011-09-16 A | 100% | 2010-12-10 | 2011-09-16 | 201d? | finish no earlier than 2011-09-16 | R5 | 1608h | 1608h | EHNB-LTE_UEConTest | 26 | Qualcomm | Mrs Lena Chaponniere (lchaponn@qualcomm.com) | Rel-9 | 50 | Ingbert | HNB | EHNB-LTE_UEConTest | RP-110972 |
| 6990 | 2331.15 | Home NB and Home eNB enhancements - GERAN aspects | 341d? | 2009-05-18 A | 2010-09-03 A | 100% | 2009-05-18 | 2010-09-03 | 341d? | finish no earlier than 2010-09-03 | GP | 2728h | 2728h | EHNB-GERAN | 23 | Nokia Siemens Networks | leonardo.provvedi@roke.co.uk | Rel-9 | 42 | Paolo | HNB | EHNB-GERAN |  |
| 6991 | 2332 | **Value-Added Services for Short Message Service** | 845.88d? | 2007-09-10 A | 2009-12-04 A | 100% | 2007-09-10 | 2009-12-04 | 586d? |  | S1; C4; C1 | 20264h | 20264h | VAS4SMS | 19 | China Mobile | Wu Bin (wubin@chinamobile.com) | Rel-9 | 37 | Alain |  | VAS4SMS |  |
| 6992 | 2332.1 | Stage 1 for VAS4SMS | 133d? | 2007-09-10 A | 2008-03-12 A | 100% | 2007-09-10 | 2008-03-12 | 133d? | finish no earlier than 2008-03-21 | S1 | 1064h | 1064h | VAS4SMS | 19 | China Mobile | Wu Bin (wubin@chinamobile.com) | Rel-9 | 37 | Alain |  |  |  |
| 6993 | 2332.2 | CT4 aspects of VAS4SMS Interface and Signalling Flow | 322d? | 2008-09-12 A | 2009-12-04 A | 100% | 2008-09-12 | 2009-12-04 | 322d? | finish no earlier than 2009-12-04 | C4 | 2568h | 2568h | VAS4SMS | 21 | China Mobile | Wu Bin (wubin@chinamobile.com) | Rel-9 | 41 | Kimmo |  |  |  |
| 6994 | 2332.3 | CT1 aspects of VAS4SMS Interface and Signalling Flow | 321d? | 2008-09-09 A | 2009-12-04 A | 100% | 2008-09-09 | 2009-12-04 | 321d? | finish no earlier than 2009-12-04 | C1 | 2568h | 2568h | VAS4SMS | 21 | China Mobile | Wu Bin (wubin@chinamobile.com) | Rel-9 | 41 | Frederic |  |  |  |
| 6995 | 2333 | **Definition of End-User Identity** | 482.5d? | 2007-09-03 A | 2008-12-11 A | 100% | 2007-09-03 | 2008-12-11 | 334d? |  | S1 | 5344h | 5344h | EUI | 19 | Nokia Siemens Networks | Juergen.Merkel@nsn.com | Rel-9 | 37 | Alain |  | EUI |  |
| 6996 | 2333.1 | Stage 1 for Definition of End-User Identity | 334d? | 2007-09-03 A | 2008-12-11 A | 100% | 2007-09-03 | 2008-12-11 | 334d? | finish no earlier than 2008-12-11 | S1 | 2672h | 2672h | EUI | 21 | Nokia Siemens Networks | Juergen.Merkel@nsn.com | Rel-9 | 38 | Alain |  |  |  |
| 6997 | 2334 | **Customized Ringing Signal** | 754.88d? | 2007-12-06 A | 2009-12-03 A | 100% | 2007-12-06 | 2009-12-03 | 522d? |  | S1; C1 | 11296h | 11296h | CRS | 21 | SK Telecom, China Mobile | Donghee Shim (SK Telecom), Jianping Zheng (China Mobile) | Rel-9 | 38 | Alain |  | CRS |  |
| 6998 | 2334.1 | Stage 1 for Customized Ringing Signal | 266d? | 2007-12-06 A | 2008-12-11 A | 100% | 2007-12-06 | 2008-12-11 | 266d? | finish no earlier than 2008-12-11 | S1 | 2128h | 2128h | CRS | 21 | SK Telecom, China Mobile | Donghee Shim (SK Telecom), Jianping Zheng (China Mobile) | Rel-9 | 38 | Alain |  |  |  |
| 6999 | 2334.2 | Stage 3 for IMS Customized Ringing Signal (CRS) Service | 195.62d? | 2009-05-29 A | 2009-12-03 A | 100% | 2009-05-29 | 2009-12-03 | 136d? | finish no earlier than 2010-06-04 | C1 | 816h | 816h | CRS | 23 | China Mobile | wangzhao | Rel-9 | 44 | Frederic |  |  |  |

Notes:
- 6975: RP#54 Testing completed / Impacted TSs and TRs: UTRA; LTE
- 6976: CP#49 the SA1-reqs are moving. CT1 will align when the work in SA1 is clear. (was SP#44 completed.) / Impacted TSs and TRs: 22.220; 22.011
- 6977: SP#45 completed / Impacted TSs and TRs: 23.401; 23.402; 23.060; New 23.830
- 6978: SP#46 completed / Impacted TSs and TRs: New 33.320
- 6979: CP#50 completed (Roaming aspects for manual CSG selection, Support of temporary users and CSG membership changes, Support of user controlled and operator controlled lists) / Impacted TSs and TRs: 23.122; 24.008; 24.285; 24.301
- 6980: CP#47 completed. Storing of CSG related data items on the USIM / Impacted TSs and TRs: 31.102
- 6981: SP#47 completed / Impacted TSs and TRs: 32.632; 32.633; 32.635; New (32.771; 32.772; 32.773; 32.775; 32.781; 32.782; 32.783; 32.785)
- 6982: SP#47 completed / Impacted TSs and TRs: 32.581; 32.582; 32.583; 32.584; New (32.591; 32.592; 32.593; 32.594)
- 6983: SP#47 completed / Impacted TSs and TRs: New (32.571; 32.572)
- 6984: RP#47 completed / Impacted TSs and TRs: 36.104; 36.141; New 36.921
- 6985: RP#47 completed / Impacted TSs and TRs: 36.104; 36.141; 36.300; 36.331; 36.413; New 36.922
- 6986: RP#46 completed (based on high priority items specified in RP-090995) / Impacted TSs and TRs: 25.413; 25.467; 25.467; 25.468; 25.469; 25.469; 36.401; 36.413; New 25.444
- 6987: RP#47 completed / Impacted TSs and TRs: 25.304; 25.331; 25.367; 36.300; 36.304; 36.331
- 6988: UTRA. RP#54 completed. Testing for UID_430026 Support of Home NB and Home eNB enhancements RAN2 aspects (25.304, 25.331, 25.367) / Impacted TSs and TRs: 34.108; 34.121-1; 34.121-2; 34.123-1; 34.123-2; 34.123-3
- 6989: RP#53 completed / Impacted TSs and TRs: 36.508; 36.523-1; 36.523-2; 36.523-3
- 6990: GP#47 completed. GP#42 WID approved / Impacted TSs and TRs: 43.055; 43.129; 44.018; 44.060; 45.008; 48.008; 48.018
- 6991: CP#46 completed
- 6992: SP#39 completed. SP#43 Feature moved to Rel-9 / Impacted TSs and TRs: new 22.142
- 6993: CP#46 completed / Impacted TSs and TRs: new 23.142
- 6994: CP#46 completed / Impacted TSs and TRs: 23.040
- 6995: SP#42 closed. Stage 1 work closed at 5% completion due to lack of input (added only the EUI definition in 21.905)
- 6996: SP#42 closed. Stage 1 work closed at 5% completion due to lack of input (added only the EUI definition in 21.905) / Impacted TSs and TRs: 21.905
- 6997: CP#48 completed
- 6998: SP#42 completed. / Impacted TSs and TRs: 22.173; new 22.183
- 6999: CP#48 completed / Impacted TSs and TRs: 24.173; new 24.183

| ID | WBS | Task | Type | Duration | Start | Finish | Complete | Baseline start | Baseline finish | Baseline duration | Constraint | Resources | Work | Actual work | Acronym | PCG approved | Impacted TSs and TRs | WI rapporteur name | Release | TSG approved | MCC resp | Special Focus Doc | Acronym_3GU_Export | Status Report |
| --- | --- | --- | --- | --- | --- | --- | --- | --- | --- | --- | --- | --- | --- | --- | --- | --- | --- | --- | --- | --- | --- | --- | --- | --- |
| 7000 | 2335 | **Public Warning System** |  | 1893.25d? | 2007-12-06 A | 2012-12-07 A | 100% | 2007-12-06 | 2012-12-07 | 1315d? |  | S1; C1; C4; R2; R3; R5 | 73920h | 73920h | PWS | 21 | LTE | T-Mobile | Rel-9 | 38 | Alain | Public Safety (I-A) | PWS |  |
| 7001 | 2335.1 | Stage 1 for Public Warning System |  | 266d? | 2007-12-06 A | 2008-12-11 A | 100% | 2007-12-06 | 2008-12-11 | 266d? | finish no earlier than 2008-12-11 | S1 | 2128h | 2128h | PWS | 21 | 22.268 | T-Mobile | Rel-9 | 38 | Alain | Public Safety (I-A) |  |  |
| 7002 | 2335.2 | **Stage 3 for Public Warning System** |  | 196.62d? | 2009-05-29 A | 2009-12-04 A | 100% | 2009-05-29 | 2009-12-04 | 137d? |  | C1; C4 | 4368h | 4368h | PWS-St3 | 23 |  | Qualcomm | Rel-9 | 44 | Frederic | Public Safety (I-A) | PWS-St3 |  |
| 7003 | 2335.2.1 | CT1 aspects of Stage 3 for Public Warning System |  | 137d? | 2009-05-29 A | 2009-12-04 A | 100% | 2009-05-29 | 2009-12-04 | 137d? | finish no earlier than 2009-12-04 | C1 | 1088h | 1088h | PWS-St3 | 23 | 23.041 | Qualcomm | Rel-9 | 44 | Frederic | Public Safety (I-A) |  |  |
| 7004 | 2335.2.2 | CT4 aspects of Stage 3 for Public Warning System |  | 136d? | 2009-05-30 A | 2009-12-04 A | 100% | 2009-05-30 | 2009-12-04 | 136d? | finish no earlier than 2009-12-04 | C4 | 1088h | 1088h | PWS-St3 | 23 | 29.168 | Qualcomm | Rel-9 | 44 | Kimmo | Public Safety (I-A) |  |  |
| 7005 | 2335.3 | Public Warning System (PWS) – RAN aspects |  | 136d? | 2009-05-30 A | 2009-12-04 A | 100% | 2009-05-30 | 2009-12-04 | 136d? | finish no earlier than 2009-12-04 | R2; R3 | 2176h | 2176h | PWS-RAN | 23 | LTE 36.300; 36.302; 36.331; 36.413 | AT&T | Rel-9 | 44 | Yong-Jun | Public Safety (I-A) | PWS-RAN | RP-091052 |
| 7006 | 2335.4 | Conformance Test Aspects – Public Warning System (PWS) – RAN aspects for LTE |  | 267d? | 2011-12-02 A | 2012-12-07 A | 100% | 2011-12-02 | 2012-12-07 | 267d? | finish no earlier than 2012-12-07 | R5 | 2128h | 2128h | PWS-RAN_UEConTest | 28 | 36.508; 36.523-1; 36.523-2; 36.523-3 | Qualcomm | Rel-9 | 54 | Ingbert | Public Safety (I-A) | PWS-RAN_UEConTest | RP-121525 |
| 7007 | 2336 | **Support of Personal Area Networks and Enhancements to Personal Network Management** |  | 755.88d? | 2008-06-05 A | 2010-06-04 A | 100% | 2008-06-05 | 2010-06-04 | 523d? |  | S1; C1 | 12544h | 12544h | PAN_EPNM | 21 |  | Vodafone | Rel-9 | 40 | Alain |  | PAN_EPNM |  |
| 7008 | 2336.1 | Stage 1 for Support of Personal Area Networks and Enhancements to Personal Network Management | milestone | 0d? | 2008-06-05 A | 2008-06-05 A | 100% | 2008-06-05 | 2008-06-05 | 0d? | finish no earlier than 2008-06-05 | S1 |  |  | PAN_EPNM | 21 | 22.259 | Vodafone | Rel-9 | 40 | Alain |  |  |  |
| 7009 | 2336.2 | Stage 2 for Support of Personal Area Networks and Enhancements to Personal Network Management |  | 196d? | 2009-03-06 A | 2009-12-04 A | 100% | 2009-03-06 | 2009-12-04 | 196d? | finish no earlier than 2009-12-04 | C1 | 1568h | 1568h | PAN_EPNM | 22 | 23.259 | Huawei | Rel-9 | 43 | Frederic |  |  |  |
| 7010 | 2336.3 | Stage 3 for Support of Personal Area Networks and Enhancements to Personal Network Management |  | 326d? | 2009-03-09 A | 2010-06-04 A | 100% | 2009-03-09 | 2010-06-04 | 326d? | finish no earlier than 2010-06-04 | C1 | 2608h | 2608h | PAN_EPNM | 22 | 24.259 | Huawei | Rel-9 | 43 | Frederic |  |  |  |
| 7011 | 2337 | **Multi-Media Telephony Service enhancements** |  | 682.38d? | 2008-06-05 A | 2010-03-25 A | 100% | 2008-06-05 | 2010-03-25 | 472d? |  | S1; S5; C1 | 17840h | 17840h | eMMTel | 21 |  | France Telecom | Rel-9 | 40 | Alain |  | eMMTel |  |
| 7012 | 2337.1 | Stage 1 for eMMTel |  | 136d? | 2008-06-05 A | 2008-12-11 A | 100% | 2008-06-05 | 2008-12-11 | 136d? | start no earlier than 2008-06-05 | S1 | 1088h | 1088h | eMMTel | 21 | 22.173 | France Telecom | Rel-9 | 40 | Alain |  |  |  |
| 7013 | 2337.2 | Multimedia Telephony (MMTel) Service and Supplementary Services - Online Charging and completion for Offline Charging (all supplementary services) |  | 272d? | 2009-03-12 A | 2010-03-25 A | 100% | 2009-03-12 | 2010-03-25 | 272d? | finish no earlier than 2010-03-25 | S5 | 2168h | 2168h | eMMTel-SS-CH | 22 | 32.275; 32.298; 32.299 | Alcatel-Lucent | Rel-9 | 43 | Mirko |  | eMMTel-SS-CH |  |
| 7014 | 2337.3 | Support of Real-time Transfer of Tariff Information (RTTI) in IMS charging |  | 271d? | 2009-03-12 A | 2010-03-25 A | 100% | 2009-03-12 | 2010-03-25 | 271d? | finish no earlier than 2010-03-25 | S5 | 2168h | 2168h | IMSTSS-RTTI-CH | 22 | 32.240; 32.280; 32.298; 32.299 | Orange | Rel-9 | 43 | Mirko |  | IMSTSS-RTTI-CH |  |
| 7015 | 2337.4 | Stage 3 - Enhancements for Completion of Communications Supplementary service |  | 136d? | 2009-05-30 A | 2009-12-04 A | 100% | 2009-05-30 | 2009-12-04 | 136d? | finish no earlier than 2009-12-04 | C1 | 1088h | 1088h | eMMTel-CC | 23 | 24.642 | France Telecom | Rel-9 | 44 | Frederic |  | eMMTel-CC |  |
| 7016 | 2338 | **User Data Convergence (UDC)** |  | 762.12d? | 2008-06-05 A | 2010-06-10 A | 100% | 2008-06-05 | 2010-06-10 | 527d? |  | S1; S5; C4 | 25056h | 25056h | UDC | 21 |  | Nokia Siemens Networks | Rel-9 | 40 | Alain |  | UDC |  |
| 7017 | 2338.1 | Stage 1 for User Data Convergence (UDC) |  | 136d? | 2008-06-05 A | 2008-12-11 A | 100% | 2008-06-05 | 2008-12-11 | 136d? | start no earlier than 2008-06-05 | S1 | 1088h | 1088h | UDC | 21 | 22.101; new 22.985 | Nokia Siemens Networks | Rel-9 | 40 | Alain |  |  |  |
| 7018 | 2338.2 | **Stage 2/3 for User Data Convergence (UDC) Technical Realization** |  | 392.38d? | 2009-03-06 A | 2010-03-19 A | 100% | 2009-03-06 | 2010-03-19 | 272d? |  | C4 | 5376h | 5376h | UDC-CN | 22 |  | Ericsson | Rel-9 | 43 | Kimmo |  | UDC-CN |  |
| 7019 | 2338.2.1 | User Data Convergence (UDC) Technical Realization (Stage 2) |  | 271d? | 2009-03-06 A | 2010-03-19 A | 100% | 2009-03-06 | 2010-03-19 | 271d? | finish no earlier than 2010-03-19 | C4 | 2168h | 2168h | UDC-CN | 22 | new 23.335 | Ericsson | Rel-9 | 43 | Kimmo |  |  |  |
| 7020 | 2338.2.2 | User Data Convergence (UDC) Protocol Description |  | 130d? | 2009-09-18 A | 2010-03-19 A | 100% | 2009-09-18 | 2010-03-19 | 130d? | finish no earlier than 2010-03-19 | C4 | 1040h | 1040h | UDC-CN | 23 | new 29.335 | China Mobile, Ericsson | Rel-9 | 45 | Kimmo |  |  |  |
| 7021 | 2338.3 | **User Data Convergence (UDC) Modelling and Management** |  | 385.25d? | 2009-06-04 A | 2010-06-10 A | 100% | 2009-06-04 | 2010-06-10 | 266d? |  | S5 | 5944h | 5944h | UDC-MMAN | 23 |  | T-Mobile, China Mobile, Ericsson | Rel-9 | 44 | Mirko |  | UDC-MMAN |  |
| 7022 | 2338.3.1 | UDC – Framework for Model Handling and Management |  | 266d? | 2009-06-04 A | 2010-06-10 A | 100% | 2009-06-04 | 2010-06-10 | 266d? | finish no earlier than 2010-06-10 | S5 | 2128h | 2128h | UDC-MMAN-MFRM | 23 | 32.172; new 32.181 | T-Mobile | Rel-9 | 44 | Mirko |  | UDC-MMAN-MFRM |  |
| 7023 | 2338.3.2 | UDC – Common Baseline Information Model |  | 211d? | 2009-06-04 A | 2010-03-25 A | 100% | 2009-06-04 | 2010-03-25 | 211d? | finish no earlier than 2010-03-25 | S5 | 1688h | 1688h | UDC-MMAN-CBIM | 23 | 32.172; new 32.182 | China Mobile, Ericsson | Rel-9 | 44 | Mirko |  | UDC-MMAN-CBIM |  |

Notes:
- 7000: TSG#46 completed. Larger scope than Rel-8 Feature UID_370051 (ETWS). Triggered by TR 22.968 Study UID_320025 (FS_PWS) / WI rapporteur e-mail: Mark.Younge@t-mobile.com
- 7001: SP#42 completed / WI rapporteur e-mail: Mark.Younge@t-mobile.com
- 7002: RP#46 completed / WI rapporteur e-mail: Ramachandran Subramanian (rsubrama@qualcomm.com)
- 7003: CP#46 completed / WI rapporteur e-mail: Ramachandran Subramanian (rsubrama@qualcomm.com)
- 7004: CP#46 completed / WI rapporteur e-mail: Ramachandran Subramanian (rsubrama@qualcomm.com)
- 7005: RP#46 completed / WI rapporteur e-mail: don.zelmer@att.com
- 7006: RP#58 completed / WI rapporteur e-mail: Shubhang Vora (svora@qualcomm.com)
- 7007: CP#48 completed / WI rapporteur e-mail: armin.toepfer@vodafone.com
- 7008: SP#40 completed / WI rapporteur e-mail: armin.toepfer@vodafone.com
- 7009: CP#46 completed / WI rapporteur e-mail: Lili Yang (kadyyang@huawei.com)
- 7010: CP#48 completed / WI rapporteur e-mail: Lili Yang (kadyyang@huawei.com)
- 7011: SP#47 completed / WI rapporteur e-mail: philippe.lottin@orange.com
- 7012: SP#42 completed / WI rapporteur e-mail: philippe.lottin@orange.com
- 7013: SP#47 completed / WI rapporteur e-mail: maryse.gardella@alcatel-lucent.com
- 7014: SP#47 completed. Linked to SA5 Rel-8 UID_380042 AoC support in IMS Charging (IMSTSS) / WI rapporteur e-mail: Jean-Luc Garcia (jl.garcia@orange-ftgroup.com)
- 7015: CP#46 completed / WI rapporteur e-mail: Youssef.chadli@orange-ftgroup.com
- 7016: SP#48 completed. Triggered by Rel-8 SA5 Study of Common Profile Storage Framework of User Data for network services and management (UID_320006) TR 32.808 / WI rapporteur e-mail: juergen.merkel@nsn.com
- 7017: SP#42 completed / WI rapporteur e-mail: juergen.merkel@nsn.com
- 7018: - / WI rapporteur e-mail: emiliano.merino@ericsson.com
- 7019: CP#47 completed / WI rapporteur e-mail: emiliano.merino@ericsson.com
- 7020: CP#47 completed / WI rapporteur e-mail: Lan Si Zhong (lansizhong@chinamobile.com), emiliano.merino@ericsson.com
- 7021: SP#48 completed / WI rapporteur e-mail: istvan.aba@t-mobile.at, lansizhong@chinamobile.com, miguel.a.garcia@ericsson.com
- 7022: SP#48 completed / WI rapporteur e-mail: istvan.aba@t-mobile.at
- 7023: SP#47 completed / WI rapporteur e-mail: Lan Si Zhong, Miguel Garcia

| ID | WBS | Task | Duration | Start | Finish | Complete | Baseline start | Baseline finish | Baseline duration | Constraint | Resources | Work | Actual work | Acronym | PCG approved | WI rapporteur name | WI rapporteur e-mail | Release | TSG approved | MCC resp | Acronym_3GU_Export | Status Report | Special Focus Doc |
| --- | --- | --- | --- | --- | --- | --- | --- | --- | --- | --- | --- | --- | --- | --- | --- | --- | --- | --- | --- | --- | --- | --- | --- |
| 7024 | 2339 | **IMS Services Centralization and Continuity** | 567.38d? | 2008-09-18 A | 2010-03-19 A | 100% | 2008-09-18 | 2010-03-19 | 393d? |  | S1; S2; C1 | 30992h | 30992h | IMS_SCC | 21 | NEC | joerg.swetina@neclab.eu | Rel-9 | 41 | Alain | IMS_SCC |  |  |
| 7025 | 2339.1 | Stage 1 - Inter-Device Transfer – Requirements | 61d? | 2008-09-18 A | 2008-12-11 A | 100% | 2008-09-18 | 2008-12-11 | 61d? | finish no earlier than 2009-06-18 | S1 | 488h | 488h | IMS_SCC-IDT | 21 | NEC | joerg.swetina@neclab.eu | Rel-9 | 41 | Alain | IMS_SCC-IDT |  |  |
| 7026 | 2339.2 | **Stage 2/3 for IMS Service Continuity Enhancements: Service, Policy and Interactions** | 567.38d? | 2008-09-18 A | 2010-03-19 A | 100% | 2008-09-18 | 2010-03-19 | 393d? |  | S2; C1 | 9456h | 9456h | IMS_SCC-SPI | 21 | Huawei | HengLiang Zhang (hl_zhang@huawei.com) | Rel-9 | 41 | Maurice | IMS_SCC-SPI |  |  |
| 7027 | 2339.2.1 | Stage 2 for IMS Service Continuity Enhancements: Service, Policy and Interactions | 186d? | 2008-09-18 A | 2009-06-04 A | 100% | 2008-09-18 | 2009-06-04 | 186d? | finish no earlier than 2009-06-04 | S2 | 1488h | 1488h | IMS_SCC-SPI | 21 | Huawei | HengLiang Zhang (hl_zhang@huawei.com) | Rel-9 | 41 | Maurice |  |  |  |
| 7028 | 2339.2.2 | Stage 3 for IMS Service Continuity Enhancements: Service, Policy, Interactions and Inter UE Transfer | 212d? | 2009-05-29 A | 2010-03-19 A | 100% | 2009-05-29 | 2010-03-19 | 212d? | finish no earlier than 2010-03-19 | C1 | 1696h | 1696h | IMS_SCC-SPI | 23 | Qualcomm | Roozbeh Atarius (ratarius@qualcomm.com) | Rel-9 | 44 | Frederic |  |  |  |
| 7029 | 2339.3 | **Stage 2/3 for IMS Centralized Services** | 567.38d? | 2008-09-18 A | 2010-03-19 A | 100% | 2008-09-18 | 2010-03-19 | 393d? |  | S2; C1 | 9448h | 9448h | IMS_SCC-ICS | 21 | Alcatel-Lucent | andy.bennett@alcatel-lucent.com | Rel-9 | 41 | Maurice | IMS_SCC-ICS |  |  |
| 7030 | 2339.3.1 | Stage 2 for IMS Centralized Services | 186d? | 2008-09-18 A | 2009-06-04 A | 100% | 2008-09-18 | 2009-06-04 | 186d? | finish no earlier than 2009-06-04 | S2 | 1488h | 1488h | IMS_SCC-ICS | 21 | Alcatel-Lucent | andy.bennett@alcatel-lucent.com | Rel-9 | 41 | Maurice |  |  |  |
| 7031 | 2339.3.2 | Stage 3 for Enhancements to IMS Centralized Services | 212d? | 2009-05-29 A | 2010-03-19 A | 100% | 2009-05-29 | 2010-03-19 | 212d? | finish no earlier than 2010-03-19 | C1 | 1688h | 1688h | IMS_SCC-ICS | 23 | Nokia Siemens Networks | Peter.Leis@nsn.com | Rel-9 | 44 | Frederic |  |  |  |
| 7032 | 2339.4 | Stage 3 - IMS Centralized Services support via I1 interface | 271d? | 2009-03-06 A | 2010-03-19 A | 100% | 2009-03-06 | 2010-03-19 | 271d? | finish no earlier than 2010-03-19 | C1 | 2168h | 2168h | IMS_SCC-ICS_I1 | 22 | Huawei | Lili Yang(kadyyang@huawei.com) | Rel-9 | 43 | Frederic | IMS_SCC-ICS_I1 |  |  |
| 7033 | 2340 | **Service Specific Access Control in EPS** | 1328.12d? | 2008-12-11 A | 2012-06-15 A | 100% | 2008-12-11 | 2012-06-15 | 922d? |  | S1; C1; R5 | 26000h | 26000h | SSAC | 22 | NTT DoCoMo | Frederic Thepot (thepot@docomolab-euro.com) | Rel-9 | 42 | Alain | SSAC |  |  |
| 7034 | 2340.1 | Stage 1 for Service Specific Access Control in EPS | 1d? | 2008-12-11 A | 2008-12-11 A | 100% | 2008-12-11 | 2008-12-11 | 1d? | start no earlier than 2008-12-11 | S1 | 8h | 8h | SSAC | 22 | NTT DoCoMo | Frederic Thepot (thepot@docomolab-euro.com) | Rel-9 | 42 | Alain |  |  |  |
| 7035 | 2340.2 | Stage 3 for Service Specific Access Control in EPS | 212d? | 2009-05-29 A | 2010-03-19 A | 100% | 2009-05-29 | 2010-03-19 | 212d? | finish no earlier than 2010-03-19 | C1 | 1696h | 1696h | SSAC | 23 | NTT DoCoMo | Hideyuki Yamashita (yamashitahi@s1.nttdocomo.co.jp) | Rel-9 | 44 | Frederic |  |  |  |
| 7036 | 2340.3 | Conformance Test Aspects - Service Specific Access Control | 272d? | 2011-06-07 A | 2012-06-15 A | 100% | 2011-06-07 | 2012-06-15 | 272d? | finish no earlier than 2012-06-15 | R5 | 2168h | 2168h | SSAC_UEConTest | 27 | NTT DoCoMo | Takao.Shimizu.rp@nttdocomo.com | Rel-9 | 52 | Ingbert | SSAC_UEConTest | RP-120447 |  |
| 7037 | 2341 | **Support for IMS Emergency Calls over GPRS and EPS** | 5462.38d? | 2000-01-03 A | 2014-06-13 A | 100% | 2000-01-03 | 2014-06-13 | 3785d? |  | S1; S2; S3; C1; C3; C4; R2; R3; R5; IETF | 293512h | 293512h | IMS_EMER_GPRS_EPS | 21 | Alcatel-Lucent | Deborah Barclay | Rel-9 | 38 | Maurice | IMS_EMER_GPRS_EPS |  | Public Safety (I-A) |
| 7038 | 2341.1 | Stage 1 for IMS Emergency Calls over GPRS and EPS | 239d? | 2008-01-14 A | 2008-12-11 A | 100% | 2008-01-14 | 2008-12-11 | 239d? | finish no earlier than 2008-12-11 | S1 | 1912h | 1912h | IMS_EMER_GPRS_EPS | 21 | Alcatel-Lucent | Deborah Barclay | Rel-9 | 38 | Alain |  |  | Public Safety (I-A) |
| 7039 | 2341.2 | Stage 2 for IMS Emergency Calls over GPRS and EPS | 364d? | 2008-01-14 A | 2009-06-04 A | 100% | 2008-01-14 | 2009-06-04 | 364d? | finish no earlier than 2009-06-04 | S2 | 2912h | 2912h | IMS_EMER_GPRS_EPS | 21 | Alcatel-Lucent | Deborah Barclay | Rel-9 | 38 | Maurice |  |  | Public Safety (I-A) |
| 7040 | 2341.3 | Security aspects for IMS Emergency Calls over GPRS and EPS | 391d? | 2008-12-12 A | 2010-06-10 A | 100% | 2008-12-12 | 2010-06-10 | 391d? | finish no earlier than 2010-03-25 | S3 | 3128h | 3128h | IMS_EMER_GPRS_EPS-Sec | 22 | Alcatel-Lucent | Deborah Barclay | Rel-9 | 42 | Mirko | IMS_EMER_GPRS_EPS-Sec |  | Public Safety (I-A) |
| 7041 | 2341.4 | **Stage 3 for IMS Emergency Calls over GPRS and EPS** | 1153.12d? | 2009-05-29 A | 2012-06-15 A | 100% | 2009-05-29 | 2012-06-15 | 801d? |  | C1; C3; C4; R5 | 33331.7h | 33331.7h | IMS_EMER_GPRS_EPS | 23 | Alcatel-Lucent | Frank Alfano (falfano@alcatel-lucent.com) | Rel-9 | 44 | Frederic |  |  | Public Safety (I-A) |
| 7042 | 2341.4.1 | CT1 aspects - Stage 3 for IMS Emergency Calls over GPRS and EPS | 212d? | 2009-05-29 A | 2010-03-19 A | 100% | 2009-05-29 | 2010-03-19 | 212d? | finish no earlier than 2010-03-19 | C1 | 1696h | 1696h | IMS_EMER_GPRS_EPSC1 | 23 | Alcatel-Lucent | Frank Alfano (falfano@alcatel-lucent.com) | Rel-9 | 44 | Frederic |  |  | Public Safety (I-A) |
| 7043 | 2341.4.2 | Conformance Test Aspects - CT1 aspects for IMS Emergency Calls over GPRS and EPS | 532d? | 2010-06-04 A | 2012-06-15 A | 100% | 2010-06-04 | 2012-06-15 | 532d? | finish no earlier than 2012-06-15 | R5 | 4256h | 4256h | IMS_EMER_GPRS_EPS_UEConTest | 25 | Samsung | stoyan.baev@partner.samsung.com | Rel-9 | 48 | Ingbert | IMS_EMER_GPRS_EPS_UEConTest | RP-120445 | Public Safety (I-A) |
| 7044 | 2341.4.3 | CT3 aspects - Stage 3 for IMS Emergency Calls over GPRS and EPS | 82d? | 2009-05-29 A | 2009-09-18 A | 100% | 2009-05-29 | 2009-09-18 | 82d? | start no earlier than 2009-05-29 | C3 | 651.68h | 651.68h | IMS_EMER_GPRS_EPSC3 | 23 | Alcatel-Lucent | Frank Alfano (falfano@alcatel-lucent.com) | Rel-9 | 44 | Adrian |  |  | Public Safety (I-A) |
| 7045 | 2341.4.4 | CT4 aspects - Stage 3 for IMS Emergency Calls over GPRS and EPS | 137d? | 2009-05-29 A | 2009-12-04 A | 100% | 2009-05-29 | 2009-12-04 | 137d? | finish no earlier than 2009-12-04 | C4 | 1096h | 1096h | IMS_EMER_GPRS_EPSC4 | 23 | Alcatel-Lucent | Frank Alfano (falfano@alcatel-lucent.com) | Rel-9 | 44 | Kimmo |  |  | Public Safety (I-A) |
| 7046 | 2341.5 | Support for IMS Emergency Calls over LTE | 207d? | 2000-01-03 A | 2000-10-16 A | 100% | 2000-01-03 | 2000-10-16 | 207d? |  | R2; R3 | 3312h | 3312h | IMS_EMER_LTE | 22 | Alcatel-Lucent | Sudeep Palat (spalat@alcatel-lucent.com) | Rel-9 | 42 | Yong-Jun | IMS_EMER_LTE | RP-090698 | Public Safety (I-A) |
| 7047 | 2341.6 | Conformance Test Aspects – Support for IMS Emergency Calls over LTE | 187d? | 2010-03-25 A | 2010-12-10 A | 100% | 2010-03-25 | 2010-12-10 | 187d? | finish no earlier than 2010-12-10 | R5 | 1496h | 1496h | IMS_EMER_LTE_UEConTest | 24 | Ericsson | leif.mattisson@ericsson.com | Rel-9 | 47 | Ingbert | IMS_EMER_LTE_UEConTest | RP-101068 | Public Safety (I-A) |

Notes:
- 7024: CP#47 completed
- 7025: SP#42 completed / Impacted TSs and TRs: 22.101; 22.228
- 7026: -
- 7027: SP#57 Removal of the MSC server assisted mid-call feature from Rel-9 by 23.237CR#0433 (CT1 proposed moving this feature to Rel-10). SP#44 completed. TR 23.838 for Approval / Impacted TSs and TRs: 23.237; 23.292; 23.216; new 23.838
- 7028: CP#47 completed / Impacted TSs and TRs: 24.216; 24.229; 24.237
- 7029: -
- 7030: SP#44 completed. TR 23.883 for Information + Approval / Impacted TSs and TRs: 23.292; new 23.883
- 7031: CP#47 completed / Impacted TSs and TRs: 24.292; 24.604; 24.607; 24.608; 24.611; 24.623
- 7032: CP#47 completed / Impacted TSs and TRs: 24.237; 24.292; new 24.294
- 7033: CP#47 completed. Triggered by TR 22.986 Study on Service Specific Access Control in EPS. As EPS is a PS-Domain only system, Domain Specific Access Control (DSAC) doesn't apply, hence SSAC allows restriction of voice and non-voice calls separately
- 7034: SP#42 completed. If UE supports E-UTRA and IMS, SSAC is a mandatory Rel-9 function (during congestion in emergency case earthquake/tsunami improves mobile communications). / Impacted TSs and TRs: 22.011 CR0136
- 7035: CP#47 completed / Impacted TSs and TRs: 24.173; 27.007
- 7036: RP#56 completed. Testing for Stage 3 for Service Specific Access Control in EPS (24.173, 27.007) UID_440040 / Impacted TSs and TRs: 34.229-1; 34.229-2; 34.229-3
- 7037: RP#56 completed testing. CP#47 completed. SP#48 completed / Impacted TSs and TRs: GERAN; LTE
- 7038: SP#42 completed / Impacted TSs and TRs: 22.101
- 7039: SP#44 completed / Impacted TSs and TRs: 23.869; 23.060; 23.167; 23.203; 23.221; 23.228; 23.271; 23.401; 23.402
- 7040: SP#48 completed / Impacted TSs and TRs: 33.401; 33.402
- 7041: RP#56 completed testing. CP#47 completed / Impacted TSs and TRs: GERAN; LTE
- 7042: CP#47 completed / Impacted TSs and TRs: 23.122; 24.008; 24.229; 24.301; 24.302
- 7043: RP#56 completed / Impacted TSs and TRs: 34.108; 34.123-1; 34.123-2; 34.123-3; 34.229-1; 34.229-2; 34.229-3; 36.508; 36.523-1; 36.523-2; 36.523-3
- 7044: CP#45 completed / Impacted TSs and TRs: 29.212; 29.213; 29.214; 29.215
- 7045: CP#46 completed / Impacted TSs and TRs: 23.003; 23.008; 29.060; 29.272; 29.273; 29.274; 29.275; 29.276
- 7046: RP#45 completed / Impacted TSs and TRs: 36.331; 36.413
- 7047: RP#50 completed / Impacted TSs and TRs: 36.508; 36.523-1; 36.523-2; 36.523-3

| ID | WBS | Task | Type | Duration | Start | Finish | Complete | Baseline start | Baseline finish | Baseline duration | Constraint | Resources | Work | Actual work | Acronym | PCG approved | WI rapporteur name | WI rapporteur e-mail | Release | TSG approved | MCC resp | Special Focus Doc | Acronym_3GU_Export | Status Report |
| --- | --- | --- | --- | --- | --- | --- | --- | --- | --- | --- | --- | --- | --- | --- | --- | --- | --- | --- | --- | --- | --- | --- | --- | --- |
| 7048 | 2341.7 | **Single Radio Voice Call Continuity (SRVCC) support for IMS Emergency Calls** |  | 2168d? | 2008-09-18 A | 2014-06-13 A | 100% | 2008-09-18 | 2014-06-13 | 1511d? |  | S2; C1; C4; C3; IETF | 112300h | 112300h | IMS_EMER_GPRS_EPS-SRVCC | 21 | China Mobile | Yu Qing (Yuqing@chinamobile.com) | Rel-9 | 41 | Maurice | Public Safety (I-A) | IMS_EMER_GPRS_EPS-SRVCC |  |
| 7049 | 2341.7.1 | SRVCC support for IMS Emergency Calls |  | 322d? | 2008-09-18 A | 2009-12-10 A | 100% | 2008-09-18 | 2009-12-10 | 322d? | finish no earlier than 2009-12-10 | S2 | 2576h | 2576h | IMS_EMER_GPRS_EPS-SRVCC | 21 | China Mobile | Yu Qing (Yuqing@chinamobile.com) | Rel-9 | 41 | Maurice | Public Safety (I-A) |  |  |
| 7050 | 2341.7.2 | **CT aspects of SRVCC support for IMS Emergency Calls** |  | 1906d? | 2009-05-29 A | 2014-06-13 A | 100% | 2009-05-29 | 2014-06-13 | 1330d? |  | C1; C4; C3; IETF | 49284h | 49284h | IMS_EMER_GPRS_EPS-SRVCC | 24 | China Mobile | jiangyi@chinamobile.com | Rel-9 | 46 | Frederic | Public Safety (I-A) |  |  |
| 7051 | 2341.7.2.1 | CT1 aspects of SRVCC support for IMS Emergency Calls |  | 137d? | 2009-05-29 A | 2009-12-04 A | 100% | 2009-05-29 | 2009-12-04 | 137d? | finish no earlier than 2009-12-04 | C1 | 1096h | 1096h | IMS_EMER_GPRS_EPS-SRVCC | 23 | China Mobile | jiangyi@chinamobile.com | Rel-9 | 44 | Frederic | Public Safety (I-A) |  |  |
| 7052 | 2341.7.2.2 | CT4 aspects of SRVCC support for IMS Emergency Calls |  | 137d? | 2009-05-29 A | 2009-12-04 A | 100% | 2009-05-29 | 2009-12-04 | 137d? | finish no earlier than 2009-12-04 | C4 | 1096h | 1096h | IMS_EMER_GPRS_EPS-SRVCC | 23 | China Mobile | jiangyi@chinamobile.com | Rel-9 | 44 | Kimmo | Public Safety (I-A) |  |  |
| 7053 | 2341.7.2.3 | CT3 aspects of SRVCC support for IMS Emergency Calls |  | 1d? | 2009-12-04 A | 2009-12-04 A | 100% | 2009-12-04 | 2009-12-04 | 1d? | finish no earlier than 2009-12-04 | C3 | 8h | 8h | IMS_EMER_GPRS_EPS-SRVCC | 24 | China Mobile | jiangyi@chinamobile.com | Rel-9 | 46 | Kimmo | Public Safety (I-A) |  |  |
| 7054 | 2341.7.2.4 | (IETF) CT3 aspects of SRVCC support for IMS Emergency Calls (RFC 7254) |  | 568d? | 2012-04-20 A | 2014-06-13 A | 100% | 2012-04-20 | 2014-06-13 | 568d? | finish no earlier than 2014-06-13 | C3-IETF | 4524h | 4524h | IMS_EMER_GPRS_EPS-SRVCC | 29 | Andrew Allen | Andrew Allen | Rel-9 | 56 | Adrian | Public Safety (I-A) |  |  |
| 7055 | 2342 | **LCS for LTE and EPS** |  | 1415.25d? | 2008-06-05 A | 2012-03-02 A | 100% | 2008-06-05 | 2012-03-02 | 981d? |  | S2; C1; C4; R2; R1; R3; R4; R5 | 83592h | 83592h | LCS_LTE_EPS | 22 |  |  | Rel-9 | 43 | Maurice | Public Safety (I-A) | LCS_LTE_EPS |  |
| 7056 | 2342.1 | **LCS Control Plane Solution for EPS** |  | 676.12d? | 2008-06-05 A | 2010-03-19 A | 100% | 2008-06-05 | 2010-03-19 | 468d? |  | S2; C4; C1 | 16712h | 16712h | LCS_EPS-CPS | 21 | Polaris Wireless | Robert Gross (rgross@polariswireless.com) | Rel-9 | 40 | Maurice | Public Safety (I-A) | LCS_EPS-CPS |  |
| 7057 | 2342.1.1 | Stage 2 for LCS Control Plane Solution for EPS |  | 261d? | 2008-06-05 A | 2009-06-04 A | 100% | 2008-06-05 | 2009-06-04 | 261d? | finish no earlier than 2009-06-04 | S2 | 2088h | 2088h | LCS_EPS-CPS | 21 | Polaris Wireless | Robert Gross (rgross@polariswireless.com) | Rel-9 | 40 | Maurice | Public Safety (I-A) |  |  |
| 7058 | 2342.1.2 | CT4 aspects of Control Plane LCS in the EPC |  | 212d? | 2009-05-29 A | 2010-03-19 A | 100% | 2009-05-29 | 2010-03-19 | 212d? | finish no earlier than 2010-03-19 | C4 | 1696h | 1696h | LCS_EPS-CPS | 23 | Polaris Wireless | Robert Gross (rgross@polariswireless.com) | Rel-9 | 44 | Kimmo | Public Safety (I-A) |  |  |
| 7059 | 2342.1.3 | CT1 aspects of Control Plane LCS in the EPC |  | 212d? | 2009-05-29 A | 2010-03-19 A | 100% | 2009-05-29 | 2010-03-19 | 212d? | finish no earlier than 2010-03-19 | C1 | 1696h | 1696h | LCS_EPS-CPS | 23 | Polaris Wireless | Robert Gross (rgross@polariswireless.com) | Rel-9 | 44 | Frederic | Public Safety (I-A) |  |  |
| 7060 | 2342.2 | Positioning Support for LTE | milestone | 0d? | 2008-12-05 A | 2008-12-05 A | 100% | 2008-12-05 | 2010-06-04 | 392d? | finish no earlier than 2010-06-04 | R2; R1; R3; R4 |  |  | LCS_LTE | 22 | Qualcomm | Nathan Tenny (ntenny@qualcomm.com) | Rel-9 | 42 | Yong-Jun | Public Safety (I-A) | LCS_LTE | RP-100442 |
| 7061 | 2342.3 | Conformance Test Aspects – Positioning Support for LTE |  | 512d? | 2010-03-19 A | 2012-03-02 A | 100% | 2010-03-19 | 2012-03-02 | 512d? | finish no earlier than 2012-03-02 | R5 | 4096h | 4096h | LCS_LTE_UEConTest | 24 | Qualcomm | Shubhang Vora (svoral@qualcomm.com) | Rel-9 | 47 | Ingbert | Public Safety (I-A) | LCS_LTE_UEConTest | RP-120034 |
| 7062 | 2343 | **MBMS support in EPS** |  | 1328.25d? | 2008-06-05 A | 2011-12-09 A | 100% | 2008-06-05 | 2011-12-09 | 921d? |  | S2; S3; S5; C3; C4; R2; R3; R4; R5 | 82896h | 82896h | MBMS_EPS | 21 | China Mobile | Liu Hong (liuhongyfw@chinamobile.com) | Rel-9 | 40 | Maurice |  | MBMS_EPS |  |
| 7063 | 2343.1 | Stage 2 for MBMS support in EPS |  | 261d? | 2008-06-05 A | 2009-06-04 A | 100% | 2008-06-05 | 2009-06-04 | 261d? | finish no earlier than 2009-06-04 | S2 | 2088h | 2088h | MBMS_EPS | 21 | China Mobile | Liu Hong (liuhongyfw@chinamobile.com) | Rel-9 | 40 | Maurice |  |  |  |
| 7064 | 2343.2 | Security for MBMS support in EPS |  | 261d? | 2008-12-11 A | 2009-12-10 A | 100% | 2008-12-11 | 2009-12-10 | 261d? | finish no earlier than 2009-12-10 | S3 | 2088h | 2088h | MBMS_EPS | 22 | China Mobile | Liu Hong (liuhongyfw@chinamobile.com) | Rel-9 | 42 | Mirko |  |  |  |
| 7065 | 2343.3 | MBMS Charging in EPS |  | 201d? | 2009-03-06 A | 2009-12-10 A | 100% | 2009-03-06 | 2009-12-10 | 201d? | finish no earlier than 2009-12-10 | S5 | 1600h | 1600h | MBMS_EPS | 22 | ZTE | guo.wenjie1@zte.com.cn | Rel-9 | 43 | Mirko |  |  |  |
| 7066 | 2343.4 | CT4 aspects of MBMS support in EPS (Stage 3) |  | 137d? | 2009-05-29 A | 2009-12-04 A | 100% | 2009-05-29 | 2009-12-04 | 137d? | finish no earlier than 2009-12-04 | C4 | 1096h | 1096h | MBMS_EPS | 23 | China Mobile, ZTE | wangjingyf@chinamobile.com, lu.fei1@zte.com.cn | Rel-9 | 44 | Kimmo |  |  |  |
| 7067 | 2343.5 | CT3 aspects of MBMS support in EPS (Stage 3) |  | 137d? | 2009-05-29 A | 2009-12-04 A | 100% | 2009-05-29 | 2009-12-04 | 137d? | start no earlier than 2009-05-29 | C3 | 1096h | 1096h | MBMS_EPS | 23 | ZTE, China Mobile | zhou.xiaoyun@zte.com.cn, wangjingyf@chinamobile.com | Rel-9 | 44 | Adrian |  |  |  |
| 7068 | 2343.6 | MBMS support in LTE |  | 272d? | 2009-03-06 A | 2010-03-19 A | 100% | 2009-03-06 | 2010-03-19 | 272d? | finish no earlier than 2010-03-19 | R2; R3; R4 | 6528h | 6528h | MBMS_LTE | 22 | Huawei | arnaud.meylan@huawei.com | Rel-9 | 43 | Yong-Jun |  | MBMS_LTE | RP-100033 |
| 7069 | 2343.7 | Conformance Test Aspects – MBMS support in LTE |  | 262d? | 2010-12-10 A | 2011-12-09 A | 100% | 2010-12-10 | 2011-12-09 | 262d? | finish no earlier than 2011-12-09 | R5 | 2088h | 2088h | MBMS_LTE-UEConTest | 26 | Huawei | Zhang Xin (zhangxin0208@huawei.com) | Rel-9 | 50 | Ingbert |  | MBMS_LTE-UEConTest | RP-111437 |
| 7070 | 2344 | **Access Network Discovery and Selection Function enhancements** |  | 480.38d? | 2008-12-11 A | 2010-03-19 A | 100% | 2008-12-11 | 2010-03-19 | 333d? |  | S2; C1 | 7384h | 7384h | eANDSF | 22 | Motorola | Apostolis Salkintzis (salki@motorola.com) | Rel-9 | 42 | Maurice |  | eANDSF |  |
| 7071 | 2344.1 | Stage 2 for Access Network Discovery and Selection Function enhancements |  | 126d? | 2008-12-11 A | 2009-06-04 A | 100% | 2008-12-11 | 2009-06-04 | 126d? | finish no earlier than 2009-06-04 | S2 | 1008h | 1008h | eANDSF | 22 | Motorola | Apostolis Salkintzis (salki@motorola.com) | Rel-9 | 42 | Maurice |  |  |  |
| 7072 | 2344.2 | CT1 aspects of Access Network Discovery and Selection Function enhancements |  | 131d? | 2009-09-18 A | 2010-03-19 A | 100% | 2009-09-18 | 2010-03-19 | 131d? | finish no earlier than 2010-03-19 | C1 | 1048h | 1048h | eANDSF | 23 | Panasonic | benjamin.limck@sg.panasonic.com | Rel-9 | 45 | Frederic |  |  |  |

Notes:
- 7048: CP#56 added IETF dependency
- 7049: SP#46 completed / Impacted TSs and TRs: 23.870; 23.216; 23.237
- 7050: CP#46 completed
- 7051: CP#46 completed / Impacted TSs and TRs: 24.229; 24.237
- 7052: CP#46 completed / Impacted TSs and TRs: 29.205; 29.280
- 7053: CP#46 completed / Impacted TSs and TRs: 29.163
- 7054: CP#64 completed / Impacted TSs and TRs: RFC 7254 (was draft-montemurro-gsma-imei-urn)
- 7055: - / Impacted TSs and TRs: LTE
- 7056: Triggered by abandoned Study UID_380068 (FS_LCS_EPS). Linked to Feature UID_380064 Support for IMS Emergency Calls over GPRS and EPS
- 7057: SP#44 completed / Impacted TSs and TRs: 23.891; 23.271; 23.401; 23.402
- 7058: CP#47 completed (IANA registrations outstanding). Stage 3 SLs and SLg interfaces & transport of positioning messages between E-SMLC and MME in the scope of UID_420006 (Positioning Support for LTE) / Impacted TSs and TRs: 24.080; 29.002; 29.272; 29.230; new 24.171; 29.171; 29.172; 29.173
- 7059: CP#47 completed / Impacted TSs and TRs: 24.301
- 7060: RP#48 completed. UID_400038 (LCS Control Plane Solution for EPS) depends on this WI / Impacted TSs and TRs: 34.213; 36.133; 36.211; 36.214; 36.300; 36.305; 36.331; 36.355; 36.410; 36.413; 36.455; new 36.171
- 7061: RP#55 completed. RP#56 TS 37.571-4 v200 for Approval / Impacted TSs and TRs: 36.508; 36.509; new (37.571-1; 37.571-2; 37.571-3; 37.571-4; 37.571-5)
- 7062: RP#47 completed. SP#46, CP#46 completed / Impacted TSs and TRs: LTE
- 7063: SP#44 completed / Impacted TSs and TRs: 23.246
- 7064: SP#46 completed / Impacted TSs and TRs: 33.246
- 7065: SP#46 completed / Impacted TSs and TRs: 32.273; 32.251; 32.298; 32.299
- 7066: CP#46 completed / Impacted TSs and TRs: 29.274; 29.281; 23.007; 23.008
- 7067: CP#46 completed / Impacted TSs and TRs: 29.061
- 7068: RP#47 completed / Impacted TSs and TRs: 25.446; 36.101; 36.104; 36.141; 36.300; 36.304; 36.321; 36.322; 36.323; 36.331; 36.440; 36.441; 36.442; 36.444; 36.445
- 7069: RP#54 completed / Impacted TSs and TRs: 36.508; 36.521-1; 36.521-2; 36.523-1; 36.523-2; 36.523-3
- 7070: CP#47 completed. No new Rel-9 use cases defined. Implement service requirements not covered in Rel-8 / Impacted TSs and TRs: 22.278; SA3 33.402 CR#0055
- 7071: SP#44 completed / Impacted TSs and TRs: 23.402; 23.002
- 7072: CP#47 completed / Impacted TSs and TRs: 24.302; 24.312

| ID | WBS | Task | Duration | Start | Finish | Complete | Baseline start | Baseline finish | Baseline duration | Constraint | Resources | Work | Actual work | Acronym | PCG approved | WI rapporteur name | WI rapporteur e-mail | Release | TSG approved | MCC resp | Acronym_3GU_Export | Impacted TSs and TRs | Status Report |
| --- | --- | --- | --- | --- | --- | --- | --- | --- | --- | --- | --- | --- | --- | --- | --- | --- | --- | --- | --- | --- | --- | --- | --- |
| 7073 | 2345 | **Multiple PDN Connection to the Same APN for PMIP-based Interfaces** | 385.12d? | 2009-03-13 A | 2010-03-19 A | 100% | 2009-03-13 | 2010-03-19 | 267d? |  | S2; C4; C1 | 8392h | 8392h | MUPSAP | 22 | Samsung | erik.guttman@partner.samsung.com | Rel-9 | 43 | Maurice | MUPSAP |  |  |
| 7074 | 2345.1 | Stage 2 for Multiple PDN Connection to the Same APN for PMIP-based Interfaces | 61d? | 2009-03-13 A | 2009-06-04 A | 100% | 2009-03-13 | 2009-06-04 | 61d? | finish no earlier than 2009-06-04 | S2 | 488h | 488h | MUPSAP | 22 | Samsung | erik.guttman@partner.samsung.com | Rel-9 | 43 | Maurice |  | 23.060; 23.203; 23.401; 23.402 |  |
| 7075 | 2345.2 | CT4 aspects of Multiple PDN Connection to the Same APN for PMIP-based Interfaces | 56d? | 2009-09-18 A | 2009-12-04 A | 100% | 2009-09-18 | 2009-12-04 | 56d? | finish no earlier than 2009-12-04 | C4 | 448h | 448h | MUPSAP | 23 | Samsung | Surjyakanta Mohapatra (surjya.kanta@samsung.com) | Rel-9 | 45 | Kimmo |  | 29.275; 23.008; 29.282 |  |
| 7076 | 2345.3 | CT1 aspects of Multiple PDN Connection to the Same APN for PMIP-based Interfaces | 131d? | 2009-09-18 A | 2010-03-19 A | 100% | 2009-09-18 | 2010-03-19 | 131d? | finish no earlier than 2010-03-19 | C1 | 1048h | 1048h | MUPSAP | 23 | Samsung | Surjyakanta Mohapatra (surjya.kanta@samsung.com) | Rel-9 | 45 | Frederic |  | 24.302 |  |
| 7077 | 2346 | **System aspects of vocoder rate adaptation for LTE** | 2024.68d? | 2007-05-07 A | 2012-09-12 A | 100% | 2007-05-07 | 2012-09-12 | 1403.68d? |  | S2; S4; C1; C3; R2; IETF | 108798h | 108798h | LTEimp-Vocoder | 23 | Qualcomm | AC Mahendran (ac@qualcomm.com) | Rel-9 | 45 | Maurice | LTEimp-Vocoder | LTE |  |
| 7078 | 2346.1 | SA2 system aspects of vocoder rate adaptation for LTE | 81d? | 2009-06-04 A | 2009-09-24 A | 100% | 2009-06-04 | 2009-09-24 | 81d? | start no earlier than 2009-06-04 | S2 | 648h | 648h | LTEimp-Vocoder | 23 | Qualcomm | AC Mahendran (ac@qualcomm.com) | Rel-9 | 45 | Maurice |  | 23.401 CR#1103r3 |  |
| 7079 | 2346.2 | SA4 system aspects of vocoder rate adaptation for LTE | 136d? | 2009-06-04 A | 2009-12-10 A | 100% | 2009-06-04 | 2009-12-10 | 136d? | finish no earlier than 2009-12-07 | S4 | 1088h | 1088h | LTEimp-Vocoder | 23 | Qualcomm | Nikolai Leung | Rel-9 | 45 | Paolo |  | 26.114 |  |
| 7080 | 2346.3 | Vocoder rate adaptation for LTE | 115.88d? | 2009-05-30 A | 2009-09-18 A | 100% | 2009-05-30 | 2009-09-18 | 81d? | finish no earlier than 2009-09-18 | R2 | 648h | 648h | LTEimp-Vocoder | 23 | Alcatel-Lucent | Sudeep Palat (spalat@alcatel-lucent.com) | Rel-9 | 44 | Yong-Jun |  | 36.300 CR#0114 | RP-090704 |
| 7081 | 2346.4 | (IETF) SA4 system aspects of vocoder rate adaptation for LTE | 677.6d? | 2009-06-04 A | 2012-09-12 A | 100% | 2009-06-04 | 2012-09-12 | 677.6d? | finish no earlier than 2012-09-14 | S4-IETF | 5420.8h | 5420.8h | LTEimp-Vocoder | 27 | Lionel Morand |  | Rel-9 | 52 | Paolo |  | RFC 6679 (was draft-ietf-avtcore-ecn-for-rtp) |  |
| 7082 | 2346.5 | (IETF) CT aspects of vocoder rate adaptation for LTE | 1400.68d? | 2007-05-07 A | 2012-09-07 A | 100% | 2007-05-07 | 2012-09-07 | 1400.68d? | finish no earlier than 2012-09-07 | C1-IETF; C3-IETF; C4-IETF | 33616.3h | 33616.3h | LTEimp-Vocoder | 27 | Lionel Morand |  | Rel-9 | 52 | Frederic |  | RFC 6679 (was draft-ietf-avtcore-ecn-for-rtp) |  |
| 7083 | 2347 | Access Security Enhancements | 505d? | 2007-07-02 A | 2009-06-04 A | 100% | 2007-07-02 | 2009-06-04 | 505d? | finish no earlier than 2009-06-03 | S3 | 4040h | 4040h | ACCSEC2 | 17 | Ericsson | Bengt.Sahlin@ericsson.com | Rel-9 | 33 | Mirko | ACCSEC2 | 33.102; 43.020 |  |
| 7084 | 2348 | **Protection against Unsolicited Communication for IMS (PUCI)** | 464.88d? | 2008-09-18 A | 2009-12-10 A | 100% | 2008-09-18 | 2009-12-10 | 322d? |  | S3; S1 | 8216h | 8216h | PUCI | 21 | NEC | Anand R. Prasad (anand@bq.jp.nec.com) | Rel-9 | 41 | Alain | PUCI |  |  |
| 7085 | 2348.1 | Stage 1 for PUCI | 61d? | 2008-09-18 A | 2008-12-11 A | 100% | 2008-09-18 | 2008-12-11 | 61d? | finish no earlier than 2009-06-18 | S1 | 488h | 488h | PUCI | 21 | NEC | Anand R. Prasad (anand@bq.jp.nec.com) | Rel-9 | 41 | Alain |  | 22.228 |  |
| 7086 | 2348.2 | SA3 work on PUCI | 322d? | 2008-09-18 A | 2009-12-10 A | 100% | 2008-09-18 | 2009-12-10 | 322d? | finish no earlier than 2009-12-10 | S3 | 2576h | 2576h | PUCI | 21 | NEC | Anand R. Prasad (anand@bq.jp.nec.com) | Rel-9 | 41 | Mirko |  | New 33.937 |  |
| 7087 | 2349 | **IMS Media Plane Security** | 3987.75d? | 2002-03-01 A | 2012-09-14 A | 100% | 2009-03-13 | 2012-09-14 | 922d? |  | S3; C1; C4; C3; IETF | 89984h | 89984h | MEDIASEC | 22 | Vodafone | Peter.Howard@vodafone.com | Rel-9 | 43 | Mirko | MEDIASEC |  |  |
| 7088 | 2349.1 | SA3 aspects of IMS Media Plane Security | 271d? | 2009-03-13 A | 2010-03-25 A | 100% | 2009-03-13 | 2010-03-25 | 271d? | finish no earlier than 2010-03-25 | S3 | 2168h | 2168h | MEDIASEC | 22 | Vodafone | Peter.Howard@vodafone.com | Rel-9 | 43 | Mirko |  | New 33.828; 33.328 |  |
| 7089 | 2349.2 | (IETF) SA3, CT1, CT3 aspects of IMS Media Plane Security | 919d? | 2009-03-18 A | 2012-09-14 A | 100% | 2009-03-18 | 2012-09-14 | 919d? | finish no earlier than 2012-09-14 | S3-IETF; C1-IETF; C3-IETF | 22056h | 22056h | MEDIASEC | 27 | Peter Dawes |  | Rel-9 | 52 | Mirko |  | draft-dawes-dispatch-mediasec-parameter |  |
| 7090 | 2349.3 | (IETF) Security Considerations for WebRTC (draft-ietf-rtcweb-security) | 2757d? | 2002-03-01 A | 2012-09-14 A | 100% | 2009-03-18 | 2012-09-14 | 919d? | finish no earlier than 2012-09-14 | S3-IETF | 22056h | 22056h | MEDIASEC | 44 |  |  | Rel-9 | 87 | Mirko |  | RFC 8826 |  |
| 7091 | 2349.4 | **CN aspects of IMS Media Plane Security** | 269.25d? | 2009-09-18 A | 2010-06-04 A | 100% | 2009-09-18 | 2010-06-04 | 186d? |  | C1; C4; C3 | 6824h | 6824h | MEDIASEC_CORE | 23 | Vodafone | peter.dawes@vodafone.com | Rel-9 | 45 | Frederic | MEDIASEC_CORE |  |  |
| 7092 | 2349.4.1 | CT1 aspects of IMS Media Plane Security | 33d? | 2009-09-18 A | 2010-03-19 A | 100% | 2009-09-18 | 2010-03-19 | 33d? | finish no earlier than 2010-03-19 | C1 | 264h | 264h | MEDIASEC_CORE | 23 | Vodafone | peter.dawes@vodafone.com | Rel-9 | 45 | Frederic |  | 23.218; 24.229 |  |
| 7093 | 2349.4.2 | CT4 aspects of IMS Media Plane Security | 131d? | 2009-09-18 A | 2010-03-19 A | 100% | 2009-09-18 | 2010-03-19 | 131d? | finish no earlier than 2010-03-19 | C4 | 1048h | 1048h | MEDIASEC_CORE | 23 | Vodafone | peter.dawes@vodafone.com | Rel-9 | 45 | Kimmo |  | 29.238; 23.334; 29.334 |  |
| 7094 | 2349.4.3 | CT3 aspects of IMS Media Plane Security | 131d? | 2009-12-04 A | 2010-06-04 A | 100% | 2009-12-04 | 2010-06-04 | 131d? | finish no earlier than 2010-06-04 | C3 | 1048h | 1048h | MEDIASEC_CORE | 24 | Vodafone | peter.dawes@vodafone.com | Rel-9 | 46 | Adrian |  | 29.162 |  |
| 7095 | 2350 | **GBAPush enhancements (Generic push layer)** | 770.38d? | 2008-03-12 A | 2010-03-25 A | 100% | 2008-03-12 | 2010-03-25 | 533d? |  | S3 | 8528h | 8528h | eGBAPush | 23 | Ericsson | Rolf Blom | Rel-9 | 44 | Mirko | eGBAPush | New 33.224 |  |
| 7096 | 2350.1 | SA3 part of eGBAPush (Generic push layer) | 533d? | 2008-03-12 A | 2010-03-25 A | 100% | 2008-03-12 | 2010-03-25 | 533d? | finish no earlier than 2010-03-25 | S3 | 4264h | 4264h | eGBAPush | 21 | Ericsson | Rolf Blom | Rel-9 | 39 | Mirko |  | New 33.224 |  |
| 7097 | 2351 | Extended Identity Management | 136d? | 2009-06-04 A | 2009-12-10 A | 100% | 2009-06-04 | 2009-12-10 | 136d? | finish no earlier than 2009-12-10 | S3 | 1088h | 1088h | GBA-IdM | 23 | Nokia | Silke.Holtmanns@nokia.com | Rel-9 | 44 | Mirko | GBA-IdM | New 33.924; CT4 29.109 (added service code) |  |

Notes:
- 7073: CP#47 completed. Continues Rel-8 SAES Stage 2 UID_320005. Stage 1 in 22.278 (EPS Service requirements)
- 7074: SP#44 completed
- 7075: CP#46 completed
- 7076: CP#47 completed
- 7077: Triggered by RAN2 UID_440013 Vocoder rate adaptation for LTE
- 7078: SP#45 completed (CR adding support for Explicit Congestion Notification)
- 7079: SP#46 completed
- 7080: RP#45 completed
- 7081: SP#57 completed
- 7082: CP#57 completed
- 7083: SP#44 completed. Stopped TR 33.801. CRs 33.102,43.020 on A5/2 removal done long time ago. A5/4 introduction CRs will be done under UID_440057 128 bit encryption for GSM and GPRS. SP#26 approved WID (improved GERAN security)
- 7084: SP#46 TR 33.937 completed but no specification work done in Rel-9. Related work in OMA Categorization Based Content Screening
- 7085: SP#42 completed
- 7086: SP#46 completed. No normative work done in Rel-9
- 7087: -
- 7088: SP#47 completed
- 7089: CP#57 completed, ietf-draft discontinued, documented within 3GPP
- 7090: 9/4/21: RFC 8826 added;
- 7091: CP#48 completed
- 7092: CP#47 completed
- 7093: CP#47 completed
- 7094: CP#48 completed
- 7095: SP#43 umbrella to host 33.224, moved from Rel-8 to Rel-9. SP#47 completed
- 7096: SP#47 completed
- 7097: SP#46 completed. Stage 1 not identified (GBA Liberty Interworking has been outlined and GBAOpenID interworking is analogous)

| ID | WBS | Task | Duration | Start | Finish | Complete | Baseline start | Baseline finish | Baseline duration | Constraint | Resources | Work | Actual work | Acronym | PCG approved | WI rapporteur name | Release | TSG approved | MCC resp | Acronym_3GU_Export | PCG stopped | TSG stopped |
| --- | --- | --- | --- | --- | --- | --- | --- | --- | --- | --- | --- | --- | --- | --- | --- | --- | --- | --- | --- | --- | --- | --- |
| 7098 | 2352 | **Network Domain Security (NDS) enhancements to support backhaul security** | 1327.88d? | 2009-06-04 A | 2012-12-07 A | 100% | 2009-06-04 | 2012-12-07 | 924d? |  | S3; IETF | 23452.8h | 23452.8h | NDS_Backhaul | 23 | Vodafone | Rel-9 | 44 | Mirko | NDS_Backhaul |  |  |
| 7099 | 2352.1 | SA3 part of Network Domain Security (NDS) enhancements to support backhaul security | 211d? | 2009-06-04 A | 2010-03-25 A | 100% | 2009-06-04 | 2010-03-25 | 211d? | finish no earlier than 2010-03-25 | S3 | 1688h | 1688h | NDS_Backhaul | 23 | Vodafone | Rel-9 | 44 | Mirko |  |  |  |
| 7100 | 2352.2 | (IETF) SA3 part of Network Domain Security (NDS) enhancements to support backhaul security | 740.6d? | 2009-06-04 A | 2012-12-07 A | 100% | 2009-06-04 | 2012-12-07 | 740.6d? | finish no earlier than 2012-12-07 | S3-IETF | 5924.8h | 5924.8h | NDS_Backhaul | 27 | Bengt Sahlin | Rel-9 | 52 | Mirko |  |  |  |
| 7101 | 2352.3 | Deleted - CT4 part of Network Domain Security (NDS) enhancements to support backhaul security | 132d? | 2009-06-04 A | 2009-12-04 A | 100% | 2009-06-04 | 2009-12-04 | 132d? | finish no earlier than 2009-12-04 | C4 | 1056h | 1056h | NDS_Backhaul | 23 | Vodafone | Rel-9 | 44 | Kimmo |  | PCG-24 | CP-46 |
| 7102 | 2353 | **128 bit encryption for GSM and GPRS** | 196.75d? | 2009-06-04 A | 2009-12-10 A | 100% | 2009-06-04 | 2009-12-10 | 136d? |  | S3; C1; C4; G2; G3new | 10392h | 10392h | A5/4-GEA4 | 23 | Ericsson | Rel-9 | 44 | Mirko | A5/4-GEA4 |  |  |
| 7103 | 2353.1 | SA3 part of 128 bit encryption for GSM and GPRS | 136d? | 2009-06-04 A | 2009-12-10 A | 100% | 2009-06-04 | 2009-12-10 | 136d? | finish no earlier than 2010-01-06 | S3 | 1088h | 1088h | A5/4-GEA4 | 23 | Ericsson | Rel-9 | 44 | Mirko |  |  |  |
| 7104 | 2353.2 | CT1 part of 128 bit encryption for GSM and GPRS | 77d? | 2009-06-04 A | 2009-09-18 A | 100% | 2009-06-04 | 2009-09-18 | 77d? | start no earlier than 2009-06-04 | C1 | 616h | 616h | A5/4-GEA4 | 23 | Ericsson | Rel-9 | 44 | Frederic |  |  |  |
| 7105 | 2353.3 | CT4 part of 128 bit encryption for GSM and GPRS | 136d? | 2009-06-04 A | 2009-12-10 A | 100% | 2009-06-04 | 2009-12-10 | 136d? | start no earlier than 2009-06-04 | C4 | 1088h | 1088h | A5/4-GEA4 | 23 | Ericsson | Rel-9 | 44 | Kimmo |  |  |  |
| 7106 | 2353.4 | GERAN2 part of 128 bit encryption for GSM and GPRS | 67d? | 2009-06-04 A | 2009-09-04 A | 100% | 2009-06-04 | 2009-09-04 | 67d? | finish no earlier than 2009-09-04 | G2 | 536h | 536h | A5/4-GEA4 | 23 | Ericsson | Rel-9 | 44 | Gert |  |  |  |
| 7107 | 2353.5 | GERAN3new (testing) part of 128 bit encryption for GSM and GPRS | 122d? | 2009-06-04 A | 2009-11-20 A | 100% | 2009-06-04 | 2009-11-20 | 122d? | finish no earlier than 2009-11-20 | G3new | 976h | 976h | A5/4-GEA4 | 23 | Ericsson | Rel-9 | 44 | Ingbert |  |  |  |
| 7108 | 2353.6 | Deleted - SA2 part of 128 bit encryption for GSM and GPRS | 81d? | 2009-06-04 A | 2009-09-24 A | 100% | 2009-06-04 | 2009-09-24 | 81d? | finish no earlier than 2009-09-24 | S2 | 648h | 648h | A5/4-GEA4 | 23 | Ericsson | Rel-9 | 44 | Maurice |  | PCG-23 | SP-45 |
| 7109 | 2354 | Timed Graphics | 486.62d? | 2008-12-11 A | 2010-03-25 A | 100% | 2008-12-11 | 2010-03-25 | 337d? | finish no earlier than 2010-03-25 | S4 | 2696h | 2696h | TG | 22 | Ericsson | Rel-9 | 42 | Paolo | TG |  |  |
| 7110 | 2355 | Managing MTSI Media Adaptation | 283.62d? | 2009-03-12 A | 2009-12-10 A | 100% | 2009-03-12 | 2009-12-10 | 197d? | finish no earlier than 2009-12-10 | S4 | 1568h | 1568h | M3A | 22 | Samsung | Rel-9 | 43 | Paolo | M3A |  |  |
| 7111 | 2356 | **PSS and MBMS Aspects** | 392.38d? | 2009-03-12 A | 2010-03-25 A | 100% | 2009-03-12 | 2010-03-25 | 272d? |  | S4 | 6512h | 6512h | PMA | 23 | Ericsson, Nokia | Rel-9 | 44 | Paolo | PMA |  |  |
| 7112 | 2356.1 | PSS and MBMS extensions | 271d? | 2009-03-12 A | 2010-03-25 A | 100% | 2009-03-12 | 2010-03-25 | 271d? | finish no earlier than 2010-03-25 | S4 | 2168h | 2168h | PMA-MBS_Ext | 22 | Ericsson | Rel-9 | 43 | Paolo | PMA-MBS_Ext |  |  |
| 7113 | 2356.2 | Improved Video Support for PSS and MBMS | 271d? | 2009-03-12 A | 2010-03-25 A | 100% | 2009-03-12 | 2010-03-25 | 271d? | finish no earlier than 2010-03-25 | S4 | 2168h | 2168h | PMA-IVS | 22 | Nokia | Rel-9 | 43 | Paolo | PMA-IVS |  |  |
| 7114 | 2357 | IMS based PSS and MBMS User Service extensions | 197d? | 2009-03-12 A | 2009-12-10 A | 100% | 2009-03-12 | 2009-12-10 | 197d? | finish no earlier than 2009-12-10 | S4 | 1576h | 1576h | IMS_PSS_MBMS_US_EXT | 22 | Ericsson | Rel-9 | 43 | Paolo | IMS_PSS_MBMS_US_EXT |  |  |
| 7115 | 2358 | Syndicated Feed Reception within 3GPP environments | 136d? | 2009-06-04 A | 2009-12-10 A | 100% | 2009-06-04 | 2009-12-10 | 136d? | start no earlier than 2009-06-04 | S4 | 1088h | 1088h | SFR | 23 | Ericsson | Rel-9 | 44 | Paolo | SFR |  |  |
| 7116 | 2359 | Distortion Measurement Test Methods and Requirements | 131d? | 2009-09-24 A | 2010-03-25 A | 100% | 2009-09-24 | 2010-03-25 | 131d? | finish no earlier than 2010-03-25 | S4 | 1048h | 1048h | DTMR | 23 | Motorola | Rel-9 | 45 | Paolo | DTMR |  |  |
| 7117 | 2360 | **Rel-9 Operations, Administration, Maintenance and Provisioning (OAM&P)** | 869.88d? | 2008-02-22 A | 2010-06-10 A | 100% | 2008-02-22 | 2010-06-10 | 601d? |  | S5 | 36890.4h | 36890.4h | OAM9 | 22 |  | Rel-9 | 42 | Mirko | OAM9 |  |  |
| 7118 | 2360.1 | **Rel-9 Network Infrastructure Management** | 486.62d? | 2008-12-11 A | 2010-03-25 A | 100% | 2008-12-11 | 2010-03-25 | 337d? |  | S5 | 8760h | 8760h | OAM9-NIM | 22 |  | Rel-9 | 42 | Mirko | OAM9-NIM |  |  |
| 7119 | 2360.1.1 | Software Management for Network Elements | 336d? | 2008-12-11 A | 2010-03-25 A | 100% | 2008-12-11 | 2010-03-25 | 336d? | finish no earlier than 2010-03-25 | S5 | 2688h | 2688h | OAM9-NE_SWM | 22 | Huawei, Nokia Siemens Networks | Rel-9 | 42 | Mirko | OAM9-NE_SWM |  |  |
| 7120 | 2360.1.2 | Service Oriented Architecture (SOA) for IRP | 211d? | 2009-06-04 A | 2010-03-25 A | 100% | 2009-06-04 | 2010-03-25 | 211d? | finish no earlier than 2010-03-25 | S5 | 1688h | 1688h |  | 23 | Ericsson, Nokia Siemens Networks | Rel-9 | 44 | Mirko |  |  |  |
| 7121 | 2360.1.3 | IRP SOAP Solution Sets continuation from Rel-8 | 211d? | 2009-06-04 A | 2010-03-25 A | 100% | 2009-06-04 | 2010-03-25 | 211d? | finish no earlier than 2010-03-25 | S5 | 1688h | 1688h |  | 23 | Ericsson | Rel-9 | 44 | Mirko |  |  |  |

Notes:
- 7098: Continuation of Rel-8 UID_390044 SAE security architecture. Covers gaps in backhaul security in SAE (also applicable to UTRAN and GERAN backhaul) / WI rapporteur e-mail: Peter.Howard@vodafone.com
- 7099: SP#47 completed / Impacted TSs and TRs: 33.102; 33.210; 33.310; 33.401; 33.402 / WI rapporteur e-mail: Peter.Howard@vodafone.com
- 7100: CP#58 completed / Impacted TSs and TRs: RFC 6712 (was draft-ietf-pkix-cmp-transport-protocols)
- 7101: CP#46 completed. No impact on CT4 specs / WI rapporteur e-mail: Peter.Howard@vodafone.com
- 7102: Allow 128 as an alternative to 64 bit keys (Stage 2/3 + Test spec) / WI rapporteur e-mail: Karl Norrman
- 7103: SP#46 completed / Impacted TSs and TRs: 33.102.43.020; New 55.226 / WI rapporteur e-mail: Karl Norrman
- 7104: CP#45 completed / Impacted TSs and TRs: 24.008.44.064 / WI rapporteur e-mail: Karl Norrman
- 7105: CP#46 completed. Kc128 enhancements are carried as UMTS keys => no impact on CT4 29.002, 29.060 / WI rapporteur e-mail: Karl Norrman
- 7106: GP#43 WID approved + completed / Impacted TSs and TRs: 44.018.48.008.48.018.48.058 / WI rapporteur e-mail: Karl Norrman
- 7107: GP#44 completed. GP#43 WID approved / Impacted TSs and TRs: 51.010 / WI rapporteur e-mail: Karl Norrman
- 7108: SP#45 work stopped/abandoned / Impacted TSs and TRs: 23.060 / WI rapporteur e-mail: Karl Norrman
- 7109: SP#47 completed. Provide graphics in parallel to a video stream (without requiring an umbrella scene descriptor such as 3GPP DIMS in TS 26.142) / Impacted TSs and TRs: 26.114; 26.140; 26.234; 26.244; 26.245; 26.346; New 26.430 / WI rapporteur e-mail: clinton.priddle@ericsson.com
- 7110: SP#46 completed. Work extending Rel-8 UID_34041 MTSI Video - Dynamic Rate Adaptation/Signalling of Image Size. Update speech/video adaptation algorithms used by network to control MTSI client terminal in congestion or poor transmission conditions. / Impacted TSs and TRs: 26.114 / WI rapporteur e-mail: kyunghun.jung@samsung.com
- 7111: Umbrella WI / WI rapporteur e-mail: Clinton.Priddle@ericsson.com, imed.bouazizi@nokia.com
- 7112: SP#47 completed. Extends Rel-8 UID_34043 (PSS_MBMS_OMTV) & ensures compatibility with UID_34046 (IMS_PSS_MBMS_US) / Impacted TSs and TRs: 26.234; 26.346 / WI rapporteur e-mail: Clinton.Priddle@ericsson.com
- 7113: SP#47 completed / Impacted TSs and TRs: 26.234; 26.244; 26.346; new 26.903 / WI rapporteur e-mail: imed.bouazizi@nokia.com
- 7114: SP#46 completed. Work extending Rel-8 UID_34046 (IMS_PSS_MBMS_US), SA2 UID_410034 IMSSCC-SPI (IMS Service Continuity Enhancements: Service, Policy and Interactions) / Impacted TSs and TRs: 26.237 / WI rapporteur e-mail: Markus Kampmann
- 7115: SP#46 completed. TS 26.150v100 for Approval. RSS optimized for mobile use. Reuse/reference OMA's enabler DCD. / Impacted TSs and TRs: New 26.150 / WI rapporteur e-mail: Thorsten.Lohmar@ericsson.com
- 7116: SP#47 completed / Impacted TSs and TRs: 26.131; 26.132 / WI rapporteur e-mail: Stephen Kendall (wcsk01@motorola.com)
- 7117: OAM9 is an umbrella Feature also for OAM&P related TEI9 type of changes that are not part of any other dedicated feature/WI / Impacted TSs and TRs: 30.819
- 7118: SP#42 umbrella BB created to host OAM WIs
- 7119: SP#47 completed / Impacted TSs and TRs: 32.531; 32.532; 32.533; new 32.537 / WI rapporteur e-mail: Bidipta Das (bidipta@huawei.com), Clemens Suerbaum (clemens.suerbaum@nsn.com)
- 7120: SP#47 completed (covering SOA Architecture & SOA-supporting Solution Set). Triggered by UID_400029 Study on Service Oriented Architecture (SOA) for IRP (TR 32.824) / Impacted TSs and TRs: 32.101; 32.102; 32.150 / WI rapporteur e-mail: edwin.tse@ericsson.com, Jörg Schmidt (joerg@cox.net)
- 7121: SP#47 completed. Continuation of Rel-8 UID_400030 IRP SOAP Solution Sets / Impacted TSs and TRs: New (32.127/ 327/ 337/ 357/ 387/ 397/ 447/ 397/ 447/ 507/ 537); 32.121.32.122.32.123.32.32.321.32.322.32.323.32.325.32.331.32.332.32.333.32.335.32.351.32.352.32.353.32.381.32.382.32.383.32.385.32.391.32.392.32.393.32.395.32.441.32.442.32.443 / WI rapporteur e-mail: John Power

| ID | WBS | Task | Duration | Start | Finish | Complete | Baseline start | Baseline finish | Baseline duration | Constraint | Resources | Work | Actual work | Acronym | PCG approved | Release | TSG approved | MCC resp | Acronym_3GU_Export | Impacted TSs and TRs | WI rapporteur name | Special Focus Doc | PCG stopped | TSG stopped |
| --- | --- | --- | --- | --- | --- | --- | --- | --- | --- | --- | --- | --- | --- | --- | --- | --- | --- | --- | --- | --- | --- | --- | --- | --- |
| 7122 | 2360.2 | **Rel-9 Performance Management** | 472.12d? | 2009-03-12 A | 2010-06-10 A | 100% | 2009-03-12 | 2010-06-10 | 327d? |  | S5 | 7890.41h | 7890.41h | OAM9-PM | 22 | Rel-9 | 42 | Mirko | OAM9-PM |  |  |  |  |  |
| 7123 | 2360.2.1 | Enhancement of UTRAN Performance Measurements | 136d? | 2009-06-04 A | 2009-12-10 A | 100% | 2009-06-04 | 2009-12-10 | 136d? | start no earlier than 2009-06-04 | S5 | 1088h | 1088h |  | 23 | Rel-9 | 44 | Mirko |  | 32.405 | China Mobile |  |  |  |
| 7124 | 2360.2.2 | Enhancement of E-UTRAN Performance Measurements | 327d? | 2009-03-12 A | 2010-06-10 A | 100% | 2009-03-12 | 2010-06-10 | 327d? | finish no earlier than 2010-06-10 | S5 | 2616h | 2616h |  | 22 | Rel-9 | 43 | Mirko |  | 32.425 | Motorola, Huawei |  |  |  |
| 7125 | 2360.2.3 | Enhancement of EPC Performance Measurements | 197d? | 2009-03-12 A | 2009-12-10 A | 100% | 2009-03-12 | 2009-12-10 | 197d? | finish no earlier than 2010-03-25 | S5 | 1570.41h | 1570.41h |  | 22 | Rel-9 | 43 | Mirko |  | 32.426 | China Mobile |  |  |  |
| 7126 | 2360.3 | **Rel-9 Self-Organizing Networks (SON) - OAM aspects** | 869.88d? | 2008-02-22 A | 2010-06-10 A | 100% | 2008-02-22 | 2010-06-10 | 601d? |  | S5 | 11736h | 11736h | OAM9-SON | 22 | Rel-9 | 43 | Mirko | OAM9-SON |  |  | SON |  |  |
| 7127 | 2360.3.1 | SON self-optimization management (moved from Rel-8 LTE_SON-OAM) | 600d? | 2008-02-22 A | 2010-06-10 A | 100% | 2008-02-22 | 2010-06-10 | 600d? | finish no earlier than 2010-06-10 | S5 | 4800h | 4800h |  | 21 | Rel-9 | 39 | Mirko |  | 32.425; new (32.521; 32.522; 32.523; 32.525) | Huawei | SON |  |  |
| 7128 | 2360.3.2 | Automatic Radio Network Configuration Data Preparation | 266d? | 2009-06-04 A | 2010-06-10 A | 100% | 2009-06-04 | 2010-06-10 | 266d? | finish no earlier than 2010-06-10 | S5 | 2128h | 2128h |  | 23 | Rel-9 | 44 | Mirko |  | 32.501; 32.502; 32.503; 32.505; new 32.507 | Nokia Siemens Networks | SON |  |  |
| 7129 | 2360.4 | Rel-9 Subscription Management (SuM) evolution | 266d? | 2009-06-04 A | 2010-06-10 A | 100% | 2009-06-04 | 2010-06-10 | 266d? | finish no earlier than 2010-06-10 | S5 | 2128h | 2128h | OAM9-SuM | 23 | Rel-9 | 44 | Mirko | OAM9-SuM | 32.140; 32.141; 32.152; 32.172; 32.175 | Ericsson |  |  |  |
| 7130 | 2360.5 | Deleted - Rel-9 Trace | 196d? | 2009-03-13 A | 2009-12-10 A | 100% | 2009-03-13 | 2009-12-10 | 196d? | finish no earlier than 2009-12-10 | S5 | 1568h | 1568h | OAM9-Trace | 22 | Rel-9 | 42 | Mirko | OAM9-Trace |  |  |  | PCG-24 | SP-46 |
| 7131 | 2361 | Rel-9 Charging Management small Enhancements | 211d? | 2009-06-04 A | 2010-03-25 A | 100% | 2009-06-04 | 2010-03-25 | 211d? |  | S5 | 1688h | 1688h | CH9 | 23 | Rel-9 | 44 | Mirko | CH9 | 30.819 |  |  |  |  |
| 7132 | 2362 | **CS-IBCF and CS-TrGW definition in 3GPP specifications** | 682.38d? | 2008-05-30 A | 2010-03-19 A | 100% | 2008-05-30 | 2010-03-19 | 472d? |  | C3; C4 | 14490.3h | 14490.3h | CS-IBCF | 21 | Rel-9 | 40 | Adrian | CS-IBCF |  | Telecom Italia |  |  |  |
| 7133 | 2362.1 | CT3 aspects of CS-IBCF and CS-TrGW definition in 3GPP specifications | 472d? | 2008-05-30 A | 2010-03-19 A | 100% | 2008-05-30 | 2010-03-19 | 472d? | finish no earlier than 2009-12-04 | C3 | 3770.34h | 3770.34h | CS-IBCF | 21 | Rel-9 | 40 | Adrian |  | 29.235 | Telecom Italia |  |  |  |
| 7134 | 2362.2 | CT4 aspects of CS-IBCF and CS-TrGW definition in 3GPP specifications | 396d? | 2008-05-30 A | 2009-12-04 A | 100% | 2008-05-30 | 2009-12-04 | 396d? | finish no earlier than 2009-12-04 | C4 | 3168h | 3168h | CS-IBCF | 21 | Rel-9 | 40 | Kimmo |  | 23.231; 29.232; new 29.238 | Telecom Italia |  |  |  |
| 7135 | 2363 | **IMS – Interconnection Border Control Function (IBCF) – Transition Gateway (TrGW); Ix Interface; Stage 3** | 464.88d? | 2008-09-12 A | 2009-12-04 A | 100% | 2008-09-12 | 2009-12-04 | 322d? |  | C4; C3 | 10086.4h | 10086.4h | IMS_IBCF | 21 | Rel-9 | 41 | Kimmo | IMS_IBCF |  | Alcatel-Lucent |  |  |  |
| 7136 | 2363.1 | CT4 part of IMS – Interconnection Border Control Function (IBCF) – Transition Gateway (TrGW); Ix Interface; Stage 3 | 321d? | 2008-09-12 A | 2009-12-04 A | 100% | 2008-09-12 | 2009-12-04 | 321d? | finish no earlier than 2009-12-04 | C4 | 2568h | 2568h | IMS_IBCF | 21 | Rel-9 | 41 | Kimmo |  | new 29.238 | Alcatel-Lucent |  |  |  |
| 7137 | 2363.2 | CT3 part of IMS – Interconnection Border Control Function (IBCF) – Transition Gateway (TrGW); Ix Interface; Stage 3 | 295.8d? | 2008-09-12 A | 2009-12-04 A | 100% | 2008-09-12 | 2009-12-04 | 295.8d? | finish no earlier than 2010-03-19 | C3 | 2366.4h | 2366.4h | IMS_IBCF | 21 | Rel-9 | 41 | Adrian |  | 29.162; 29.235 | Alcatel-Lucent |  |  |  |
| 7138 | 2364 | IMS Application Level Gateway Control Function (ALGCF) – IMS Access Media Gateway (IMA-MGW); Iq Interface; Stage 2 and Stage 3 | 321d? | 2008-09-12 A | 2009-12-04 A | 100% | 2008-09-12 | 2009-12-04 | 321d? | finish no earlier than 2009-12-04 | C4 | 2568h | 2568h | IMS_AGCF | 21 | Rel-9 | 41 | Kimmo | IMS_AGCF | New 23.334; 29.334 | Alcatel-Lucent |  |  |  |
| 7139 | 2365 | **Enhancements of IMS Customized Alerting Tone (CAT) Service** | 566.38d? | 2008-12-05 A | 2010-06-04 A | 100% | 2008-12-05 | 2010-06-04 | 392d? |  | C1 | 5846.4h | 5846.4h | eCAT | 22 | Rel-9 | 42 | Frederic | eCAT |  | China Mobile |  |  |  |
| 7140 | 2365.1 | Stage 3 for Enhancements of IMS Customized Alerting Tone (CAT) Service | 391d? | 2008-12-05 A | 2010-06-04 A | 100% | 2008-12-05 | 2010-06-04 | 391d? | finish no earlier than 2010-06-04 | C1 | 3128h | 3128h | eCAT-SS | 22 | Rel-9 | 42 | Frederic | eCAT-SS | 24.182 | China Mobile |  |  |  |
| 7141 | 2366 | **Completion of IMS Restoration Procedures** | 305.38d? | 2009-05-29 A | 2010-03-19 A | 100% | 2009-05-29 | 2010-03-19 | 212d? |  | C3; C4; C1 | 10176h | 10176h | eIMS_RP | 23 | Rel-9 | 44 | Kimmo | eIMS_RP |  | Ericsson |  |  |  |
| 7142 | 2366.1 | CT4 aspects of Completion of IMS Restoration Procedures | 212d? | 2009-05-29 A | 2010-03-19 A | 100% | 2009-05-29 | 2010-03-19 | 212d? | finish no earlier than 2010-03-19 | C4 | 1696h | 1696h | eIMS_RP | 23 | Rel-9 | 44 | Kimmo |  | 23.380; 23.820 | Ericsson |  |  |  |
| 7143 | 2366.2 | CT1 aspects of Completion of IMS Restoration Procedures | 212d? | 2009-05-29 A | 2010-03-19 A | 100% | 2009-05-29 | 2010-03-19 | 212d? | finish no earlier than 2010-03-19 | C1 | 1696h | 1696h | eIMS_RP | 23 | Rel-9 | 44 | Kimmo |  | 24.229 | Ericsson |  |  |  |
| 7144 | 2366.3 | CT3 aspects of Completion of IMS Restoration Procedures | 212d? | 2009-05-29 A | 2010-03-19 A | 100% | 2009-05-29 | 2010-03-19 | 212d? | finish no earlier than 2010-03-19 | C3 | 1696h | 1696h | eIMS_RP | 24 | Rel-9 | 46 | Kimmo |  | 29.061; 29.212; 29.213; 29.214; 29.215 | Ericsson |  |  |  |
| 7145 | 2367 | **IMS Stage 3 IETF Protocol Alignment - phase 3** | 2086.88d? | 2009-05-29 A | 2014-12-05 A | 100% | 2009-05-29 | 2014-12-05 | 1455d? |  | C1; IETF | 40216h | 40216h | IMSProtoc3 | 23 | Rel-9 | 44 | Frederic | IMSProtoc3 |  | Alcatel-Lucent |  |  |  |
| 7146 | 2367.1 | CT1 aspects of IMS Stage 3 - IETF Protocol Alignment - phase 3 | 212d? | 2009-05-29 A | 2010-03-19 A | 100% | 2009-05-29 | 2010-03-19 | 212d? | finish no earlier than 2010-03-19 | C1 | 1696h | 1696h | IMSProtoc3 | 23 | Rel-9 | 44 | Frederic |  | 23.218; 24.229; 24.930 | Alcatel-Lucent |  |  |  |
| 7147 | 2367.2 | (IETF) CT1 IMS Stage 3 - IETF Protocol Alignment (RFC 7329) | 1242d? | 2009-05-29 A | 2014-12-05 A | 100% | 2009-05-29 | 2014-12-05 | 1240d? | finish no earlier than 2014-12-09 | C1-IETF | 9936h | 9936h | IMSProtoc3 | 27 | Rel-9 | 52 | Frederic |  | RFC 7329 (was draft-kaplan-insipid-session-id) | christer.holmberg@ericsson.com |  |  |  |
| 7148 | 2367.3 | (IETF) CT1 IMS Stage 3 - IETF Protocol Alignment (RFC 7044) | 659d? | 2011-09-13 A | 2014-03-07 A | 100% | 2011-09-13 | 2014-03-07 | 659d? | finish no earlier than 2014-02-10 | C1-IETF | 5256h | 5256h | IMSProtoc3 | 27 | Rel-9 | 53 | Frederic |  | RFC 7044 (was draft-ietf-sipcore-rfc4244bis) | christer.holmberg@ericsson.com |  |  |  |

Notes:
- 7122: SP#42 umbrella BB created to host OAM WIs
- 7123: SP#46 completed / WI rapporteur e-mail: liangshuangchun@cmdi.chinamobile.com, lijian@chinamobile.com, Bao Haitao
- 7124: SP#48 completed / WI rapporteur e-mail: Yizhi Yao (yzyao@motorola.com),Lan Zou (zlan@huawei.com)
- 7125: SP#46 completed / WI rapporteur e-mail: Li Jian (lijian@chinamobile.com), Liang Shuangchun (liangshuangchun@cmdi.chinamobile.com)
- 7126: SP#43 umbrella BB created to host OAM WIs
- 7127: SP#48 completed / WI rapporteur e-mail: Lan Zou (zlan@huawei.com)
- 7128: SP#48 completed / WI rapporteur e-mail: clemens.suerbaum@nsn.com
- 7129: SP#48 completed / WI rapporteur e-mail: frode.nergard@ericsson.com
- 7130: SP#46 stopped (no work in Rel-9)
- 7131: CH9 is an umbrella Feature also for OAM&P related TEI9 type of changes that are not part of any other dedicated feature/WI
- 7132: CP#47 completed. Rel-8 UID_380061 (Ipinterc) covers Stage 1 in SA1 22.101, 22.228 / WI rapporteur e-mail: mauro.ficaccio@telecomitalia.it
- 7133: CP#47 completed / WI rapporteur e-mail: mauro.ficaccio@telecomitalia.it
- 7134: CP#46 completed / WI rapporteur e-mail: mauro.ficaccio@telecomitalia.it
- 7135: CP#46 completed / WI rapporteur e-mail: bruno.landais@alcatel-lucent.fr
- 7136: CP#46 completed / WI rapporteur e-mail: bruno.landais@alcatel-lucent.fr
- 7137: CP#46 completed / WI rapporteur e-mail: bruno.landais@alcatel-lucent.fr
- 7138: CP#46 completed / WI rapporteur e-mail: bruno.landais@alcatel-lucent.fr
- 7139: CP#48 completed. Stage 1 in 22.182 / WI rapporteur e-mail: Jiang Yi
- 7140: CP#48 completed / WI rapporteur e-mail: Jiang Yi
- 7141: CP#47 completed. Continuation of Rel-8 Feature UID_400012 IMS Restoration Procedures / WI rapporteur e-mail: Emiliano Merino (emiliano.merino@ericsson.com)
- 7142: CP#47 completed / WI rapporteur e-mail: Emiliano Merino (emiliano.merino@ericsson.com)
- 7143: CP#47 completed / WI rapporteur e-mail: Emiliano Merino (emiliano.merino@ericsson.com)
- 7144: CP#47 completed / WI rapporteur e-mail: Emiliano Merino (emiliano.merino@ericsson.com)
- 7145: CP#47 completed / WI rapporteur e-mail: Keith Drage (drage@alcatel-lucent.com)
- 7146: CP#47 completed / WI rapporteur e-mail: Keith Drage (drage@alcatel-lucent.com)
- 7147: CP#65 completed / WI rapporteur e-mail: christer.holmberg@ericsson.com
- 7148: CP#63 completed / WI rapporteur e-mail: christer.holmberg@ericsson.com

| ID | WBS | Task | Type | Duration | Start | Finish | Complete | Baseline start | Baseline finish | Baseline duration | Constraint | Resources | Work | Actual work | Acronym | PCG approved | WI rapporteur name | WI rapporteur e-mail | Release | TSG approved | MCC resp | Acronym_3GU_Export | TSG stopped | Special Focus Doc | Status Report |
| --- | --- | --- | --- | --- | --- | --- | --- | --- | --- | --- | --- | --- | --- | --- | --- | --- | --- | --- | --- | --- | --- | --- | --- | --- | --- |
| 7149 | 2368 | **Operational description of the Inter-IMS Network to Network Interface (II-NNI)** |  | 2091.12d? | 2009-05-29 A | 2014-12-09 A | 100% | 2009-05-29 | 2014-12-05 | 1455d? |  | C3; IETF | 58408h | 58408h | II-NNI | 23 | Orange | sebastien.daudet@orange-ftgroup.com | Rel-9 | 44 | Adrian | II-NNI |  |  |  |
| 7150 | 2368.1 | Operational description of the Inter-IMS Network to Network Interface |  | 267d? | 2009-05-29 A | 2010-06-04 A | 100% | 2009-05-29 | 2010-06-04 | 267d? | start no earlier than 2009-05-29 | C3 | 2136h | 2136h | II-NNI | 23 | Orange |  | Rel-9 | 44 | Adrian |  |  |  |  |
| 7151 | 2368.2 | (IETF) Operational description of the Inter-IMS Network to Network Interface (RFC 7329) |  | 633d? | 2012-04-20 A | 2014-09-12 A | 100% | 2012-04-20 | 2014-12-05 | 693d? | finish no earlier than 2014-09-12 | C3-IETF | 5040h | 5040h | II-NNI | 29 | christer.holmberg@ericsson.com | christer.holmberg@ericsson.com | Rel-9 | 56 | Adrian |  |  |  |  |
| 7152 | 2368.3 | (IETF) Operational description of the Inter-IMS Network to Network Interface (RFC 7316) |  | 634d? | 2012-04-20 A | 2014-09-12 A | 100% | 2012-04-20 | 2014-12-05 | 694d? | finish no earlier than 2014-12-09 | C3-IETF | 5064h | 5064h | II-NNI | 29 | Keith Drage | Keith Drage | Rel-9 | 56 | Adrian |  |  |  |  |
| 7153 | 2368.4 | (IETF) Operational description of the Inter-IMS Network to Network Interface |  | 696d? | 2012-04-20 A | 2014-12-09 A | 100% | 2012-04-20 | 2014-12-05 | 694d? | finish no earlier than 2014-12-09 | C3-IETF | 5560h | 5560h | II-NNI | 29 | Roland Jesske | Roland Jesske | Rel-9 | 56 | Adrian |  |  |  |  |
| 7154 | 2368.5 | (IETF) Operational description of the Inter-IMS Network to Network Interface |  | 696d? | 2012-04-20 A | 2014-12-09 A | 100% | 2012-04-20 | 2014-12-05 | 694d? | finish no earlier than 2014-12-09 | C3-IETF | 5536h | 5536h | II-NNI | 29 | Roland Jesske | Roland Jesske | Rel-9 | 56 | Adrian |  |  |  |  |
| 7155 | 2368.6 | (IETF) Operational description of the Inter-IMS Network to Network Interface |  | 697d? | 2012-04-20 A | 2014-12-09 A | 100% | 2012-04-20 | 2014-12-05 | 695d? | finish no earlier than 2014-12-09 | C3-IETF | 5560h | 5560h | II-NNI | 29 | Keith Drage | Keith Drage | Rel-9 | 56 | Adrian |  |  |  |  |
| 7156 | 2368.7 | Deleted - (IETF) Operational description of the Inter-IMS Network to Network Interface |  | 433d? | 2012-04-20 A | 2013-12-06 A | 100% | 2012-04-20 | 2014-12-05 | 694d? | finish no earlier than 2013-12-06 | C3-IETF | 3456h | 3456h | II-NNI | 29 | Peter Dawes | peter.dawes@vodafone.com | Rel-9 | 56 | Adrian |  | SP-69 |  |  |
| 7157 | 2368.8 | Deleted - (IETF) Operational description of the Inter-IMS Network to Network Interface (avasarala-dispatch-comm-div-notification) |  | 340d? | 2013-03-01 A | 2014-06-13 A | 100% | 2013-03-01 | 2014-06-13 | 340d? | finish no earlier than 2014-06-13 | C3-IETF | 2696h | 2696h | II-NNI | 30 | Andrew Allen | Andrew Allen | Rel-9 | 59 | Adrian |  | SP-69 |  |  |
| 7158 | 2369 | Definition of Ml interface for Control Plane LCS (Stage 3) |  | 131d? | 2009-09-18 A | 2010-03-19 A | 100% | 2009-09-18 | 2010-03-19 | 131d? | finish no earlier than 2010-03-19 | C1 | 1048h | 1048h | EMC2 | 23 | Alcatel-Lucent | Keith Drage (drage@alcatel-lucent.com) | Rel-9 | 45 | Frederic | EMC2 |  | Public Safety (I-A) |  |
| 7159 | 2370 | PCC enhancements |  | 56d? | 2009-09-18 A | 2009-12-04 A | 100% | 2009-09-18 | 2009-12-04 | 56d? | finish no earlier than 2009-12-04 | C3 | 448h | 448h | PCC-Enh | 23 | Huawei | Wei Weihua (weiwh@huawei.com) | Rel-9 | 45 | Adrian | PCC-Enh |  |  |  |
| 7160 | 2371 | 3GPP IMS Conferencing Management Object (MO) |  | 2d? | 2009-12-03 A | 2009-12-04 A | 100% | 2009-12-03 | 2009-12-04 | 2d? | start no earlier than 2009-12-03 | C1 | 16h | 16h | IMS_ConfMO | 24 |  |  | Rel-9 | 46 | Frederic | IMS_ConfMO |  |  |  |
| 7161 | 2372 | In Case of Emergency (ICE) Graphics |  | 3d? | 2010-03-17 A | 2010-03-19 A | 100% | 2010-03-17 | 2010-03-19 | 3d? | finish no earlier than 2010-03-19 | C6 | 24h | 24h | ICE_Graphics | 24 | Sagem-Orga | heiko.kruse@sagem-orga.com | Rel-9 | 47 | Xavier | ICE_Graphics |  |  |  |
| 7162 | 2373 | **Rel-9 Improvements of the Radio Interface** |  | 573.62d? | 2008-09-12 A | 2010-03-19 A | 100% | 2008-09-12 | 2010-03-19 | 397d? |  | RP; GP | 19744h | 19744h | RInImp9 | 21 |  |  | Rel-9 | 41 | Issam | RInImp9 |  |  |  |
| 7163 | 2373.1 | LCR TDD UE OTA Performance Requirements |  | 186d? | 2008-09-12 A | 2009-05-29 A | 100% | 2008-09-12 | 2009-05-29 | 186d? | finish no earlier than 2009-05-29 | R4 | 1488h | 1488h | RInImp9-RFLCROTA | 21 | RITT | Wu Xiang (wuxiang@chinattl.com) | Rel-9 | 41 | Issam | RInImp9-RFLCROTA |  |  | RP-090389 |
| 7164 | 2373.2 | **RF requirements for Multicarrier and Multi-RAT BS** |  | 501.12d? | 2008-11-21 A | 2010-03-19 A | 100% | 2008-11-21 | 2010-03-19 | 347d? |  | R4; G1 | 10336h | 10336h | RInImp9-RFmulti | 21 | Ericsson | Johan.skold@ericsson.com | Rel-9 | 41 | Issam | RInImp9-RFmulti |  |  |  |
| 7165 | 2373.2.1 | RAN4 part of RF requirements for Multicarrier and Multi RAT BS |  | 337d? | 2008-12-05 A | 2010-03-19 A | 100% | 2008-12-05 | 2010-03-19 | 337d? | finish no earlier than 2010-03-19 | R4 | 2696h | 2696h | RInImp9-Rfmulti | 22 | Ericsson | johan.skold@ericsson.com | Rel-9 | 42 | Issam |  |  |  | RP-100027 |
| 7166 | 2373.2.2 | GERAN part of RF requirements for Multicarrier and Multi RAT BS |  | 261d? | 2008-11-21 A | 2009-11-20 A | 100% | 2008-11-21 | 2009-11-20 | 261d? | finish no earlier than 2009-11-20 | G1 | 2088h | 2088h | RInImp9-RFmulti-GERAN | 22 | Ericsson | mats.y.samuelsson@ericsson.com | Rel-9 | 40 | Paolo | RInImp9-RFmulti-GERAN |  |  |  |
| 7167 | 2373.3 | Extended UMTS/LTE 800 MHz | milestone | 0d? | 2008-12-05 A | 2008-12-05 A | 100% | 2008-12-05 | 2009-09-18 | 207d? |  | R4; R2; R3 |  |  | RInImp9-UMTSLTE800 | 22 | NTT DoCoMo | Shingo Suwa (suwas@nttdocomo.co.jp) | Rel-9 | 42 | Issam | RInImp9-UMTSLTE800 |  |  | RP-090687 |
| 7168 | 2373.4 | UMTS/LTE 800 MHz for Europe | milestone | 0d? | 2009-03-06 A | 2009-03-06 A | 100% | 2009-03-06 | 2010-03-19 | 272d? | finish no earlier than 2010-03-19 | R4; R2; R3 |  |  | RInImp9-UMTSLTE800EU | 22 | Ericsson | olav.queseth@ericsson.com | Rel-9 | 43 | Issam | RInImp9-UMTSLTE800EU |  |  | RP-100028 |
| 7169 | 2373.5 | Performance requirement for LCR TDD with UE speeds up to 350 km/h |  | 196d? | 2009-03-06 A | 2009-12-04 A | 100% | 2009-03-06 | 2009-12-04 | 196d? | finish no earlier than 2009-12-04 | R4 | 1568h | 1568h | RInImp9-LCRTDD350 | 22 | CATT | Yuexia Song (songyuexia@catt.cn) | Rel-9 | 43 | Issam | RInImp9-LCRTDD350 |  |  | RP-091035 |
| 7170 | 2373.6 | Extended UMTS/LTE 1500 MHz | milestone | 0d? | 2009-05-30 A | 2009-05-30 A | 100% | 2009-05-30 | 2010-03-19 | 211d? | finish no earlier than 2010-03-19 | R4; R2; R3 |  |  | UMTSLTE1500 | 23 | NTT DoCoMo | Shingo Suwa (suwas@nttdocomo.co.jp) | Rel-9 | 44 | Issam | UMTSLTE1500 |  |  | RP-100029 |
| 7171 | 2374 | **Rel-9 Improvements of the Radio Interface - UE Conformance Testing** |  | 504.12d? | 2009-05-19 A | 2010-09-17 A | 100% | 2009-05-19 | 2010-09-17 | 350d? |  | R5 | 8184h | 8184h |  | 23 |  |  | Rel-9 | 44 | Ingbert |  |  |  |  |
| 7172 | 2374.1 | Conformance Test Aspects – UMTS/LTE in 800 MHz for Europe |  | 350d? | 2009-05-19 A | 2010-09-17 A | 100% | 2009-05-19 | 2010-09-17 | 350d? | finish no earlier than 2010-09-17 | R5 | 2800h | 2800h | RInImp-UEConTest-UMTSLTE800EU | 23 | Ericsson | fredrik.sundstrom@ericsson.com | Rel-9 | 44 | Ingbert | RInImp-UEConTest-UMTSLTE800EU |  |  | RP-100736 |
| 7173 | 2374.2 | Conformance Test Aspects – Extended UMTS/LTE 1500 MHz |  | 186d? | 2009-09-18 A | 2010-06-04 A | 100% | 2009-09-18 | 2010-06-04 | 186d? | finish no earlier than 2010-06-04 | R5 | 1488h | 1488h | UMTSLTE1500_UEConTest | 23 | NTT DoCoMo | Nguyen Dung Dao (dao@nttdocomo.co.jp) | Rel-9 | 45 | Ingbert | UMTSLTE1500_UEConTest |  |  | RP-100487 |
| 7174 | 2374.3 | TDD UE Over The Air (Antenna) conformance testing methodology |  | 81d? | 2009-05-30 A | 2009-09-18 A | 100% | 2009-05-30 | 2009-09-18 | 81d? | finish no earlier than 2009-09-18 | R5 | 648h | 648h | UEAnt_TDDTest | 23 | CATR | Qu Yan (quyan@emcite.com) | Rel-9 | 44 | Ingbert | UEAnt_TDDTest |  |  | RP-090727 |
| 7175 | 2374.4 | Conformance Test Aspects – Performance requirement for LCR TDD with UE speeds up to 350 km/h |  | 56d? | 2010-03-19 A | 2010-06-04 A | 100% | 2010-03-19 | 2010-06-04 | 56d? | finish no earlier than 2010-06-04 | R5 | 448h | 448h | RInImp9-LCRTDD350_UEConTest | 24 | CATT | Xiaozhong Chen (chexiaozhong@datangmobile.cn) | Rel-9 | 47 | Ingbert | RInImp9-LCRTDD350_UEConTest |  |  | RP-100496 |
| 7176 | 2375 | Conformance Test Aspects – SMS over IMS in E-UTRAN |  | 131d? | 2009-09-18 A | 2010-03-19 A | 100% | 2009-09-18 | 2010-03-19 | 131d? | finish no earlier than 2010-06-18 | R5 | 1048h | 1048h | SMSoverIMS_UEConTest | 23 | Alcatel-Lucent | Nidal Khrais (khrais@alcatel-lucent.com) | Rel-9 | 45 | Ingbert | SMSoverIMS_UEConTest |  |  | RP-100072 |

Notes:
- 7149: -
- 7150: CP#48 completed / Impacted TSs and TRs: 29.165
- 7151: CP#65 complete / Impacted TSs and TRs: RFC 7329 (was draft-kaplan-insipid-session-id)
- 7152: CP#65 complete / Impacted TSs and TRs: RFC 7316 (was draft-vanelburg-dispatch-private-network-ind)
- 7153: In RFC Editors Queue. Dec.14: 75->90¦7/3/16: 90%->100 / Impacted TSs and TRs: draft-ietf-salud-alert-info-urns
- 7154: In RFC Editors Queue. Mar15: 90->100%. RFC updated (was draft-ietf-cuss-sip-uui). Jun 15: RFC 7433 (was draft-ietf-cuss-sip-uui) / Impacted TSs and TRs: RFC 7433
- 7155: In RFC Editors Queue. Dec.14: 75->90. Mar15: 90->100%. RFC updated (was draft-ietf-cuss-sip-uui-isdni). June 15: RFC 7434 (was draft-ietf-cuss-sip-uui-isdn) / Impacted TSs and TRs: RFC 7434
- 7156: CP#62 removed from Rel-8 to Rel-11. Not completed internet-draft / Impacted TSs and TRs: Rel-12 remains draft-dawes-sipping-debug
- 7157: CP#64 Draft removed from 3GPP documentation / Impacted TSs and TRs: draft-avasarala-dispatch-comm-div-notification
- 7158: CP#47 completed [Stage 3 for Rel-7 Emergency Calls (EMC1)]. Related to Rel-9 UID_400038 LCS Control Plane Solution for EPS. Stage 2 in Rel-9 UID_400038 (23.271), UID_410037 (23.167) / Impacted TSs and TRs: 24.229
- 7159: CP#46 completed / Impacted TSs and TRs: 29.212; 29.213; 29.215
- 7160: CP#46 completed. Linked to Rel-6 UID_11051 (IMS Management objects) under the Feature UID_32021 (IMS Phase 2). MO compatible with OMA DM v1.2 & upwards and defined using OMA DM Device Description Framework (OMA-ERELD _DM-V1_2) / Impacted TSs and TRs: New 24.166
- 7161: CP#47 approved WID and completed. Added capability to store ICE graphical information (picture). Linked to CT6 Rel-8 ICE Feature UID_380059 In Case of Emergency numbers storage and easy access on UICC / Impacted TSs and TRs: 31.102 CR#0433
- 7162: RP#41 umbrella Feature created to host Rel-9 WIs / Impacted TSs and TRs: GERAN; UTRA; LTE
- 7163: RP#44 completed technical work (RAN4 internal TR abandoned) / Impacted TSs and TRs: UTRA (no 25.8xy produced)
- 7164: RP#47 completed. RF requirements specification applicable to Multi-Standard Radio (MSR) Base Station with multiple carriers and/or multiple 3GPP Radio Access Technologies (RAT) / Impacted TSs and TRs: GERAN; UTRA; LTE
- 7165: RP#48 completed / Impacted TSs and TRs: UTRA; LTE 25.104; 25.105; 36.104; new 37.104; 37.113; 37.141; 37.900
- 7166: GP#44 Core spec completed. GP#40 WID approved / Impacted TSs and TRs: GERAN 45.005; 51.021
- 7167: RP#45 completed / Impacted TSs and TRs: UTRA; LTE 25.101; 25.104; 25.113; 25.133; 34.124; 36.101; 36.104; 36.113; 36.124; 36.133; 36.141; 25.306; 25.307; 25.331; 36.331; 25.461; 25.466; new 36.800
- 7168: RP#47 completed / Impacted TSs and TRs: UTRA; LTE 25.101; 25.104; 25.113; 25.133; 25.141; 34.124; 36.101; 36.104; 36.113; 36.124; 36.133; 36.141; new 36.810; 25.306; 25.307; 25.331; 36.331; 25.461; 25.466
- 7169: RP#46 completed / Impacted TSs and TRs: UTRA 25.102; 25.105; 25.142
- 7170: RP#47 completed. For potential deployment in Japan / Impacted TSs and TRs: UTRA; LTE 25.101; 25.104; 25.113; 25.133; 25.141; 25.306; 25.307; 25.331; 25.461; 25.466; 34.124; 36.101; 36.104; 36.113; 36.124; 36.133; 36.141; 36.331; new (36.821; 36.307)
- 7171: - / Impacted TSs and TRs: UTRA; LTE
- 7172: RP#49 completed. Testing for UID_430009 UMTS/LTE 800 MHz for Europe / Impacted TSs and TRs: UTRA; LTE 34.108; 34.121-1; 34.121-2; 36.508; 36.521-1; 36.521-2; 36.521-3
- 7173: RP#48 completed / Impacted TSs and TRs: UTRA; LTE 34.108; 34.121-1; 34.121-2; 34.123-1; 34.123-2; 36.508; 36.521-1; 36.521-2; 36.521-3; 36.523-1; 36.523-2; 36.523-3
- 7174: RP#45 completed. Finalized TDD UE test methodology based on R4 TR 25.914 (UE and MS antenna performance evaluation method) and TS 25.144 Over the Air (Antenna) minimum performance requirements for the speech mode (terminal close to head) / Impacted TSs and TRs: UTRA 34.114
- 7175: RP#48 completed. Testing for UID_430010 Performance requirement for LCR TDD with UE speeds up to 350 km/h / Impacted TSs and TRs: UTRA 34.122
- 7176: RP#47 completed / Impacted TSs and TRs: LTE 34.229-1; 34.229-2; 34.229-3

| ID | WBS | Task | Type | Duration | Start | Finish | Complete | Baseline start | Baseline finish | Baseline duration | Constraint | Resources | Work | Actual work | PCG approved | Release | TSG approved | MCC resp | Acronym | WI rapporteur name | WI rapporteur e-mail | Status Report | Acronym_3GU_Export | Special Focus Doc |
| --- | --- | --- | --- | --- | --- | --- | --- | --- | --- | --- | --- | --- | --- | --- | --- | --- | --- | --- | --- | --- | --- | --- | --- | --- |
| 7177 | 2376 | **Rel-9 RAN improvements** |  | 571.62d? | 2009-03-06 A | 2010-09-08 A | 100% | 2000-01-03 | 2010-03-19 | 2667d? |  | RP | 12640h | 12640h | 22 | Rel-9 | 43 | Issam |  |  |  |  |  |  |
| 7178 | 2376.1 | Dual-Cell HSUPA | milestone | 0d? | 2009-03-06 A | 2009-03-06 A | 100% | 2009-03-06 | 2010-03-19 | 272d? | finish no earlier than 2010-03-19 | R1; R2; R3; R4 |  |  | 22 | Rel-9 | 43 | Patrick | RANimp-DC_HSUPA | Nokia Siemens Networks | Karri Ranta-aho (karri.ranta-aho@nsn.com) | RP-100030 | RANimp-DC_HSUPA |  |
| 7179 | 2376.2 | Support for different bands for Dual-Cell HSDPA | milestone | 0d? | 2009-03-06 A | 2009-03-06 A | 100% | 2009-03-06 | 2009-12-04 | 197d? |  | R4; R2; R3 |  |  | 22 | Rel-9 | 43 | Issam | RANimp-MultiBand_DC_HSDPA | Nokia Siemens Networks | Tuomo Säynäjäkangas (tuomo.saynajakangas@nsn.com) | RP-091038 | RANimp-MultiBand_DC_HSDPA |  |
| 7180 | 2376.3 | Combination of DC-HSDPA with MIMO | milestone | 0d? | 2009-03-06 A | 2009-03-06 A | 100% | 2009-03-06 | 2009-12-04 | 197d? |  | R1; R2; R3; R4 |  |  | 22 | Rel-9 | 43 | Patrick | RANimp-DC_MIMO | Ericsson | johan.bergman@ericsson.com | RP-091039 | RANimp-DC_MIMO |  |
| 7181 | 2376.4 | Transmit Antenna Array (TxAA) extension for non-MIMO UEs | milestone | 0d? | 2009-03-06 A | 2009-03-06 A | 100% | 2009-03-06 | 2009-12-04 | 197d? |  | R1; R2; R3; R4 |  |  | 22 | Rel-9 | 43 | Patrick | RANimp-TxAA_nonMIMO | Nokia | Arto Lehti (arto.lehti@nokia.com) | RP-091040 | RANimp-TxAA_nonMIMO |  |
| 7182 | 2376.5 | Cell Portion for 1.28 Mcps TDD |  | 395d? | 2009-03-06 A | 2010-09-08 A | 100% | 2000-01-03 | 2000-07-07 | 136d? | finish no earlier than 2009-03-06 | R3; R1; R4 | 9480h | 9480h | 23 | Rel-9 | 44 | Juha | CP_LCRTDD | CATT | Ying Zhang (zhangying2@datangmobile.cn) | RP-091041 | CP_LCRTDD |  |
| 7183 | 2377 | **Rel-9 RAN improvements - UE Conformance Testing** |  | 841.12d? | 2010-09-17 A | 2012-12-07 A | 100% | 2010-09-17 | 2012-12-07 | 588d? |  | R5 | 11848h | 11848h | 25 | Rel-9 | 49 | Ingbert |  |  |  |  |  |  |
| 7184 | 2377.1 | Conformance Test Aspects – Combination of DC-HSDPA with MIMO |  | 186d? | 2010-09-17 A | 2011-06-03 A | 100% | 2010-09-17 | 2011-06-03 | 186d? | finish no earlier than 2011-06-03 | R5 | 1488h | 1488h | 25 | Rel-9 | 49 | Ingbert | RANimp-DC_MIMO_UEConTest | Ericsson | leif.mattisson@ericsson.com | RP-110510 | RANimp-DC_MIMO_UEConTest |  |
| 7185 | 2377.2 | Conformance Test Aspects – Dual-Cell HSUPA |  | 453d? | 2011-03-18 A | 2012-12-07 A | 100% | 2011-03-18 | 2012-12-07 | 453d? | finish no earlier than 2012-12-07 | R5 | 3624h | 3624h | 26 | Rel-9 | 51 | Ingbert | RANimp-DC_HSUPA_UEConTest | Ericsson | leif.mattisson@ericsson.com | RP-121524 | RANimp-DC_HSUPA_UEConTest |  |
| 7186 | 2377.3 | Conformance Test Aspects – Support for different bands for Dual-Cell HSDPA |  | 254d? | 2011-03-18 A | 2012-03-02 A | 100% | 2011-03-18 | 2012-03-02 | 254d? | finish no earlier than 2012-03-02 | R5 | 2032h | 2032h | 26 | Rel-9 | 51 | Ingbert | RANimp-MultiBand_DC_HSDPA_UEConTest | Ericsson | leif.mattisson@ericsson.com | RP-120036 | RANimp-MultiBand_DC_HSDPA_UEConTest |  |
| 7187 | 2378 | **LTE improvements** |  | 849.12d? | 2009-03-06 A | 2011-06-03 A | 100% | 2009-03-06 | 2011-06-03 | 587d? |  | R1; R2; R4; R5 | 21840h | 21840h | 22 | Rel-9 | 42 | Patrick | LTEimp |  |  |  | LTEimp |  |
| 7188 | 2378.1 | LTE Pico NodeB RF Requirements |  | 196d? | 2009-03-06 A | 2009-12-04 A | 100% | 2009-03-06 | 2009-12-04 | 196d? | finish no earlier than 2010-03-05 | R4 | 1568h | 1568h | 22 | Rel-9 | 43 | Issam | LTEimp-Pico_eNB-RF | Huawei | Liyan Yin (yinliyan@huawei.com) | RP-091045 | LTEimp-Pico_eNB-RF |  |
| 7189 | 2378.2 | Enhanced Dual-Layer transmission for LTE | milestone | 0d? | 2009-03-06 A | 2009-03-06 A | 100% | 2009-03-06 | 2010-03-19 | 272d? | finish no earlier than 2010-03-18 | R1; R2; R4 |  |  | 22 | Rel-9 | 43 | Patrick | LTEimp-eDL | China Mobile | Xu Xiaodong (xuxiaodong@chinamobile.com) | RP-100034 | LTEimp-eDL |  |
| 7190 | 2378.3 | UE Conformance Test Aspects – Enhanced Dual-layer transmission for LTE TDD |  | 186d? | 2010-09-17 A | 2011-06-03 A | 100% | 2010-09-17 | 2011-06-03 | 186d? | finish no earlier than 2011-06-03 | R5 | 1488h | 1488h | 25 | Rel-9 | 49 | Ingbert | LTEimp-eDL_UEConTest | China Mobile | Shanpeng Xiao (xiaoshanpeng@chinamobile.com) | RP-110509 | LTEimp-eDL_UEConTest |  |
| 7191 | 2379 | Rel-9 Self-Organizing Networks (SON) | milestone | 0d? | 2009-03-06 A | 2009-03-06 A | 100% | 2009-03-06 | 2010-03-19 | 272d? | finish no earlier than 2010-03-19 | R3; R2 |  |  | 22 | Rel-9 | 42 | Juha | SON | Nokia Siemens Networks | krzysztof.kordybach@nsn.com | RP-100038 | SON | SON |
| 7192 | 2380 | **AGNSS Performances and Testing Procedures** |  | 1139.12d? | 2008-05-16 A | 2011-05-20 A | 100% | 2008-05-16 | 2011-05-20 | 787d? |  | G1; G3new | 22664h | 22664h | 20 | Rel-9 | 38 | Paolo | AGNSSPTP | Thales | Michel.monnerat@thalesaleniaspace.com |  | AGNSSPTP |  |
| 7193 | 2380.1 | AGNSS Minimum Performances |  | 472d? | 2008-05-16 A | 2010-03-05 A | 100% | 2008-05-16 | 2010-03-05 | 472d? | finish no earlier than 2010-03-05 | G1 | 3776h | 3776h | 20 | Rel-9 | 38 | Paolo | AGNSSPTP-Perfreq | Thales | Michel.monnerat@thalesaleniaspace.com |  | AGNSSPTP-Perfreq |  |
| 7194 | 2380.2 | AGNSS Testing Procedures |  | 787d? | 2008-05-16 A | 2011-05-20 A | 100% | 2008-05-16 | 2011-05-20 | 787d? | finish no earlier than 2011-05-20 | G3new | 6296h | 6296h | 20 | Rel-9 | 38 | Ingbert | AGNSSPTP-MStest | Thales | Michel.monnerat@thalesaleniaspace.com |  | AGNSSPTP-MStest |  |
| 7195 | 2381 | **Voice services over Adaptive Multi-user channels on One Slot** |  | 1240.25d? | 2008-11-21 A | 2012-03-02 A | 100% | 2008-11-21 | 2012-03-02 | 860d? |  | GP; G1; G2; G3new | 71592h | 71592h | 22 | Rel-9 | 42 | Paolo | VAMOS | Nokia Siemens Networks, China Mobile | juergen.hofmann@nsn.com, liuxiaoyu@chinamobile.com |  | VAMOS |  |
| 7196 | 2381.1 | Stage 2 for Voice services over Adaptive Multi-user channels on One Slot |  | 392d? | 2008-11-21 A | 2010-05-21 A | 100% | 2008-11-21 | 2010-05-21 | 392d? | finish no earlier than 2010-05-21 | GP; G1; G2 | 9408h | 9408h | 22 | Rel-9 | 40 | Paolo | VAMOS | Nokia Siemens Networks, China Mobile | juergen.hofmann@nsn.com, liuxiaoyu@chinamobile.com |  |  |  |
| 7197 | 2381.2 | Stage 3 for Voice services over Adaptive Multi-user channels on One Slot |  | 596d? | 2008-11-24 A | 2011-03-04 A | 100% | 2008-11-24 | 2011-03-04 | 596d? | finish no earlier than 2011-03-04 | GP; G1; G2 | 14304h | 14304h | 22 | Rel-9 | 40 | Paolo | VAMOS | Nokia Siemens Networks, China Mobile | juergen.hofmann@nsn.com, liuxiaoyu@chinamobile.com |  |  |  |
| 7198 | 2381.3 | VAMOS Radio Performance Requirements |  | 651d? | 2008-11-24 A | 2011-05-20 A | 100% | 2008-11-24 | 2011-05-20 | 651d? | finish no earlier than 2011-05-20 | GP; G1; G2 | 15624h | 15624h | 22 | Rel-9 | 40 | Paolo | VAMOS | Nokia Siemens Networks, China Mobile | juergen.hofmann@nsn.com, liuxiaoyu@chinamobile.com |  |  |  |
| 7199 | 2381.4 | VAMOS - MS conformance testing |  | 392d? | 2010-09-03 A | 2012-03-02 A | 100% | 2010-09-03 | 2012-03-02 | 392d? | finish no earlier than 2012-03-02 | G3new | 3128h | 3128h | 25 | Rel-9 | 47 | Ingbert | VAMOS_MStest | BlackBerry | Raveendra Seetharam (rseetharam@rim.com) |  | VAMOS_MStest |  |
| 7200 | 2381.5 | VAMOS - BTS conformance testing |  | 201d? | 2010-11-26 A | 2011-09-02 A | 100% | 2010-11-26 | 2011-09-02 | 201d? | finish no earlier than 2011-09-02 | G1 | 1608h | 1608h | 26 | Rel-9 | 48 | Paolo | VAMOS_BTStest | Nokia Siemens Networks | eddie.riddington@nsn.com |  | VAMOS_BTStest |  |

Notes:
- 7177: RP#47 completed / Impacted TSs and TRs: UTRA
- 7178: RP#47 completed / Impacted TSs and TRs: 25.101; 25.104; 25.133; 25.211; 25.212; 25.213; 25.214; 25.215; 25.319; 25.306; 25.321; 25.331; 25.423; 25.433
- 7179: RP#46 completed. RP#62 existing TS 25.317 replaced by new TS 25.327 / Impacted TSs and TRs: 25.101; 25.104; 25.133; 25.306; 25.308; 25.331; 25.423; 25.433; new 25.317 replaced by new 25.327
- 7180: RP#46 completed / Impacted TSs and TRs: 25.101; 25.104; 25.133; 25.211; 25.212; 25.213; 25.214; 25.215; 25.308; 25.321; 25.331; 26.306; 25.423; 25.433
- 7181: RP#46 completed / Impacted TSs and TRs: 25.101; 25.104; 25.211; 25.212; 25.213; 25.214; 25.215; 25.308; 25.306; 25.321; 25.331; 25.423; 25.433
- 7182: RP#46 completed / Impacted TSs and TRs: 25.102; 25.105; 25.123; 25.225; 25.423; 25.433
- 7183: -
- 7184: UTRA. RP#52 completed. Testing for Rel-9 UID_430016 Combination of DC-HSDPA with MIMO / Impacted TSs and TRs: UTRA 34.108; 34.121-1; 34.121-2; 34.123-1; 34.123-2; 34.123-3
- 7185: RP#58 completed. Testing for Rel-9 UID_430014 Dual-Cell HSUPA / Impacted TSs and TRs: UTRA 34.108; 34.121-1; 34.121-2; 34.123-1; 34.123-2; 34.123-3
- 7186: RP#55 completed. Testing for Rel-9 UID_430015 Support for different bands for Dual-Cell HSDPA / Impacted TSs and TRs: UTRA 34.108; 34.121-1; 34.121-2; 34.123-1; 34.123-2; 34.123-3
- 7187: - / Impacted TSs and TRs: LTE
- 7188: RP#46 completed / Impacted TSs and TRs: 36.104; 36.141; new 36.931
- 7189: RP#47 completed / Impacted TSs and TRs: 36.101; 36.211; 36.212; 36.213; 36.331
- 7190: RP#52 completed. Testing for UID_430029 (Enhanced Dual-Layer transmission for LTE) / Impacted TSs and TRs: 36.508; 36.521-1; 36.521-2
- 7191: RP#47 completed / Impacted TSs and TRs: LTE 25.413; 36.300; 36.413; 36.423; 48.018; New 36.902
- 7192: GP#46 still ongoing MS testing. Linked to Rel-10 RAN4 UID_450027 (AGNSS Minimum Performance for UTRAN)
- 7193: GP#45 completed (open performance requirements alignment GPS/Galileo) / Impacted TSs and TRs: 45.005
- 7194: GP#50 completed / Impacted TSs and TRs: 51.010-1; new 51.010-7
- 7195: Triggered by UID_50590 (MUROS) Study on Multi-User Reusing-One-Slot
- 7196: GP#46 completed. GP#40 WID approved / Impacted TSs and TRs: 45.001
- 7197: GP#49 completed. GP#40 WID approved / Impacted TSs and TRs: 24.008; 44.018; 45.002; 45.003; 45.004; 45.008; 48.008; 48.058
- 7198: GP#50 completed. GP#40 WID approved / Impacted TSs and TRs: 45.005
- 7199: GP#53 completed. GP#47 WID approved / Impacted TSs and TRs: 51.010-1; 51.010-2
- 7200: GP#51 completed. GP#48 WID approved / Impacted TSs and TRs: 51.021

| ID | WBS | Task | Type | Duration | Start | Finish | Complete | Baseline start | Baseline finish | Baseline duration | Constraint | Resources | Work | Actual work | Acronym | PCG approved | WI rapporteur name | WI rapporteur e-mail | Release | TSG approved | MCC resp | Acronym_3GU_Export | PCG stopped | TSG stopped | Special Focus Doc | Status Report |
| --- | --- | --- | --- | --- | --- | --- | --- | --- | --- | --- | --- | --- | --- | --- | --- | --- | --- | --- | --- | --- | --- | --- | --- | --- | --- | --- |
| 7201 | 2382 | **Cell Broadcast protocol Base Station Controller – Cell Broadcast Centre (BSC-CBC)** |  | 319.88d? | 2009-05-15 A | 2010-03-19 A | 100% | 2009-05-15 | 2010-03-19 | 222d? |  | GP; C1 | 7024h | 7024h | CEBRO | 23 | Ericsson | claes-goran.persson@ericsson.com | Rel-9 | 42 | Paolo | CEBRO |  |  |  |  |
| 7202 | 2382.1 | GERAN part of Cell Broadcast protocol Base Station Controller – Cell Broadcast Centre |  | 212d? | 2009-05-15 A | 2010-03-05 A | 100% | 2009-05-15 | 2010-03-05 | 212d? | finish no earlier than 2010-03-05 | GP | 1696h | 1696h | CEBRO | 23 | Ericsson | claes-goran.persson@ericsson.com | Rel-9 | 42 | Paolo |  |  |  |  |  |
| 7203 | 2382.2 | CT1 part of Cell Broadcast protocol Base Station Controller – Cell Broadcast Centre |  | 222d? | 2009-05-15 A | 2010-03-19 A | 100% | 2009-05-15 | 2010-03-19 | 222d? | finish no earlier than 2010-03-19 | C1 | 1776h | 1776h | CEBRO | 23 | Ericsson | claes-goran.persson@ericsson.com | Rel-9 | 42 | Frederic |  |  |  |  |  |
| 7204 | 2383 | Hybrid Location |  | 136d? | 2009-05-18 A | 2009-11-20 A | 100% | 2009-05-18 | 2009-11-20 | 136d? | finish no earlier than 2009-11-20 | GP | 1088h | 1088h | HILT | 23 | TruePosition | Matt Ward (mward@trueposition.com) | Rel-9 | 42 | Paolo | HILT |  |  |  |  |
| 7205 | 2384 | (Small) Technical Enhancements and Improvements for Rel-9 |  | 325d? | 2008-09-15 A | 2009-12-10 A | 100% | 2008-09-15 | 2009-12-10 | 325d? | finish no earlier than 2009-12-10 | SP; CP; RP; GP | 10400h | 10400h | TEI9 | 22 |  |  | Rel-9 | 42 | All | TEI9 |  |  |  |  |
| 7206 | 2385 | Test - (Small) Technical Enhancements and Improvements for Rel-9 |  | 286d? | 2009-11-20 A | 2010-12-24 A | 100% | 2009-11-20 | 2010-12-24 | 286d? | finish no earlier than 2010-12-24 | R5; G3new | 4576h | 4576h | TEI9_Test | 24 |  |  | Rel-9 | 44 | Ingbert | TEI9_Test |  |  |  |  |
| 7207 | 2386 | **Deleted - Services Alignment and Migration** |  | 676.25d? | 2006-12-06 A | 2008-09-18 A | 100% | 2006-12-06 | 2008-09-18 | 467d? |  | S1 | 7472h | 7472h | ServAl | 17 | Telefónica O2 | chris.friel@O2.com | Rel-9 | 33 | Alain | ServAl | PCG-21 | SP-41 |  |  |
| 7208 | 2386.1 | Deleted - Stage 1 for ServAl |  | 467d? | 2006-12-06 A | 2008-09-18 A | 100% | 2006-12-06 | 2008-09-18 | 467d? | finish no earlier than 2008-12-11 | S1 | 3736h | 3736h |  | 21 | Telefónica O2 | chris.friel@O2.com | Rel-9 | 33 | Alain |  | PCG-21 | SP-41 |  |  |
| 7209 | 2387 | Deleted - Harmonization of Gq'/Rx for Common IMS |  | 304d? | 2008-01-14 A | 2009-03-12 A | 100% | 2008-01-14 | 2009-03-12 | 304d? | finish no earlier than 2009-03-12 | S2 | 2432h | 2432h | IMS_Comm_GqRx_Harm | 21 | Alcatel-Lucent | geoffrey.cristallo@alcatel-lucent.be | Rel-9 | 38 | Maurice | IMS_Comm_GqRx_Harm | PCG-22 | SP-43 |  |  |
| 7210 | 2388 | Deleted - Support of WiMAX - LTE Mobility |  | 407d? | 2008-06-06 A | 2009-12-25 A | 100% | 2008-06-06 | 2009-12-25 | 407d? | start no earlier than 2008-06-06 | R2 | 3248h | 3248h | WiMAX_LTE_Mobility | 21 | Samsung |  | Rel-9 | 38 | Yong-Jun | WiMAX_LTE_Mobility | PCG-21 | SP-39 |  |  |
| 7211 | 2389 | Deleted - Support of WiMAX - UMTS Mobility |  | 407d? | 2008-06-06 A | 2009-12-25 A | 100% | 2008-06-06 | 2009-12-25 | 407d? | start no earlier than 2008-06-06 | R2 | 3248h | 3248h | WiMAX_UMTS_Mobility | 21 | Intel |  | Rel-9 | 38 | Yong-Jun | WiMAX_UMTS_Mobility | PCG-21 | SP-39 |  |  |
| 7212 | 2390 | Deleted - Definition of 3GPP UICC services over the new high-speed interface | milestone | 0d? | 2010-03-19 A | 2010-03-19 A | 100% | 2010-03-19 | 2010-03-19 | 0d? |  | C6 |  |  | UICCHS | 21 | Gemalto | Denis.Lheriteau@gemalto.com | Rel-9 | 38 | Xavier | UICCHS | PCG-24 | CP-47 |  |  |
| 7213 | 2391 | **Deleted - SAES Enhancements (non RAN aspects)** |  | 552d? | 2007-06-25 A | 2008-12-08 A | 100% | 2007-06-25 | 2008-12-08 | 381d? |  | S2 | 11664h | 11664h | SAES_Ph2 | 20 | Nokia Siemens Networks |  | Rel-9 | 39 | Maurice | SAES_Ph2 | PCG-21 | SP-39 |  |  |
| 7214 | 2391.1 | Deleted - Functions and procedures for SAE to support LTE MBMS |  | 381d? | 2007-06-25 A | 2008-12-08 A | 100% | 2007-06-25 | 2008-12-08 | 381d? | finish no earlier than 2008-12-08 | S2 | 3048h | 3048h | SAES_Ph2 | 18 |  |  | Rel-9 | 35 | Maurice |  | PCG-21 | SP-39 |  |  |
| 7215 | 2391.2 | Deleted - CS over EPS |  | 194d? | 2008-03-12 A | 2008-12-08 A | 100% | 2008-03-12 | 2008-12-08 | 194d? | finish no earlier than 2008-12-08 | S2 | 1552h | 1552h | SAES_Ph2 | 21 |  |  | Rel-9 | 39 | Maurice |  | PCG-21 | SP-39 |  |  |
| 7216 | 2391.3 | **Deleted - SAE for generic support for non-3GPP accesses** |  | 363.5d? | 2007-06-25 A | 2008-06-09 A | 100% | 2007-06-25 | 2008-06-09 | 251d? |  | S2 | 4016h | 4016h | SAES_Ph2 | 21 |  |  | Rel-9 | 39 | Maurice |  | PCG-21 | SP-39 |  |  |
| 7217 | 2391.3.1 | Deleted - Single Radio Aspects of SAE for Optimized Handover with WiMAX |  | 251d? | 2007-06-25 A | 2008-06-09 A | 100% | 2007-06-25 | 2008-06-09 | 251d? | finish no earlier than 2008-06-09 | S2 | 2008h | 2008h | SAES_Ph2 | 21 |  |  | Rel-9 | 39 | Maurice |  | PCG-21 | SP-39 |  |  |
| 7218 | 2392 | Deleted - Lawful Interception in the 3GPP Rel-9 |  | 211d? | 2009-06-04 A | 2010-03-25 A | 100% | 2009-06-04 | 2010-03-25 | 211d? | finish no earlier than 2010-03-25 | S3 | 1688h | 1688h | LI9 | 23 | PIDS, Nortel | Koen Jaspers, Ronald Ryan | Rel-9 | 44 | Mirko | LI9 | PCG-24 | SP-47 |  |  |
| 7219 | 2393 | Release 9 Studies | milestone | 0d? | 2008-06-05 A | 2008-06-05 A | 100% | 2008-06-05 | 2010-03-19 | 468d? |  | CP; RP; SP |  |  |  |  |  |  | Rel-9 |  |  |  |  |  |  |  |
| 7220 | 2394 | Study on Service Specific Access Control in EPS |  | 136d? | 2008-06-05 A | 2008-12-11 A | 100% | 2008-06-05 | 2008-12-11 | 136d? | start no earlier than 2008-06-05 | S1 | 1088h | 1088h | FS_SSAC | 21 | NTT DoCoMo | Shin-ichi Isobe (isobes@nttdocomo.co.jp) | Rel-9 | 40 | Alain | FS_SSAC |  |  |  |  |
| 7221 | 2395 | Study on CS Domain Services over EPS access |  | 492d? | 2007-04-25 A | 2009-03-12 A | 100% | 2007-04-25 | 2009-03-12 | 492d? | finish no earlier than 2009-03-12 | S2 | 3936h | 3936h | FS_CSoPS | 18 | T-Mobile | Karl-Heinz.Nenner@T-Mobile.net | Rel-9 | 35 | Maurice | FS_CSoPS |  |  |  |  |
| 7222 | 2396 | Study on Extended Support of IMS Emergency Calls |  | 319d? | 2007-09-24 A | 2008-12-11 A | 100% | 2007-09-24 | 2008-12-11 | 319d? | finish no earlier than 2009-06-18 | S2 | 2552h | 2552h | FS_IMS-eCall | 19 | Qualcomm | Stephen Edge | Rel-9 | 37 | Maurice | FS_IMS-eCall |  |  | Public Safety (I-A) |  |
| 7223 | 2397 | Study on Service Continuity for Emergency Voice Calls |  | 721d? | 2006-06-08 A | 2009-03-12 A | 100% | 2006-06-08 | 2009-03-12 | 721d? | finish no earlier than 2009-03-12 | S2 | 5768h | 5768h | FS_VCCEm | 17 | Nortel | Ricky Kaura (rkaura@nortel.com) | Rel-9 | 32 | Maurice | FS_VCCEm |  |  | Public Safety (I-A) |  |
| 7224 | 2398 | Study on Security Aspects of Remote Provisioning and Change of Subscription for M2M Equipment |  | 1483.15d? | 2004-04-06 A | 2009-12-10 A | 100% | 2004-04-06 | 2009-12-10 | 1483.15d? | finish no earlier than 2009-12-10 | S3; C6 | 23730.4h | 23730.4h | FS_UM2M | 19 | Ericsson | vesa.lehtovirta@ericsson.com | Rel-9 | 37 | Mirko | FS_UM2M |  |  | MTC, M2M |  |
| 7225 | 2399 | Study on System Maintenance over Itf-N |  | 602d? | 2007-06-07 A | 2009-09-24 A | 100% | 2007-06-07 | 2009-09-24 | 602d? | finish no earlier than 2009-09-24 | S5 | 4808h | 4808h | FS_OAM-Maint-Itf-N | 19 | ZTE | Shuqiang Huang (huangsq@zte.com.cn) | Rel-9 | 36 | Mirko | FS_OAM-Maint-Itf-N |  |  |  |  |
| 7226 | 2400 | Study on Self-Organizing Networks (SON) related OAM interfaces for Home NodeB |  | 522d? | 2007-06-07 A | 2009-06-04 A | 100% | 2007-06-07 | 2009-06-04 | 522d? | finish no earlier than 2009-12-10 | S5 | 4168h | 4168h | FS_OAM-SON-HNB | 19 | Huawei | Zou Lan (zlan@huawei.com) | Rel-9 | 36 | Mirko | FS_OAM-SON-HNB |  |  | HNB, SON |  |
| 7227 | 2401 | Study on Self-healing of Self-Organizing Networks (SON) |  | 416d? | 2008-02-22 A | 2009-09-24 A | 100% | 2008-02-22 | 2009-09-24 | 416d? | finish no earlier than 2009-09-24 | S5 | 3320.15h | 3320.15h | FS_OAM-SON-SH | 21 | ZTE | zhu.weihong@zte.com.cn | Rel-9 | 39 | Mirko | FS_OAM-SON-SH |  |  | SON |  |
| 7228 | 2402 | Study on Service Oriented Architecture (SOA) for IRP |  | 262d? | 2008-06-05 A | 2009-06-04 A | 100% | 2008-06-05 | 2009-06-04 | 262d? | finish no earlier than 2009-05-20 | S5 | 2088h | 2088h | FS_OAM_SOA_IRP | 21 | Ericsson | edwin.tse@ericsson.com | Rel-9 | 40 | Mirko | FS_OAM_SOA_IRP |  |  |  |  |
| 7229 | 2403 | Study on Evaluation of the inclusion of Path Loss Based Technology in the UTRAN |  | 516d? | 2007-12-17 A | 2009-12-04 A | 100% | 2007-12-17 | 2009-12-04 | 516d? | finish no earlier than 2009-09-18 | R4 | 4120h | 4120h | FS_RAN-Pathloss | 21 | Polaris Wireless | Norman Shaw (nshaw@polariswireless.com) | Rel-9 | 38 | Issam | FS_RAN-Pathloss |  |  |  | RP-091080 |
| 7230 | 2404 | Study on LTE-Advanced |  | 522d? | 2008-03-21 A | 2010-03-19 A | 100% | 2007-03-23 | 2010-03-19 | 781.2d? | finish no earlier than 2010-03-19 | R1; R2; R3; R4 | 16704h | 16704h | FS_RAN_LTEA | 21 | NTT DoCoMo | Tetsushi Abe | Rel-9 | 39 | Patrick | FS_RAN_LTEA |  |  | CA | RP-100080 |
| 7231 | 2405 | Study on 1.28 Mcps TDD Home NodeB |  | 387d? | 2008-02-20 A | 2009-12-04 A | 100% | 2008-02-20 | 2009-12-04 | 387d? | finish no earlier than 2009-12-04 | R4 | 3096h | 3096h | FS_RAN-HNBLCRTDD | 21 | TD Tech | Li Rong (lirong@td-tech.com) | Rel-9 | 41 | Issam | FS_RAN-HNBLCRTDD |  |  | HNB | RP-091081 |
| 7232 | 2406 | Study on E-UTRAN Mobility Evaluation and Enhancement |  | 126d? | 2008-12-05 A | 2009-05-29 A | 100% | 2008-12-05 | 2009-05-29 | 126d? | finish no earlier than 2009-05-29 | R1 | 1008h | 1008h | FS_EUTRAN_mob | 22 | Qualcomm | Rajat Prakash (rprakash@qualcomm.com) | Rel-9 | 42 | Patrick | FS_EUTRAN_mob |  |  |  | RP-090426 |
| 7233 | 2407 | Study on Minimization of drive-tests in Next Generation Networks |  | 196d? | 2009-03-06 A | 2009-12-04 A | 100% | 2009-03-06 | 2009-12-04 | 196d? | finish no earlier than 2009-12-04 | R2 | 1568h | 1568h | FS_NGN_min_drive-tests | 22 | Qualcomm | Masato Kitazoe (mkitazoe@qualcomm.com) | Rel-9 | 43 | Yong-Jun | FS_NGN_min_drive-tests |  |  |  | RP-091084 |
| 7234 | 2408 | Study on Enhanced Interference Management for HNBs |  | 61d? | 2009-03-06 A | 2009-05-29 A | 100% | 2009-03-06 | 2009-05-29 | 61d? | start no earlier than 2009-03-06 | R4 | 488h | 488h | FS_eInterfMgmt_HNB | 22 | Qualcomm | Farhad Meshkati (fmeshkat@qualcomm.com) | Rel-9 | 43 | Issam | FS_eInterfMgmt_HNB |  |  | HNB | RP-090429 |
| 7235 | 2409 | Study on Enhanced Interference Management Mechanisms for HNBs |  | 81d? | 2009-05-30 A | 2009-09-18 A | 100% | 2009-05-30 | 2009-09-18 | 81d? | finish no earlier than 2009-09-18 | R3 | 648h | 648h | FS_eInterfMgmtMchsm_HNB | 23 | Qualcomm | Farhad Meshkati (fmeshkat@qualcomm.com) | Rel-9 | 44 | Juha | FS_eInterfMgmtMchsm_HNB |  |  | HNB | RP-090733 |
| 7236 | 2410 | Deleted - Study on Protection against SMS and MMS spam |  | 862d? | 2006-06-08 A | 2009-09-24 A | 100% | 2006-06-08 | 2009-09-24 | 862d? | finish no earlier than 2009-09-24 | S3 | 6896h | 6896h | FS_CPSMal | 17 | Orange | eric.gauthier@orange.ch | Rel-9 | 32 | Mirko | FS_CPSMal | PCG-23 | SP-45 |  |  |
| 7237 | 2411 | --- RELEASE 8 --- |  | 914.3d? | 2006-09-19 A | 2010-03-19 A | 100% | 2006-09-19 | 2010-03-19 | 914.3d? | start no earlier than 2000-01-03 | CP; GP; RP; SP | 29257.6h | 29257.6h |  |  |  |  | Rel-8 |  |  |  |  |  |  |  |

Notes:
- 7201: CP#47 completed. GP#45 completed. GP#42 WID approved
- 7202: GP#45 completed. GP#42 WID approved / Impacted TSs and TRs: new 48.049
- 7203: CP#47 completed / Impacted TSs and TRs: 23.041
- 7204: GP#44 completed. GP#42 WID approved (Hybrid Integrated Location Technology=HILT) / Impacted TSs and TRs: 43.059; 48.071
- 7205: SP#46 completed
- 7206: GP#44 created
- 7207: SP#41 closed (no tangible result of this work¦no CR against TR 22.983). Triggered by Study UID_370086 (FSServAl)
- 7208: SP#41 closed (no tangible result of this work¦no CR against TR 22.983) / Impacted TSs and TRs: 22.983
- 7209: SP#43 stopped. LS_out to TISPAN informs about stopping this activity / Impacted TSs and TRs: 23.822; 23.203
- 7210: RP#39: No agreed WID / Impacted TSs and TRs: 36.306; 36.331; 36.413; 36.300; 36.214; 36.133; 36.304
- 7211: RP#39: No agreed WID / Impacted TSs and TRs: 25.306; 25.331; 25.413
- 7212: CP#47 work stopped/abandoned / Impacted TSs and TRs: 31.xyz
- 7213: SP#39 created to host Rel-9 Wis. BUT no agreed WID
- 7214: SP#39 SAE functionality moved to Rel-9. WID returned to SA2 for re-consideration & remove MBMS for EPS from Rel 8
- 7215: SP#39 SAE functionality moved to Rel-9. BUT no agreed WID
- 7216: SP#39 SAE functionality moved to Rel-9. BUT no agreed WID
- 7217: SP#39 SAE functionality moved to Rel-9. BUT no agreed WID
- 7218: SP#47 stopped. WI + new topics moved to Rel-10 / Impacted TSs and TRs: 33.106; 33.107; 33.108
- 7219: -
- 7220: SP#42 completed. Spin-off Feature UID_420020 (SSAC) / Impacted TSs and TRs: 22.986
- 7221: SP#43 completed. Linked to Combinational Services UID_31064, Services Alignment and Migration (ServAl) UID_330017 and 3GPP System Architecture Evolution (SAES) UID_3208 / Impacted TSs and TRs: 23.879
- 7222: SP#42 completed / Impacted TSs and TRs: 23.868
- 7223: SP#43 completed / Impacted TSs and TRs: 23.826
- 7224: SP#46 completed. Triggered by the SA1 Rel-8 Study on Facilitating Machine to Machine Communication in GSM and UMTS (FS_M2M) UID_7027 in TR 22.868. / Impacted TSs and TRs: 33.812
- 7225: SP#45 completed / Impacted TSs and TRs: 32.822
- 7226: SP#44 completed. Linked to SA5 TR 32.816 Study of Management for LTE and SAE (UID_340036) / Impacted TSs and TRs: 32.821
- 7227: SP#45 completed. Linked to SA5 TR 32.816 Study of Management for LTE and SAE (UID_340036) / Impacted TSs and TRs: 32.823
- 7228: SP#44 completed. Spin-off implementation WI UID_440064 Service Oriented Architecture (SOA) for IRP / Impacted TSs and TRs: 32.824
- 7229: RP#46 completed / Impacted TSs and TRs: 25.907
- 7230: RP#47 completed / Impacted TSs and TRs: 36.913 ; New 36.814; 36.912; R2 36.806 (Relay architectures for E-UTRA); R4 36.815 (LTE-Advanced feasibility studies in RAN4)
- 7231: RP#46 completed / Impacted TSs and TRs: 25.866
- 7232: RP#44 closed (RP-090452 R1 LS to RAN on Conclusions for LTE Mobility Study Item - no further Rel-9 action / no TR needed) / Impacted TSs and TRs: none
- 7233: RP#46 completed / Impacted TSs and TRs: 36.805
- 7234: RP#44 completed. Linked to UID_420008 LTE FDD Home eNodeB RF Requirements. Spin-off RAN3 UID_440015 Study on Enhanced Interference Management Mechanisms for HNBs / Impacted TSs and TRs: 25.967
- 7235: RP#45 completed. Triggered by RAN4 UID_430027 Study on Enhanced Interference Management for HNBs / Impacted TSs and TRs: 25.967
- 7236: SP#45 work stopped/abandoned / Impacted TSs and TRs: 33.9xx
- 7237: -

| ID | WBS | Task | Duration | Start | Finish | Complete | Baseline start | Baseline finish | Baseline duration | Constraint | Resources | Work | Actual work | Acronym | PCG approved | WI rapporteur name | WI rapporteur e-mail | Release | TSG approved | MCC resp | Acronym_3GU_Export |
| --- | --- | --- | --- | --- | --- | --- | --- | --- | --- | --- | --- | --- | --- | --- | --- | --- | --- | --- | --- | --- | --- |
| 7238 | 2412 | **3GPP System Architecture Evolution Specification - Evolved Packet System (non RAN aspects)** | 2336.88d? | 2006-04-12 A | 2012-06-15 A | 100% | 2006-04-12 | 2012-06-15 | 1618d? |  | S1; S2; S3; S5; C1; C3; C4; C6; IETF | 510115h | 510115h | SAES | 17 | T-Mobile | michael.kurz@t-mobile.at | Rel-8 | 32 | Alain | SAES |
| 7239 | 2412.1 | Requirements for evolution of the 3GPP system architecture | 395d? | 2006-06-08 A | 2007-12-12 A | 100% | 2006-06-08 | 2007-12-12 | 395d? | finish no earlier than 2007-11-30 | S1 | 3160h | 3160h | AIPN-SAE | 17 | T-Mobile | michael.kurz@t-mobile.at | Rel-8 | 32 | Alain | AIPN-SAE |
| 7240 | 2412.2 | **High level and common (for all accesses) functions** | 910.25d? | 2007-01-02 A | 2009-05-29 A | 100% | 2007-01-02 | 2009-05-29 | 629d? |  | S2; S3; C1; C3; C4 | 62664h | 62664h | EPS-ComF | 19 | Nokia Siemens Networks | balazs.bertenyi@nsn.com | Rel-8 | 37 | Maurice | EPS-ComF |
| 7241 | 2412.2.1 | Stage 2 for High level functions | 370d? | 2007-01-02 A | 2008-06-02 A | 100% | 2007-01-02 | 2008-06-02 | 370d? | finish no earlier than 2008-06-02 | S2 | 2960h | 2960h | SAES-SA-HLF | 18 | Motorola | Irfan.Ali@motorola.com | Rel-8 | 35 | Maurice | SAES-SA-HLF |
| 7242 | 2412.2.2 | Stage 2 Security Architecture | 197d? | 2008-03-12 A | 2008-12-11 A | 100% | 2008-03-12 | 2008-12-11 | 197d? | finish no earlier than 2008-12-11 | S3 | 1576h | 1576h | SAES | 21 | Nokia Siemens Networks | marc.blommaert.ext@nsn.com | Rel-8 | 39 | Mirko |  |
| 7243 | 2412.2.3 | Stage 3 (CT1) for SAE impact on services, network functions and capabilities | 545d? | 2007-02-05 A | 2009-03-06 A | 100% | 2007-02-05 | 2009-03-06 | 545d? | finish no earlier than 2009-03-06 | C1 | 4360h | 4360h | SAES | 18 | Nokia Siemens Networks | robert.zaus@nsn.com | Rel-8 | 34 | Frederic |  |
| 7244 | 2412.2.4 | Stage 3 SAE impact on existing capabilities | 480d? | 2007-02-05 A | 2008-12-05 A | 100% | 2007-02-05 | 2008-12-05 | 480d? | finish no earlier than 2008-12-12 | C3 | 3840h | 3840h | SAES | 18 | Huawei | Wei Weihua (weiwh@huawei.com) | Rel-8 | 34 | Adrian |  |
| 7245 | 2412.2.5 | Stage 3 (CT4) of SAE impact on existing capabilities | 788d? | 2007-02-05 A | 2009-03-06 A | 100% | 2007-02-05 | 2009-03-06 | 545d? | finish no earlier than 2009-03-06 | C4 | 4360h | 4360h | SAES | 18 | Huawei | shahab.lavasani@huawei.com | Rel-8 | 34 | Kimmo |  |
| 7246 | 2412.2.6 | Stage 2/3 for Network selection procedures | 480d? | 2007-02-05 A | 2008-12-05 A | 100% | 2007-02-05 | 2008-12-05 | 480d? | finish no earlier than 2009-03-06 | C1 | 3840h | 3840h | SAES | 18 | Nokia Siemens Networks | robert.zaus@nsn.com | Rel-8 | 34 | Frederic |  |
| 7247 | 2412.2.7 | Stage 3 EPC interworking with external PDNs (SGi) | 605d? | 2007-02-05 A | 2009-05-29 A | 100% | 2007-02-05 | 2009-05-29 | 605d? | finish no earlier than 2009-05-29 | C3 | 4840h | 4840h | SAES-St3-intwk | 18 | Huawei | Wei Weihua (weiwh@huawei.com) | Rel-8 | 34 | Adrian | SAES-St3-intwk |
| 7248 | 2412.2.8 | Stage 3 PCC within SAE | 605d? | 2007-02-05 A | 2009-05-29 A | 100% | 2007-02-05 | 2009-05-29 | 605d? | finish no earlier than 2009-05-29 | C3 | 4840h | 4840h | SAES-St3-PCC | 18 | Ericsson | j.javier.pastor@ericsson.com | Rel-8 | 34 | Adrian | SAES-St3-PCC |
| 7249 | 2412.2.9 | Stage 3 for SAE / LTE identities | 545d? | 2007-02-05 A | 2009-03-06 A | 100% | 2007-02-05 | 2009-03-06 | 545d? | finish no earlier than 2009-03-06 | C4 | 4360h | 4360h | SAES | 18 | Huawei | shahab.lavasani@huawei.com | Rel-8 | 34 | Kimmo |  |
| 7250 | 2412.2.10 | Unified guidelines for Diameter usage within 3GPP | 316d? | 2007-09-21 A | 2008-12-05 A | 100% | 2007-09-21 | 2008-12-05 | 316d? | finish no earlier than 2008-12-05 | C3 | 2528h | 2528h | SAES-DIAM | 19 | Huawei | Javier Gonzalez Gallego | Rel-8 | 37 | Adrian | SAES-DIAM |
| 7251 | 2412.3 | **SAE for LTE access** | 823.25d? | 2007-01-02 A | 2009-03-06 A | 100% | 2007-01-02 | 2009-03-06 | 569d? |  | S2; C1; C3; C4 | 80584h | 80584h | SAES-LTE | 18 | Motorola | Irfan.Ali@motorola.com | Rel-8 | 35 | Maurice | SAES-LTE |
| 7252 | 2412.3.1 | CT4 Stage 3 for protocol between EPCs | 545d? | 2007-02-05 A | 2009-03-06 A | 100% | 2007-02-05 | 2009-03-06 | 545d? | finish no earlier than 2009-03-06 | C4 | 4360h | 4360h | SAES-LTE | 18 | Huawei | shahab.lavasani@huawei.com | Rel-8 | 34 | Kimmo |  |
| 7253 | 7.2.2.1 | **SAES-SA-FP_LTE with GTP variant** | 823.25d? | 2007-01-02 A | 2009-03-06 A | 100% | 2007-01-02 | 2009-03-06 | 569d? |  | S2; C4 | 16448h | 16448h | SAES-SA-FP_LTE-GTP | 18 | Nokia Siemens Networks | balazs.bertenyi@nsn.com | Rel-8 | 35 | Maurice | SAES-SA-FP_LTE-GTP |
| 7254 | 2412.3.2.1 | Stage 2 for SAES-SA-FP_LTE with GTP variant | 373d? | 2007-01-02 A | 2008-06-05 A | 100% | 2007-01-02 | 2008-06-05 | 373d? | finish no earlier than 2008-06-02 | S2 | 2984h | 2984h | SAES-SA-FP_LTE-GTP-St2 | 19 | Nokia Siemens Networks | balazs.bertenyi@nsn.com | Rel-8 | 37 | Maurice | SAES-SA-FP_LTE-GTP-St2 |
| 7255 | 2412.3.2.2 | CT4 Stage 3 for GTP v2 protocol | 545d? | 2007-02-05 A | 2009-03-06 A | 100% | 2007-02-05 | 2009-03-06 | 545d? | finish no earlier than 2009-03-06 | C4 | 4360h | 4360h | SAES-SA-FP_LTE-GTP | 18 | Huawei | shahab.lavasani@huawei.com | Rel-8 | 34 | Kimmo | SAES-SA-FP_LTE-GTP |
| 7256 | 7.2.2.2 | **SAES-SA-FP_LTE with PMIP variant** | 823.25d? | 2007-01-02 A | 2009-03-06 A | 100% | 2007-01-02 | 2009-03-06 | 569d? |  | S2; C4 | 20288h | 20288h | SAES-SA-FP_LTE-IETF | 18 | Nokia Siemens Networks | balazs.bertenyi@nsn.com | Rel-8 | 35 | Maurice | SAES-SA-FP_LTE-IETF |
| 7257 | 2412.3.3.1 | Stage 2 for SAES-SA-FP_LTE with PMIP variant | 373d? | 2007-01-02 A | 2008-06-05 A | 100% | 2007-01-02 | 2008-06-05 | 373d? | finish no earlier than 2008-06-02 | S2 | 2984h | 2984h | SAES-SA-FP_LTE-IETF-St2 | 19 | Nokia Siemens Networks | balazs.bertenyi@nsn.com | Rel-8 | 37 | Maurice | SAES-SA-FP_LTE-IETF-St2 |
| 7258 | 2412.3.3.2 | CT4 Stage 3 for PMIP protocol within EPC | 545d? | 2007-02-05 A | 2009-03-06 A | 100% | 2007-02-05 | 2009-03-06 | 545d? | finish no earlier than 2009-03-06 | C4 | 4360h | 4360h | SAES-SA-FP_LTE-IETF | 19 | Huawei | shahab.lavasani@huawei.com | Rel-8 | 37 | Kimmo | SAES-SA-FP_LTE-IETF |
| 7259 | 2412.3.3.3 | Mobile IPv4 (MIPv4) based Mobility protocols | 480d? | 2007-02-05 A | 2008-12-05 A | 100% | 2007-02-05 | 2008-12-05 | 480d? | finish no earlier than 2008-12-05 | C4 | 3840h | 3840h | SAES-SA-FP_LTE-IETF | 21 | Motorola | Lewis Milton | Rel-8 | 41 | Kimmo |  |
| 7260 | 2412.3.4 | Stage 3 for UE Non-Access-Stratum (NAS) mobility procedures in idle and active mode | 545d? | 2007-02-05 A | 2009-03-06 A | 100% | 2007-02-05 | 2009-03-06 | 545d? | finish no earlier than 2009-03-06 | C1 | 4360h | 4360h | SAES-LTE | 18 | Nokia Siemens Networks | robert.zaus@nsn.com | Rel-8 | 34 | Frederic |  |
| 7261 | 2412.3.5 | Stage 3 for Session management, bearer control and QoS aspects | 545d? | 2007-02-05 A | 2009-03-06 A | 100% | 2007-02-05 | 2009-03-06 | 545d? | finish no earlier than 2009-03-06 | C1 | 4360h | 4360h | SAES-LTE | 18 | Nokia Siemens Networks | robert.zaus@nsn.com | Rel-8 | 34 | Frederic |  |
| 7262 | 2412.3.6 | Stage 3 for security aspects of LTE Access | 545d? | 2007-02-05 A | 2009-03-06 A | 100% | 2007-02-05 | 2009-03-06 | 545d? | finish no earlier than 2009-03-06 | C1 | 4360h | 4360h | SAES-LTE | 18 | Nokia Siemens Networks | robert.zaus@nsn.com | Rel-8 | 34 | Frederic |  |
| 7263 | 2412.3.7 | Stage 3 for QoS mechanisms | 480d? | 2007-02-05 A | 2008-12-05 A | 100% | 2007-02-05 | 2008-12-05 | 480d? | finish no earlier than 2008-12-12 | C3 | 3840h | 3840h | SAES-LTE | 18 | Ericsson | j.javier.pastor@ericsson.com | Rel-8 | 34 | Adrian |  |
| 7264 | 2412.3.8 | Stage 3 for EPC - HSS interface | 545d? | 2007-02-05 A | 2009-03-06 A | 100% | 2007-02-05 | 2009-03-06 | 545d? | finish no earlier than 2009-03-06 | C4 | 4360h | 4360h | SAES-LTE | 18 | Huawei | shahab.lavasani@huawei.com | Rel-8 | 34 | Kimmo |  |

Notes:
- 7238: Role model for SAE/LTE system wide project management by SA2 in SP-060166
- 7239: SP#38 completed / Impacted TSs and TRs: 22.011; 22.246; New 22.278
- 7240: CP#44 completed
- 7241: SP#40 completed / Impacted TSs and TRs: New 23.402
- 7242: SP#42 completed / Impacted TSs and TRs: 33.210; 33.310; New 33.401
- 7243: CP#43 completed / Impacted TSs and TRs: 24.229; 27.007; New 24.305
- 7244: CP#42 completed / Impacted TSs and TRs: 29.061
- 7245: CP#43 completed / Impacted TSs and TRs: New (29.274; 29.275)
- 7246: CP#42 completed / Impacted TSs and TRs: 23.122; New 24.302
- 7247: CP#44 completed / Impacted TSs and TRs: 29.061
- 7248: CP#44 completed / Impacted TSs and TRs: 29.212; 29.213; 29.214; New 29.215
- 7249: CP#43 completed / Impacted TSs and TRs: 23.003
- 7250: CP#42 completed / Impacted TSs and TRs: New 29.909
- 7251: CP#43 completed
- 7252: CP#43 completed / Impacted TSs and TRs: 29.274; 29.275
- 7253: CP#43 completed
- 7254: SP#40 completed / Impacted TSs and TRs: 23.401; 23.060; 23.002; 23.246; 23.203; 23.107; 23.234; 23.271
- 7255: CP#43 completed / Impacted TSs and TRs: 29.274
- 7256: CP#43 completed
- 7257: SP#40 completed
- 7258: CP#43 completed / Impacted TSs and TRs: 29.275; 29.282
- 7259: CP#42 completed / Impacted TSs and TRs: 29.279
- 7260: CP#43 completed / Impacted TSs and TRs: 24.007; 24.301
- 7261: CP#43 completed / Impacted TSs and TRs: 24.007; 24.301
- 7262: CP#43 completed / Impacted TSs and TRs: 24.008; 24.301
- 7263: CP#42 completed / Impacted TSs and TRs: 29.213
- 7264: CP#43 completed / Impacted TSs and TRs: 29.272

| ID | WBS | Task | Type | Duration | Start | Finish | Complete | Baseline start | Baseline finish | Baseline duration | Constraint | Resources | Work | Actual work | Acronym | PCG approved | WI rapporteur name | WI rapporteur e-mail | Release | TSG approved | MCC resp | Acronym_3GU_Export | Impacted TSs and TRs | TSG stopped |
| --- | --- | --- | --- | --- | --- | --- | --- | --- | --- | --- | --- | --- | --- | --- | --- | --- | --- | --- | --- | --- | --- | --- | --- | --- |
| 7265 | 2412.4 | **SAE for Interoperation between LTE and legacy cellular PS accesses** |  | 788d? | 2007-02-05 A | 2009-03-06 A | 100% | 2007-02-05 | 2009-03-06 | 545d? |  | S2; C1; C4 | 48872h | 48872h | SAES-SA-FP_3GPP | 18 | Motorola | Irfan.Ali@motorola.com | Rel-8 | 35 | Maurice | SAES-SA-FP_3GPP |  |  |
| 7266 | 2412.4.1 | Stage 2 for Interoperation between LTE and 2G/3G |  | 424d? | 2007-02-05 A | 2008-09-18 A | 100% | 2007-02-05 | 2008-09-18 | 424d? | finish no earlier than 2008-09-11 | S2 | 3392h | 3392h | EPSto2_3G | 19 | Motorola | Irfan.Ali@motorola.com | Rel-8 | 37 | Maurice | EPSto2_3G | 23.401; 23.402 |  |
| 7267 | 2412.4.2 | Stage 3 for Inter-system mobility between E-UTRAN and 2G/3G |  | 545d? | 2007-02-05 A | 2009-03-06 A | 100% | 2007-02-05 | 2009-03-06 | 545d? | finish no earlier than 2009-03-06 | C1 | 4360h | 4360h | SAES-SA-FP_3GPP | 21 | Nokia Siemens Networks | robert.zaus@nsn.com | Rel-8 | 38 | Frederic | SAES-SA-FP_3GPP | 24.008; 24.301 |  |
| 7268 | 2412.4.3 | Stage 2 GPRS enhancements for LTE access |  | 272d? | 2007-09-04 A | 2008-09-18 A | 100% | 2007-09-04 | 2008-09-18 | 272d? | start no earlier than 2007-09-04 | S2 | 2176h | 2176h | SAES-GPRS_LTE | 18 | Vodafone | chris.pudney@vodafone.com | Rel-8 | 34 | Maurice | SAES-GPRS_LTE | 23.401 |  |
| 7269 | 2412.4.4 | Stage 2 GPRS for EPC (23.060, etc.) |  | 179d? | 2008-01-14 A | 2008-09-18 A | 100% | 2008-01-14 | 2008-09-18 | 179d? | finish no earlier than 2008-09-18 | S2 | 1432h | 1432h | SAES-SA-FP_3GPP | 21 | Nokia Siemens Networks | balazs.bertenyi@nsn.com | Rel-8 | 39 | Maurice |  | 23.060 |  |
| 7270 | 2412.4.5 | Stage 3 for EPC - GPRS |  | 545d? | 2007-02-05 A | 2009-03-06 A | 100% | 2007-02-05 | 2009-03-06 | 545d? | finish no earlier than 2009-03-06 | C4 | 4360h | 4360h | SAES-SA-FP_3GPP | 18 | Huawei | shahab.lavasani@huawei.com | Rel-8 | 34 | Kimmo |  | 29.274; 29.275; 29.281 |  |
| 7271 | 2412.4.6 | Stage 3 for EPC to UTRAN |  | 545d? | 2007-02-05 A | 2009-03-06 A | 100% | 2007-02-05 | 2009-03-06 | 545d? | finish no earlier than 2009-03-06 | C4 | 4360h | 4360h | SAES-SA-FP_3GPP | 21 | Huawei | shahab.lavasani@huawei.com | Rel-8 | 38 | Kimmo |  | 29.274; 29.275; 29.281 |  |
| 7272 | 2412.4.7 | Stage 3 for EPC to 3GPP2 |  | 545d? | 2007-02-05 A | 2009-03-06 A | 100% | 2007-02-05 | 2009-03-06 | 545d? | finish no earlier than 2009-03-06 | C4 | 4360h | 4360h | SAES-SA-FP_3GPP | 21 | Huawei | shahab.lavasani@huawei.com | Rel-8 | 38 | Kimmo |  | 29.277; 29.276 |  |
| 7273 | 2412.4.8 | Stage 2 for Interoperation between LTE and CDMA2000 |  | 329d? | 2007-06-18 A | 2008-09-18 A | 100% | 2007-06-18 | 2008-09-18 | 329d? | finish no earlier than 2008-04-25 | S2 | 2632h | 2632h | EPStoC2k | 19 | Motorola, Vodafone | Irfan.Ali@motorola.com, chris.pudney@vodafone.com | Rel-8 | 37 | Maurice | EPStoC2k | 23.401; 23.402 |  |
| 7274 | 2412.4.9 | Stage 3 for Inter-system mobility between E-UTRAN and CDMA2000 |  | 545d? | 2007-02-05 A | 2009-03-06 A | 100% | 2007-02-05 | 2009-03-06 | 545d? | finish no earlier than 2009-03-06 | C1 | 4360h | 4360h | SAES-SA-FP_3GPP | 19 | Nokia Siemens Networks | robert.zaus@nsn.com | Rel-8 | 36 | Frederic |  | 24.301; 24.302 |  |
| 7275 | 2412.4.10 | Stage 3 for MME - SGSN signalling free protocol |  | 545d? | 2007-02-05 A | 2009-03-06 A | 100% | 2007-02-05 | 2009-03-06 | 545d? | finish no earlier than 2009-03-06 | C4 | 4360h | 4360h | SAES-SA-FP_3GPP | 18 | Huawei | shahab.lavasani@huawei.com | Rel-8 | 34 | Kimmo |  | 29.272; 29.274 |  |
| 7276 | 2412.5 | **SAE for support for non-3GPP accesses** |  | 2062.38d? | 2007-01-02 A | 2012-06-15 A | 100% | 2007-01-02 | 2012-06-15 | 1429d? |  | S2; S3; C1; C4; IETF | 123829h | 123829h | SAES-SA-FP_n3GPP | 18 | Motorola | Irfan.Ali@motorola.com | Rel-8 | 35 | Maurice | SAES-SA-FP_n3GPP |  |  |
| 7277 | 7.2.4.1 | Stage 2 for Host-based Mobility aspects |  | 373d? | 2007-01-02 A | 2008-06-05 A | 100% | 2007-01-02 | 2008-06-05 | 373d? | finish no earlier than 2008-04-11 | S2 | 2984h | 2984h | SAES-SA-FP_n3GPP-HBMob | 18 | Motorola | Irfan.Ali@motorola.com | Rel-8 | 35 | Maurice | SAES-SA-FP_n3GPP-HBMob | 23.402 |  |
| 7278 | 7.2.4.2 | Stage 2 for Network-based Mobility aspects |  | 448d? | 2007-01-02 A | 2008-09-18 A | 100% | 2007-01-02 | 2008-09-18 | 448d? | finish no earlier than 2008-09-18 | S2 | 3584h | 3584h | SAES-SA-FP_n3GPP-NBMob | 18 | Motorola | Irfan.Ali@motorola.com | Rel-8 | 35 | Maurice | SAES-SA-FP_n3GPP-NBMob | 23.402 |  |
| 7279 | 2412.5.3 | Stage 3 for Mobility management based on DSMIPv6 |  | 480d? | 2007-02-05 A | 2008-12-05 A | 100% | 2007-02-05 | 2008-12-05 | 480d? | finish no earlier than 2008-12-05 | C1 | 3840h | 3840h | SAES-SA-FP_n3GPP | 19 | Nokia Siemens Networks | robert.zaus@nsn.com | Rel-8 | 36 | Frederic |  | 24.303 |  |
| 7280 | 2412.5.4 | (IETF) Stage 3 for Mobility management based on DSMIPv6 (draft-ietf-mip6-hiopt) |  | 589d? | 2007-02-05 A | 2012-06-15 A | 100% | 2007-02-05 | 2012-06-15 | 589d? | finish no earlier than 2012-09-14 | C1-IETF | 4712h | 4712h | SAES-SA-FP_n3GPP | 27 | Mark Jones |  | Rel-8 | 52 | Frederic |  | RFC 6610 (was draft-ietf-mip6-hiopt); RFC 6610 |  |
| 7281 | 2412.5.5 | (IETF) Stage 3 for Mobility management based on DSMIPv6 (RFC6275) |  | 356d? | 2007-02-05 A | 2011-07-29 A | 100% | 2007-02-05 | 2011-07-29 | 356d? | finish no earlier than 2011-07-29 | C1-IETF | 2848h | 2848h | SAES-SA-FP_n3GPP | 27 |  |  | Rel-8 | 52 | Frederic |  | RFC 6275 (was draft-ietf-mext-rfc3775bis) |  |
| 7282 | 2412.5.6 | Stage 3 for Mobility management based on MIP v4 |  | 480d? | 2007-02-05 A | 2008-12-05 A | 100% | 2007-02-05 | 2008-12-05 | 480d? | start no earlier than 2007-02-05 | C1 | 3840h | 3840h | SAES-SA-FP_n3GPP | 21 | Nokia Siemens Networks | robert.zaus@nsn.com | Rel-8 | 39 | Frederic |  | 24.304 |  |
| 7283 | 2412.5.7 | Stage 3 for Inter-system mobility between E-UTRAN and non 3GPP accesses |  | 545d? | 2007-02-05 A | 2009-03-06 A | 100% | 2007-02-05 | 2009-03-06 | 545d? | finish no earlier than 2009-03-06 | C1 | 4360h | 4360h | SAES-SA-FP_n3GPP | 21 | Nokia Siemens Networks | robert.zaus@nsn.com | Rel-8 | 38 | Frederic |  | 24.008; 24.301 |  |
| 7284 | 2412.5.8 | Stage 2 for Optimized Dual-Radio Handover with WiMAX |  | 249d? | 2007-06-25 A | 2008-06-05 A | 100% | 2007-06-25 | 2008-06-05 | 249d? | finish no earlier than 2008-06-09 | S2 | 1992h | 1992h | SAES-SA-FP_n3GPP-OptWIMAX | 19 | Motorola | Irfan.Ali@motorola.com | Rel-8 | 36 | Maurice | SAES-SA-FP_n3GPP-OptWIMAX | 23.402 |  |
| 7285 | 2412.5.9 | Stage 2 Security aspects for non-3GPP Access |  | 197d? | 2008-03-12 A | 2008-12-11 A | 100% | 2008-03-12 | 2008-12-11 | 197d? | finish no earlier than 2008-12-11 | S3 | 1576h | 1576h | SAES-SA-FP_n3GPP | 21 | Nokia Siemens Networks | marc.blommaert.ext@nsn.com | Rel-8 | 39 | Mirko |  | 33.402; 33.210; 33.310 |  |
| 7286 | 2412.5.10 | Stage 3 security aspects for DSMIPv6 Access |  | 480d? | 2007-02-05 A | 2008-12-05 A | 100% | 2007-02-05 | 2008-12-05 | 480d? | finish no earlier than 2008-12-05 | C1 | 3840h | 3840h | SAES-SA-FP_n3GPP | 19 | Nokia Siemens Networks | robert.zaus@nsn.com | Rel-8 | 37 | Frederic |  | 24.303 |  |
| 7287 | 2412.5.11 | Stage 3 security aspects for MIPv4 Access |  | 480d? | 2007-02-05 A | 2008-12-05 A | 100% | 2007-02-05 | 2008-12-05 | 480d? | finish no earlier than 2008-12-05 | C1 | 3840h | 3840h | SAES-SA-FP_n3GPP | 21 | Nokia Siemens Networks | robert.zaus@nsn.com | Rel-8 | 39 | Frederic |  | 24.304 |  |
| 7288 | 2412.5.12 | Stage 3 for Access to the EPC via non-3GPP access networks |  | 545d? | 2007-02-05 A | 2009-03-06 A | 100% | 2007-02-05 | 2009-03-06 | 545d? | finish no earlier than 2009-03-06 | C1 | 4360h | 4360h | SAES-SA-FP_n3GPP | 19 | Nokia Siemens Networks | robert.zaus@nsn.com | Rel-8 | 36 | Frederic |  | 24.302; 24.312 |  |
| 7289 | 2412.5.13 | Stage 3 for interfaces within EPC |  | 383d? | 2007-09-19 A | 2009-03-06 A | 100% | 2007-09-19 | 2009-03-06 | 383d? | finish no earlier than 2009-03-06 | C4 | 3064h | 3064h | SAES-SA-FP_n3GPP | 19 | Huawei | shahab.lavasani@huawei.com | Rel-8 | 37 | Kimmo |  | 29.274; 29.281 |  |
| 7290 | 2412.5.14 | Stage 3 for Interfaces EPC - non-3GPP IP access |  | 545d? | 2007-02-05 A | 2009-03-06 A | 100% | 2007-02-05 | 2009-03-06 | 545d? | finish no earlier than 2009-03-06 | C4 | 4360h | 4360h | SAES-SA-FP_n3GPP | 18 | Huawei | shahab.lavasani@huawei.com | Rel-8 | 34 | Kimmo |  | 29.273; 29.275 |  |
| 7291 | 2412.5.15 | (IETF) Stage 3 for Interfaces EPC - non-3GPP IP access |  | 1224.6d? | 2007-02-05 A | 2012-06-15 A | 100% | 2007-02-05 | 2012-06-15 | 1224.6d? | finish no earlier than 2012-06-15 | C4-IETF | 9788.8h | 9788.8h | SAES-SA-FP_n3GPP | 27 | Lionel Morand |  | Rel-8 | 52 | Kimmo |  | RFC 6611 (was draft-ietf-mip6-bootstrapping-integrated) |  |
| 7292 | 2412.5.16 | Stage 3 for AAA/HSS related |  | 480d? | 2007-02-05 A | 2008-12-05 A | 100% | 2007-02-05 | 2008-12-05 | 480d? | finish no earlier than 2008-12-05 | C4 | 3840h | 3840h | SAES-SA-FP_n3GPP | 18 | Huawei | shahab.lavasani@huawei.com | Rel-8 | 34 | Kimmo |  | 29.273 |  |
| 7293 | 2412.5.17 | Stage 3 for EPC - AAA interface |  | 480d? | 2007-02-05 A | 2008-12-05 A | 100% | 2007-02-05 | 2008-12-05 | 480d? | finish no earlier than 2008-12-05 | C4 | 3840h | 3840h | SAES-SA-FP_n3GPP | 18 | Huawei | shahab.lavasani@huawei.com | Rel-8 | 34 | Kimmo |  | 29.273 |  |
| 7294 | 2412.5.18 | Deleted (already covered) SAES-SA-FP_n3GPP Optimized Handover with CDMA | milestone | 0d? | 2007-06-25 A | 2007-06-25 A | 100% | 2007-06-25 | 2007-06-25 | 0d? | finish no earlier than 2007-06-25 | S2 |  |  | SAES-SA-FP_n3GPP-OptCDMA | 19 | Nokia Siemens Networks |  | Rel-8 | 36 | Maurice | SAES-SA-FP_n3GPP-OptCDMA |  | SP-37 |

Notes:
- 7265: CP#43 completed
- 7266: SP#41 completed
- 7267: CP#43 completed
- 7268: SP#41 completed
- 7269: SP#41 completed
- 7270: CP#43 completed
- 7271: CP#43 completed
- 7272: CP#43 completed
- 7273: SP#41 completed (except: Handover of multiple PDNs=>Rel-9)
- 7274: CP#43 completed
- 7275: CP#43 completed
- 7276: CP#43 completed. SP#39 retained in Rel-8 (in addition to the essential functionality defined in SP-070699). Replaces UID_340037
- 7277: SP#40 completed
- 7278: SP#41 completed
- 7279: CP#42 completed
- 7280: CP#56 completed; 9/4/21: RFC 6610 added;
- 7281: SP#53/IETF#81 completed
- 7282: CP#42 completed
- 7283: CP#43 completed
- 7284: SP#40 completed
- 7285: SP#42 completed
- 7286: CP#42 completed
- 7287: CP#42 completed
- 7288: CP#43 completed
- 7289: CP#43 completed
- 7290: CP#43 completed
- 7291: CP#56 completed
- 7292: CP#42 completed
- 7293: CP#42 completed
- 7294: SP#37 stopped

| ID | WBS | Task | Type | Duration | Start | Finish | Complete | Baseline start | Baseline finish | Baseline duration | Constraint | Resources | Work | Actual work | Acronym | PCG approved | WI rapporteur name | Release | TSG approved | MCC resp | Acronym_3GU_Export | Impacted TSs and TRs | PCG stopped | TSG stopped | Special Focus Doc |
| --- | --- | --- | --- | --- | --- | --- | --- | --- | --- | --- | --- | --- | --- | --- | --- | --- | --- | --- | --- | --- | --- | --- | --- | --- | --- |
| 7295 | 2412.6 | **Single Radio Voice Call Continuity for 3GPP (SRVCC)** |  | 823.25d? | 2007-01-02 A | 2009-03-06 A | 100% | 2007-01-02 | 2009-03-06 | 569d? |  | S2; C1; C4 | 19856h | 19856h | SAES-SRVCC | 18 | Nokia Siemens Networks | Rel-8 | 35 | Maurice | SAES-SRVCC |  |  |  |  |
| 7296 | 2412.6.1 | Stage 2 for 2G/3G SRVCC |  | 648.25d? | 2007-01-02 A | 2008-09-18 A | 100% | 2007-01-02 | 2008-09-18 | 448d? | finish no earlier than 2008-09-15 | S2 | 3584h | 3584h | SAES-SRVCC | 18 | Nokia Siemens Networks | Rel-8 | 35 | Maurice |  | New 23.216 |  |  |  |
| 7297 | 2412.6.2 | Stage 3 for SRVCC in EPS |  | 201d? | 2008-05-30 A | 2009-03-06 A | 100% | 2008-05-30 | 2009-03-06 | 201d? | finish no earlier than 2009-03-06 | C1 | 1608h | 1608h | SAES-SRVCC | 21 | Nokia Siemens Networks | Rel-8 | 41 | Frederic |  | 23.009; 24.008; New 24.301 |  |  |  |
| 7298 | 2412.6.3 | MME to MSC interface for SRVCC |  | 126d? | 2008-09-12 A | 2009-03-06 A | 100% | 2008-09-12 | 2009-03-06 | 126d? | finish no earlier than 2009-03-06 | C4 | 1008h | 1008h | SAES-SRVCC | 21 | Nokia Siemens Networks | Rel-8 | 41 | Kimmo |  | 23.003; 23.008; New (29.274; 29.277; 29.280) |  |  |  |
| 7299 | 2412.7 | Voice Call Continuity for CDMA2000 1X |  | 249d? | 2007-06-25 A | 2008-06-05 A | 100% | 2007-06-25 | 2008-06-05 | 249d? | finish no earlier than 2008-06-13 | S2 | 1992h | 1992h | SAES-VCC_1X | 19 | Nokia Siemens Networks | Rel-8 | 36 | Maurice | SAES-VCC_1X |  |  |  |  |
| 7300 | 2412.8 | SAE impacts on IMS |  | 373d? | 2007-01-02 A | 2008-06-05 A | 100% | 2007-01-02 | 2008-06-05 | 373d? | finish no earlier than 2008-06-13 | S2 | 2984h | 2984h | SAES-SA_IMS | 18 | Nokia Siemens Networks | Rel-8 | 35 | Maurice | SAES-SA_IMS |  |  |  |  |
| 7301 | 2412.9 | **CS Fallback in EPS** |  | 372.75d? | 2008-03-12 A | 2009-03-06 A | 100% | 2008-03-12 | 2009-03-06 | 258d? |  | S2; C1; C4 | 9384h | 9384h | SAES-CSFB | 21 | T-Mobile, Vodafone | Rel-8 | 39 | Maurice | SAES-CSFB |  |  |  |  |
| 7302 | 2412.9.1 | Stage 2 for CS Fallback in EPS |  | 62d? | 2008-03-12 A | 2008-06-05 A | 100% | 2008-03-12 | 2008-06-05 | 62d? | finish no earlier than 2008-12-05 | S2 | 496h | 496h | SAES-CSFB | 21 | T-Mobile, Vodafone | Rel-8 | 40 | Maurice |  | New (23.272; 23.401) |  |  |  |
| 7303 | 2412.9.2 | CT1 part of Stage 3 for CS Fallback in EPS |  | 201d? | 2008-05-30 A | 2009-03-06 A | 100% | 2008-05-30 | 2009-03-06 | 201d? | finish no earlier than 2009-03-06 | C1 | 1608h | 1608h | SAES-CSFB | 21 | NEC | Rel-8 | 40 | Frederic |  | 24.007; 24.008; 24.011; 29.018; New (24.301; 24.801; 29.118) |  |  |  |
| 7304 | 2412.9.3 | CT4 part of Stage 3 for CS Fallback in EPS |  | 136d? | 2008-05-30 A | 2008-12-05 A | 100% | 2008-05-30 | 2008-12-05 | 136d? | finish no earlier than 2008-12-05 | C4 | 1088h | 1088h | SAES-CSFB | 21 | NEC | Rel-8 | 40 | Kimmo |  | 23.007; 23.008; 29.274; New 29.277 |  |  |  |
| 7305 | 2412.10 | System enhancements for the use of IMS services in local breakout |  | 62d? | 2008-03-12 A | 2008-06-05 A | 100% | 2008-03-12 | 2008-06-05 | 62d? | finish no earlier than 2008-06-05 | S2 | 496h | 496h | SAES-IMS_LBO | 21 | Telecom Italia | Rel-8 | 39 | Maurice | SAES-IMS_LBO | 23.228; 23.221; 23.203 |  |  |  |
| 7306 | 2412.11 | **EPC Data Definitions** |  | 446.25d? | 2008-01-07 A | 2009-03-12 A | 100% | 2008-01-07 | 2009-03-12 | 309d? |  | S5 | 7144h | 7144h | EPC-OAM | 21 |  | Rel-8 | 39 | Mirko | EPC-OAM |  |  |  |  |
| 7307 | 2412.11.1 | EPC Network Resource Model (NRM) Integration Reference Point (IRP) |  | 309d? | 2008-01-07 A | 2009-03-12 A | 100% | 2008-01-07 | 2009-03-12 | 309d? | finish no earlier than 2009-03-12 | S5 | 2472h | 2472h | EPC-OAM | 21 | Huawei | Rel-8 | 38 | Mirko |  | New (32.751; 32.752; 32.753; 32.755) |  |  |  |
| 7308 | 2412.11.2 | Performance measurements for EPC |  | 275d? | 2008-02-22 A | 2009-03-12 A | 100% | 2008-02-22 | 2009-03-12 | 275d? | finish no earlier than 2009-03-12 | S5 | 2200h | 2200h | EPC-OAM | 21 | China Mobile | Rel-8 | 39 | Mirko |  | New 32.426 |  |  |  |
| 7309 | 2412.12 | EPC Charging |  | 309d? | 2008-01-07 A | 2009-03-12 A | 100% | 2008-01-07 | 2009-03-12 | 309d? | finish no earlier than 2009-03-12 | S5 | 2472h | 2472h | EPC-CH | 21 | Nokia Siemens Networks | Rel-8 | 38 | Mirko | EPC-CH | 32.240; 32.296; 32.251; 32.252; 32.298; 32.299 |  |  |  |
| 7310 | 2412.13 | Domain Name System Procedures for Evolved Packet System (DEPS) |  | 179.75d? | 2008-05-30 A | 2009-03-06 A | 100% | 2008-05-30 | 2009-03-06 | 179.75d? | finish no earlier than 2009-03-06 | C4 | 1438h | 1438h | SAES-DEPS | 21 | TeliaSonera | Rel-8 | 40 | Kimmo | SAES-DEPS | 23.003; New 29.303 |  |  |  |
| 7311 | 2412.14 | InterWorking Function (IWF) between MAP based and Diameter based interfaces |  | 126d? | 2008-09-12 A | 2009-03-06 A | 100% | 2008-09-12 | 2009-03-06 | 126d? | finish no earlier than 2009-03-06 | C4 | 1008h | 1008h | SAES-MAP2Diam | 21 | Huawei | Rel-8 | 41 | Kimmo | SAES-MAP2Diam | New 29.305 |  |  |  |
| 7312 | 2412.15 | **CT6 aspects of SAE** |  | 1226.12d? | 2008-03-07 A | 2011-06-03 A | 100% | 2008-03-07 | 2011-06-03 | 847d? |  | C6 | 13480h | 13480h | SAES | 21 | Nokia | Rel-8 | 39 | Xavier |  |  |  |  |  |
| 7313 | 2412.15.1 | Core specification for CT6 aspects of SAE |  | 465d? | 2008-03-07 A | 2009-05-29 A | 100% | 2008-03-07 | 2009-05-29 | 321d? | finish no earlier than 2009-05-29 | C6 | 2568h | 2568h | SAES | 21 | Nokia | Rel-8 | 39 | Xavier |  | 31.102; 31.111 |  |  |  |
| 7314 | 2412.15.2 | Test interworking of LTE Terminals with the USIM |  | 526d? | 2008-12-05 A | 2010-12-10 A | 100% | 2008-12-05 | 2010-12-10 | 526d? | finish no earlier than 2010-12-10 | C6 | 4208h | 4208h | SAES-USIM_LTE-Test | 22 | Comprion | Rel-8 | 42 | Xavier | SAES-USIM_LTE-Test | 31.121; 31.124 |  |  |  |
| 7315 | 2412.15.3 | Test interworking of IP Multimedia Services Identity Module (ISIM) terminals with IP Multimedia Subsystem (IMS) |  | 186d? | 2010-09-17 A | 2011-06-03 A | 100% | 2010-09-17 | 2011-06-03 | 186d? | finish no earlier than 2011-06-03 | C6 | 1488h | 1488h | SAES-ISIM_IMS_Test | 25 | Comprion | Rel-8 | 49 | Xavier | SAES-ISIM_IMS_Test | 31.121; 31.124; New 31.134 |  |  |  |
| 7316 | 2412.16 | Issues for CT1 TR 24.801 |  | 420d? | 2007-01-04 A | 2008-12-05 A | 100% | 2007-01-04 | 2008-12-05 | 420d? | finish no earlier than 2008-12-05 | C1 | 3360h | 3360h | SAES | 21 | Nokia Siemens Networks | Rel-8 | 39 | Frederic |  | 24.801 |  |  |  |
| 7317 | 2412.17 | Issues for CT3 TR 29.804 |  | 420d? | 2007-02-05 A | 2008-09-12 A | 100% | 2007-02-05 | 2008-09-12 | 420d? | finish no earlier than 2008-12-12 | C3 | 3360h | 3360h | SAES | 21 | Ericsson | Rel-8 | 39 | Adrian |  | 29.804 |  |  |  |
| 7318 | 2412.18 | Deleted - Issues for CT4 TR 29.803 |  | 420d? | 2007-01-04 A | 2008-09-12 A | 100% | 2007-01-04 | 2008-09-12 | 420d? | finish no earlier than 2008-12-11 | C4 | 3360h | 3360h | SAES | 21 | Huawei | Rel-8 | 39 | Kimmo |  | 29.803 | PCG-21 | CP-41 |  |
| 7319 | 2412.19 | Deleted (covered by 380068): Functions and procedures for SAE to support LCS | milestone | 0d? | 2008-03-03 A | 2008-03-03 A | 100% | 2008-03-03 | 2008-03-03 | 0d? | finish no earlier than 2008-03-03 | S2 |  |  | SAES-SA-FP_LCS | 18 | Nokia Siemens Networks | Rel-8 | 35 | Maurice | SAES-SA-FP_LCS |  |  | SP-37 |  |
| 7320 | 2412.20 | Deleted (covered by 380064): SAE aspects of Emergency Calls | milestone | 0d? | 2008-03-03 A | 2008-03-03 A | 100% | 2008-03-03 | 2008-03-03 | 0d? | start no earlier than 2008-03-03 | S2 |  |  | SAES-SA-EmCall | 18 | Nokia Siemens Networks | Rel-8 | 35 | Maurice | SAES-SA-EmCall |  |  | SP-37 | Public Safety (I-A) |

Notes:
- 7295: CP#43 completed. SP#38 WID approved (extract from SAE WID SP-070817). / WI rapporteur e-mail: curt.c.wong@nokia.com
- 7296: SP#41 completed. SP#38 WID approved / WI rapporteur e-mail: curt.c.wong@nokia.com
- 7297: CP#43 completed / WI rapporteur e-mail: robert.zaus@nsn.com
- 7298: CP#43 completed / WI rapporteur e-mail: Giorgi Gulbani
- 7299: SP#40 completed / WI rapporteur e-mail: balazs.bertenyi@nsn.com
- 7300: SP#40 completed / WI rapporteur e-mail: balazs.bertenyi@nsn.com
- 7301: CP#43 completed / WI rapporteur e-mail: sabine.demel@t-mobile.at, chris.pudney@vodafone.com
- 7302: SP#40 completed / WI rapporteur e-mail: sabine.demel@t-mobile.at, chris.pudney@vodafone.com
- 7303: CP#43 completed / WI rapporteur e-mail: yannick.lair@nectech.fr
- 7304: CP#42 completed / WI rapporteur e-mail: yannick.lair@nectech.fr
- 7305: SP#40 completed / WI rapporteur e-mail: mario.madella@telecomitalia.it
- 7306: SP#43 completed
- 7307: SP#43 completed / WI rapporteur e-mail: WANG, Xuelong
- 7308: SP#43 completed / WI rapporteur e-mail: Li Jian (lijian@chinamobile.com), Liang Shuangchun (liangshuangchun@cmdi.chinamobile.com)
- 7309: SP#43 completed / WI rapporteur e-mail: Gerald.Goermer@nsn.com
- 7310: CP#43 completed / WI rapporteur e-mail: jouni.korhonen@teliasonera.com
- 7311: CP#43 completed. Triggered by UID_380023 (FS_MAP2Diam) / WI rapporteur e-mail: liming49985@huawei.com
- 7312: CP#44 completed core specification / WI rapporteur e-mail: Rune Lindholm
- 7313: CP#44 completed (specified Network Measurement Results collection via USAT) / WI rapporteur e-mail: Rune Lindholm
- 7314: CP#50 completed. Steering of Roaming test cases have been introduced. Remaining issues CSG display testing (Provide Local Information, Call Control for EPS/PDN, Event Download (Access Technology Change - Multiple Access Technologies) / WI rapporteur e-mail: Udo Willenbrink (uwillenbrink@comprion.com )
- 7315: CP#52 completed. Linked to R5 UID_1273 Provisioning of IP-based multimedia services (24.229, 31.103), R8 UID_390021 CT6 aspects of SAE, UID_420018 Test interworking of LTE Terminals with the USIM, R UID_450018 Testing SMS over IMS in E-UTRAN (34.229). / WI rapporteur e-mail: Udo Willenbrink (uwillenbrink@comprion.com )
- 7316: CP#43 completed / WI rapporteur e-mail: robert.zaus@nsn.com
- 7317: CP#41 completed / WI rapporteur e-mail: j.javier.pastor@ericsson.com
- 7318: CP#41 Work stopped and continued in Normative specifications
- 7319: SP#37 stopped
- 7320: SP#37 stopped

| ID | WBS | Task | Type | Duration | Start | Finish | Complete | Baseline start | Baseline finish | Baseline duration | Constraint | Resources | Work | Actual work | Acronym | PCG approved | Release | TSG approved | MCC resp | TSG stopped | Acronym_3GU_Export | WI rapporteur name | WI rapporteur e-mail | Status Report | PCG stopped |
| --- | --- | --- | --- | --- | --- | --- | --- | --- | --- | --- | --- | --- | --- | --- | --- | --- | --- | --- | --- | --- | --- | --- | --- | --- | --- |
| 7321 | 2412.21 | **Deleted - CT aspects of SAES** |  | 198.75d? | 2007-09-04 A | 2008-03-14 A | 100% | 2007-09-04 | 2008-03-14 | 138d? |  | C3; C1; C4 | 1104h | 1104h | SAES-St3 | 18 | Rel-8 | 34 | Frederic | SP-37 | SAES-St3 |  |  |  |  |
| 7322 | 2412.21.1 | Deleted - CT1 aspects of SAES | milestone | 0d? | 2007-09-04 A | 2007-09-04 A | 100% | 2007-09-04 | 2007-09-04 | 0d? | start no earlier than 2007-09-04 | C1 |  |  | SAES-St3 | 18 | Rel-8 | 35 | Frederic | SP-37 |  |  |  |  |  |
| 7323 | 2412.21.2 | Deleted - Interoperability | milestone | 0d? | 2008-03-14 A | 2008-03-14 A | 100% | 2008-03-14 | 2008-03-14 | 0d? | start no earlier than 2008-03-14 | C1 |  |  | SAES-St3-interop | 18 | Rel-8 | 34 | Frederic | SP-37 | SAES-St3-interop |  |  |  |  |
| 7324 | 2412.21.3 | Deleted - CT3 aspects of SAES | milestone | 0d? | 2007-09-04 A | 2007-09-04 A | 100% | 2007-09-04 | 2007-09-04 | 0d? | start no earlier than 2007-09-04 | C3 |  |  | SAES | 18 | Rel-8 | 35 | Adrian | SP-37 |  |  |  |  |  |
| 7325 | 2412.21.4 | Deleted - CT4 aspects of SAES | milestone | 0d? | 2007-09-04 A | 2007-09-04 A | 100% | 2007-09-04 | 2007-09-04 | 0d? | start no earlier than 2007-09-04 | C4 |  |  | SAES | 18 | Rel-8 | 35 | Kimmo | SP-37 |  |  |  |  |  |
| 7326 | 2412.21.5 | Deleted - UE to EPC NAS signalling (incl. MBMS and QoS aspects) | milestone | 0d? | 2008-03-14 A | 2008-03-14 A | 100% | 2008-03-14 | 2008-03-14 | 0d? | start no earlier than 2008-03-14 | C1 |  |  | SAES-St3-sig | 18 | Rel-8 | 34 | Frederic | SP-37 | SAES-St3-sig |  |  |  |  |
| 7327 | 2412.21.6 | Deleted - User and Control plane protocols | milestone | 0d? | 2007-09-21 A | 2007-09-21 A | 100% | 2007-09-21 | 2007-09-21 | 0d? | start no earlier than 2007-09-21 | C4 |  |  | SAES-St3-prot | 18 | Rel-8 | 34 | Kimmo | SP-37 | SAES-St3-prot |  |  |  |  |
| 7328 | 2412.22 | Deleted - Architecture enhancements for non-3GPP accesses | milestone | 0d? | 2007-09-04 A | 2007-09-04 A | 100% | 2007-09-04 | 2007-09-04 | 0d? | start no earlier than 2007-09-04 | S2 |  |  | SAES-non_3GPP | 18 | Rel-8 | 34 | Maurice | SP-34 | SAES-non_3GPP | Motorola | Irfan.Ali@motorola.com |  |  |
| 7329 | 2412.23 | Deleted - Stage 2 of architecture for the 3GPP System Architecture Evolution | milestone | 0d? | 2007-10-02 A | 2007-10-02 A | 100% | 2007-10-02 | 2007-10-02 | 0d? | start no earlier than 2007-10-02 | S2 |  |  | SAES-St2 | 17 | Rel-8 | 32 | Maurice | SP-34 | SAES-St2 | Vodafone | chris.pudney@vodafone.com |  |  |
| 7330 | 2412.24 | Deleted - SA aspects of System Architecture Evolution |  | 557.25d? | 2006-04-12 A | 2007-10-01 A | 100% | 2006-04-12 | 2007-10-01 | 384d? | finish no earlier than 2007-10-02 | S2 | 3072h | 3072h | SAES-SA | 18 | Rel-8 | 35 | Maurice | SP-34 | SAES-SA |  |  |  |  |
| 7331 | 2413 | Conformance Test Aspects – Mobility management based on DSMIPv6 (Dual-Stack Mobile IPv6) |  | 261d? | 2009-09-18 A | 2010-09-17 A | 100% | 2009-09-18 | 2010-09-17 | 261d? | finish no earlier than 2010-09-17 | R5 | 2088h | 2088h | DSMIPv6_UEConTest | 23 | Rel-8 | 45 | Ingbert |  | DSMIPv6_UEConTest | Qualcomm | Lena Chaponniere (lchaponn@qualcomm.com) | RP-100738 |  |
| 7332 | 2414 | **IMS Centralized Service control** |  | 3441.72d? | 2005-11-01 A | 2014-12-09 A | 100% | 2005-11-01 | 2014-12-05 | 2387.1d? |  | S1; S2; C1; C3; C4; IETF | 239598h | 239598h | ICSRA | 19 | Rel-8 | 37 | Alain |  | ICSRA | AT&T | Randolph Wohlert (rwohlert@tri.sbc.com) |  |  |
| 7333 | 2414.1 | Stage 1 for ICS Requirement and Architecture |  | 138d? | 2007-09-03 A | 2008-03-12 A | 100% | 2007-09-03 | 2008-03-12 | 138d? | finish no earlier than 2007-12-14 | S1 | 1104h | 1104h | ICSRA | 21 | Rel-8 | 38 | Alain |  |  | AT&T | Randolph Wohlert (rwohlert@tri.sbc.com) |  |  |
| 7334 | 2414.2 | Stage 2 for ICS Requirement and Architecture |  | 125d? | 2007-12-14 A | 2008-06-05 A | 100% | 2007-12-14 | 2008-06-05 | 125d? | start no earlier than 2007-12-14 | S2 | 1000h | 1000h | ICSRA-St2 | 21 | Rel-8 | 38 | Maurice |  | ICSRA-St2 | Alcatel-Lucent |  |  |  |
| 7335 | 2414.3 | **Stage 3 for ICSRA – Protocol, Addressing, Subscriber Data** |  | 3441.72d? | 2005-11-01 A | 2014-12-09 A | 100% | 2005-11-01 | 2014-12-05 | 2387.1d? |  | C1; C3; C4; IETF | 122674h | 122674h | ICSRA |  | Rel-8 |  | Frederic |  |  | Ericsson | sean.schneyer@ericsson.com |  |  |
| 7336 | 2414.3.1 | CT1 aspects - Stage 3 for ICSRA |  | 201d? | 2008-05-30 A | 2009-03-06 A | 100% | 2008-05-30 | 2009-03-06 | 201d? | finish no earlier than 2009-03-06 | C1 | 1608h | 1608h | ICSRA | 21 | Rel-8 | 40 | Frederic |  |  | Ericsson | Sean Schneyer |  |  |
| 7337 | 2414.3.2 | (IETF) CT1 aspects - Stage 3 for ICSRA (draft-ietf-salud-alert-info-urns) |  | 1244d? | 2008-05-30 A | 2014-12-09 A | 100% | 2008-05-30 | 2014-12-05 | 1242d? | finish no earlier than 2014-12-09 | C1-IETF | 9952h | 9952h | ICSRA | 27 | Rel-8 | 52 | Frederic |  |  | Roland Jesske | Roland Jesske |  |  |
| 7338 | 2414.3.3 | (IETF) CT1 aspects - Stage 3 for ICSRA (RFC 6871) |  | 779d? | 2008-05-30 A | 2013-03-01 A | 100% | 2008-05-30 | 2013-03-01 | 779d? | finish no earlier than 2013-02-28 | C1-IETF | 6232h | 6232h | ICSRA | 27 | Rel-8 | 52 | Frederic |  |  | Andrew Allen |  |  |  |
| 7339 | 2414.3.4 | (IETF) CT1 aspects - Stage 3 for ICSRA (RFC 7195) |  | 1117d? | 2008-05-30 A | 2014-06-13 A | 100% | 2008-05-30 | 2014-06-13 | 1117d? | finish no earlier than 2014-06-13 | C1-IETF | 8936h | 8936h | ICSRA | 27 | Rel-8 | 52 | Frederic |  |  | Andrew Allen |  |  |  |
| 7340 | 2414.3.5 | (IETF) CT1 aspects - Stage 3 for ICSRA (RFC 7006) |  | 977d? | 2008-06-03 A | 2013-12-06 A | 100% | 2008-06-03 | 2013-12-06 | 977d? | finish no earlier than 2013-12-06 | C1-IETF | 7816h | 7816h | ICSRA | 27 | Rel-8 | 52 | Frederic |  |  | Andrew Allen |  |  |  |
| 7341 | 2414.3.6 | CT3 aspects - Stage 3 for ICSRA |  | 201d? | 2008-05-30 A | 2009-03-06 A | 100% | 2008-05-30 | 2009-03-06 | 201d? | finish no earlier than 2009-03-06 | C3 | 1608h | 1608h | ICSRA | 21 | Rel-8 | 40 | Adrian |  |  | Mavenir | Brett Wallis ( brett@mavenir.com) |  |  |
| 7342 | 2414.3.7 | CT4 aspects - Stage 3 for ICSRA |  | 136d? | 2008-05-30 A | 2008-12-05 A | 100% | 2008-05-30 | 2008-12-05 | 136d? | start no earlier than 2008-05-30 | C4 | 1088h | 1088h | ICSRA | 21 | Rel-8 | 40 | Kimmo |  |  | Ericsson | Sean Schneyer |  |  |
| 7343 | 2414.3.8 | (IETF) CT4 aspects - Stage 3 for ICSRA (RFC 7254) |  | 1034.8d? | 2005-11-01 A | 2014-06-13 A | 100% | 2005-11-01 | 2014-06-13 | 1034.8d? | finish no earlier than 2014-06-13 | C4-IETF | 8278.4h | 8278.4h | ICSRA | 27 | Rel-8 | 52 | Kimmo |  |  | Andrew Allen |  |  |  |
| 7344 | 2414.3.9 | Deleted - Stage 3 for ICSRA – I1 interface |  | 76d? | 2008-05-30 A | 2008-09-12 A | 100% | 2008-05-30 | 2008-09-12 | 76d? | finish no earlier than 2008-09-12 | C1 | 608h | 608h | ICSRA | 21 | Rel-8 | 40 | Frederic | CP-41 |  | Huawei | xupeili@huawei.com |  | PCG-21 |

Notes:
- 7321: SP#37 stopped
- 7322: SP#37 stopped
- 7323: SP#37 stopped
- 7324: SP#37 stopped
- 7325: SP#37 stopped / Impacted TSs and TRs: 29.803
- 7326: SP#37 stopped
- 7327: SP#37 stopped
- 7328: SP#34 stopped. Replaced by UID_350027 and its children / Impacted TSs and TRs: 23.402
- 7329: SP#34 stopped. Replaced by UIDs 340018 and 340037. (SP#34 report discussion of SP-060917.) / Impacted TSs and TRs: 23.002; 23.060; 23.107; 23.203; 23.228; 23.234; 23.246; 23.271; 23.279
- 7330: SP#34 stopped
- 7331: RP#49 completed. Testing for CT1's UID_360022 (24.303) under Rel-8 Feature SAES / Impacted TSs and TRs: 36.508; 36.523-1; 36.523-2; 36.523-3
- 7332: CP#46 completed
- 7333: SP#39 completed / Impacted TSs and TRs: 22.101
- 7334: SP#40 completed / Impacted TSs and TRs: 23.292; 23.206
- 7335: CP#46 completed
- 7336: CP#46 completed / Impacted TSs and TRs: 24.229; new (24.292; 24.286)
- 7337: In RFC Editors Queue. Dec.14: 75->90¦7/3/16: 90%->100; 9/4/21: RFC 7462 added; / Impacted TSs and TRs: draft-ietf-salud-alert-info-urns; RFC 7462
- 7338: CP#59 completed / Impacted TSs and TRs: RFC 6871 (was draft-ietf-mmusic-sdp-media-capabilities)
- 7339: CP#64 complete / Impacted TSs and TRs: RFC 7195 (was draft-ietf-mmusic-sdp-cs)
- 7340: CP#62 completed / Impacted TSs and TRs: RFC7006 (was draft-ietf-mmusic-sdp-miscellaneous-caps)
- 7341: CP#43 completed / Impacted TSs and TRs: new 29.292
- 7342: CP#42 completed / Impacted TSs and TRs: 23.003; 29.232; 23.018; 29.002
- 7343: CP#64 complete / Impacted TSs and TRs: RFC 7254 (was draft-montemurro-gsma-imei-urn)
- 7344: CP#41 work stopped / Impacted TSs and TRs: 24.293

| ID | WBS | Task | Duration | Start | Finish | Complete | Baseline start | Baseline finish | Baseline duration | Constraint | Resources | Work | Actual work | Acronym | PCG approved | Release | TSG approved | MCC resp | Acronym_3GU_Export | WI rapporteur name | WI rapporteur e-mail |
| --- | --- | --- | --- | --- | --- | --- | --- | --- | --- | --- | --- | --- | --- | --- | --- | --- | --- | --- | --- | --- | --- |
| 7345 | 2415 | **IMS Multimedia Telephony and Supplementary Services** | 2876.12d? | 2007-05-02 A | 2014-12-09 A | 100% | 2007-05-02 | 2014-12-05 | 1997d? |  | S1; S5; C1; C3; C4; IETF | 272222h | 272222h | IMSTSS | 19 | Rel-8 | 37 | Alain | IMSTSS |  |  |
| 7346 | 2415.1 | **General aspects of IMS Sup Services** | 570.5d? | 2007-09-03 A | 2009-03-06 A | 100% | 2007-09-03 | 2009-03-06 | 395d? |  | S1; C1; C3; C4 | 19232h | 19232h | IMSSS-Gal | 19 | Rel-8 | 37 | Alain | IMSSS-Gal | Ericsson | Susana Sabater |
| 7347 | 2415.1.1 | Service and Capability for Core IMS - inclusion of TISPAN requirements | 75d? | 2007-09-03 A | 2007-12-14 A | 100% | 2007-09-03 | 2007-12-14 | 75d? | finish no earlier than 2007-12-14 | S1 | 600h | 600h | TISCAPR8 | 19 | Rel-8 | 37 | Alain | TISCAPR8 | Ericsson | Susana Sabater |
| 7348 | 2415.1.2 | Documentation of TISPAN R1 and R2 in CT1 | 208d? | 2007-11-28 A | 2008-09-12 A | 100% | 2007-11-28 | 2008-09-12 | 208d? | finish no earlier than 2008-09-12 | C1 | 1664h | 1664h | REDOC_TIS-C1 | 21 | Rel-8 | 38 | Frederic | REDOC_TIS-C1 | Nokia Siemens Networks | peter.leis@nsn.com |
| 7349 | 2415.1.3 | Documentation of TISPAN R1 and R2 in CT3 | 333d? | 2007-11-28 A | 2009-03-06 A | 100% | 2007-11-28 | 2009-03-06 | 333d? | finish no earlier than 2009-03-06 | C3 | 2664h | 2664h | REDOC_TIS-C3 | 21 | Rel-8 | 38 | Adrian | REDOC_TIS-C3 | Nokia Siemens Networks | peter.leis@nsn.com |
| 7350 | 2415.1.4 | Documentation of TISPAN R1 and R2 in CT4 | 208d? | 2007-11-28 A | 2008-09-12 A | 100% | 2007-11-28 | 2008-09-12 | 208d? | finish no earlier than 2008-09-12 | C4 | 1664h | 1664h | REDOC_TIS-C4 | 21 | Rel-8 | 38 | Kimmo | REDOC_TIS-C4 | Nokia Siemens Networks | peter.leis@nsn.com |
| 7351 | 2415.2 | **IMS Multimedia Telephony Service** | 569.5d? | 2007-09-10 A | 2009-03-12 A | 100% | 2007-09-10 | 2009-03-12 | 394d? |  | S1; S5 | 9296h | 9296h | IMS-MMTel | 19 | Rel-8 | 37 | Alain | IMS-MMTel |  |  |
| 7352 | 2415.2.1 | Merging TISPAN MMTel [requirements] for Common IMS | 65d? | 2007-09-10 A | 2007-12-07 A | 100% | 2007-09-10 | 2007-12-07 | 65d? | finish no earlier than 2007-12-07 | S1 | 520h | 520h | TMMTEL | 19 | Rel-8 | 37 | Alain | TMMTEL | Nokia Siemens Networks |  |
| 7353 | 2415.2.2 | Multimedia Telephony Service and Supplementary Services (MMTel) offline Charging | 309d? | 2008-01-07 A | 2009-03-12 A | 100% | 2008-01-07 | 2009-03-12 | 309d? | finish no earlier than 2009-03-12 | S5 | 2472h | 2472h | MMTel-CH | 21 | Rel-8 | 38 | Mirko | MMTel-CH | Alcatel-Lucent | maryse.gardella@alcatel-lucent.com |
| 7354 | 2415.3 | **Call Completion on Busy Subscriber (CCBS)/Call Completion on Non-Reachable (CCNR) on IMS** | 2314.5d? | 2007-05-02 A | 2013-06-14 A | 100% | 2007-05-02 | 2013-06-14 | 1608d? |  | C1; C3; IETF | 71528h | 71528h | CCBS_CCNR | 21 | Rel-8 | 38 | Frederic | CCBS_CCNR | Deutsche Telekom | martin.huelsemann@telekom.de |
| 7355 | 2415.3.1 | CT1 part of Stage 3 CCBS_CCNR | 483d? | 2007-05-02 A | 2009-03-06 A | 100% | 2007-05-02 | 2009-03-06 | 483d? | finish no earlier than 2009-03-06 | C1 | 3864h | 3864h | CCBS_CCNR | 21 | Rel-8 | 38 | Frederic |  | Deutsche Telekom | martin.huelsemann@telekom.de |
| 7356 | 2415.3.2 | CT3 part of Stage 3 CCBS_CCNR | 418d? | 2007-05-02 A | 2008-12-05 A | 100% | 2007-05-02 | 2008-12-05 | 418d? | finish no earlier than 2008-12-05 | C3 | 3344h | 3344h | CCBS_CCNR | 21 | Rel-8 | 38 | Adrian |  | Deutsche Telekom | martin.huelsemann@telekom.de |
| 7357 | 2415.3.3 | (IETF) Stage 3 CCBS_CCNR [RFC 6910 (was draft-ietf-bliss-call-completion)] | 1608d? | 2007-05-02 A | 2013-06-14 A | 100% | 2007-05-02 | 2013-06-14 | 1608d? | finish no earlier than 2013-06-10 | C1-IETF; C3-IETF | 25728h | 25728h | CCBS_CCNR | 27 | Rel-8 | 52 | Frederic |  | Roland Jesske |  |
| 7358 | 2415.4 | **Flexible Alerting** | 416.25d? | 2008-01-30 A | 2009-03-06 A | 100% | 2008-01-30 | 2009-03-06 | 288d? |  | S1; C1 | 7582.4h | 7582.4h | FA | 21 | Rel-8 | 39 | Alain | FA | Nortel | milanpa@nortel.com |
| 7359 | 2415.4.1 | Stage 1 FA | 132.5d? | 2008-01-30 A | 2008-06-05 A | 100% | 2008-01-30 | 2008-06-05 | 92d? |  | S1 | 670.4h | 670.4h | FA | 21 | Rel-8 | 39 | Alain |  | Telecom Italia |  |
| 7360 | 2415.4.2 | Stage 3 FA | 288d? | 2008-01-30 A | 2009-03-06 A | 100% | 2008-01-30 | 2009-03-06 | 288d? | finish no earlier than 2009-03-06 | C1 | 2304h | 2304h | FA | 21 | Rel-8 | 39 | Frederic |  | Nortel | milanpa@nortel.com |
| 7361 | 2415.5 | **Communication Wait on IMS** | 2823.38d? | 2007-06-22 A | 2014-12-09 A | 100% | 2007-06-22 | 2014-12-05 | 1960d? |  | C1; C3; IETF | 61880h | 61880h | CW_IMS | 21 | Rel-8 | 38 | Frederic | CW_IMS | Deutsche Telekom | martin.huelsemann@telekom.de |
| 7362 | 2415.5.1 | CT1 part of Stage 3 CW-IMS | 331d? | 2007-11-30 A | 2009-03-06 A | 100% | 2007-11-30 | 2009-03-06 | 331d? | finish no earlier than 2009-03-06 | C1 | 2648h | 2648h | CW_IMS | 21 | Rel-8 | 38 | Frederic |  | Deutsche Telekom | martin.huelsemann@telekom.de |
| 7363 | 2415.5.2 | (IETF) Stage 3 CW-IMS (salud-alert-info-urns) | 1244d? | 2007-06-22 A | 2014-12-09 A | 100% | 2007-06-22 | 2014-12-05 | 1242d? | finish no earlier than 2014-12-09 | C1-IETF | 9952h | 9952h | CW_IMS | 27 | Rel-8 | 52 | Frederic |  | Roland Jesske | Roland Jesske |
| 7364 | 2415.5.3 | CT3 part of Stage 3 CW-IMS | 265d? | 2007-11-30 A | 2008-12-04 A | 100% | 2007-11-30 | 2008-12-04 | 265d? | finish no earlier than 2008-12-05 | C3 | 2120h | 2120h | CW_IMS | 21 | Rel-8 | 38 | Adrian |  | Deutsche Telekom | martin.huelsemann@telekom.de |
| 7365 | 2415.6 | **IMS Charging** | 562.25d? | 2007-09-17 A | 2009-03-12 A | 100% | 2007-09-17 | 2009-03-12 | 389d? |  | S5 | 6608h | 6608h | CH8_IMS | 19 | Rel-8 | 37 | Mirko | CH8 | Alcatel-Lucent | maryse.gardella@alcatel-lucent.com |
| 7366 | 2415.6.1 | Add Interconnection Border Control Function (IBCF) to IMS Charging | 128d? | 2007-09-17 A | 2008-03-12 A | 100% | 2007-09-17 | 2008-03-12 | 128d? | finish no earlier than 2008-03-12 | S5 | 1024h | 1024h | CH8_IMS | 19 | Rel-8 | 37 | Mirko |  | Alcatel-Lucent | maryse.gardella@alcatel-lucent.com |
| 7367 | 2415.6.2 | Advice of Charge (AoC) support in IMS Charging | 309d? | 2008-01-07 A | 2009-03-12 A | 100% | 2008-01-07 | 2009-03-12 | 309d? | finish no earlier than 2009-03-12 | S5 | 2472h | 2472h | CH8_IMS | 21 | Rel-8 | 38 | Mirko |  | Nokia Siemens Networks | Gerald.Goermer@nsn.com |
| 7368 | 2416 | **3GPP2 Input to Common IMS** | 290d? | 2008-03-07 A | 2008-12-11 A | 100% | 2008-03-07 | 2008-12-11 | 200d? |  | S1; S2; S3; C1; C3; C4 | 21453.2h | 21453.2h | CIMS_3GPP2 | 21 | Rel-8 | 39 | Alain | CIMS_3GPP2, IMS_Common | Nortel | Amar Deol (deola@nortelnetworks.com) |
| 7369 | 2416.1 | Stage 1 CIMS_3GPP2 | 30.65d? | 2008-03-12 A | 2008-06-05 A | 100% | 2008-03-12 | 2008-06-05 | 30.65d? | finish no earlier than 2008-06-12 | S1 | 245.2h | 245.2h | CIMS_3GPP2 | 21 | Rel-8 | 39 | Alain |  | Nortel | Amar Deol (deola@nortelnetworks.com) |
| 7370 | 2416.2 | Stage 2 CIMS_3GPP2 | 62d? | 2008-03-12 A | 2008-06-05 A | 100% | 2008-03-12 | 2008-06-05 | 62d? | finish no earlier than 2008-09-11 | S2 | 496h | 496h | CIMS_3GPP2 | 21 | Rel-8 | 39 | Maurice |  | Nortel | Amar Deol (deola@nortelnetworks.com) |
| 7371 | 2416.3 | Security CIMS_3GPP2 | 197d? | 2008-03-12 A | 2008-12-11 A | 100% | 2008-03-12 | 2008-12-11 | 197d? | finish no earlier than 2008-12-11 | S3 | 1576h | 1576h | CIMS_3GPP2 | 21 | Rel-8 | 39 | Mirko |  | Nortel | Amar Deol (deola@nortelnetworks.com) |

Notes:
- 7345: SP#43 completed
- 7346: CP#43 completed
- 7347: SP#39 completed / Impacted TSs and TRs: 22.228; 22.115; 22.101
- 7348: CP#41 completed / Impacted TSs and TRs: 24.141; 24.147; 24.173; 24.229; 24.247; 24.341; 24.604; 24.605; 24.606; 24.607; 24.608; 24.610; 24.611; 24.616; 24.623; 24.628; 24.629; 24.647; 24.654
- 7349: CP#43 completed / Impacted TSs and TRs: 29.162; 29.163; 29.658
- 7350: CP#41 completed / Impacted TSs and TRs: 29.228; 29.229
- 7351: SP#43 completed
- 7352: SP#38 completed / Impacted TSs and TRs: 22.173
- 7353: CP#43 completed / Impacted TSs and TRs: 32.275; 32.298/299
- 7354: CP#43 completed
- 7355: CP#43 completed / Impacted TSs and TRs: 24.642; 24.229; 24.173
- 7356: CP#42 completed / Impacted TSs and TRs: 29.163
- 7357: CP#60 completed / Impacted TSs and TRs: RFC 6910 (was draft-ietf-bliss-call-completion)
- 7358: CP#43 completed
- 7359: SP#40 completed / Impacted TSs and TRs: 22.173
- 7360: CP#43 completed / Impacted TSs and TRs: 24.239; 24.173
- 7361: CP#43 completed
- 7362: CP#43 completed / Impacted TSs and TRs: 24.615; 24.229; 24.173
- 7363: In RFC Editors Queue. Dec.14: 75->90¦7/3/16: 90%->100; 9/4/21: RFC 7462 added; / Impacted TSs and TRs: draft-ietf-salud-alert-info-urns; RFC 7462
- 7364: CP#42 completed / Impacted TSs and TRs: 29.163
- 7365: SP#39 completed / Impacted TSs and TRs: 32.260; 32.298
- 7366: SP#39 completed / Impacted TSs and TRs: 32.260; 32.298
- 7367: SP#43 completed / Impacted TSs and TRs: 32.240; 32.260; 32.296; 32.298; 32.299; new 32.280
- 7368: TSG#42 completed. Acronym changed from "CIMS_3GPP2, IMS_Common"
- 7369: SP#40 completed. Acronym changed from "CIMS_3GPP2, IMS_Common" / Impacted TSs and TRs: 22.228; 22.173; 22.101; 22.153
- 7370: SP#40 completed. Acronym changed from "CIMS_3GPP2, IMS_Common" / Impacted TSs and TRs: 23.002; 23.141; 23.203; 23.167; 23.228
- 7371: SP#42 completed [issues addressed under UID_370078 (IMS-Sec)]. Acronym changed from "CIMS_3GPP2, IMS_Common" / Impacted TSs and TRs: 33.141; 33.203; 33.210

| ID | WBS | Task | Duration | Start | Finish | Complete | Baseline start | Baseline finish | Baseline duration | Constraint | Resources | Work | Actual work | Acronym | PCG approved | WI rapporteur name | WI rapporteur e-mail | Release | TSG approved | MCC resp | Acronym_3GU_Export | TSG stopped |
| --- | --- | --- | --- | --- | --- | --- | --- | --- | --- | --- | --- | --- | --- | --- | --- | --- | --- | --- | --- | --- | --- | --- |
| 7372 | 2416.4 | **Stage 3 CIMS_3GPP2** | 290d? | 2008-03-07 A | 2008-12-11 A | 100% | 2008-03-07 | 2008-12-11 | 200d? |  | C1; C3; C4 | 9536h | 9536h | REDOC_3GPP2 | 21 | Alcatel-Lucent | orsic@alcatel-lucent.com | Rel-8 | 39 | Frederic | REDOC_3GPP2 |  |
| 7373 | 2416.4.1 | Stage 3 CIMS_3GPP2 (CT1) | 196d? | 2008-03-07 A | 2008-12-05 A | 100% | 2008-03-07 | 2008-12-05 | 196d? | finish no earlier than 2008-12-11 | C1 | 1568h | 1568h | REDOC_3GPP2 | 21 | Alcatel-Lucent | orsic@alcatel-lucent.com | Rel-8 | 39 | Frederic |  |  |
| 7374 | 2416.4.2 | Stage 3 CIMS_3GPP2 (CT3) | 196d? | 2008-03-07 A | 2008-12-05 A | 100% | 2008-03-07 | 2008-12-05 | 196d? | finish no earlier than 2008-12-05 | C3 | 1568h | 1568h | REDOC_3GPP2 | 21 | Alcatel-Lucent | orsic@alcatel-lucent.com | Rel-8 | 39 | Adrian |  |  |
| 7375 | 2416.4.3 | Stage 3 CIMS_3GPP2 (CT4) | 200d? | 2008-03-07 A | 2008-12-11 A | 100% | 2008-03-07 | 2008-12-11 | 200d? | finish no earlier than 2008-12-11 | C4 | 1600h | 1600h | REDOC_3GPP2 | 21 | Alcatel-Lucent | orsic@alcatel-lucent.com | Rel-8 | 39 | Kimmo |  |  |
| 7376 | 2417 | **IMS Enhancements for support of Packet Cable access** | 561.25d? | 2006-12-06 A | 2008-05-30 A | 100% | 2006-12-06 | 2008-05-30 | 388d? |  | S2; S3; C1; C3; C4 | 58616h | 58616h | PktCbl | 18 | Cablelabs | Bernie McKibben (b.mckibben@cablelabs.com) | Rel-8 | 35 | Maurice | PktCbl |  |
| 7377 | 2417.1 | **IMS Enhancements for Cable Client Types and Deployment Models** | 498d? | 2007-02-05 A | 2008-05-30 A | 100% | 2007-02-05 | 2008-05-30 | 345d? |  | S2; C1 | 9752h | 9752h | PktCbl-Deploy | 18 | Cablelabs | Bernie McKibben (b.mckibben@cablelabs.com) | Rel-8 | 35 | Maurice | PktCbl-Deploy |  |
| 7378 | 2417.1.1 | Architecture aspects of PktCbl-Deploy | 219d? | 2007-02-05 A | 2007-12-06 A | 100% | 2007-02-05 | 2007-12-06 | 219d? | finish no earlier than 2007-12-03 | S2 | 1752h | 1752h | PktCbl-Deploy | 18 | Cablelabs | Bernie McKibben (b.mckibben@cablelabs.com) | Rel-8 | 35 | Maurice |  |  |
| 7379 | 2417.1.2 | CT1 aspects of PktCbl-Deploy | 310d? | 2007-03-26 A | 2008-05-30 A | 100% | 2007-03-26 | 2008-05-30 | 310d? | finish no earlier than 2008-06-15 | C1 | 2480h | 2480h | PktCbl-Deploy | 18 | Cablelabs | D.Hancock@CableLabs.com | Rel-8 | 35 | Frederic |  |  |
| 7380 | 2417.2 | **IMS Inter-working aspects in Support of Cable Regulatory requirements** | 418.25d? | 2007-02-05 A | 2008-03-14 A | 100% | 2007-02-05 | 2008-03-14 | 290d? |  | S2; C1; C3 | 12320h | 12320h | PktCbl-Intw | 18 | Cablelabs | B.McKibben@CableLabs.com | Rel-8 | 35 | Maurice | PktCbl-Intw |  |
| 7381 | 2417.2.1 | Architecture aspects of PktCbl-Interwork | 160d? | 2007-02-05 A | 2007-09-14 A | 100% | 2007-02-05 | 2007-09-14 | 160d? | start no earlier than 2007-02-05 | S2 | 1280h | 1280h | PktCbl-Intw | 18 | Cablelabs | B.McKibben@CableLabs.com | Rel-8 | 35 | Maurice |  |  |
| 7382 | 2417.2.2 | CT1,CT3 aspects of PktCbl-Interwork | 255d? | 2007-03-26 A | 2008-03-14 A | 100% | 2007-03-26 | 2008-03-14 | 255d? | finish no earlier than 2008-03-15 | C1; C3 | 4080h | 4080h | PktCbl-Intw | 18 | Cablelabs | D.Hancock@CableLabs.com | Rel-8 | 35 | Frederic |  |  |
| 7383 | 2417.3 | **IMS Enhancements for Security Requirements in Support of Cable Deployments** | 561.25d? | 2006-12-06 A | 2008-05-30 A | 100% | 2006-12-06 | 2008-05-30 | 388d? |  | S3; C1; C3; C4 | 21024h | 21024h | PktCbl-Sec | 18 | Cablelabs | s.dotson@cablelabs.com | Rel-8 | 34 | Mirko | PktCbl-Sec |  |
| 7384 | 2417.3.1 | SA3 aspects of PktCbl-Sec | 331d? | 2006-12-06 A | 2008-03-12 A | 100% | 2006-12-06 | 2008-03-12 | 331d? | finish no earlier than 2007-12-20 | S3 | 2648h | 2648h | PktCbl-Sec | 18 | Cablelabs | s.dotson@cablelabs.com | Rel-8 | 35 | Mirko |  |  |
| 7385 | 2417.3.2 | CT1 aspects of PktCbl-Sec | 310d? | 2007-03-26 A | 2008-05-30 A | 100% | 2007-03-26 | 2008-05-30 | 310d? | finish no earlier than 2008-06-06 | C1 | 2480h | 2480h | PktCbl-Sec | 18 | Cablelabs | D.Hancock@CableLabs.com | Rel-8 | 35 | Frederic |  |  |
| 7386 | 2417.3.3 | CT3 aspects of PktCbl-Sec | 180d? | 2007-03-26 A | 2007-11-30 A | 100% | 2007-03-26 | 2007-11-30 | 180d? | finish no earlier than 2008-03-15 | C3 | 1440h | 1440h | PktCbl-Sec | 21 | Cablelabs | D.Hancock@CableLabs.com | Rel-8 | 38 | Adrian |  |  |
| 7387 | 2417.3.4 | CT4 aspects of PktCbl-Sec | 255d? | 2007-03-26 A | 2008-03-14 A | 100% | 2007-03-26 | 2008-03-14 | 255d? | finish no earlier than 2008-03-14 | C4 | 2040h | 2040h | PktCbl-Sec | 18 | Cablelabs | D.Hancock@CableLabs.com | Rel-8 | 35 | Kimmo |  |  |
| 7388 | 2418 | **IMS System enhancements for corporate network access** | 2732.38d? | 2007-06-22 A | 2014-09-12 A | 100% | 2007-06-22 | 2014-12-05 | 1960d? |  | S2; S1; C1; C4; IETF | 91240.9h | 91240.9h | IMS_Corp | 19 | Orange | Delphin Barankanira | Rel-8 | 36 | Maurice | IMS_Corp |  |
| 7389 | 2418.1 | SA1 aspects of IMS_Corp | 23.6d? | 2008-03-12 A | 2008-06-05 A | 100% | 2008-03-12 | 2008-06-05 | 23.6d? | finish no earlier than 2008-06-05 | S1 | 188.8h | 188.8h | IMS_Corp | 21 | Telecom Italia |  | Rel-8 | 39 | Alain |  |  |
| 7390 | 2418.2 | SA2 aspects of IMS_Corp | 325d? | 2007-06-22 A | 2008-09-18 A | 100% | 2007-06-22 | 2008-09-18 | 325d? | finish no earlier than 2008-12-25 | S2 | 2600h | 2600h | IMS_Corp | 19 | Orange | Delphin Barankanira | Rel-8 | 36 | Maurice |  |  |
| 7391 | 2418.3 | CT1 aspects of IMS_Corp | 532d? | 2008-03-07 A | 2010-03-19 A | 100% | 2008-03-07 | 2010-03-19 | 532d? | finish no earlier than 2010-03-19 | C1 | 4244.09h | 4244.09h | IMS_Corp | 21 | Alcatel-Lucent | Keith Drage (drage@alcatel-lucent.com) | Rel-8 | 39 | Frederic |  |  |
| 7392 | 2418.4 | (IETF) CT1 aspects of IMS_Corp (RFC 7316) | 825d? | 2011-06-29 A | 2014-09-12 A | 100% | 2011-06-29 | 2014-12-05 | 885d? | finish no earlier than 2014-09-12 | C1-IETF | 6600h | 6600h | IMS_Corp | 27 | Keith Drage | Keith Drage (drage@alcatel-lucent.com) | Rel-8 | 53 | Frederic |  |  |
| 7393 | 2418.5 | CT4 aspects of IMS_Corp | 196d? | 2008-02-26 A | 2008-12-05 A | 100% | 2008-02-26 | 2008-12-05 | 196d? | finish no earlier than 2008-12-11 | C4 | 1568h | 1568h | IMS_Corp | 21 | Alcatel-Lucent | Keith Drage (drage@alcatel-lucent.com) | Rel-8 | 39 | Kimmo |  |  |
| 7394 | 2419 | **Maintenance of TISPAN documentation** | 2627.75d? | 2007-07-02 A | 2014-06-13 A | 100% | 2007-07-02 | 2014-06-13 | 1829d? |  | S2; C1; C3; C4; IETF | 85904h | 85904h | MAINTISP | 21 |  |  | Rel-8 | 38 | Maurice | MAINTISP |  |
| 7395 | 2419.1 | Maintenance of TISPAN R2 | 86d? | 2007-11-09 A | 2008-03-07 A | 100% | 2007-11-09 | 2008-03-07 | 86d? | start no earlier than 2007-11-09 | C1; C3; C4 | 2064h | 2064h | MAINT_R2 | 21 | Alcatel-Lucent | Keith Drage (drage@alcatel-lucent.com) | Rel-8 | 38 | Frederic | MAINT_R2 |  |
| 7396 | 2419.2 | Deleted - (IETF) Maintenance of TISPAN R2 (avasarala-dispatch-comm-div-notification) | 1117d? | 2007-11-09 A | 2014-06-13 A | 100% | 2007-11-09 | 2014-06-13 | 1117d? | finish no earlier than 2014-06-13 | C1-IETF | 8936h | 8936h | MAINT_R2_IETF | 27 | Andrew Allen |  | Rel-8 | 52 | Frederic | MAINT_R2_IETF | SP-69 |
| 7397 | 2419.3 | Documentation of TISPAN NGN R1 and R2 in 3GPP SA2 | 104d? | 2008-01-14 A | 2008-06-05 A | 100% | 2008-01-14 | 2008-06-05 | 104d? | finish no earlier than 2008-06-20 | S2 | 832h | 832h | IMS_Comm_Doc | 21 | Nokia Siemens Networks | jozsef.varga@nsn.com | Rel-8 | 38 | Maurice | IMS_Comm_Doc |  |
| 7398 | 2419.4 | Maintenance of TISPAN release 2 common IMS | 114d? | 2007-07-02 A | 2007-12-06 A | 100% | 2007-07-02 | 2007-12-06 | 114d? | finish no earlier than 2007-12-06 | S2 | 912h | 912h | IMS_Comm_Mtce8 | 21 | Telecom Italia | antonio.ascolese@telecomitalia.it | Rel-8 | 38 | Maurice | IMS_Comm_Mtce8 |  |

Notes:
- 7372: -
- 7373: CP#42 completed / Impacted TSs and TRs: 23.218; 24.141; 24.147; 24.173; 24.229; 24.238; 24.247; 24.604; 24.605; 24.606; 24.607; 24.608; 24.610; 24.611; 24.629; 24.930
- 7374: CP#42 completed / Impacted TSs and TRs: 29.163; 29.212; 29.213; 29.214
- 7375: CP#42 completed / Impacted TSs and TRs: 29.228; 29.229; 29.328; 29.329
- 7376: CP#40 completed
- 7377: CP#40 completed
- 7378: SP#38 completed / Impacted TSs and TRs: 23.228
- 7379: CP#40 completed
- 7380: CP#39 completed
- 7381: SP#37 completed / Impacted TSs and TRs: 23.228
- 7382: CP#39 completed / Impacted TSs and TRs: 24.229
- 7383: CP#40 completed
- 7384: SP#39 completed / Impacted TSs and TRs: 33.203; 33.210; 33.220
- 7385: CP#40 completed / Impacted TSs and TRs: 24.229
- 7386: CP#38 completed / Impacted TSs and TRs: 29.163
- 7387: CP#39 completed / Impacted TSs and TRs: 29.228; 29.229; 23.008
- 7388: CP#47 completed
- 7389: SP#40 completed
- 7390: no Stage 2 impacts / Impacted TSs and TRs: 23.228
- 7391: CP#47 completed / Impacted TSs and TRs: 24.229; 24.503
- 7392: CP#65 completed / Impacted TSs and TRs: RFC 7316 (was draft-vanelburg-dispatch-private-network-ind)
- 7393: CP#42 completed / Impacted TSs and TRs: 29.228; 29.229; 23.003; 23.008; 29.433
- 7394: SP#40 completed
- 7395: CP#39 completed / Impacted TSs and TRs: 24.406; 24.407; 24.410; 24.411; 24.423; 24.430; 24.447; 24.451; 24.454; 24.503; 24.505; 24.508; 24.516; 24.528; 24.529; 29.412; 29.421; 29.433; 29.458; 29.527; 29.624
- 7396: CP#64 Draft removed from 3GPP documentation / Impacted TSs and TRs: draft-avasarala-dispatch-comm-div-notification
- 7397: SP#40 completed / Impacted TSs and TRs: 23.228; 23.204; 23.167
- 7398: SP#38 completed / Impacted TSs and TRs: 23.506; 23.507.23.517; 23.521

| ID | WBS | Task | Type | Duration | Start | Finish | Complete | Baseline start | Baseline finish | Baseline duration | Constraint | Resources | Work | Actual work | Acronym | PCG approved | WI rapporteur name | WI rapporteur e-mail | Release | TSG approved | MCC resp | Acronym_3GU_Export | Impacted TSs and TRs |
| --- | --- | --- | --- | --- | --- | --- | --- | --- | --- | --- | --- | --- | --- | --- | --- | --- | --- | --- | --- | --- | --- | --- | --- |
| 7399 | 2420 | **IMS Service Continuity** |  | 459.75d? | 2008-03-12 A | 2009-05-29 A | 100% | 2008-03-12 | 2009-05-29 | 318d? |  | S2; S1; C1 | 10712h | 10712h | IMS-Cont | 21 | LG Electronics | JaeSeung SONG (anthonys@lge.com) | Rel-8 | 39 | Maurice | IMS-Cont |  |
| 7400 | 2420.1 | Stage 1 IMS Service Continuity |  | 62d? | 2008-03-12 A | 2008-06-05 A | 100% | 2008-03-12 | 2008-06-05 | 62d? | start no earlier than 2008-03-12 | S1 | 496h | 496h | IMS-Cont | 21 | LG Electronics | JaeSeung SONG (anthonys@lge.com) | Rel-8 | 39 | Alain |  |  |
| 7401 | 2420.2 | Stage 2 IMS Service Continuity |  | 62d? | 2008-03-12 A | 2008-06-05 A | 100% | 2008-03-12 | 2008-06-05 | 62d? | finish no earlier than 2008-06-05 | S2 | 496h | 496h | IMS-Cont | 21 | LG Electronics | JaeSeung SONG (anthonys@lge.com) | Rel-8 | 39 | Maurice |  | 23.237; 23.292 |
| 7402 | 2420.3 | Stage 3 IMS Service Continuity |  | 261d? | 2008-05-30 A | 2009-05-29 A | 100% | 2008-05-30 | 2009-05-29 | 261d? | finish no earlier than 2009-05-29 | C1 | 2088h | 2088h | IMS-Cont | 21 | Huawei | Lili Yang (kadyyang@huawei.com) | Rel-8 | 40 | Frederic |  | 24.237; 24.229; 24.216 |
| 7403 | 2421 | **Security Enhancements for IMS** |  | 931.3d? | 2006-09-19 A | 2009-03-06 A | 100% | 2006-09-19 | 2009-03-06 | 643.3d? |  | S3; C1; C4 | 29847.2h | 29847.2h | IMS-Sec | 19 | Ericsson | Bengt.Sahlin@ericsson.com | Rel-8 | 37 | Mirko | IMS-Sec |  |
| 7404 | 2421.1 | Stage 2 for IMS-Sec |  | 466d? | 2007-03-01 A | 2008-12-11 A | 100% | 2007-03-01 | 2008-12-11 | 466d? | finish no earlier than 2008-12-11 | S3 | 3728h | 3728h | IMS-Sec | 19 | Ericsson | Bengt.Sahlin@ericsson.com | Rel-8 | 36 | Mirko |  | 33.203; 33.141; 33.803 |
| 7405 | 2421.2 | CT1 part of Stage 3 for IMS-Sec |  | 392d? | 2006-09-19 A | 2008-12-05 A | 100% | 2006-09-19 | 2008-12-05 | 392d? | finish no earlier than 2008-12-05 | C1 | 3136h | 3136h | IMS-Sec | 21 | Ericsson |  | Rel-8 | 39 | Frederic |  |  |
| 7406 | 2421.3 | CT4 part of Stage 3 for IMS-Sec |  | 457d? | 2007-06-07 A | 2009-03-06 A | 100% | 2007-06-07 | 2009-03-06 | 457d? | finish no earlier than 2009-03-06 | C4 | 3656h | 3656h | IMS-Sec | 21 | Ericsson |  | Rel-8 | 39 | Kimmo |  |  |
| 7407 | 2421.4 | CT1 part of Network Attachment Subsystem (NASS) Bundled Authentication |  | 343d? | 2007-11-14 A | 2009-03-06 A | 100% | 2007-11-14 | 2009-03-06 | 343d? | finish no earlier than 2009-03-06 | C1 | 2744h | 2744h | NBA | 21 | Alcatel-Lucent | Keith Drage (drage@alcatel-lucent.com) | Rel-8 | 39 | Frederic | NBA | 24.229 |
| 7408 | 2421.5 | CT4 part of Network Attachment Subsystem (NASS) Bundled Authentication |  | 143d? | 2007-11-14 A | 2008-05-30 A | 100% | 2007-11-14 | 2008-05-30 | 143d? | start no earlier than 2007-11-14 | C4 | 1144h | 1144h | NBA-CT4 | 21 | Alcatel-Lucent |  | Rel-8 | 39 | Kimmo | NBA-CT4 | 29.229; 29.228; 23.008 |
| 7409 | 2422 | **IMS initiated and controlled PSS and MBMS User Service** |  | 1334.62d? | 2008-03-12 A | 2011-09-21 A | 100% | 2008-03-12 | 2011-09-21 | 924d? |  | S4; S3; IETF | 28108.8h | 28108.8h | IMS_PSS_MBMS_US | 18 | FT, Ericsson | olle.franceschi@ericsson.com | Rel-8 | 34 | Paolo | IMS_PSS_MBMS_US |  |
| 7410 | 2422.1 | SA4, SA3 part of IMS initiated and controlled PSS and MBMS User Service | milestone | 0d? | 2008-03-12 A | 2008-03-12 A | 100% | 2008-03-12 | 2008-03-12 | 0d? | finish no earlier than 2009-03-12 | S4; S3 |  |  | IMS_PSS_MBMS_US | 18 | FT, Ericsson | olle.franceschi@ericsson.com | Rel-8 | 34 | Paolo |  | 26.234; 26.346; 33.246; New 26.237 |
| 7411 | 2422.2 | (IETF) IMS initiated and controlled PSS and MBMS User Service (RFC 6080) |  | 743.6d? | 2008-03-12 A | 2011-09-21 A | 100% | 2008-03-12 | 2011-09-21 | 743.6d? | finish no earlier than 2011-09-21 | S4-IETF | 5932.8h | 5932.8h | IMS_PSS_MBMS_US | 27 | Ericsson |  | Rel-8 | 52 | Paolo |  | RFC 6080 (was draft-ietf-sipping-config-framework) |
| 7412 | 2423 | **Multimedia interworking between IMS and CS networks** |  | 1211.75d? | 2005-09-23 A | 2008-12-05 A | 100% | 2005-09-23 | 2008-12-05 | 836d? |  | C3; C4 | 22800h | 22800h | MIW-IMS | 36 | Vodafone | nico.gabriele@vodafone.com | Rel-8 | 71 | Adrian | MIW-IMS |  |
| 7413 | 2423.1 | Stage 1 and 2 defined in earlier Releases |  | 49d? | 2005-09-23 A | 2005-11-30 A | 100% | 2005-09-23 | 2005-11-30 | 49d? | start no earlier than 2005-09-23 | S2 | 392h | 392h | MIW-IMS | 36 | Vodafone | nico.gabriele@vodafone.com | Rel-8 | 70 | Maurice |  |  |
| 7414 | 2423.2 | Stage 3 of MW-IMS |  | 571d? | 2005-09-23 A | 2007-11-30 A | 100% | 2005-09-23 | 2007-11-30 | 571d? | finish no earlier than 2007-09-14 | C3 | 4568h | 4568h | MIW-IMS-St3C3 | 36 | Vodafone | nico.gabriele@vodafone.com | Rel-8 | 70 | Adrian | MIW-IMS-St3 | 29.863; 29.163 |
| 7415 | 2423.3 | Stage 3 for MW-IMS, MONA extension |  | 285d? | 2007-11-05 A | 2008-12-05 A | 100% | 2007-11-05 | 2008-12-05 | 285d? | finish no earlier than 2008-12-05 | C3 | 2280h | 2280h | MIW-IMS-St3C3_MONA | 21 | Vodafone | Christer.Holmberg@ericsson.com | Rel-8 | 38 | Adrian |  | 29.863; 29.163 |
| 7416 | 2423.4 | Mn interface (MGCF – IM MGW) |  | 273d? | 2007-11-21 A | 2008-12-05 A | 100% | 2007-11-21 | 2008-12-05 | 273d? | finish no earlier than 2008-12-19 | C4 | 2184h | 2184h | MIW-IMS-St3C4 | 21 | Vodafone | Christer.Holmberg@ericsson.com | Rel-8 | 38 | Kimmo |  | 29.332 |
| 7417 | 2424 | **IMS Stage 3 IETF Protocol Alignment - phase 2** |  | 2823.38d? | 2007-06-22 A | 2014-12-09 A | 100% | 2007-06-22 | 2014-12-05 | 1960d? |  | C1; IETF | 55368h | 55368h | IMSProtoc2 | 19 | Alcatel-Lucent | Keith Drage (drage@alcatel-lucent.com) | Rel-8 | 36 | Frederic | IMSProtoc2 |  |
| 7418 | 2424.1 | CT1 aspects of IMS Stage 3 IETF Protocol Alignment - phase 2 |  | 446d? | 2007-06-22 A | 2009-03-06 A | 100% | 2007-06-22 | 2009-03-06 | 446d? | finish no earlier than 2009-03-06 | C1 | 3568h | 3568h | IMSProtoc2 | 19 | Alcatel-Lucent | Keith Drage (drage@alcatel-lucent.com) | Rel-8 | 36 | Frederic |  | 23.218; 24.229; 24.930 |
| 7419 | 2424.2 | (IETF) IMS Stage 3 IETF Protocol Alignment (draft-bakker-sipping-3gpp-ims-xml-body-handling) |  | 715d? | 2007-06-22 A | 2012-12-07 A | 100% | 2007-06-22 | 2012-12-07 | 715d? | finish no earlier than 2012-12-07 | C1-IETF | 5720h | 5720h | IMSProtoc2 | 27 | Andrew Allen |  | Rel-8 | 52 | Frederic |  | draft-bakker-sipping-3gpp-ims-xml-body-handling |
| 7420 | 2424.3 | (IETF) IMS Stage 3 IETF Protocol Alignment (RFC 6544) |  | 587d? | 2007-06-22 A | 2012-06-15 A | 100% | 2007-06-22 | 2012-06-15 | 587d? | finish no earlier than 2012-04-20 | C1-IETF | 4688h | 4688h | IMSProtoc2 | 27 | Keith Drage |  | Rel-8 | 52 | Frederic |  | RFC 6544 (was draft-ietf-mmusic-ice-tcp) |
| 7421 | 2424.4 | (IETF) IMS Stage 3 IETF Protocol Alignment (draft-ietf-salud-alert-info-urns) |  | 1244d? | 2007-06-22 A | 2014-12-09 A | 100% | 2007-06-22 | 2014-12-05 | 1242d? | finish no earlier than 2014-12-09 | C1-IETF | 9952h | 9952h | IMSProtoc2 | 27 | Roland Jesske | Roland Jesske | Rel-8 | 52 | Frederic |  | draft-ietf-salud-alert-info-urns; RFC 7462 |
| 7422 | 2425 | **Interworking between User-to-User Signalling (UUS) and SIP** |  | 2656.62d? | 2007-11-30 A | 2014-12-09 A | 100% | 2007-11-30 | 2014-12-05 | 1845d? |  | C1; C3; IETF | 68624.4h | 68624.4h | UUSIW | 21 | Huawei | Lili Yang (kadyyang@huawei.com) | Rel-8 | 38 | Kimmo | UUSIW |  |
| 7423 | 2425.1 | CT1 part of Stage 3 MGCF UUSIW |  | 266d? | 2007-11-30 A | 2008-12-05 A | 100% | 2007-11-30 | 2008-12-05 | 266d? | finish no earlier than 2008-12-05 | C1 | 2128h | 2128h | UUSIW | 21 | Huawei | Lili Yang (kadyyang@huawei.com) | Rel-8 | 38 | Frederic |  | 24.279; 24.229 |
| 7424 | 2425.2 | (IETF) Stage 3 MGCF UUSIW (cuss-sip-uui) |  | 227.03d? | 2007-11-30 A | 2014-12-09 A | 100% | 2007-11-30 | 2014-12-05 | 225.03d? | finish no earlier than 2014-12-09 | C1-IETF; C3-IETF | 3632.4h | 3632.4h | UUSIW | 27 | Roland Jesske | Roland Jesske | Rel-8 | 52 | Frederic |  | RFC 7433 |
| 7425 | 2425.3 | (IETF) Stage 3 MGCF UUSIW (cuss-sip-uui-isdn) |  | 986.5d? | 2011-03-17 A | 2014-12-09 A | 100% | 2011-03-17 | 2014-12-05 | 984.5d? | finish no earlier than 2014-12-09 | C1-IETF; C3-IETF | 15784h | 15784h | UUSIW | 28 | Keith Drage | Keith Drage (drage@alcatel-lucent.com) | Rel-8 | 55 | Frederic |  | RFC 7434 |
| 7426 | 2425.4 | CT3 part of Stage 3 MGCF UUSIW |  | 335d? | 2007-11-30 A | 2009-03-12 A | 100% | 2007-11-30 | 2009-03-12 | 335d? | finish no earlier than 2009-03-12 | C3 | 2680h | 2680h | UUSIW | 21 | Huawei | Lili Yang (kadyyang@huawei.com) | Rel-8 | 38 | Adrian |  | 29.163 |

Notes:
- 7399: CP#44 completed
- 7400: SP#40 completed
- 7401: SP#40 completed
- 7402: CP#44 completed
- 7403: CP#43 completed
- 7404: SP#42 completed. SP#46 withdrawn draft 33.178-100 and 33.978 from Rel-8 onwards
- 7405: CP#42 completed
- 7406: CP#43 completed
- 7407: CP#43 completed
- 7408: CP#40 completed
- 7409: SP#39 WID approved
- 7410: SP#43 completed
- 7411: SP#53/IETF#81 completed
- 7412: CP#42 completed
- 7413: SP#31 Moved from FS section Feb 2006
- 7414: Moved from Rel-7. Feature extended in Rel-8 by including Stage 3 covering MONA UID_380021
- 7415: CP#42 completed
- 7416: CP#42 completed
- 7417: CP#43 completed
- 7418: CP#43 completed
- 7419: CP#58 completed. ietf-draft discontinued. Documented within 3GPP
- 7420: CP#56 completed
- 7421: In RFC Editors Queue. Dec.14: 75->90¦7/3/16: 90%->100; 9/4/21: RFC 7462 added;
- 7422: CP#43 completed
- 7423: CP#42 completed
- 7424: In RFC Editors Queue. Mar15: 90->100%. RFC updated (was draft-ietf-cuss-sip-uui). June 2015: RFC 7433 (was draft-ietf-cuss-sip-uui)
- 7425: In RFC Editors Queue. Dec.14: 75->90. Mar15: 90->100%. RFC updated (was draft-ietf-cuss-sip-uui-isdn). June 2015: RFC 7434 (was draft-ietf-cuss-sip-uui-isdn)
- 7426: CP#43 completed

| ID | WBS | Task | Type | Duration | Start | Finish | Complete | Baseline start | Baseline finish | Baseline duration | Constraint | Resources | Work | Actual work | Acronym | PCG approved | WI rapporteur name | WI rapporteur e-mail | Release | TSG approved | MCC resp | Acronym_3GU_Export | Impacted TSs and TRs | Special Focus Doc | Status Report |
| --- | --- | --- | --- | --- | --- | --- | --- | --- | --- | --- | --- | --- | --- | --- | --- | --- | --- | --- | --- | --- | --- | --- | --- | --- | --- |
| 7427 | 2426 | **Support of Overlap signalling** |  | 479.5d? | 2007-11-30 A | 2009-03-06 A | 100% | 2007-11-30 | 2009-03-06 | 331d? |  | C3; C1; C4 | 15304.2h | 15304.2h | Overlap | 21 | Deutsche Telekom | r.jesske@telekom.de | Rel-8 | 38 | Adrian | Overlap |  |  |  |
| 7428 | 2426.1 | Stage 3 Overlap (CT1) |  | 331d? | 2007-11-30 A | 2009-03-06 A | 100% | 2007-11-30 | 2009-03-06 | 331d? | finish no earlier than 2009-03-06 | C1 | 2648h | 2648h | Overlap | 21 | Deutsche Telekom | r.jesske@telekom.de | Rel-8 | 38 | Frederic |  | 24.229 |  |  |
| 7429 | 2426.2 | Stage 3 Overlap (CT3) |  | 331d? | 2007-11-30 A | 2009-03-06 A | 100% | 2007-11-30 | 2009-03-06 | 331d? | finish no earlier than 2009-03-06 | C3 | 2648h | 2648h | Overlap | 21 | Deutsche Telekom | r.jesske@telekom.de | Rel-8 | 38 | Adrian |  | 29.163 |  |  |
| 7430 | 2426.3 | Stage 3 Overlap (CT4) |  | 258.02d? | 2007-11-30 A | 2008-12-05 A | 100% | 2007-11-30 | 2008-12-05 | 258.02d? | start no earlier than 2007-11-30 | C4 | 2064.16h | 2064.16h | Overlap | 21 | Deutsche Telekom | r.jesske@telekom.de | Rel-8 | 38 | Kimmo |  | 29.228; 29.229 |  |  |
| 7431 | 2427 | **AS/MRFC Stage 2 and 3** |  | 1735.12d? | 2007-11-14 A | 2012-06-15 A | 100% | 2007-11-14 | 2012-06-15 | 1203d? |  | C1; IETF | 28384h | 28384h | MRFC_TS | 21 | Hewlett-Packard | mark.syrett@hp.com | Rel-8 | 38 | Frederic | MRFC_TS |  |  |  |
| 7432 | 2427.1 | AS/MRFC Stage 2 |  | 278d? | 2007-11-14 A | 2008-12-05 A | 100% | 2007-11-14 | 2008-12-05 | 278d? | finish no earlier than 2008-12-05 | C1 | 2224h | 2224h | MRFC_TS | 21 | Hewlett-Packard | mark.syrett@hp.com | Rel-8 | 38 | Frederic |  | 23.218 |  |  |
| 7433 | 2427.2 | AS/MRFC Stage 3 |  | 278d? | 2007-11-14 A | 2008-12-05 A | 100% | 2007-11-14 | 2008-12-05 | 278d? | finish no earlier than 2008-12-05 | C1 | 2224h | 2224h | MRFC_TS | 21 | Hewlett-Packard | mark.syrett@hp.com | Rel-8 | 38 | Frederic |  | 24.229; 24.147; 24.247 |  |  |
| 7434 | 2427.3 | (IETF) AS/MRFC Stage 2 and 3 (RFC 6505) |  | 590d? | 2007-11-14 A | 2012-06-15 A | 100% | 2007-11-14 | 2012-06-15 | 590d? | finish no earlier than 2012-06-15 | C1-IETF | 4688h | 4688h | MRFC_TS | 27 | Keith Drage |  | Rel-8 | 52 | Frederic |  | RFC 6505 (was draft-ietf-mediactrl-mixer-control-package) |  |  |
| 7435 | 2428 | **IMS Restoration Procedures** |  | 291d? | 2008-05-30 A | 2009-03-06 A | 100% | 2008-05-30 | 2009-03-06 | 201d? |  | C4; C1 | 6432h | 6432h | IMS_RP | 21 | Ericsson | german.blanco@ericsson.com | Rel-8 | 40 | Kimmo | IMS_RP |  |  |  |
| 7436 | 2428.1 | IMS Restoration Procedures (CT4) |  | 201d? | 2008-05-30 A | 2009-03-06 A | 100% | 2008-05-30 | 2009-03-06 | 201d? | finish no earlier than 2009-03-06 | C4 | 1608h | 1608h | IMS_RP | 21 | Ericsson | german.blanco@ericsson.com | Rel-8 | 40 | Kimmo |  | 23.380; 29.228; 29.229; 29.230; 23.008 |  |  |
| 7437 | 2428.2 | IMS Restoration Procedures (CT1) |  | 201d? | 2008-05-30 A | 2009-03-06 A | 100% | 2008-05-30 | 2009-03-06 | 201d? | finish no earlier than 2009-03-06 | C1 | 1608h | 1608h | IMS_RP | 21 | Ericsson | german.blanco@ericsson.com | Rel-8 | 40 | Frederic |  | 24.229 |  |  |
| 7438 | 2429 | IMS Application Server Service Data Descriptions for AS interoperability |  | 125d? | 2008-09-12 A | 2009-03-06 A | 100% | 2008-09-12 | 2009-03-06 | 125d? | finish no earlier than 2009-03-06 | C4 | 1000h | 1000h | IMS_ASIO | 21 | Alcatel-Lucent | nhberry@alcatel-lucent.com | Rel-8 | 41 | Kimmo | IMS_ASIO | 29.328; 29.329; 29.364 |  |  |
| 7439 | 2430 | **I-WLAN Network Selection Principle (NSP)** |  | 653.5d? | 2007-06-14 A | 2009-03-06 A | 100% | 2007-06-14 | 2009-03-06 | 451d? |  | S1; C1; C6 | 13859.2h | 13859.2h | IWLANNSP | 18 | Telefónica O2 | chris.friel@O2.com | Rel-8 | 34 | Alain | IWLANNSP |  | WLAN |  |
| 7440 | 2430.1 | Stage 1 for I-WLAN NSP | milestone | 0d? | 2007-06-14 A | 2007-06-14 A | 100% | 2007-06-14 | 2007-06-14 | 0d? |  | S1 |  |  | IWLANNSP | 21 | Telefónica O2 | chris.friel@O2.com | Rel-8 | 39 | Alain |  | 22.234 | WLAN |  |
| 7441 | 2430.2 | CT1 part of Stage 3 for I-WLAN NSP |  | 261d? | 2008-03-07 A | 2009-03-06 A | 100% | 2008-03-07 | 2009-03-06 | 261d? | finish no earlier than 2008-12-05 | C1 | 2088h | 2088h | IWLANNSP | 21 | Research In Motion | Adrian Buckley (abuckley@rim.com) | Rel-8 | 39 | Frederic |  | 24.234 | WLAN |  |
| 7442 | 2430.3 | CT6 part of Stage 3 for I-WLAN NSP |  | 118.4d? | 2008-03-07 A | 2008-12-11 A | 100% | 2008-03-07 | 2008-12-11 | 118.4d? | finish no earlier than 2008-12-11 | C6 | 947.2h | 947.2h | IWLANNSP | 21 | Research In Motion | Adrian Buckley (abuckley@rim.com) | Rel-8 | 39 | Xavier |  | 31.102; 31.111 | WLAN |  |
| 7443 | 2431 | **Mobility between 3GPP-WLAN Interworking and 3GPP Systems** |  | 559.25d? | 2007-09-14 A | 2009-03-06 A | 100% | 2007-09-14 | 2009-03-06 | 386d? |  | S2; C1 | 9304h | 9304h | IWLAN_Mob | 19 | Orange | xiaobao.chen@orange-ftgroup.com | Rel-8 | 37 | Maurice | IWLAN_Mob |  | WLAN |  |
| 7444 | 2431.1 | Stage 2 for Mobility between 3GPP-WLAN Interworking and 3GPP Systems |  | 190d? | 2007-09-14 A | 2008-06-05 A | 100% | 2007-09-14 | 2008-06-05 | 190d? | finish no earlier than 2008-09-08 | S2 | 1520h | 1520h | IWLAN_Mob | 21 | Orange | xiaobao.chen@orange-ftgroup.com | Rel-8 | 38 | Maurice |  | new 23.327 | WLAN |  |
| 7445 | 2431.2 | CT1 aspects of Mobility between 3GPP-WLAN Interworking and 3GPP Systems |  | 201d? | 2008-05-30 A | 2009-03-06 A | 100% | 2008-05-30 | 2009-03-06 | 201d? | finish no earlier than 2009-03-06 | C1 | 1608h | 1608h | IWLAN_Mob | 21 | Orange | reina.nader@orange-ftgroup.com | Rel-8 | 40 | Frederic |  | 24.303; new 24.327 | WLAN |  |
| 7446 | 2432 | Conformance Test Aspects – Mobility between 3GPP WLAN Interworking and 3GPP Systems |  | 206d? | 2009-12-04 A | 2010-09-17 A | 100% | 2009-12-04 | 2010-09-17 | 206d? | finish no earlier than 2010-09-17 | R5 | 1648h | 1648h | IWLAN_Mob_UEConTest | 24 | Qualcomm | Patrick Stupar (pstupar@qualcomm.com) | Rel-8 | 46 | Ingbert | IWLAN_Mob_UEConTest | 34.108; 34.123-1; 34.123-2; 34.123-3 | WLAN | RP-100740 |
| 7447 | 2433 | **Enhancements for Voice Group Call Service (VGCS) Applications (EVA)** |  | 1329.62d? | 2006-03-15 A | 2009-09-18 A | 100% | 2006-03-15 | 2009-09-18 | 919d? |  | S1; C1; C4; G2 | 45559.5h | 45559.5h | EVA | 36 | Nortel | Amar Deol (deola@nortelnetworks.com) | Rel-8 | 70 | Alain | EVA |  |  |  |
| 7448 | 2433.1 | SA1 aspects of EVA |  | 191d? | 2006-03-15 A | 2006-12-06 A | 100% | 2006-03-15 | 2006-12-06 | 191d? | finish no earlier than 2006-12-06 | S1 | 1528h | 1528h | EVA | 17 | Nortel | Amar Deol (deola@nortelnetworks.com) | Rel-8 | 32 | Alain |  | 42.068 |  |  |
| 7449 | 2433.2 | VGCS/VBS and GPRS Interactions |  | 145d? | 2007-09-03 A | 2008-03-21 A | 100% | 2007-09-03 | 2008-03-21 | 145d? | finish no earlier than 2008-03-21 | S1 | 1160h | 1160h | EVA | 19 | Huawei | Ling Liu | Rel-8 | 37 | Alain |  | 42.068; 42.069 |  |  |
| 7450 | 2433.3 | CT1 aspects of EVA |  | 862d? | 2006-06-02 A | 2009-09-18 A | 100% | 2006-06-02 | 2009-09-18 | 862d? | finish no earlier than 2009-12-04 | C1 | 6887.53h | 6887.53h | EVA | 17 | Nortel | milanpa@nortel.com | Rel-8 | 32 | Frederic |  | 43.068; 44.068 |  |  |
| 7451 | 2433.4 | CT4 aspects of EVA |  | 391d? | 2006-06-02 A | 2007-11-30 A | 100% | 2006-06-02 | 2007-11-30 | 391d? | finish no earlier than 2007-06-01 | C4 | 3128h | 3128h | EVA | 17 | Nortel |  | Rel-8 | 32 | Kimmo |  | 29.002 |  |  |
| 7452 | 2433.5 | GERAN2 aspects of EVA |  | 431d? | 2006-06-30 A | 2008-02-22 A | 100% | 2006-06-30 | 2008-02-22 | 431d? | finish no earlier than 2008-02-22 | G2 | 3448h | 3448h | EVA |  | Nortel | frank.billenkamp@nortel.com | Rel-8 |  | Gert |  | 44.018; 48.008 |  |  |

Notes:
- 7427: CP#43 completed
- 7428: CP#43 completed
- 7429: CP#43 completed
- 7430: CP#42 completed
- 7431: Triggered by Study UID_7048 (MRFC)
- 7432: CP#42 completed
- 7433: CP#42 completed
- 7434: CP#56 completed
- 7435: CP#43 completed. Triggered by Study TR 23.820 (FS_IMS_RP) UID_350018
- 7436: CP#43 completed
- 7437: CP#43 completed
- 7438: CP#43 completed. Triggered by UID_360030 (FS_IMS_ASIO)
- 7439: CP#43 completed
- 7440: SP#36 completed
- 7441: CP#43 completed
- 7442: CP#42 completed
- 7443: CP#43 completed
- 7444: SP#40 completed
- 7445: CP#43 completed
- 7446: RP#49 completed. Testing for Rel-8 UID_400013 CT1 aspects of mobility between 3GPP WLAN Interworking and 3GPP Systems (24.327)
- 7447: CP#45 completed
- 7448: SP#38 completed
- 7449: SP#39 completed
- 7450: CP#45 completed
- 7451: CP#38 completed
- 7452: GP#37 completed

| ID | WBS | Task | Type | Duration | Start | Finish | Complete | Baseline start | Baseline finish | Baseline duration | Constraint | Resources | Work | Actual work | Acronym | WI rapporteur name | WI rapporteur e-mail | Release | MCC resp | Acronym_3GU_Export | Impacted TSs and TRs | TSG stopped | Special Focus Doc | TSG approved | PCG approved | Status Report |
| --- | --- | --- | --- | --- | --- | --- | --- | --- | --- | --- | --- | --- | --- | --- | --- | --- | --- | --- | --- | --- | --- | --- | --- | --- | --- | --- |
| 7453 | 2434 | **Personal Network Management** |  | 1382.5d? | 2005-07-11 A | 2009-03-06 A | 100% | 2005-07-11 | 2009-03-06 | 955d? |  | S1; C1; S3 | 46368h | 46368h | PNM | Vodafone | armin.toepfer@vodafone.com | Rel-8 | Alain | PNM |  |  |  |  |  |  |
| 7454 | 2434.1 | Stage 1 for PNM |  | 276d? | 2005-07-11 A | 2006-07-31 A | 100% | 2005-07-11 | 2006-07-31 | 276d? | start no earlier than 2005-07-11 | S1 | 2208h | 2208h | PNM | Vodafone | armin.toepfer@vodafone.com | Rel-8 | Alain |  | 22.259 |  |  |  |  |  |
| 7455 | 2434.2 | Stage 2 for PNM |  | 445d? | 2007-03-26 A | 2008-12-05 A | 100% | 2007-03-26 | 2008-12-05 | 445d? | finish no earlier than 2008-12-05 | C1 | 3560h | 3560h | PNM | Vodafone | yang.lu@vodafone.com | Rel-8 | Frederic |  | 23.259 |  |  |  |  |  |
| 7456 | 2434.3 | **Stage 3 for PNM** |  | 737.25d? | 2007-03-26 A | 2009-03-06 A | 100% | 2007-03-26 | 2009-03-06 | 510d? |  | C1; C4 | 15800h | 15800h | PNM | Vodafone | yang.lu@vodafone.com | Rel-8 | Frederic |  |  |  |  |  |  |  |
| 7457 | 2434.3.1 | CT1 aspects of Stage 3 PNM |  | 510d? | 2007-03-26 A | 2009-03-06 A | 100% | 2007-03-26 | 2009-03-06 | 510d? | finish no earlier than 2008-12-05 | C1 | 4080h | 4080h | PNM | Vodafone | yang.lu@vodafone.com | Rel-8 | Frederic |  | 24.259; 24.229 |  |  |  |  |  |
| 7458 | 2434.3.2 | Deleted - CT4 aspects of Stage 3 PNM |  | 445d? | 2007-03-26 A | 2008-12-05 A | 100% | 2007-03-26 | 2008-12-05 | 445d? | finish no earlier than 2008-12-11 | C4 | 3560h | 3560h | PNM | Vodafone | yang.lu@vodafone.com | Rel-8 | Kimmo |  |  | CP-42 |  |  |  |  |
| 7459 | 2434.4 | Key establishment between a UICC hosting device and a remote device |  | 235d? | 2006-12-06 A | 2007-10-30 A | 100% | 2006-12-06 | 2007-10-30 | 235d? | finish no earlier than 2007-10-30 | S3 | 1880h | 1880h | PNM | Ericsson | Vesa.Lehtovirta@ericsson.com | Rel-8 | Mirko |  | 33.259 |  |  |  |  |  |
| 7460 | 2434.5 | Deleted - Actual Requirements of PNM | milestone | 0d? | 2007-03-26 A | 2007-03-26 A | 100% | 2007-03-26 | 2007-03-26 | 0d? | finish no earlier than 2007-03-26 | C1 |  |  | PNM | Ericsson |  | Rel-8 | Frederic |  |  | SP-37 |  |  |  |  |
| 7461 | 2435 | **eCall Data Transfer** |  | 922.75d? | 2006-09-28 A | 2009-03-06 A | 100% | 2006-09-28 | 2009-03-06 | 637d? |  | S1; C1 | 14840h | 14840h | EData | Airbiquity | rrobinson@airbiquity.com | Rel-8 | Alain | EData |  |  | Public Safety (I-A) |  |  |  |
| 7462 | 2435.1 | eData Requirements |  | 380d? | 2006-09-28 A | 2008-03-12 A | 100% | 2006-09-28 | 2008-03-12 | 380d? | finish no earlier than 2006-12-07 | S1 | 3040h | 3040h | EData | Airbiquity | rrobinson@airbiquity.com | Rel-8 | Alain |  | 22.101; 22.105 |  | Public Safety (I-A) | 37 |  |  |
| 7463 | 2435.2 | Transfer of data during an emergency call |  | 201d? | 2008-05-30 A | 2009-03-06 A | 100% | 2008-05-30 | 2009-03-06 | 201d? | finish no earlier than 2009-03-06 | C1 | 1608h | 1608h | EData | T-Mobile | Dieter Jacobsohn | Rel-8 | Frederic |  | 24.008 |  | Public Safety (I-A) | 40 | 21 |  |
| 7464 | 2436 | eCall data transfer Phase 2: Comparison of alternative in-band modem solutions and standardization of one in-band modem solution |  | 472d? | 2007-12-06 A | 2009-09-24 A | 100% | 2007-12-06 | 2009-09-24 | 472d? | finish no earlier than 2009-09-24 | S4 | 3768.09h | 3768.09h | eCall_Phase2 | Airbiquity | lhong@airbiquity.com & rrobinson@airbiquity.com | Rel-8 | Paolo | eCall_Phase2 | 26.267; 26.268; 26.269; 26.967; 26.969 |  | Public Safety (I-A) |  |  |  |
| 7465 | 2437 | eCall Conformance Testing |  | 261d? | 2009-09-04 A | 2010-09-03 A | 100% | 2009-09-04 | 2010-09-03 | 261d? | finish no earlier than 2010-09-03 | G3new | 2088h | 2088h | eCall_MSTest | Ericsson, Qualcomm | Vikrant Jain (vikrantj@qualcomm.com) | Rel-8 | Ingbert | eCall_MSTest | 51.010-1; 51.010-2 |  | Public Safety (I-A) | 45 | 23 |  |
| 7466 | 2438 | Conformance Test Aspects – non-modem procedures of eCall sessions in UTRA |  | 186d? | 2009-09-18 A | 2010-06-04 A | 100% | 2009-09-18 | 2010-06-04 | 186d? | finish no earlier than 2010-06-04 | R5 | 1488h | 1488h | UMTS_eCall_UEConTest | Ericsson, Qualcomm | Shubhang Vora (svora@qualcomm.com) | Rel-8 | Ingbert | UMTS_eCall_UEConTest | 34.108; 34.123-1; 34.123-2; 34.123-3 |  | Public Safety (I-A) | 45 | 23 | RP-100489 |
| 7467 | 2439 | **IP Interconnection of Services** |  | 967.25d? | 2006-08-16 A | 2009-03-06 A | 100% | 2006-08-16 | 2009-03-06 | 668d? |  | S1; S2; S5; C3 | 44240h | 44240h | IPinterc | Telefónica O2 | chris.friel@O2.com | Rel-8 | Alain | IPinterc |  |  |  | 38 | 21 |  |
| 7468 | 2439.1 | Stage 1 for IPinterc |  | 70d? | 2007-12-06 A | 2008-03-12 A | 100% | 2007-12-06 | 2008-03-12 | 70d? | start no earlier than 2007-12-06 | S1 | 560h | 560h | IPinterc | Telefónica O2 | chris.friel@O2.com | Rel-8 | Alain |  | 22.101; 22.228 |  |  | 38 | 21 |  |
| 7469 | 2439.2 | **System enhancements for interconnection interfaces between two IMSs** |  | 967.25d? | 2006-08-16 A | 2009-03-06 A | 100% | 2006-08-16 | 2009-03-06 | 668d? |  | S2; S5; C3 | 22304h | 22304h | IMS_NNI | Telecom Italia | Mario Madella (mario.madella@telecomitalia.it) | Rel-8 | Maurice | IMS_NNI |  |  |  |  |  |  |
| 7470 | 2439.2.1 | Stage 2 for IMS_NNI |  | 120d? | 2007-06-22 A | 2007-12-06 A | 100% | 2007-06-22 | 2007-12-06 | 120d? | finish no earlier than 2007-12-21 | S2 | 960h | 960h | IMS_NNI | Telecom Italia | Mario Madella (mario.madella@telecomitalia.it) | Rel-8 | Maurice |  | 23.002; 23.228 |  |  |  |  |  |
| 7471 | 2439.2.2 | IMS inter-operator service interconnection interface |  | 461d? | 2007-06-01 A | 2009-03-06 A | 100% | 2007-06-01 | 2009-03-06 | 461d? | finish no earlier than 2009-03-06 | C3 | 3688h | 3688h | FBI2-IOPSI | Telecom Italia | antonio.ascolese@telecomitalia.it | Rel-8 | Adrian | FBI2-IOPSI | 29.865; 29.165 |  |  |  |  |  |
| 7472 | 2439.2.3 | Charging harmonization for NGN between 3GPP and ATIS-TMOC |  | 51d? | 2006-09-28 A | 2006-12-07 A | 100% | 2006-09-28 | 2006-12-07 | 51d? | finish no earlier than 2006-12-07 | S5 | 408h | 408h | FBI2-TISP2-CH | Amdocs | yishai.brown@amdocs.com | Rel-8 | Mirko | FBI2-TISP2-CH | 32.297 |  |  |  |  |  |
| 7473 | 2439.2.4 | Deleted - Protocol impact of FBI for TISPAN R2 |  | 152d? | 2006-08-16 A | 2007-03-15 A | 100% | 2006-08-16 | 2007-03-15 | 152d? | finish no earlier than 2007-03-15 | C1 | 1216h | 1216h | FBI2-TISP2-c1 | Ericsson |  | Rel-8 | Frederic | FBI2-TISP2-c1 |  | SP-38 |  |  |  |  |
| 7474 | 2439.2.5 | Deleted (never approved) - Stage 2 of FBI for TISPAN R2 - Rel 8 | milestone | 0d? | 2007-11-30 A | 2007-11-30 A | 100% | 2007-11-30 | 2007-11-30 | 0d? | finish no earlier than 2007-11-30 | S2 |  |  | FBI2-TISP2-s2 | Nokia Siemens Networks |  | Rel-8 | Maurice | FBI2-TISP2-s2 |  | SP-36 |  |  |  |  |
| 7475 | 2440 | **Support of (G)MSC-S – (G)MSC-S Nc Interface based on the SIP-I protocol** |  | 559.25d? | 2007-09-14 A | 2009-03-06 A | 100% | 2007-09-14 | 2009-03-06 | 386d? |  | C4; C3 | 14960h | 14960h | SIP_Nc | Vodafone | David.Hutton@vodafone.com | Rel-8 | Kimmo | SIP_Nc |  |  |  |  |  |  |
| 7476 | 2440.1 | Stage 1 for SIP_Nc (covered by Feature IPinterc) |  | 70d? | 2007-12-06 A | 2008-03-12 A | 100% | 2007-12-06 | 2008-03-12 | 70d? | start no earlier than 2007-12-06 | S1 | 560h | 560h | SIP_Nc | Telefónica O2 | chris.friel@O2.com | Rel-8 | Alain |  | 22.101; 22.228 |  |  | 41 | 21 |  |
| 7477 | 2440.2 | SIP-I based circuit-switched core network; Stage 2 |  | 321d? | 2007-09-14 A | 2008-12-05 A | 100% | 2007-09-14 | 2008-12-05 | 321d? | finish no earlier than 2008-12-11 | C4 | 2568h | 2568h | SIP_Nc-St2 | Vodafone | David.Hutton@vodafone.com | Rel-8 | Kimmo | SIP_Nc-St2 | 23.231; 23.153; 23.205 |  |  |  |  |  |
| 7478 | 2440.3 | Application of SIP-I Protocols to Circuit Switched (CS) core network architecture; Stage 3 |  | 321d? | 2007-09-14 A | 2008-12-05 A | 100% | 2007-09-14 | 2008-12-05 | 321d? | finish no earlier than 2008-12-11 | C4 | 2568h | 2568h | SIP_Nc-St3C4 | Vodafone | David.Hutton@vodafone.com | Rel-8 | Kimmo | SIP_Nc-St3 | 29.231; 29.232; 29.332 |  |  |  |  |  |
| 7479 | 2440.4 | Interworking between the 3GPP CS domain with SIP-I as signalling protocol and other networks |  | 386d? | 2007-09-14 A | 2009-03-06 A | 100% | 2007-09-14 | 2009-03-06 | 386d? | finish no earlier than 2009-03-06 | C3 | 3088h | 3088h | SIP_Nc-St3C3 | Nokia Siemens Networks | Thomas.Belling@nsn.com | Rel-8 | Adrian |  | 29.235; 23.172; 23.202; 29.007; 29.163; 29.414 |  |  |  |  |  |

Notes:
- 7453: CP#43 completed
- 7454: SP#31 completed
- 7455: CP#42 completed
- 7456: CP#43 completed
- 7457: CP#43 completed
- 7458: CP#42 no impact on CT4 specs
- 7459: SP#37 completed
- 7460: SP#37 stopped
- 7461: SP#39 completed. Linked to SA4 Feature UID_34042 (eCall_Phase2)
- 7462: SP#39 completed
- 7463: CP#43 completed
- 7464: SP#45 completed. Triggered by Study UID_360015 (eCALLIBMS). Linked to SA1 Feature UID_330005 (EData)
- 7465: GP#47 completed. GP#43 WID approved. Testing for Rel-8 eCall_Phase2 (UID_34042) and EData (UID_330005)
- 7466: RP#48 completed. Testing for Rel-8 eCall_Phase2 (UID_34042) and Edata (UID_330005)
- 7467: SP#43 completed
- 7468: SP#39 completed.
- 7469: CP#43 completed
- 7470: SP#38 completed
- 7471: CP#43 completed
- 7472: SP#34 completed
- 7473: SP#38 stopped
- 7474: SP#36 stopped
- 7475: CP#43 completed. Stage 1 in Feature UID_380060 (IPinterc). CP#40 updated WID CP-070517=>CP-080282
- 7476: 22/07/08 Created. Stage 1 for SIP_Nc (covered by SA1 Feature UID_380060 Ipinterc)
- 7477: CP#42 completed
- 7478: CP#42 completed
- 7479: CP#43 completed. CP#42 target 12/08=>03/09

| ID | WBS | Task | Type | Duration | Start | Finish | Complete | Baseline start | Baseline finish | Baseline duration | Constraint | Resources | Work | Actual work | Acronym | WI rapporteur name | WI rapporteur e-mail | Release | TSG approved | MCC resp | Special Focus Doc | Acronym_3GU_Export | Impacted TSs and TRs | PCG approved | Status Report |
| --- | --- | --- | --- | --- | --- | --- | --- | --- | --- | --- | --- | --- | --- | --- | --- | --- | --- | --- | --- | --- | --- | --- | --- | --- | --- |
| 7480 | 2441 | **Earthquake and Tsunami Warning System** |  | 635.75d? | 2007-09-10 A | 2009-05-15 A | 100% | 2007-09-10 | 2009-05-15 | 440d? |  | S1; S2; C1; C4; G2 | 21280h | 21280h | ETWS | NTT DoCoMo | kitaharar@nttdocomo.co.jp | Rel-8 | 37 | Alain | Public Safety (I-A) | ETWS |  |  |  |
| 7481 | 2441.1 | Stage 1 for ETWS |  | 133d? | 2007-09-10 A | 2008-03-12 A | 100% | 2007-09-10 | 2008-03-12 | 133d? | finish no earlier than 2008-03-12 | S1 | 1064h | 1064h | ETWS | NTT DoCoMo | kitaharar@nttdocomo.co.jp | Rel-8 | 37 | Alain | Public Safety (I-A) |  | 22.168 |  |  |
| 7482 | 2441.2 | SA2 aspects of ETWS |  | 179d? | 2008-01-14 A | 2008-09-18 A | 100% | 2008-01-14 | 2008-09-18 | 179d? | finish no earlier than 2008-09-08 | S2 | 1432h | 1432h | ETWS | NTT DoCoMo | tanakai@nttdocomo.co.jp | Rel-8 | 38 | Maurice | Public Safety (I-A) |  | 23.828; 23.401 | 21 |  |
| 7483 | 2441.3 | CT1 aspects of ETWS |  | 50.5d? | 2008-05-30 A | 2008-12-05 A | 100% | 2008-05-30 | 2008-12-05 | 50.5d? | finish no earlier than 2008-12-05 | C1 | 404h | 404h | ETWS | NTT DoCoMo | yamashitahi@s1.nttdocomo.co.jp | Rel-8 | 40 | Frederic | Public Safety (I-A) |  | 23.041 | 21 |  |
| 7484 | 2441.4 | CT4 aspects of ETWS |  | 50.5d? | 2008-09-26 A | 2008-12-05 A | 100% | 2008-09-26 | 2008-12-05 | 50.5d? | finish no earlier than 2008-12-05 | C4 | 404h | 404h | ETWS | NTT DoCoMo | yamashitahi@s1.nttdocomo.co.jp | Rel-8 | 40 | Kimmo | Public Safety (I-A) |  | 29.168 | 21 |  |
| 7485 | 2441.5 | ETWS primary notification message definition in GERAN |  | 47d? | 2009-03-12 A | 2009-05-15 A | 100% | 2009-03-12 | 2009-05-15 | 47d? | finish no earlier than 2009-05-15 | G2 | 376h | 376h | ETWS | Ericsson | claes-goran.persson@ericsson.com | Rel-8 | 43 | Gert | Public Safety (I-A) |  | 44.018; 44.060 | 22 |  |
| 7486 | 2442 | Conformance Test Aspects – UMTS Earthquake and Tsunami Warning System (ETWS) FDD |  | 207d? | 2009-05-29 A | 2010-03-12 A | 100% | 2009-05-29 | 2010-03-12 | 207d? | finish no earlier than 2010-03-12 | R5 | 1656h | 1656h | ETWS_UMTS_UEConTestFDD | NTT DoCoMo | Makoto Ito (itohm@nttdocomo.co.jp) | Rel-8 | 44 | Ingbert | Public Safety (I-A) | ETWS_UMTS_UEConTestFDD | 34.108; 34.123-1; 34.123-2 | 23 | RP-100068 |
| 7487 | 2443 | **In Case of Emergency numbers storage and easy access on UICC** |  | 750.75d? | 2007-03-13 A | 2009-03-06 A | 100% | 2007-03-13 | 2009-03-06 | 519d? |  | S1; C6 | 14552h | 14552h | ICE | Vodafone | armin.toepfer@vodafone.com | Rel-8 | 38 | Alain |  | ICE |  | 21 |  |
| 7488 | 2443.1 | Stage 1 for ICE |  | 262d? | 2007-03-13 A | 2008-03-12 A | 100% | 2007-03-13 | 2008-03-12 | 262d? | finish no earlier than 2008-03-12 | S1 | 2096h | 2096h | ICE | Vodafone | armin.toepfer@vodafone.com | Rel-8 | 38 | Alain |  |  | 22.030; 22.101 | 21 |  |
| 7489 | 2443.2 | CT6 aspects of ICE |  | 519d? | 2007-03-13 A | 2009-03-06 A | 100% | 2007-03-13 | 2009-03-06 | 519d? | finish no earlier than 2009-03-06 | C6 | 4152h | 4152h | ICE | Vodafone | armin.toepfer@vodafone.com | Rel-8 | 38 | Xavier |  |  | 31.102 | 21 |  |
| 7490 | 2444 | Local Charging Zone Requirements |  | 380d? | 2006-09-28 A | 2008-03-12 A | 100% | 2006-09-28 | 2008-03-12 | 380d? | finish no earlier than 2006-12-07 | S1 | 3040h | 3040h | LCZR | China Mobile | liuhongyfw@chinamobile.com | Rel-8 |  | Alain |  | LCZR | 22.115 |  |  |
| 7491 | 2445 | **Customized Alerting Tone (CAT) service** |  | 1054.12d? | 2006-12-06 A | 2009-09-18 A | 100% | 2006-12-06 | 2009-09-18 | 729d? |  | S1; C1; C3; C4 | 39854h | 39854h | CAT | China Mobile | fenglingjuan@chinamobile.com | Rel-8 | 34 | Alain |  | CAT |  |  |  |
| 7492 | 2445.1 | Stage 1 for CAT |  | 207d? | 2006-12-06 A | 2007-09-20 A | 100% | 2006-12-06 | 2007-09-20 | 207d? | start no earlier than 2006-12-06 | S1 | 1656h | 1656h | CAT | China Mobile | fenglingjuan@chinamobile.com | Rel-8 | 37 | Alain |  |  | 22.182 |  |  |
| 7493 | 2445.2 | TISPAN requirements for customized multimedia information services |  | 71d? | 2007-09-03 A | 2007-12-10 A | 100% | 2007-09-03 | 2007-12-10 | 71d? | finish no earlier than 2007-12-10 | S1 | 568h | 568h | TISCMI | China Mobile | fenglingjuan@chinamobile.com | Rel-8 | 37 | Alain |  | TISCMI | 22.182 |  |  |
| 7494 | 2445.3 | **IMS CAT Supplementary Service** |  | 575.62d? | 2008-03-12 A | 2009-09-18 A | 100% | 2008-03-12 | 2009-09-18 | 399d? |  | C1; C3 | 10814.4h | 10814.4h | CAT-SS | Nortel | milanpa@nortel.com | Rel-8 | 39 | Frederic |  | CAT-SS |  | 21 |  |
| 7495 | 2445.3.1 | IMS CAT SS |  | 164d? | 2008-04-21 A | 2008-12-04 A | 100% | 2008-04-21 | 2008-12-04 | 164d? | finish no earlier than 2008-12-05 | C1 | 1312h | 1312h | CAT-SS | Nortel | milanpa@nortel.com | Rel-8 | 39 | Frederic |  |  | 24.182 | 21 |  |
| 7496 | 2445.3.2 | CAT solution for voice and video call in CS domain |  | 389.8d? | 2008-03-12 A | 2009-09-18 A | 100% | 2008-03-12 | 2009-09-18 | 389.8d? | finish no earlier than 2009-09-11 | C3 | 3118.4h | 3118.4h | CAT-SS | Nortel | milanpa@nortel.com | Rel-8 | 39 | Adrian |  |  | 29.163 | 21 |  |
| 7497 | 2445.4 | **CAT Service in 3GPP CS domain** |  | 182.25d? | 2008-09-12 A | 2009-03-06 A | 100% | 2008-09-12 | 2009-03-06 | 126d? |  | C4; C1 | 3487.6h | 3487.6h | CAT-3G_CS | China Mobile | zhaoyuyi@chinamobile.com | Rel-8 | 41 | Kimmo |  | CAT-3G_CS | 23.205; 23.231; 29.002 | 21 |  |
| 7498 | 2445.4.1 | CT4 part of CAT Service in 3GPP CS domain |  | 126d? | 2008-09-12 A | 2009-03-06 A | 100% | 2008-09-12 | 2009-03-06 | 126d? | finish no earlier than 2009-03-06 | C4 | 1008h | 1008h | CAT-3G_CS | China Mobile | zhaoyuyi@chinamobile.com | Rel-8 | 41 | Kimmo |  |  | 23.205; 23.231; 29.002 | 21 |  |
| 7499 | 2445.4.2 | CT1 part of CAT Service in 3GPP CS domain |  | 57.95d? | 2008-09-12 A | 2008-12-05 A | 100% | 2008-09-12 | 2008-12-05 | 57.95d? | start no earlier than 2008-09-12 | C1 | 463.6h | 463.6h | CAT-3G_CS | China Mobile | zhaoyuyi@chinamobile.com | Rel-8 | 41 | Frederic |  |  | 24.008; 23.014 | 21 |  |
| 7500 | 2446 | **Service-Level Interworking for Messaging Services** |  | 736.25d? | 2007-03-26 A | 2009-03-06 A | 100% | 2007-03-26 | 2009-03-06 | 509d? |  | S1; S2; C3; C1 | 20800h | 20800h | MESSIW | Huawei | ling.liu@huawei.com; duanxiaoqin@huawei.com | Rel-8 | 34 | Alain |  | MESSIW |  |  |  |
| 7501 | 2446.1 | Stage 1 for MESSIW | milestone | 0d? | 2007-03-26 A | 2007-03-26 A | 100% | 2007-03-26 | 2007-03-26 | 0d? | finish no earlier than 2007-12-01 | S1 |  |  | MESSIW | Huawei | ling.liu@huawei.com | Rel-8 |  | Alain |  |  | 22.105; 22.340 |  |  |
| 7502 | 2446.2 | Stage 2 for MESSIW |  | 227d? | 2007-04-26 A | 2008-03-07 A | 100% | 2007-04-26 | 2008-03-07 | 227d? | finish no earlier than 2008-03-07 | S2 | 1816h | 1816h | MESSIW | Huawei | patrice.hede@huawei.com | Rel-8 |  | Maurice |  |  | 23.811; 23.204 |  |  |
| 7503 | 2446.3 | CT3 part of Stage 3 for MESSIW |  | 201d? | 2008-05-30 A | 2009-03-06 A | 100% | 2008-05-30 | 2009-03-06 | 201d? | finish no earlier than 2008-12-05 | C3 | 1608h | 1608h | MESSIW | Huawei | xupeili@huawei.com | Rel-8 | 40 | Adrian |  |  | 29.311 | 21 |  |
| 7504 | 2446.4 | CT1 part of Stage 3 for MESSIW |  | 136d? | 2008-05-30 A | 2008-12-05 A | 100% | 2008-05-30 | 2008-12-05 | 136d? | finish no earlier than 2008-12-12 | C1 | 1088h | 1088h | MESSIW | Huawei | xupeili@huawei.com | Rel-8 | 40 | Frederic |  |  | 24.229 | 21 |  |

Notes:
- 7480: SP#43 Larger scope Feature UID_380057 (PWS) moved to Rel-9
- 7481: SP#39 completed
- 7482: SP#41 completed
- 7483: CP#42 completed
- 7484: CP#42 completed
- 7485: SP#44 completed with CT1 help (GERAN2 LS_in SP-090154)
- 7486: RP#47 completed. Testing for Rel-8 ETWS UID_370051
- 7487: CP#43 completed (ICE Graphics not included in Rel-8)
- 7488: SP#39 Stage 1 completed
- 7489: CP#43 completed (ICE Graphics not in Rel-8 / not explicitly in SA1 WID either)
- 7490: SP#39 Stage 1 completed
- 7491: CP#45 completed
- 7492: -
- 7493: SP#38 completed
- 7494: -
- 7495: CP#42 completed
- 7496: CP#45 completed. Triggered by Study UID_360031 (TR 29.882)
- 7497: -
- 7498: CP#43 completed. Triggered by Study UID_360031 (TR 29.882)
- 7499: CP#42 completed. Triggered by Study UID_360031 (TR 29.882)
- 7500: CP#43 completed
- 7501: SP#35 completed
- 7502: SP#39 completed
- 7503: CP#43 completed
- 7504: CP#42 completed

| ID | WBS | Task | Duration | Start | Finish | Complete | Baseline start | Baseline finish | Baseline duration | Constraint | Resources | Work | Actual work | Acronym | WI rapporteur name | WI rapporteur e-mail | Release | TSG approved | MCC resp | Special Focus Doc | Acronym_3GU_Export | Impacted TSs and TRs | PCG stopped | TSG stopped | PCG approved |
| --- | --- | --- | --- | --- | --- | --- | --- | --- | --- | --- | --- | --- | --- | --- | --- | --- | --- | --- | --- | --- | --- | --- | --- | --- | --- |
| 7505 | 2447 | **Multimedia Priority Service** | 1241.62d? | 2006-06-08 A | 2009-09-18 A | 100% | 2006-06-08 | 2009-09-18 | 858d? |  | S1; C1; C3; C4 | 43016h | 43016h | PRIOR_EMR | Telcordia | jgarraha@telcordia.com | Rel-8 | 34 | Alain | Public Safety (I-A) | PRIOR |  |  |  |  |
| 7506 | 2447.1 | Service Requirements for PRIOR | 391d? | 2006-06-08 A | 2007-12-06 A | 100% | 2006-06-08 | 2007-12-06 | 391d? | finish no earlier than 2007-11-30 | S1 | 3128h | 3128h | PRIOR_EMR | Telcordia | jgarraha@telcordia.com | Rel-8 | 32 | Alain | Public Safety (I-A) | PRIOR-EMR | New 22.153 |  |  |  |
| 7507 | 2447.2 | CT1 part of Stage 3 for PRIOR | 732d? | 2006-12-01 A | 2009-09-18 A | 100% | 2006-12-01 | 2009-09-18 | 732d? | finish no earlier than 2009-09-18 | C1 | 5856h | 5856h | PRIOR_EMR | Alcatel-Lucent | Keith Drage (drage@alcatel-lucent.com) | Rel-8 | 34 | Frederic | Public Safety (I-A) |  | 24.229 |  |  |  |
| 7508 | 2447.3 | CT4 part of Stage 3 for PRIOR | 381d? | 2007-09-21 A | 2009-03-06 A | 100% | 2007-09-21 | 2009-03-06 | 381d? | finish no earlier than 2009-03-06 | C4 | 3048h | 3048h | PRIOR_EMR | Alcatel-Lucent | Keith Drage (drage@alcatel-lucent.com) | Rel-8 | 37 | Kimmo | Public Safety (I-A) |  | 23.008; 29.228; 29.229 |  |  |  |
| 7509 | 2447.4 | Deleted - Stage 3 for PRIOR | 441d? | 2007-09-21 A | 2009-05-29 A | 100% | 2007-09-21 | 2009-05-29 | 441d? | finish no earlier than 2009-05-29 | C3 | 3528h | 3528h | PRIOR-EMR | Alcatel-Lucent | Keith Drage (drage@alcatel-lucent.com) | Rel-8 | 37 | Adrian | Public Safety (I-A) |  | 29.212; 29.213; 29.214; 29.163 | PCG-23 | CP-44 |  |
| 7510 | 2448 | **Open Service Access (OSA) Rel-8** | 292d? | 2007-08-23 A | 2008-05-30 A | 100% | 2007-08-23 | 2008-05-30 | 202d? |  | S1; C5 | 25528h | 25528h | OSA8 | Orange | Song Dong | Rel-8 |  | Alain |  | OSA8 |  |  |  |  |
| 7511 | 2448.1 | OSA Stage 1 - Service Requirements | 145d? | 2007-08-23 A | 2008-03-12 A | 100% | 2007-08-23 | 2008-03-12 | 145d? | finish no earlier than 2007-12-04 | S1 | 1160h | 1160h | OSA8 | Orange, AePONA | Song Dong | Rel-8 |  | Alain |  |  | 22.127 |  |  |  |
| 7512 | 2448.2 | OSA Stage 1 - NGN Service Requirement | 140d? | 2007-09-03 A | 2008-03-14 A | 100% | 2007-09-03 | 2008-03-14 | 140d? | finish no earlier than 2008-03-14 | S1 | 1120h | 1120h | OSA8-IMSReq | Orange | Song Dong | Rel-8 | 37 | Alain |  | OSA8-IMS | 22.127 |  |  |  |
| 7513 | 2448.3 | **Rel-8 OSA Stage 2/3 enhancements** | 226.75d? | 2007-10-25 A | 2008-05-30 A | 100% | 2007-10-25 | 2008-05-30 | 157d? |  | C5 | 20016h | 20016h | OSA8-IMS | Alcatel-Lucent | unmehopa@alcatel-lucent.com | Rel-8 |  | Kimmo |  |  | 23.198; 29.198; 29.199 |  |  |  |
| 7514 | 2448.3.1 | Deleted - Ensure Parlay-X composable with identity management frameworks, in particular Liberty Alliance | 157d? | 2007-10-25 A | 2008-05-30 A | 100% | 2007-10-25 | 2008-05-30 | 157d? | finish no earlier than 2008-12-25 | C5 | 1256h | 1256h |  | Ericsson | catherine.mulligan@ericsson.com | Rel-8 | 37 | Kimmo |  |  | existing 29.199-xy | PCG-21 | CP-40 | 21 |
| 7515 | 2448.3.2 | Parlay-X Content Management web service (store/manage meta-data) | 157d? | 2007-10-25 A | 2008-05-30 A | 100% | 2007-10-25 | 2008-05-30 | 157d? | finish no earlier than 2008-12-04 | C5 | 1256h | 1256h | OSA8-IMS | Alcatel-Lucent | unmehopa@alcatel-lucent.com | Rel-8 | 37 | Kimmo |  |  | 29.199-21 |  |  |  |
| 7516 | 2448.3.3 | Parlay-X Policy web service | 157d? | 2007-10-25 A | 2008-05-30 A | 100% | 2007-10-25 | 2008-05-30 | 157d? | finish no earlier than 2008-12-04 | C5 | 1256h | 1256h | OSA8-IMS | Alcatel-Lucent | unmehopa@alcatel-lucent.com | Rel-8 | 37 | Kimmo |  |  | 29.199-22 |  |  |  |
| 7517 | 2448.3.4 | Parlay-X Terminal status web service | 157d? | 2007-10-25 A | 2008-05-30 A | 100% | 2007-10-25 | 2008-05-30 | 157d? | finish no earlier than 2008-05-30 | C5 | 1256h | 1256h | OSA8-IMS | Alcatel-Lucent | unmehopa@alcatel-lucent.com | Rel-8 | 37 | Kimmo |  |  | 29.199-08 |  |  |  |
| 7518 | 2448.3.5 | Deleted - Identify communication format used by a particular application | 157d? | 2007-10-25 A | 2008-05-30 A | 100% | 2007-10-25 | 2008-05-30 | 157d? | finish no earlier than 2008-05-30 | C5 | 1256h | 1256h |  | Ericsson | catherine.mulligan@ericsson.com | Rel-8 | 37 | Kimmo |  |  | existing 29.199-xy | PCG-21 | CP-40 | 21 |
| 7519 | 2448.3.6 | Deleted - Security on User Profile Management - reuse GUP API (22.127 CR 0084 S1-071794) | 128d? | 2007-12-05 A | 2008-05-30 A | 100% | 2007-12-05 | 2008-05-30 | 128d? | finish no earlier than 2008-12-25 | C5 | 1024h | 1024h |  | Telecom Italia | vincenzo.amorino@telecomitalia.it | Rel-8 | 38 | Kimmo |  |  | PXWS Framework | PCG-21 | CP-40 | 21 |
| 7520 | 2448.3.7 | Deleted - Privacy on Subscriber Identity (Liberty Alliance, OASIS) (22.127 CR 0085 S1-071835) | 128d? | 2007-12-05 A | 2008-05-30 A | 100% | 2007-12-05 | 2008-05-30 | 128d? | finish no earlier than 2008-12-25 | C5 | 1024h | 1024h |  | Telecom Italia | vincenzo.amorino@telecomitalia.it | Rel-8 | 38 | Kimmo |  |  | PXWS Framework | PCG-21 | CP-40 | 21 |
| 7521 | 2448.3.8 | Deleted - Topology Hiding (22.127 CR 0086 S1-071838) | 128d? | 2007-12-05 A | 2008-05-30 A | 100% | 2007-12-05 | 2008-05-30 | 128d? | finish no earlier than 2008-12-25 | C5 | 1024h | 1024h |  | Telecom Italia | vincenzo.amorino@telecomitalia.it | Rel-8 | 38 | Kimmo |  |  | PXWS Framework | PCG-21 | CP-40 | 21 |
| 7522 | 2448.3.9 | Deleted - Subscriber event notification (22.127 CR 0087 S1-071836) | 128d? | 2007-12-05 A | 2008-05-30 A | 100% | 2007-12-05 | 2008-05-30 | 128d? | finish no earlier than 2008-12-25 | C5 | 1024h | 1024h |  | Telecom Italia | vincenzo.amorino@telecomitalia.it | Rel-8 | 38 | Kimmo |  |  | PXWS Framework | PCG-21 | CP-40 | 21 |
| 7523 | 2448.3.10 | Deleted - Event notification (22.127 CR 0088 S1-071762) | 128d? | 2007-12-05 A | 2008-05-30 A | 100% | 2007-12-05 | 2008-05-30 | 128d? | finish no earlier than 2008-12-25 | C5 | 1024h | 1024h |  | Telecom Italia | vincenzo.amorino@telecomitalia.it | Rel-8 | 38 | Kimmo |  |  | PXWS Framework | PCG-21 | CP-40 | 21 |
| 7524 | 2448.3.11 | Deleted - Access policy (22.127 CR 0089 S1-071763) | 128d? | 2007-12-05 A | 2008-05-30 A | 100% | 2007-12-05 | 2008-05-30 | 128d? | finish no earlier than 2008-12-25 | C5 | 1024h | 1024h |  | Telecom Italia | vincenzo.amorino@telecomitalia.it | Rel-8 | 38 | Kimmo |  |  | PXWS Framework | PCG-21 | CP-40 | 21 |
| 7525 | 2448.3.12 | Deleted - API usage accounting (22.127 CR 0090 S1-071792) | 128d? | 2007-12-05 A | 2008-05-30 A | 100% | 2007-12-05 | 2008-05-30 | 128d? | finish no earlier than 2008-12-25 | C5 | 1024h | 1024h |  | Telecom Italia | vincenzo.amorino@telecomitalia.it | Rel-8 | 38 | Kimmo |  |  | PXWS Framework | PCG-21 | CP-40 | 21 |
| 7526 | 2448.3.13 | Presence alignment with OMA and IETF (22.127 CR 0092 S1-071764) | 128d? | 2007-12-05 A | 2008-05-30 A | 100% | 2007-12-05 | 2008-05-30 | 128d? | finish no earlier than 2008-05-30 | C5 | 1024h | 1024h | OSA8-IMS | Alcatel-Lucent | unmehopa@alcatel-lucent.com | Rel-8 | 38 | Kimmo |  |  | 29.199-14/13 |  |  | 21 |
| 7527 | 2448.3.14 | Deleted - Service identification (22.127 CR 0095 S1-071837) | 128d? | 2007-12-05 A | 2008-05-30 A | 100% | 2007-12-05 | 2008-05-30 | 128d? | finish no earlier than 2008-05-30 | C5 | 1024h | 1024h |  | Ericsson | catherine.mulligan@ericsson.com | Rel-8 | 38 | Kimmo |  |  | existing 29.199-xy | PCG-21 | CP-40 | 21 |
| 7528 | 2448.3.15 | Framework Enterprise Operator (Service Subscription function) | 102d? | 2008-01-10 A | 2008-05-30 A | 100% | 2008-01-10 | 2008-05-30 | 102d? | finish no earlier than 2008-05-30 | C5 | 816h | 816h | OSA8-IMS | Alcatel-Lucent | unmehopa@alcatel-lucent.com | Rel-8 | 39 | Kimmo |  |  | 29.198-03 |  |  | 21 |
| 7529 | 2448.3.16 | Mobility Emergency Location | 102d? | 2008-01-10 A | 2008-05-30 A | 100% | 2008-01-10 | 2008-05-30 | 102d? | finish no earlier than 2008-05-30 | C5 | 816h | 816h | OSA8-IMS | Alcatel-Lucent | unmehopa@alcatel-lucent.com | Rel-8 | 39 | Kimmo |  |  | 29.198-06 |  |  | 21 |
| 7530 | 2448.3.17 | Connectivity Manager SCF | 102d? | 2008-01-10 A | 2008-05-30 A | 100% | 2008-01-10 | 2008-05-30 | 102d? |  | C5 | 816h | 816h | OSA8-IMS | Alcatel-Lucent | unmehopa@alcatel-lucent.com | Rel-8 | 39 | Kimmo |  |  | 29.198-10 |  |  | 21 |
| 7531 | 2448.3.18 | PAM Presence Agent | 102d? | 2008-01-10 A | 2008-05-30 A | 100% | 2008-01-10 | 2008-05-30 | 102d? | finish no earlier than 2008-05-30 | C5 | 816h | 816h | OSA8-IMS | Alcatel-Lucent | unmehopa@alcatel-lucent.com | Rel-8 | 39 | Kimmo |  |  | 29.198-14 |  |  | 21 |

Notes:
- 7505: CP#45 completed
- 7506: SP#38 completed
- 7507: CP#45 completed
- 7508: CP#43 completed
- 7509: CP#44 stopped (Reason: No Rel-8 solution expected (LS sent to SA2, but not prioritized in SA2)
- 7510: SP#40 maintenance & new OSA work moved to OMA. Rel-9 onwards 3GPP references to 22.127 changed to OMA Parlay Service Access Requirements (OMA-RD-Parlay_Service_Access-V1_0-20100427-A).
- 7511: SP#40 maintenance & new OSA work moved to OMA. Rel-9 onwards 3GPP references to 22.127 changed to OMA Parlay Service Access Requirements (OMA-RD-Parlay_Service_Access-V1_0-20100427-A).
- 7512: SP#40 maintenance & new OSA work moved to OMA
- 7513: SP#40 maintenance & new OSA work moved to OMA
- 7514: CP#40: Work moved to OMA
- 7515: CP#40 completed
- 7516: CP#40 completed
- 7517: CP#40 completed
- 7518: CP#40: Work moved to OMA
- 7519: SP#38 SP-070853 R8 CRs 22.127 OSA Stage 1. CP#40: Work moved to OMA
- 7520: SP#38 SP-070853 R8 CRs 22.127 OSA Stage 1. CP#40: Work moved to OMA
- 7521: SP#38 SP-070853 R8 CRs 22.127 OSA Stage 1. CP#40: Work moved to OMA
- 7522: SP#38 SP-070853 R8 CRs 22.127 OSA Stage 1. CP#40: Work moved to OMA
- 7523: SP#38 SP-070853 R8 CRs 22.127 OSA Stage 1. CP#40: Work moved to OMA
- 7524: SP#38 SP-070853 R8 CRs 22.127 OSA Stage 1. CP#40: Work moved to OMA
- 7525: SP#38 SP-070853 R8 CRs 22.127 OSA Stage 1. CP#40: Work moved to OMA
- 7526: CP#40 completed
- 7527: SP#38 SP-070853 R8 CRs 22.127 OSA Stage 1. CP#40: Work moved to OMA
- 7528: CP#40 completed
- 7529: CP#40 completed
- 7530: CP#40 completed
- 7531: CP#40 completed

| ID | WBS | Task | Duration | Start | Finish | Complete | Remaining | Baseline start | Baseline finish | Baseline duration | Total slack | Constraint | Resources | Work | Actual work | Acronym | WI rapporteur name | Release | MCC resp | Acronym_3GU_Export | TSG approved | PCG approved | Status Report | Special Focus Doc |
| --- | --- | --- | --- | --- | --- | --- | --- | --- | --- | --- | --- | --- | --- | --- | --- | --- | --- | --- | --- | --- | --- | --- | --- | --- |
| 7532 | 2449 | **Paging Permission with Access Control (PPACR)** | 562.25d? | 2007-06-12 A | 2008-12-05 A | 100% |  | 2007-06-12 | 2008-12-05 | 389d? |  |  | S1; C1 | 9000h | 9000h | PPACR | NTT DoCoMo | Rel-8 | Alain | PPACR |  |  |  |  |
| 7533 | 2449.1 | Stage 1 for PPACR | 69d? | 2007-06-12 A | 2007-09-14 A | 100% |  | 2007-06-12 | 2007-09-14 | 69d? |  | finish no earlier than 2007-09-14 | S1 | 552h | 552h | PPACR-S1 | NTT DoCoMo | Rel-8 | Alain | PPACR-S1 | 37 |  |  |  |
| 7534 | 2449.2 | Stage 3 for PPACR (CT1) | 278d? | 2007-11-14 A | 2008-12-05 A | 100% |  | 2007-11-14 | 2008-12-05 | 278d? |  | finish no earlier than 2008-12-05 | C1 | 2224h | 2224h | PPACR-CT1 | NTT DoCoMo | Rel-8 | Frederic | PPACR-CT1 | 38 | 21 |  |  |
| 7535 | 2450 | Conformance Test Aspects – Paging Permission with Access Control (PPAC) | 61d? | 2010-09-17 A | 2010-12-10 A | 100% |  | 2010-09-17 | 2010-12-10 | 61d? |  | finish no earlier than 2010-12-10 | R5 | 488h | 488h | PPAC_UEConTest | NTT DoCoMo | Rel-8 | Ingbert | PPAC_UEConTest | 49 | 25 | RP-101074 |  |
| 7536 | 2451 | **Charging for multi-phases services** | 101.5d? | 2007-12-06 A | 2008-03-12 | 99% | 0d? | 2007-12-06 | 2008-03-12 | 70d? | 0d |  | S1 | 560h | 560h | CHRGMPH | Telecom Italia | Rel-8 | Alain | CHRGMPH | 38 | 21 |  |  |
| 7537 | 2451.1 | Stage 1 for CHRGMPH | 70d? | 2007-12-06 A | 2008-03-12 A | 100% |  | 2007-12-06 | 2008-03-12 | 70d? |  | start no earlier than 2007-12-06 | S1 | 560h | 560h | CHRGMPH-s1 | Telecom Italia | Rel-8 | Alain | CHRGMPH-s1 | 38 | 21 |  |  |
| 7538 | 2452 | **Home NodeB / eNodeB** | 473.25d? | 2007-12-06 A | 2009-03-06 A | 100% |  | 2007-12-06 | 2009-03-06 | 327d? |  |  | S1; C1; C4 | 10952h | 10952h | HomeNB | Vodafone | Rel-8 | Alain | HomeNB | 38 | 21 |  | HNB |
| 7539 | 2452.1 | Stage 1 for Home NodeB / eNodeB | 70d? | 2007-12-06 A | 2008-03-12 A | 100% |  | 2007-12-06 | 2008-03-12 | 70d? |  | start no earlier than 2007-12-06 | S1 | 560h | 560h | HomeNB-S1 | Vodafone | Rel-8 | Alain | HomeNB-S1 | 38 | 21 |  | HNB |
| 7540 | 2452.2 | Support of Closed Subscriber Group (CSG) | 66d? | 2008-12-05 A | 2009-03-06 A | 100% |  | 2008-12-05 | 2009-03-06 | 66d? |  | finish no earlier than 2009-03-06 | C4 | 528h | 528h |  | CT#42 | Rel-8 | Kimmo |  | 42 | 22 |  | HNB |
| 7541 | 2452.3 | CSG and Idle Mode Mobility for LTE Home eNodeB | 126d? | 2008-09-12 A | 2009-03-06 A | 100% |  | 2008-09-12 | 2009-03-06 | 126d? |  | finish no earlier than 2009-03-06 | C1 | 1008h | 1008h | HomeNB-LTE | Huawei | Rel-8 | Frederic | HomeNB-LTE | 41 | 21 |  | HNB |
| 7542 | 2452.4 | CSG and Idle Mode Mobility for 3G Home NodeB | 126d? | 2008-09-12 A | 2009-03-06 A | 100% |  | 2008-09-12 | 2009-03-06 | 126d? |  | finish no earlier than 2009-03-06 | C1 | 1008h | 1008h | HomeNB-3G | Qualcomm | Rel-8 | Frederic | HomeNB-3G | 41 | 21 |  | HNB |
| 7543 | 2453 | **UTRA HNB** | 471.12d? | 2008-03-07 A | 2009-06-04 A | 100% |  | 2008-03-07 | 2009-06-04 | 326d? |  |  | RP; S5 | 11008h | 11008h | HNB |  | Rel-8 | Issam | HNB | 39 | 21 |  | HNB |
| 7544 | 2453.1 | Support of UTRA HNB | 201d? | 2008-05-30 A | 2009-03-06 A | 100% |  | 2008-05-30 | 2009-03-06 | 201d? |  | finish no earlier than 2009-03-06 | R2 | 1608h | 1608h | HNB-supp | Huawei | Rel-8 | Yong-Jun | HNB-supp | 40 | 21 | RP-090040 | HNB |
| 7545 | 2453.2 | UTRAN Architecture for 3G HNB | 136d? | 2008-05-30 A | 2008-12-05 A | 100% |  | 2008-05-30 | 2008-12-05 | 136d? |  | finish no earlier than 2008-12-05 | R3 | 1088h | 1088h | HNB-arch | Alcatel-Lucent | Rel-8 | Juha | HNB-arch | 40 | 21 | RP-090042 | HNB |
| 7546 | 2453.3 | FDD Home NodeB RF requirements | 261d? | 2008-03-07 A | 2009-03-06 A | 100% |  | 2008-03-07 | 2009-03-06 | 261d? |  | finish no earlier than 2009-03-06 | R4 | 2088h | 2088h | HNB-RF | Motorola | Rel-8 | Issam | HNB-RF | 39 | 21 | RP-090041 | HNB |
| 7547 | 2453.4 | 3G Home NodeB OAM&P Type 1 Management Interface | 127d? | 2008-12-11 A | 2009-06-04 A | 100% |  | 2008-12-11 | 2009-06-04 | 127d? |  | finish no earlier than 2009-06-04 | S5 | 1008h | 1008h | HNB-3G_OAM | Huawei | Rel-8 | Mirko | HNB-3G_OAM | 42 | 22 |  | HNB |
| 7548 | 2454 | **UTRA HNB – UE Conformance Testing** | 472.12d? | 2009-03-06 A | 2010-06-04 A | 100% |  | 2009-03-06 | 2010-06-04 | 327d? |  |  | R5 | 5224h | 5224h | HNB-UEConTest |  | Rel-8 | Ingbert | HNB-UEConTest | 43 | 22 |  | HNB |
| 7549 | 2454.1 | Conformance Test Aspects – UTRA HNB (FDD) | 326d? | 2009-03-06 A | 2010-06-04 A | 100% |  | 2009-03-06 | 2010-06-04 | 326d? |  | finish no earlier than 2010-06-04 | R5 | 2608h | 2608h | HNB-UEConTestFDD | Huawei | Rel-8 | Ingbert | HNB-UEConTestFDD | 43 | 22 | RP-100482 | HNB |
| 7550 | 2455 | Lawful Interception in the 3GPP Rel-8 | 524d? | 2007-03-12 A | 2009-03-12 A | 100% |  | 2007-03-12 | 2009-03-12 | 524d? |  | finish no earlier than 2009-03-12 | S3 | 4192h | 4192h | LI8 | BMWI, Verizon | Rel-8 | Mirko | LI8 |  |  |  |  |
| 7551 | 2456 | **Generic Bootstrapping Architecture Push Function** | 372.75d? | 2008-03-12 A | 2009-03-06 A | 100% |  | 2008-03-12 | 2009-03-06 | 258d? |  |  | S3; C1; C4 | 10596.8h | 10596.8h | GBAPush | Ericsson | Rel-8 | Mirko | GBAPush | 39 | 21 |  |  |
| 7552 | 2456.1 | SA3 part of GBAPush (33.223) | 193d? | 2008-03-12 A | 2008-12-05 A | 100% |  | 2008-03-12 | 2008-12-05 | 193d? |  | finish no earlier than 2008-12-05 | S3 | 1544h | 1544h | GBAPush | Ericsson | Rel-8 | Mirko |  | 39 | 21 |  |  |
| 7553 | 2456.2 | CT1 part of GBAPush | 178.8d? | 2008-03-12 A | 2009-03-06 A | 100% |  | 2008-03-12 | 2009-03-06 | 178.8d? |  | finish no earlier than 2009-03-06 | C1 | 1430.4h | 1430.4h | GBAPush | Ericsson | Rel-8 | Frederic |  | 39 | 21 |  |  |
| 7554 | 2456.3 | CT4 part of GBAPush | 178.8d? | 2008-03-12 A | 2009-03-06 A | 100% |  | 2008-03-12 | 2009-03-06 | 178.8d? |  | finish no earlier than 2009-03-06 | C4 | 1430.4h | 1430.4h | GBAPush | Ericsson | Rel-8 | Kimmo |  | 39 | 21 |  |  |
| 7555 | 2457 | Requirements and Test methods for Wideband Terminals | 197d? | 2008-03-12 A | 2008-12-11 A | 100% |  | 2008-03-12 | 2008-12-11 | 197d? |  | start no earlier than 2008-03-12 | S4 | 1576h | 1576h | RETEM_WB_T | FT, Ericsson | Rel-8 | Paolo | RETEM_WB_T |  |  |  |  |
| 7556 | 2458 | Extending PSS and MBMS User Services for optimized Mobile TV | 266d? | 2007-12-06 A | 2008-12-11 A | 100% |  | 2007-12-06 | 2008-12-11 | 266d? |  | finish no earlier than 2008-12-11 | S4 | 2128h | 2128h | PSS_MBMS_OMTV | Ericsson | Rel-8 | Paolo | PSS_MBMS_OMTV |  |  |  |  |

Notes:
- 7532: CP#42 completed. Triggered by Study UID_330016 (PPAC). / WI rapporteur e-mail: Morita Takashi
- 7533: SP#37 completed / Impacted TSs and TRs: 22.011 / WI rapporteur e-mail: Morita Takashi
- 7534: CP#42 completed / Impacted TSs and TRs: 24.008; 23.122; 24.301
- 7535: RP#50 completed / Impacted TSs and TRs: UTRA 34.108; 34.123-1; 34.123-2; 34.123-3 / WI rapporteur e-mail: Takao.Shimizu.rp@nttdocomo.com
- 7536: SP#39 Stage 1 completed / Impacted TSs and TRs: 22.115 / WI rapporteur e-mail: Marco.DeLuca1@telecomitalia.it
- 7537: SP#39 completed / Impacted TSs and TRs: 22.115 / WI rapporteur e-mail: Marco.DeLuca1@telecomitalia.it
- 7538: CP#43 completed / WI rapporteur e-mail: John Watson
- 7539: SP#39 completed / Impacted TSs and TRs: 22.011; 22.115 / WI rapporteur e-mail: John Watson
- 7540: CP#43 completed. SP#42 SP-080874 22.011CR0141 confirmed Requirement to support roaming subscribers with CSG home network subscription but did NOT confirmed requirement for home network independent support of roamers in CSG / Impacted TSs and TRs: 29.002; 29.272; 23.008; 23.003 / WI rapporteur e-mail: Hannu Hietalahti
- 7541: CP#43 completed / Impacted TSs and TRs: 23.122; new (24.285; 24.301; 24.801) / WI rapporteur e-mail: zhang.peng@huawei.com
- 7542: CP#43 completed / Impacted TSs and TRs: 23.122; 24.008; new 24.285 / WI rapporteur e-mail: Osok Song
- 7543: SP#44 completed
- 7544: RP#43 completed / Impacted TSs and TRs: 25.304; 25.306; 25.331; new 25.367 / WI rapporteur e-mail: Yang Xudong (yangxudong@huawei.com)
- 7545: RP#42 completed / Impacted TSs and TRs: 25.401; 25.410; 25.412; 25.413; 25.414; 25.415; new (25.467; 25.468; 25.469) / WI rapporteur e-mail: Martin Warner (mw15@alcatel-lucent.com)
- 7546: RP#43 completed / Impacted TSs and TRs: 25.104; 25.141; new 25.967 / WI rapporteur e-mail: Ying Cai (yingcai@motorola.com)
- 7547: SP#44 completed. Complements work in BroadBand Forum / Impacted TSs and TRs: new (32.581; 32.582; 32.583; 32.584) / WI rapporteur e-mail: Zou Lan (zlan@huawei.com)
- 7548: RP#48 FDD completed. Testing for Feature UID_390033 UTRA HNB
- 7549: RP#48 completed / Impacted TSs and TRs: 34.108; 34.123-1; 34.123-2; 34.123-3 / WI rapporteur e-mail: Trica Li (trica_li@huawei.com)
- 7550: SP#43 completed / Impacted TSs and TRs: 33.106; 33.107; 33.108 / WI rapporteur e-mail: berthold.wilhelm@bnetza.de, ron_ryan@verizon.net
- 7551: CP#43 completed / WI rapporteur e-mail: Rolf Blom
- 7552: SP#42 completed 33.223 as Rel-8. TS 33.224 moved to Rel-9 under new UID_420039 / Impacted TSs and TRs: 33.223 / WI rapporteur e-mail: Rolf Blom
- 7553: CP#43 completed / Impacted TSs and TRs: 24.109 / WI rapporteur e-mail: Rolf Blom
- 7554: CP#43 completed / Impacted TSs and TRs: 29.109 / WI rapporteur e-mail: Rolf Blom
- 7555: SP#42 completed. SP#39 WID approved. / Impacted TSs and TRs: 26.131; 26.132 / WI rapporteur e-mail: stephane.ragot@orange-ftgroup.com, wanqing.shi@sonyericsson.com
- 7556: SP#42 completed. SP#38 WID approved. / Impacted TSs and TRs: 26.234; 26.346; 26.946 / WI rapporteur e-mail: thorsten.lohmar@ericsson.com

| ID | WBS | Task | Duration | Start | Finish | Complete | Baseline start | Baseline finish | Baseline duration | Constraint | Resources | Work | Actual work | Acronym | PCG approved | WI rapporteur name | Release | TSG approved | MCC resp | Acronym_3GU_Export | TSG stopped | PCG stopped |
| --- | --- | --- | --- | --- | --- | --- | --- | --- | --- | --- | --- | --- | --- | --- | --- | --- | --- | --- | --- | --- | --- | --- |
| 7557 | 2459 | **Encoding formats, transport formats and media description signalling for interworking, QoE, and other enhancements to MTSI-MHI** | 479.5d? | 2007-12-06 A | 2009-03-12 A | 100% | 2007-12-06 | 2009-03-12 | 331d? |  | S4; C3; C4 | 14936h | 14936h | MTSI_eMHI | 21 | Ericsson, Qualcomm | Rel-8 | 40 | Paolo | MTSI_eMHI |  |  |
| 7558 | 2459.1 | MTSI Video - Dynamic Rate Adaptation/Signalling of Image Size | 331d? | 2007-12-06 A | 2009-03-12 A | 100% | 2007-12-06 | 2009-03-12 | 331d? | finish no earlier than 2009-03-12 | S4 | 2648h | 2648h | MTSI_eMHI-DRASIS |  | Qualcomm, Samsung | Rel-8 |  | Paolo | MTSI_eMHI-DRASIS |  |  |
| 7559 | 2459.2 | CT3 part of Enhancement of interworking between MTSI and CS networks | 201d? | 2008-05-30 A | 2009-03-06 A | 100% | 2008-05-30 | 2009-03-06 | 201d? | finish no earlier than 2009-03-06 | C3 | 1608h | 1608h | MTSI_eMHI | 21 | Huawei | Rel-8 | 40 | Adrian |  |  |  |
| 7560 | 2459.3 | CT4 part of Enhancement of interworking between MTSI and CS networks | 201d? | 2008-05-30 A | 2009-03-06 A | 100% | 2008-05-30 | 2009-03-06 | 201d? | finish no earlier than 2009-03-06 | C4 | 1608h | 1608h | MTSI_eMHI | 21 | Huawei | Rel-8 | 40 | Kimmo |  |  |  |
| 7561 | 2459.4 | Deleted - CT1 part of Enhancement of interworking between MTSI and CS networks | 141d? | 2008-05-30 A | 2008-12-12 A | 100% | 2008-05-30 | 2008-12-12 | 141d? | start no earlier than 2008-05-30 | C1 | 1128h | 1128h | MTSI_eMHI | 21 | Huawei | Rel-8 | 40 | Frederic |  | CP-42 |  |
| 7562 | 2460 | **Rel-8 Operations, Administration, Maintenance and Provisioning (OAM&P)** | 2081.75d? | 2007-06-07 A | 2012-12-07 A | 100% | 2007-06-07 | 2012-12-07 | 1445d? |  | S5; C1; C4; IETF | 125494h | 125494h | OAM8 |  |  | Rel-8 | 34 | Mirko | OAM8 |  |  |
| 7563 | 2460.1 | **Rel-8 Network Infrastructure Management** | 944.38d? | 2007-06-07 A | 2009-12-04 A | 100% | 2007-06-07 | 2009-12-04 | 653d? |  | S5 | 19464h | 19464h | OAM8-NIM |  |  | Rel-8 | 34 | Mirko | OAM8-NIM |  |  |
| 7564 | 2460.1.1 | Telecom Management Methodology | 461d? | 2007-06-07 A | 2009-03-12 A | 100% | 2007-06-07 | 2009-03-12 | 461d? | finish no earlier than 2009-03-12 | S5 | 3688h | 3688h | OAM8-NIM |  | Ericsson | Rel-8 |  | Mirko |  |  |  |
| 7565 | 2460.1.2 | Advanced Alarming on Itf-N | 266d? | 2007-06-07 A | 2008-06-12 A | 100% | 2007-06-07 | 2008-06-12 | 266d? | finish no earlier than 2008-12-11 | S5 | 2128h | 2128h | OAM8-NIM |  | Nokia Siemens Networks | Rel-8 |  | Mirko |  |  |  |
| 7566 | 2460.1.3 | CN CS Bearer Transport Network (BTN) relative NRM | 266d? | 2007-06-07 A | 2008-06-12 A | 100% | 2007-06-07 | 2008-06-12 | 266d? | finish no earlier than 2008-12-11 | S5 | 2128h | 2128h | OAM8-NIM |  | China Mobile | Rel-8 |  | Mirko |  |  |  |
| 7567 | 2460.1.4 | Alignment with eTOM and M.3060 architectural concepts | 210d? | 2008-02-22 A | 2008-12-11 A | 100% | 2008-02-22 | 2008-12-11 | 210d? | start no earlier than 2008-02-22 | S5 | 1680h | 1680h | OAM8-NIM | 21 | TeliaSonera | Rel-8 | 39 | Mirko |  |  |  |
| 7568 | 2460.1.5 | IRP SOAP Solution Sets | 201d? | 2008-06-05 A | 2009-03-12 A | 100% | 2008-06-05 | 2009-03-12 | 201d? | finish no earlier than 2009-03-12 | S5 | 1608h | 1608h | OAM8-NIM | 21 | Ericsson | Rel-8 | 40 | Mirko |  |  |  |
| 7569 | 2460.1.6 | Create missing specifications for IRP XML definitions | 52d? | 2009-09-24 A | 2009-12-04 A | 100% | 2009-09-24 | 2009-12-04 | 52d? | finish no earlier than 2010-03-12 | S5 | 416h | 416h | OAM8-NIM | 23 | ZTE | Rel-8 | 45 | Mirko |  |  |  |
| 7570 | 2460.1.7 | Deleted - End point modelling for reference point | 324d? | 2007-09-17 A | 2008-12-11 A | 100% | 2007-09-17 | 2008-12-11 | 324d? | finish no earlier than 2008-12-11 | S5 | 2592h | 2592h | OAM8-NIM |  | Motorola | Rel-8 | 37 | Mirko |  | SP-41 | PCG-21 |
| 7571 | 2460.2 | **Rel-8 Performance Management** | 668d? | 2007-06-07 A | 2009-03-12 A | 100% | 2007-06-07 | 2009-03-12 | 461d? |  | S5 | 13712h | 13712h | OAM8-PM |  |  | Rel-8 | 34 | Mirko | OAM8-PM |  |  |
| 7572 | 2460.2.1 | IP bearer network Performance measurement definitions | 396d? | 2007-06-07 A | 2008-12-11 A | 100% | 2007-06-07 | 2008-12-11 | 396d? | finish no earlier than 2008-12-11 | S5 | 3168h | 3168h | OAM8-PM |  | China Mobile | Rel-8 |  | Mirko |  |  |  |
| 7573 | 2460.2.2 | HSUPA performance measurements | 396d? | 2007-06-07 A | 2008-12-11 A | 100% | 2007-06-07 | 2008-12-11 | 396d? | finish no earlier than 2008-12-11 | S5 | 3168h | 3168h | OAM8-PM |  | China Mobile | Rel-8 |  | Mirko |  |  |  |
| 7574 | 2460.2.3 | Key Performance Indicators (KPIs) for UMTS and GSM | 461d? | 2007-06-07 A | 2009-03-12 A | 100% | 2007-06-07 | 2009-03-12 | 461d? | finish no earlier than 2009-03-12 | S5 | 3688h | 3688h | OAM8-PM |  | China Mobile | Rel-8 |  | Mirko |  |  |  |
| 7575 | 2460.3 | **Rel-8 Trace Management** | 1798d? | 2008-03-07 A | 2012-12-07 A | 100% | 2008-03-07 | 2012-12-07 | 1249d? |  | C1; C4; IETF | 40854.4h | 40854.4h | OAM8-Trace |  |  | Rel-8 | 34 | Mirko | OAM8-Trace |  |  |
| 7576 | 2460.3.1 | CT1 part of Service Level Tracing in IMS | 196d? | 2008-03-07 A | 2008-12-05 A | 100% | 2008-03-07 | 2008-12-05 | 196d? | finish no earlier than 2008-12-05 | C1 | 1568h | 1568h | OAM8-Trace |  | Vodafone | Rel-8 |  | Frederic |  |  |  |
| 7577 | 2460.3.2 | (IETF) Service Level Tracing in IMS (draft-ietf-insipid-logme-marking) --> RFC 8497 | 717d? | 2008-03-07 A | 2012-12-07 A | 100% | 2008-03-07 | 2012-12-07 | 717d? | finish no earlier than 2012-12-07 | C1-IETF | 5736h | 5736h | OAM8-Trace | 27 | Peter Dawes | Rel-8 | 52 | Frederic |  |  |  |
| 7578 | 2460.3.3 | Deleted - (IETF) Service Level Tracing in IMS (draft-dawes-sipping-debug-event) | 98d? | 2008-03-07 A | 2011-12-09 A | 100% | 2008-03-07 | 2011-12-09 | 98d? | finish no earlier than 2011-12-09 | C1-IETF | 768.04h | 768.04h | OAM8-Trace | 27 | Peter Dawes | Rel-8 | 53 | Frederic |  |  |  |
| 7579 | 2460.3.4 | CT4 part of Service Level Tracing in IMS | 175.4d? | 2008-03-07 A | 2008-12-05 A | 100% | 2008-03-07 | 2008-12-05 | 175.4d? | finish no earlier than 2008-12-05 | C4 | 1403.2h | 1403.2h | OAM8-Trace | 21 | Vodafone | Rel-8 | 40 | Frederic |  |  |  |
| 7580 | 2460.3.5 | Deleted - CT3 part of Service Level Tracing in IMS | 175.4d? | 2008-03-07 A | 2008-12-05 A | 100% | 2008-03-07 | 2008-12-05 | 175.4d? | finish no earlier than 2008-12-05 | C3 | 1403.2h | 1403.2h | OAM8-Trace | 21 | Vodafone | Rel-8 | 40 | Adrian |  | CP-42 | PCG-22 |
| 7581 | 2460.4 | (IETF) A Two-Way Active Measurement Protocol (TWAMP) (draft-ietf-ippm-twamp) --> RFC 5357 | 946.62d? | 2008-03-07 A | 2010-09-06 A | 100% | 2007-06-07 | 2009-12-04 | 653d? | finish no earlier than 2008-12-05 | S5-IETF | 5224h | 5224h | OAM8 |  |  | Rel-8 | 34 | Mirko | OAM8-NIM |  |  |

Notes:
- 7557: TSG#43 completed / WI rapporteur e-mail: olle.franceschi@ericsson.com, nleung@qualcomm.com
- 7558: SP#43 completed / Impacted TSs and TRs: 26.114 / WI rapporteur e-mail: nleung@qualcomm.com & kyunghun.jung@samsung.com
- 7559: CP#43 completed / Impacted TSs and TRs: 29.163 / WI rapporteur e-mail: Tingfang Tang (tagna_online@huawei.com)
- 7560: CP#43 completed / Impacted TSs and TRs: 29.332 / WI rapporteur e-mail: Tingfang Tang (tagna_online@huawei.com)
- 7561: CP#42 stopped (No CT1-impact). WID updated CP-080422=>CP-080774 / WI rapporteur e-mail: Tingfang Tang (tagna_online@huawei.com)
- 7562: OAM8 is an umbrella Feature also for OAM&P related TEI8 type of changes that are not part of any other dedicated feature/WI / Impacted TSs and TRs: 30.818
- 7563: -
- 7564: SP#43 completed / Impacted TSs and TRs: 32.155; 32.153 / WI rapporteur e-mail: thomas.tovinger@ericsson.com
- 7565: SP#40 completed / Impacted TSs and TRs: 32.121; 32.122; 32.123 / WI rapporteur e-mail: SUERBAUM, Clemens
- 7566: SP#40 completed / Impacted TSs and TRs: 32.632; 32.633; 32.635 / WI rapporteur e-mail: Li Jian (lijian@chinamobile.com)
- 7567: SP#42 completed / Impacted TSs and TRs: 32.101/2; 32-series / WI rapporteur e-mail: tommy.berggren@teliasonera.com
- 7568: SP#43 completed / Impacted TSs and TRs: 32.111-7; 32.617; 32.417; 32.367; 32.347; 32.111-1; 32.111-2; 32.111-3; 32.111-5; 32.307; 32.317; 32.341; 32.342; 32.343; 32.345; 32.361; 32.362; 32.363; 32.365; 32.411; 32.412; 32.413; 32.415; 32.611; 32.612; 32.613; 32.615; 32.625 / WI rapporteur e-mail: edwin.tse@ericsson.com
- 7569: SP#46 completed. Create missing XML definitions specs for IRPs (Advanced Alarm Management, Communication Surveillance, Self-Configuration of Network Elements, Software Management) needed for implementation of Rel-8 Notification Log IRP (TS 32.33x) / Impacted TSs and TRs: new (32.125; 32.355; 32.505; 32.535); 32.150; 32.153; 32.335 / WI rapporteur e-mail: Shuqiang Huang (huangsq@zte.com.cn)
- 7570: SP#41 Work stopped. Contributions related to E-UTRAN/EPC to be submitted to UID_380036 E-UTRAN NRM IRP/ UID_380037 EPC NRM IRP / Impacted TSs and TRs: 32.152; 32.62/3/4x; 32.73x / WI rapporteur e-mail: Yizhi Yao (yzyao@motorola.com)
- 7571: - / WI rapporteur e-mail: Li Jian (lijian@chinamobile.com)
- 7572: SP#42 completed / Impacted TSs and TRs: 32.321; 32.322; 32.323; 32.325 / WI rapporteur e-mail: lilianyuan@chinamobile.com
- 7573: SP#42 completed / Impacted TSs and TRs: 32.405 / WI rapporteur e-mail: Li Jian (lijian@chinamobile.com)
- 7574: SP#43 completed / Impacted TSs and TRs: 32.410 / WI rapporteur e-mail: Li Jian (lijian@chinamobile.com), Liang Shuangchun (liangshuangchun@cmdi.chinamobile.com)
- 7575: -
- 7576: CP#42 completed / Impacted TSs and TRs: 24.323; 24.229 / WI rapporteur e-mail: peter.dawes@vodafone.com
- 7577: CP#58 Removed from Rel-8, Rel-9 and Rel-10 (Not completed internet-draft); 26/6/19: 100%->100 / Impacted TSs and TRs: Rel-11 remains draft-dawes-dispatch-debug / WI rapporteur e-mail: peter.dawes@vodafone.com
- 7578: CP#54 Draft removed from 3GPP documentation, covered by draft-dawes-sipping-debug; 9/4/21: 100%->100 / Impacted TSs and TRs: draft-dawes-sipping-debug-event / WI rapporteur e-mail: peter.dawes@vodafone.com
- 7579: CP#42 completed / Impacted TSs and TRs: 29.228; 29.229 / WI rapporteur e-mail: peter.dawes@vodafone.com
- 7580: CP#42 stopped (No CT3-impact) / WI rapporteur e-mail: peter.dawes@vodafone.com
- 7581: -

| ID | WBS | Task | Type | Duration | Start | Finish | Complete | Baseline start | Baseline finish | Baseline duration | Constraint | Resources | Work | Actual work | Acronym | Release | MCC resp | Acronym_3GU_Export | WI rapporteur name | WI rapporteur e-mail | PCG approved | TSG approved | PCG stopped | TSG stopped | Status Report |
| --- | --- | --- | --- | --- | --- | --- | --- | --- | --- | --- | --- | --- | --- | --- | --- | --- | --- | --- | --- | --- | --- | --- | --- | --- | --- |
| 7582 | 2461 | **Rel-8 Charging Management small Enhancements** |  | 1037.75d? | 2006-03-16 A | 2008-12-11 A | 100% | 2006-03-16 | 2008-12-11 | 716d? |  | S5 | 12544h | 12544h | CH8 | Rel-8 | Mirko | CH8 |  |  |  |  |  |  |  |
| 7583 | 2461.1 | Online charging correlation |  | 457d? | 2006-03-16 A | 2007-12-14 A | 100% | 2006-03-16 | 2007-12-14 | 457d? | start no earlier than 2006-03-16 | S5 | 3656h | 3656h | CH8 | Rel-8 | Mirko |  | Orange | Chahine, Rony |  |  |  |  |  |
| 7584 | 2461.2 | SMS online charging |  | 137d? | 2007-06-07 A | 2007-12-14 A | 100% | 2007-06-07 | 2007-12-14 | 137d? | finish no earlier than 2007-12-14 | S5 | 1096h | 1096h | CH8 | Rel-8 | Mirko |  | Vodafone | Gavin.Wong@vodafone.com |  |  |  |  |  |
| 7585 | 2461.3 | Introduce Online Charging from SMS-SC into the SMS Charging Specifications |  | 61d? | 2008-09-18 A | 2008-12-11 A | 100% | 2008-09-18 | 2008-12-11 | 61d? | finish no earlier than 2008-12-11 | S5 | 488h | 488h | CH8 | Rel-8 | Mirko |  | Acision | erik.gebler@acision.com | 21 | 41 |  |  |  |
| 7586 | 2461.4 | Deleted - WLAN Offline Charging |  | 244d? | 2008-01-07 A | 2008-12-11 A | 100% | 2008-01-07 | 2008-12-11 | 244d? | finish no earlier than 2008-12-11 | S5 | 1952h | 1952h | CH8 | Rel-8 | Mirko |  | Alcatel-Lucent | maryse.gardella@alcatel-lucent.com | 21 | 38 | PCG-22 | SP-42 |  |
| 7587 | 2462 | **Conferencing enhancements for Mp interface** |  | 385.25d? | 2007-11-30 A | 2008-12-05 A | 100% | 2007-11-30 | 2008-12-05 | 266d? |  | C4 | 6384h | 6384h | eMp | Rel-8 | Kimmo | eMp | Huawei | Chencheng@huawei.com | 21 |  |  |  |  |
| 7588 | 2462.1 | Stage 2 for eMp |  | 266d? | 2007-11-30 A | 2008-12-05 A | 100% | 2007-11-30 | 2008-12-05 | 266d? | finish no earlier than 2008-12-11 | C4 | 2128h | 2128h | eMp | Rel-8 | Kimmo |  | Huawei | Chencheng@huawei.com | 21 | 38 |  |  |  |
| 7589 | 2462.2 | Stage 3 for eMp |  | 266d? | 2007-11-30 A | 2008-12-05 A | 100% | 2007-11-30 | 2008-12-05 | 266d? | finish no earlier than 2008-12-05 | C4 | 2128h | 2128h | eMp | Rel-8 | Kimmo |  | Huawei | Chencheng@huawei.com | 21 | 38 |  |  |  |
| 7590 | 2463 | **Contact Manager for 3GPP UICC applications** |  | 930d? | 2006-06-22 A | 2008-12-05 A | 100% | 2006-06-22 | 2008-12-05 | 642d? |  | C6 | 13352h | 13352h | eUPHBOOK | Rel-8 | Xavier | eUPHBOOK | Gemalto | Jacques.seif@gemalto.com |  |  |  |  |  |
| 7591 | 2463.1 | Requirements for Contact Manager |  | 392d? | 2006-06-22 A | 2007-12-21 A | 100% | 2006-06-22 | 2007-12-21 | 392d? | finish no earlier than 2007-12-21 | C6 | 3136h | 3136h | eUPHBOOK-St1 | Rel-8 | Xavier | eUPHBOOK-St1 | Gemalto | Jacques.seif@gemalto.com |  |  |  |  |  |
| 7592 | 2463.2 | External interface for eUPHBOOK |  | 220d? | 2007-05-07 A | 2008-03-07 A | 100% | 2007-05-07 | 2008-03-07 | 220d? | finish no earlier than 2008-03-07 | C6 | 1760h | 1760h | eUPHBOOK-Ext_Spec | Rel-8 | Xavier | eUPHBOOK-Ext_Spec | Gemalto | Jacques.seif@gemalto.com |  |  |  |  |  |
| 7593 | 2463.3 | Internal interface for eUPHBOOK |  | 415d? | 2007-05-07 A | 2008-12-05 A | 100% | 2007-05-07 | 2008-12-05 | 415d? | finish no earlier than 2008-12-05 | C6 | 3320h | 3320h | eUPHBOOK-Int_Spec | Rel-8 | Xavier | eUPHBOOK-Int_Spec | Gemalto | Jacques.seif@gemalto.com |  | 37 |  |  |  |
| 7594 | 2463.4 | Deleted - Implementation of eUPHBOOK | milestone | 0d? | 2007-06-21 A | 2007-06-21 A | 100% | 2007-06-21 | 2007-06-21 | 0d? | start no earlier than 2007-06-21 | C6 |  |  | eUPHBOOK-St23 | Rel-8 | Xavier | eUPHBOOK-St23 | Giesecke & Devrient | Claus Dietze |  |  |  | SP-33 |  |
| 7595 | 2464 | **Rel-8 LTE – 3G Long Term Evolution - Evolved Packet System RAN part** |  | 932d? | 2006-09-25 A | 2009-03-12 A | 100% | 2006-09-25 | 2009-03-12 | 644d? |  | RP; S5 | 50048h | 50048h | LTE | Rel-8 |  | LTE | NTT DoCoMo | Takehiro Nakamura (nakamurata@nttdocomo.co.jp) |  |  |  |  | RP-080741 |
| 7596 | 2464.1 | LTE – Physical Layer |  | 380d? | 2006-09-25 A | 2008-03-07 A | 100% | 2006-09-25 | 2008-03-07 | 380d? | finish no earlier than 2007-09-14 | R1 | 3040h | 3040h | LTE-Phys | Rel-8 | Patrick | LTE-Phys | NTT DoCoMo | Sadayuki Abeta |  |  |  |  | RP-080741 |
| 7597 | 2464.2 | LTE – Radio Interface Layer 2 and 3 Protocol Aspect |  | 575d? | 2006-09-25 A | 2008-12-05 A | 100% | 2006-09-25 | 2008-12-05 | 575d? | finish no earlier than 2008-12-11 | R2 | 4600h | 4600h | LTE-L23 | Rel-8 | Yong-Jun | LTE-L23 | Nokia Siemens Networks | benoist.sebire@nokia.com |  |  |  |  | RP-080741 |
| 7598 | 2464.3 | LTE – eUTRAN Interfaces |  | 575d? | 2006-09-25 A | 2008-12-05 A | 100% | 2006-09-25 | 2008-12-05 | 575d? | finish no earlier than 2008-12-11 | R3 | 4600h | 4600h | LTE-interfaces | Rel-8 | Juha | LTE-interfaces | Ericsson | Martin Israelsson |  |  |  |  | RP-080741 |
| 7599 | 2464.4 | LTE – Evolved UTRA and UTRAN RF Radio Transmission/Reception, System Performance Requirements and Conformance Testing |  | 575d? | 2006-09-25 A | 2008-12-05 A | 100% | 2006-09-25 | 2008-12-05 | 575d? | finish no earlier than 2008-12-11 | R4 | 4600h | 4600h | LTE-RF | Rel-8 | Issam | LTE-RF | Nokia Siemens Networks | Tuomo Saynajakangas |  |  |  |  | RP-080741 |
| 7600 | 2464.5 | LTE – FDD repeaters |  | 386d? | 2007-09-14 A | 2009-03-06 A | 100% | 2007-09-14 | 2009-03-06 | 386d? | finish no earlier than 2009-03-06 | R4 | 3088h | 3088h | LTE-Repeaters | Rel-8 | Issam | LTE-Repeaters | Powerwave Technologies, Andrew Wireless | ralf.michanikl@andrew.com, Alf.Ahlstrom@pwav.com |  | 37 |  |  | RP-090037 |
| 7601 | 2464.6 | **E-UTRAN Data Definitions** |  | 562.25d? | 2007-09-17 A | 2009-03-12 A | 100% | 2007-09-17 | 2009-03-12 | 389d? |  | S5 | 13096h | 13096h | E-UTRAN-OAM | Rel-8 | Mirko | E-UTRAN-OAM |  |  | 21 | 39 |  |  |  |
| 7602 | 2464.6.1 | Subscriber and Equipment Trace for E-UTRAN and EPC |  | 389d? | 2007-09-17 A | 2009-03-12 A | 100% | 2007-09-17 | 2009-03-12 | 389d? | finish no earlier than 2009-03-12 | S5 | 3112h | 3112h | E-UTRAN-OAM | Rel-8 | Mirko |  | Ericsson | robert.petersen@ericsson.com |  | 37 |  |  |  |
| 7603 | 2464.6.2 | E-UTRAN Network Resource Model (NRM) Integration Reference Point (IRP) |  | 309d? | 2008-01-07 A | 2009-03-12 A | 100% | 2008-01-07 | 2009-03-12 | 309d? | finish no earlier than 2009-03-12 | S5 | 2472h | 2472h | E-UTRAN-OAM | Rel-8 | Mirko |  | Ericsson | ELMDAHL, Per | 21 | 38 |  |  |  |
| 7604 | 2464.6.3 | Performance measurements for E-UTRAN |  | 275d? | 2008-02-22 A | 2009-03-12 A | 100% | 2008-02-22 | 2009-03-12 | 275d? | finish no earlier than 2009-03-12 | S5 | 2200h | 2200h | E-UTRAN-OAM | Rel-8 | Mirko |  | Motorola, Huawei | Yizhi Yao (yzyao@motorola.com) | 21 | 39 |  |  |  |
| 7605 | 2464.6.4 | Key Performance Indicators (KPIs) for E-UTRAN |  | 275d? | 2008-02-22 A | 2009-03-12 A | 100% | 2008-02-22 | 2009-03-12 | 275d? | finish no earlier than 2009-03-12 | S5 | 2200h | 2200h | E-UTRAN-OAM | Rel-8 | Mirko |  | Ericsson | ulf.hubinette@ericsson.com | 21 | 39 |  |  |  |

Notes:
- 7582: CH8 is an umbrella Feature also for OAM&P related TEI8 type of changes that are not part of any other dedicated feature/WI / Impacted TSs and TRs: 30.818
- 7583: SP#38 completed / Impacted TSs and TRs: 32.296
- 7584: SP#38 completed / Impacted TSs and TRs: 32.240; 32.299; new 32.274
- 7585: SP#42 completed. Linked to SA2 UID 32081 (Support of SMS over IP networks) and CT4 UID 340016 (Routeing of MT-SMS via the HPLMN). / Impacted TSs and TRs: 32.274; 32.299
- 7586: SP#42 stopped / Impacted TSs and TRs: 32.252; 32.298; 32.299
- 7587: CP#42 completed
- 7588: CP#42 completed / Impacted TSs and TRs: 23.333
- 7589: CP#42 completed / Impacted TSs and TRs: 29.333
- 7590: CP#42 completed. CP#40: WID updated CP-070622=>CP-080382. aka Enhanced USIM phonebook
- 7591: CP#38 completed / Impacted TSs and TRs: 21.111
- 7592: CP#39 completed / Impacted TSs and TRs: new 31.220
- 7593: CP#42 completed / Impacted TSs and TRs: new 31.221
- 7594: SP#33 stopped / Impacted TSs and TRs: 31.102
- 7595: RP#43 completed. Role model for SAE/LTE system wide project management by SA2 in SP-060166 / Impacted TSs and TRs: LTE 36.300; 36.938
- 7596: RP#39 completed / Impacted TSs and TRs: 36.201; 36.211; 36.212; 36.213; 36.214; 25.215; 25.225
- 7597: RP#42 completed / Impacted TSs and TRs: 36.302; 36.304; 36.306; 36.314; 36.321; 36.322; 36.323; 36.331; 25.302; 25.304; 25.331
- 7598: RP#42 completed / Impacted TSs and TRs: 36.401; 36.410; 36.411; 36.412; 36.413; 36.414; 36.420; 36.421; 36.422; 36.423; 36.424; 25.413
- 7599: RP#42 completed. RP#47 abandoned draft 36.801, 36.803, 36.804 / Impacted TSs and TRs: 36.101; 36.104; 36.113; 36.124; 36.133; 36.141; 36.942; 25.123; 25.133
- 7600: RP#43 completed. RP#47 create Rel-9 TR 36.956 (see R4-100386, RP-100320_RAN4 Report) / Impacted TSs and TRs: 36.106; 36.143; 25.113
- 7601: SP#43 completed
- 7602: SP#43 completed / Impacted TSs and TRs: 32.421; 2.422; 32.423; 2.441; 32.442; 32.443; 32.445
- 7603: SP#43 completed / Impacted TSs and TRs: new (32.761; 32.762; 32.763; 32.765)
- 7604: SP#43 completed / Impacted TSs and TRs: new 32.425
- 7605: SP#43 completed / Impacted TSs and TRs: new (32.450; 32.451)

| ID | WBS | Task | Duration | Start | Finish | Complete | Baseline start | Baseline finish | Baseline duration | Constraint | Resources | Work | Actual work | Acronym | PCG approved | WI rapporteur name | WI rapporteur e-mail | Release | TSG approved | MCC resp | Special Focus Doc | Acronym_3GU_Export | Status Report | PCG stopped | TSG stopped |
| --- | --- | --- | --- | --- | --- | --- | --- | --- | --- | --- | --- | --- | --- | --- | --- | --- | --- | --- | --- | --- | --- | --- | --- | --- | --- |
| 7606 | 2464.7 | **Self-Organizing Networks (SON)** | 304.5d? | 2008-02-22 A | 2008-12-11 A | 100% | 2008-02-22 | 2008-12-11 | 210d? |  | S5 | 6720h | 6720h | LTE_SON-OAM | 21 | Vodafone | GOMPAKIS, Panagiotis | Rel-8 | 39 | Mirko | SON | LTE_SON-OAM |  |  |  |
| 7607 | 2464.7.1 | SON Concepts and requirements | 304.5d? | 2008-02-22 A | 2008-12-11 A | 100% | 2008-02-22 | 2008-12-11 | 210d? |  | S5 | 1680h | 1680h | LTE_SON-OAM | 21 | Vodafone | GOMPAKIS, Panagiotis | Rel-8 | 39 | Mirko |  |  |  |  |  |
| 7608 | 2464.7.2 | Self-Establishment of eNBs, including automated Software Management | 210d? | 2008-02-22 A | 2008-12-11 A | 100% | 2008-02-22 | 2008-12-11 | 210d? | start no earlier than 2008-02-22 | S5 | 1680h | 1680h | LTE_SON-OAM | 21 | Nokia Siemens Networks | SUERBAUM, Clemens | Rel-8 | 39 | Mirko |  |  |  |  |  |
| 7609 | 2464.7.3 | SON Automatic Neighbour Relations (ANR) List Management | 210d? | 2008-02-22 A | 2008-12-11 A | 100% | 2008-02-22 | 2008-12-11 | 210d? | finish no earlier than 2008-12-11 | S5 | 1680h | 1680h | LTE_SON-OAM | 21 | Ericsson | edwin.tse@ericsson.com | Rel-8 | 39 | Mirko |  |  |  |  |  |
| 7610 | 2465 | **Rel-8 LTE – Terminal Conformance Test Specification** | 950.62d? | 2007-06-01 A | 2009-12-04 A | 100% | 2007-06-01 | 2009-12-04 | 657d? |  | R5 | 14336h | 14336h | LTE-UEConTest |  |  |  | Rel-8 |  | Ingbert |  | LTE-UEConTest |  |  |  |
| 7611 | 2465.1 | 3G LTE – Terminal Protocol Conformance Test Specifications | 657d? | 2007-06-01 A | 2009-12-04 A | 100% | 2007-06-01 | 2009-12-04 | 657d? | finish no earlier than 2009-12-04 | R5 | 5256h | 5256h | LTE-UEConTest_SIG |  | NEC, Motorola | david.lecompte@nectech.fr, Jacob.John@motorola.com | Rel-8 |  | Ingbert |  | LTE-UEConTest_SIG | RP-091060 |  |  |
| 7612 | 2465.2 | LTE – Terminal Radio Transmission and Reception Conformance Test Specifications | 657d? | 2007-06-01 A | 2009-12-04 A | 100% | 2007-06-01 | 2009-12-04 | 657d? |  | R5 | 5256h | 5256h | LTE-UEConTest_RF |  | Agilent | andrea_leonardi@agilent.com | Rel-8 |  | Ingbert |  | LTE-UEConTest_RF | RP-091059 |  |  |
| 7613 | 2466 | **Rel-8 Improvements of the Radio Interface** | 759d? | 2007-03-05 A | 2009-03-06 A | 100% | 2007-03-05 | 2009-03-06 | 525d? |  | RP | 18152h | 18152h | RInImp8 |  |  |  | Rel-8 |  | Issam |  | RInImp8 |  |  |  |
| 7614 | 2466.1 | UMTS 1500 MHz | 140d? | 2007-03-05 A | 2007-09-14 A | 100% | 2007-03-05 | 2007-09-14 | 140d? | finish no earlier than 2007-09-14 | R4 | 1120h | 1120h | RInImp8-UMTS1500 |  | NTT DoCoMo | Takehiro Nakamura (nakamurata@nttdocomo.co.jp) | Rel-8 |  | Issam |  | RInImp8-UMTS1500 | RP-070526 |  |  |
| 7615 | 2466.2 | UMTS 700 MHz FDD | 325d? | 2007-03-05 A | 2008-05-30 A | 100% | 2007-03-05 | 2008-05-30 | 325d? | finish no earlier than 2008-06-12 | R4 | 2600h | 2600h | RInImp8-UMTS700 |  | Nokia | Tuomo Saynajakangas | Rel-8 |  | Issam |  | RInImp8-UMTS700 | RP-080260 |  |  |
| 7616 | 2466.3 | UMTS 1880 MHz TDD | 126d? | 2008-09-12 A | 2009-03-06 A | 100% | 2008-09-12 | 2009-03-06 | 126d? | finish no earlier than 2009-03-09 | R4 | 1008h | 1008h | RInImp9-UMTS1880TDD | 21 | CATT | Yuexia Song (songyuexia@catt.cn) | Rel-8 | 41 | Issam |  | RInImp9-UMTS1880TDD | RP-090044 |  |  |
| 7617 | 2466.4 | UMTS 2300 MHz TDD LCR | 195d? | 2007-12-17 A | 2008-09-12 A | 100% | 2007-12-17 | 2008-09-12 | 195d? | finish no earlier than 2008-09-12 | R4 | 1560h | 1560h | RInImp8-UMTS2300TDD | 21 | CATT | Yuexia Song (songyuexia@catt.cn) | Rel-8 | 38 | Issam |  | RInImp8-UMTS2300TDD | RP-080517 |  |  |
| 7618 | 2466.5 | Further Improved Minimum Performance Requirements for HSDPA UE (FDD) - Two-Branch Interference Cancellation | 265d? | 2007-03-05 A | 2008-03-07 A | 100% | 2007-03-05 | 2008-03-07 | 265d? | finish no earlier than 2008-03-12 | R4 | 2120h | 2120h | RInImp8-2BIC |  | AT&T | Marc Grant | Rel-8 |  | Issam |  | RInImp8-2BIC | RP-080041 |  |  |
| 7619 | 2466.6 | CS Voice Service over HSPA | 241.25d? | 2007-07-19 A | 2008-03-07 A | 100% | 2007-07-19 | 2008-03-07 | 167d? |  | R2 | 1336h | 1336h | RInImp8-CsHspa |  | Nokia Siemens Networks | woonhee.hwang@nsn.com | Rel-8 | 37 | Yong-Jun |  | RInImp8-CsHspa | RP-080042 |  |  |
| 7620 | 2466.7 | Performance requirements for 15 code reception with 16QAM/QPSK (FDD) | 126d? | 2007-06-11 A | 2008-03-07 A | 100% | 2007-06-11 | 2008-03-07 | 126d? | finish no earlier than 2008-06-12 | R4 | 1008h | 1008h | RInImp8-Hsdpa15codes |  | Vodafone | tim.frost@vodafone.com | Rel-8 | 37 | Issam |  | RInImp8-Hsdpa15codes | RP-080043 |  |  |
| 7621 | 2466.8 | Deleted - UMTS 2300 MHz FDD/TDD | 400d? | 2007-03-05 A | 2008-09-12 A | 100% | 2007-03-05 | 2008-09-12 | 400d? | finish no earlier than 2008-12-11 | R4 | 3200h | 3200h | RInImp8-UMTS2300 |  | AT&T | Marc Grant | Rel-8 |  | Issam |  | RInImp8-UMTS2300 | RP-080515 | PCG-21 | RP-41 |
| 7622 | 2467 | **Rel-8 Improvements of the Radio Interface - UE Conformance Testing** | 573.75d? | 2007-06-01 A | 2008-12-05 A | 100% | 2007-06-01 | 2008-12-05 | 396d? |  | R5 | 6256h | 6256h |  |  |  |  | Rel-8 |  | Ingbert |  |  |  |  |  |
| 7623 | 2467.1 | Conformance Test Aspects – CS Voice Service over HSPA | 336d? | 2007-06-01 A | 2008-09-12 A | 100% | 2007-06-01 | 2008-09-12 | 336d? | finish no earlier than 2008-09-12 | R5 | 2688h | 2688h | RInImp8-CsHspa_UEConTest |  | Huawei | baoyi@huawei.com | Rel-8 |  | Ingbert |  | RInImp8-CsHspa_UEConTest | RP-080542 |  |  |
| 7624 | 2467.2 | Conformance Test Aspects – Performance requirements for 15 code reception with 16QAM/QPSK (FDD) | 195d? | 2008-03-07 A | 2008-12-05 A | 100% | 2008-03-07 | 2008-12-05 | 195d? | finish no earlier than 2008-12-05 | R5 | 1560h | 1560h | RInImp8-UEConTest_Hsdpa15codes | 21 | Ericsson | Mikael.Ziren@Ericsson.com | Rel-8 | 40 | Ingbert |  | RInImp8-UEConTest_ Hsdpa15codes | RP-080818 |  |  |
| 7625 | 2468 | **Rel-8 RAN improvements** | 751.75d? | 2007-06-04 A | 2009-05-29 A | 100% | 2007-06-04 | 2009-05-29 | 520d? |  | RP | 37481.6h | 37481.6h |  |  |  |  | Rel-8 |  |  |  |  |  |  |  |
| 7626 | 2468.1 | Combination of 64QAM and MIMO for HSDPA (FDD) | 205d? | 2007-06-04 A | 2008-09-12 A | 100% | 2007-06-04 | 2008-09-12 | 205d? | finish no earlier than 2008-09-12 | R1 | 1640h | 1640h | RANimp-64QamMimoHsdpa |  | Ericsson | Johan.Bergman@ericsson.com | Rel-8 |  | Patrick |  | RANimp-64QamMimoHsdpa | RP-080518 |  |  |
| 7627 | 2468.2 | Improved L2 for uplink | 186d? | 2007-09-14 A | 2008-05-30 A | 100% | 2007-09-14 | 2008-05-30 | 186d? | finish no earlier than 2008-05-30 | R2 | 1488h | 1488h | RANimp-UplinkL2dataRates |  | Ericsson | Janne.Peisa@ericsson.com | Rel-8 | 37 | Yong-Jun |  | RANimp-UplinkL2dataRates | RP-080265 |  |  |
| 7628 | 2468.3 | Enhanced Uplink for CELL_FACH State in FDD | 321d? | 2007-09-14 A | 2008-12-05 A | 100% | 2007-09-14 | 2008-12-05 | 321d? | finish no earlier than 2008-12-12 | R2 | 2568h | 2568h | RANimp-UplinkEnhState |  | Nokia Siemens Networks | markus.wimmer@nsn.com | Rel-8 | 37 | Yong-Jun |  | RANimp-UplinkEnhState | RP-080804 |  |  |
| 7629 | 2468.4 | Enhanced UE Discontinuous Reception (DRX) for FDD | 261d? | 2007-09-14 A | 2008-09-12 A | 100% | 2007-09-14 | 2008-09-12 | 261d? | finish no earlier than 2008-09-12 | R2 | 2088h | 2088h | RANimp-DRX |  | Nokia | luis.barreto@nokia.com | Rel-8 | 37 | Yong-Jun |  | RANimp-DRX | RP-080520 |  |  |
| 7630 | 2468.5 | Enhancements for Serving Radio Network Subsystem (SRNS) Relocation Procedure | 261d? | 2007-09-14 A | 2008-09-12 A | 100% | 2007-09-14 | 2008-09-12 | 261d? | finish no earlier than 2008-09-12 | R3 | 2088h | 2088h | RANimp-SrnsReloc |  | Nokia Siemens Networks | masatoshi.nakamata@nsn.com | Rel-8 | 37 | Juha |  | RANimp-SrnsReloc | RP-080521 |  |  |
| 7631 | 2468.6 | Enhancements for FDD HSPA Evolution | 321d? | 2007-09-14 A | 2008-12-05 A | 100% | 2007-09-14 | 2008-12-05 | 321d? | finish no earlier than 2008-12-05 | R3; R2 | 5136h | 5136h | RANimp-HSPAEvo |  | Nokia Siemens Networks | masatoshi.nakamata@nsn.com | Rel-8 | 37 | Juha |  | RANimp-HSPAEvo | RP-080805 |  |  |
| 7632 | 2468.7 | 64QAM for 1.28 Mcps TDD HSDPA | 264d? | 2007-12-04 A | 2008-12-05 A | 100% | 2007-12-04 | 2008-12-05 | 264d? | finish no earlier than 2008-12-05 | R1 | 2112h | 2112h | RANimp-64Qam1.28TDD | 21 | ZTE | zfmail@zte.com.cn | Rel-8 | 38 | Patrick |  | RANimp-64Qam1.28TDD | RP-080806 |  |  |
| 7633 | 2468.8 | Enhanced CELL_FACH state in 1.28 Mcps TDD | 264d? | 2007-12-04 A | 2008-12-05 A | 100% | 2007-12-04 | 2008-12-05 | 264d? | finish no earlier than 2008-12-12 | R2 | 2112h | 2112h | RANimp-EnhState1.28TDD | 21 | ZTE | zhang.yincheng@zte.com.cn | Rel-8 | 38 | Yong-Jun |  | RANimp-EnhState1.28TDD | RP-080807 |  |  |
| 7634 | 2468.9 | Continuous Connectivity for packet data users for 1.28 Mcps TDD | 321d? | 2008-03-07 A | 2009-05-29 A | 100% | 2008-03-07 | 2009-05-29 | 321d? | finish no earlier than 2009-05-29 | R1 | 2568h | 2568h | RANimp-LCRCPC | 21 | TD Tech | chenying@td-tech.com | Rel-8 | 39 | Patrick |  | RANimp-LCRCPC | RP-090394 |  |  |
| 7635 | 2468.10 | HSPA VoIP to WCDMA/GSM CS continuity | 261d? | 2008-03-07 A | 2009-03-06 A | 100% | 2008-03-07 | 2009-03-06 | 261d? | finish no earlier than 2009-03-06 | R2 | 2088h | 2088h | RANimp-HSPAVoIP | 21 | Nokia | Simone.Provvedi@nokia.com | Rel-8 | 39 | Yong-Jun |  | RANimp-HSPAVoIP | RP-090050 |  |  |
| 7636 | 2468.11 | HS-DSCH Serving Cell Change Enhancements | 196d? | 2008-03-07 A | 2008-12-05 A | 100% | 2008-03-07 | 2008-12-05 | 196d? | finish no earlier than 2008-12-12 | R2 | 1568h | 1568h | RANimp-HSDSCH | 21 | Ericsson | henrik.enbuske@ericsson.com | Rel-8 | 39 | Yong-Jun |  | RANimp-HSDSCH | RP-080811 |  |  |
| 7637 | 2468.12 | MIMO for 1.28 Mcps TDD. Linked to Rel-8 Study on Scope of future HSPA Evolution for 1.28 Mcps TDD (UID_370041) TR 25.824 | 351.6d? | 2008-01-24 A | 2009-05-29 A | 100% | 2008-01-24 | 2009-05-29 | 351.6d? | finish no earlier than 2009-05-29 | R1; R4 | 5625.6h | 5625.6h | RANimp-MIMOLCR | 21 | CATT | wangke@datangmobile.cn | Rel-8 | 40 | Patrick |  | RANimp-MIMOLCR | RP-090313 |  |  |
| 7638 | 2468.13 | Dual-Cell HSDPA operation on adjacent carriers | 140d? | 2008-11-17 A | 2009-05-29 A | 100% | 2008-11-17 | 2009-05-29 | 140d? | finish no earlier than 2009-05-29 | R1; R4 | 2240h | 2240h | RANimp-DCHSDPA | 21 | Ericsson | johan.bergman@ericsson.com | Rel-8 | 40 | Patrick |  | RANimp-DCHSDPA | RP-080814 |  |  |

Notes:
- 7606: SP#42 completed (WT UID_390007 moved to Rel-9)
- 7607: SP#42 completed / Impacted TSs and TRs: new 32.500
- 7608: SP#42 completed / Impacted TSs and TRs: new (32.501; 32.502; 32.503; 32.531; 32.532; 32.533)
- 7609: SP#42 completed / Impacted TSs and TRs: 32.761; 32.762; 32.763; 32.765; new 32.511
- 7610: Testing for Feature UID_20068 (LTE)
- 7611: RP#46 completed / Impacted TSs and TRs: 36.521-1; 36.521-2; 36.508; 36.509; 36.523-1; 36.523-2; 36.523-3
- 7612: RP#46 completed. RP#50 TR 36.903 v100 for Approval / Impacted TSs and TRs: 36.521-1; 36.521-2; 36.521-3; new 36.903
- 7613: -
- 7614: RP#37 completed / Impacted TSs and TRs: 25.101; 25.104; 25.133; 25.141; 25.331; 25.942; 25.306; 25.307; 34.121
- 7615: RP#40 completed / Impacted TSs and TRs: 25.101; 25.104; 25.133; 25.141; 25.331; 25.942; 25.306; 25.307; 34.121
- 7616: RP#43 completed / Impacted TSs and TRs: 25.102; 25.105; 25.113; 25.123; 25.142; 34.124; 25.307
- 7617: RP#41 completed. RP#47 abandoned draft 25.828 / Impacted TSs and TRs: 25.102; 25.105; 25.113; 25.123; 25.142; 34.124; 25.306; 25.331; 34.122
- 7618: RP#39 completed / Impacted TSs and TRs: 25.101
- 7619: RP#39 completed / Impacted TSs and TRs: 25.323; 25.331; 25.322
- 7620: RP#39 completed / Impacted TSs and TRs: 25.101
- 7621: RP#41 stopped / Impacted TSs and TRs: 25.101; 25.104; 25.133; 25.141; 25.331; 25.942; 25.306; 25.307; 34.121
- 7622: 05/08: Linked to Feature UID_20028 (RInImp)
- 7623: RP#41 completed / Impacted TSs and TRs: 34.108; 34.123-1; 34.123-2; 34.123-3
- 7624: RP#42 completed / Impacted TSs and TRs: 34.121-1; 34.121-2
- 7625: -
- 7626: RP#41 completed / Impacted TSs and TRs: 25.308; 25.211; 25.212; 25.213; 25.306; 25.331; 25.433; 25.435; 25.423; 25.425; 25.101; 25.104; 25.141
- 7627: RP#40 completed. Linked to UID_370037 Enhanced Uplink for CELL_FACH State in FDD / Impacted TSs and TRs: 25.319; 25.301; 25.306; 25.321; 25.331; 25.433; 25.435; 25.423; 25.425; 25.427
- 7628: RP#42 completed. Linked to UID_370036 Improved L2 for uplink / Impacted TSs and TRs: 25.309; 25.211; 25.214; 25.321; 25.331; 25.423; 25.433
- 7629: RP#41 completed. Continuation of Rel-7 work item "Continuous connectivity for packet data users" UID_20046. / Impacted TSs and TRs: 25.306; 25.308; 25.321; 25.331; 25.423
- 7630: RP#41 completed. Linked to UID_370040 Enhancements for FDD HSPA Evolution / Impacted TSs and TRs: 25.306; 25.308; 25.321; 25.331; 25.423; 25.433; 25.214; 25.133
- 7631: RP#42 completed. Triggered by Rel-7 Study on Scope of future FDD HSPA Evolution (UID_20065) TR 25.999 / Impacted TSs and TRs: 25.401; 25.413; 25.420; 25.423; 25.427; 25.433; 25.446; 25.301; 25.346
- 7632: RP#42 completed. Linked to Rel-8 Study on Scope of future HSPA Evolution for 1.28 Mcps TDD (UID_370041) TR 25.824 / Impacted TSs and TRs: 25.102; 25.105; 25.123; 25.142; 25.201; 25.221; 25.222; 25.223; 25.224; 25.306; 25.308; 25.321; 25.331; 25.423; 25.433
- 7633: RP#42 completed. Linked to Rel-8 Study on Scope of future HSPA Evolution for 1.28 Mcps TDD (UID_370041) TR 25.824 / Impacted TSs and TRs: 25.123; 25.221; 25.222; 25.224; 25.301; 25.302; 25.304; 25.306; 25.308; 25.319; 25.321; 25.331; 25.401; 25.423; 25.425; 25.433; 25.435
- 7634: RP#44 completed. Linked to Rel-8 Study on Scope of future HSPA Evolution for 1.28 Mcps TDD (UID_370041) TR 25.824 / Impacted TSs and TRs: 25.929; 25.308; 25.319
- 7635: RP#43 completed / Impacted TSs and TRs: 25.331; 25.413
- 7636: RP#42 completed / Impacted TSs and TRs: 25.101; 25.104; 25.133; 25.212; 25.214; 25.308; 25.321; 25.331; 25.423; 25.433
- 7637: RP#43 completed / Impacted TSs and TRs: 25.201; 25.221; 25.222; 25.223; 25.224; 25.306; 25.308; 25.321; 25.331; 25.423; 25.433; 25.102; 25.105; 25.142
- 7638: RP#42 completed. Triggered by UID_390032 Study on Dual-Cell HSDPA (withdrawn TR 25.825 v100). / Impacted TSs and TRs: 25.101; 25.104; 25.133; 25.141; 25.211; 25.212; 25.213; 25.214; 25.215; 25.306; 25.308; 25.321; 25.331; 25.423; 25.433

| ID | WBS | Task | Duration | Start | Finish | Complete | Baseline start | Baseline finish | Baseline duration | Constraint | Resources | Work | Actual work | Release | MCC resp | Acronym | PCG approved | WI rapporteur name | TSG approved | Status Report | Acronym_3GU_Export |
| --- | --- | --- | --- | --- | --- | --- | --- | --- | --- | --- | --- | --- | --- | --- | --- | --- | --- | --- | --- | --- | --- |
| 7639 | 2469 | **Rel-8 RAN improvements - UE Conformance Testing** | 870.88d? | 2008-05-30 A | 2010-09-17 A | 100% | 2008-05-30 | 2010-09-17 | 602d? |  | R5 | 29391.2h | 29391.2h | Rel-8 | Ingbert |  |  |  |  |  |  |
| 7640 | 2469.1 | Conformance Test Aspects – Combination of 64QAM and MIMO for HSDPA (FDD) | 322d? | 2008-09-12 A | 2009-12-04 A | 100% | 2008-09-12 | 2009-12-04 | 322d? | finish no earlier than 2009-12-04 | R5 | 2576h | 2576h | Rel-8 | Ingbert | RANimp-UEConTest_64QamMimoHsdpa | 21 | Ericsson | 41 | RP-091058 | RANimp-UEConTest_64QamMimoHsdpa |
| 7641 | 2469.2 | Conformance Test Aspects – Improved L2 for uplink | 341d? | 2008-05-30 A | 2009-09-18 A | 100% | 2008-05-30 | 2009-09-18 | 341d? | finish no earlier than 2009-09-18 | R5 | 2728h | 2728h | Rel-8 | Ingbert | RANimp-UEConTest_UplinkL2dataRates | 21 | Ericsson | 40 | RP-090712 | RANimp-UEConTest_UplinkL2dataRates |
| 7642 | 2469.3 | Conformance Test Aspects – 1.28 Mcps TDD Improved L2 support for high data rates | 342d? | 2009-05-29 A | 2010-09-17 A | 100% | 2009-05-29 | 2010-09-17 | 342d? | finish no earlier than 2010-09-17 | R5 | 2736h | 2736h | Rel-8 | Ingbert | RANimp-UEConTest_ImprovedL2LCRTDD | 23 | CATT | 44 | RP-100737 | RANimp-UEConTest_ImprovedL2LCRTDD |
| 7643 | 2469.4 | Conformance Test Aspects – 64QAM for 1.28 Mcps TDD HSDPA | 261d? | 2008-05-30 A | 2009-05-29 A | 100% | 2008-05-30 | 2009-05-29 | 261d? | finish no earlier than 2009-05-29 | R5 | 2088h | 2088h | Rel-8 | Ingbert | RANimp-UEConTest_64Qam1.28TDD | 21 | ZTE | 40 | RP-090415 | RANimp-UEConTest_64Qam1.28TDD |
| 7644 | 2469.5 | Conformance Test Aspects – Dual-Cell HSDPA operation on adjacent carriers | 391d? | 2008-12-05 A | 2010-06-04 A | 100% | 2008-12-05 | 2010-06-04 | 391d? | finish no earlier than 2010-06-04 | R5 | 3128h | 3128h | Rel-8 | Ingbert | RANimp-UEConTest_DCHSDPA | 22 | Qualcomm | 42 | RP-100479 | RANimp-UEConTest_DCHSDPA |
| 7645 | 2469.6 | Conformance Test Aspects – Enhanced Uplink for CELL_FACH State in FDD | 326d? | 2009-03-06 A | 2010-06-04 A | 100% | 2009-03-06 | 2010-06-04 | 326d? | finish no earlier than 2010-06-04 | R5 | 2608h | 2608h | Rel-8 | Ingbert | RANimp-UEConTest_EnhancedRACHCellFACHState | 22 | Nokia | 43 | RP-100483 | RANimp-UEConTest_EnhancedRACHCellFACHState |
| 7646 | 2469.7 | Conformance Test Aspects – Receiver Type3i | 196d? | 2009-03-06 A | 2009-12-04 A | 100% | 2009-03-06 | 2009-12-04 | 196d? | finish no earlier than 2009-12-04 | R5 | 1568h | 1568h | Rel-8 | Ingbert | RANimp-UEConTest_ReceiverType3i | 22 | Qualcomm | 43 | RP-091066 | RANimp-UEConTest_ReceiverType3i |
| 7647 | 2469.8 | Conformance Test Aspects – Enhanced CELL_FACH State in LCR TDD | 341d? | 2009-05-30 A | 2010-09-17 A | 100% | 2009-05-30 | 2010-09-17 | 341d? | finish no earlier than 2010-09-17 | R5 | 2728h | 2728h | Rel-8 | Ingbert | RANimp-UEConTest_EnhancedCellFACHStateLCRTDD | 23 | CATT | 44 | RP-100735 | RANimp-UEConTest_EnhancedCellFACHStateLCRTDD |
| 7648 | 2469.9 | Conformance Test Aspects – Continuous Connectivity for packet data users for 1.28 Mcps TDD | 261d? | 2009-09-18 A | 2010-09-17 A | 100% | 2009-09-18 | 2010-09-17 | 261d? | finish no earlier than 2010-09-17 | R5 | 2088h | 2088h | Rel-8 | Ingbert | RANimp-UEConTest_CPCLCRTDD | 23 | ZTE | 45 | RP-100739 | RANimp-UEConTest_CPCLCRTDD |
| 7649 | 2469.10 | Conformance Test Aspects – MIMO for 1.28 Mcps TDD | 186d? | 2009-09-18 A | 2010-06-04 A | 100% | 2009-09-18 | 2010-06-04 | 186d? | finish no earlier than 2010-06-04 | R5 | 1488h | 1488h | Rel-8 | Ingbert | RANimp-UEConTest_MIMOLCRTDD | 23 | ZTE | 45 | RP-100660 | RANimp-UEConTest_MIMOLCRTDD |
| 7650 | 2469.11 | Conformance Test Aspects – HS-DSCH Serving Cell Change Enhancements | 131d? | 2009-09-18 A | 2010-03-19 A | 100% | 2009-09-18 | 2010-03-19 | 131d? | finish no earlier than 2010-03-12 | R5 | 1048h | 1048h | Rel-8 | Ingbert | HSDSCH_UEConTest | 23 | Qualcomm | 45 | RP-100077 | HSDSCH_UEConTest |
| 7651 | 2470 | 3.84 Mcps TDD MBMS over a Single Frequency Network (MBSFN) Integrated Mobile Broadcast | 570.5d? | 2007-06-04 A | 2008-12-05 A | 100% | 2007-06-04 | 2008-12-05 | 395d? |  | R1 | 3160h | 3160h | Rel-8 | Patrick | MBSFN-DOB |  | Ericsson |  | RP-080218 | MBSFN-DOB |
| 7652 | 2471 | Conformance Test Aspects – 3.84 Mcps TDD MBMS over a Single Frequency Network (MBSFN) Integrated Mobile Broadcast | 211d? | 2009-05-30 A | 2010-03-19 A | 100% | 2009-05-30 | 2010-03-19 | 211d? | finish no earlier than 2010-03-19 | R5 | 1688h | 1688h | Rel-8 | Ingbert | MBSFN_IMB_UEConTest | 23 | IPwireless | 44 | RP-100070 | MBSFN_IMB_UEConTest |
| 7653 | 2472 | **GERAN support for GERAN - 3G Long Term Evolution interworking** | 1972.5d? | 2006-09-08 A | 2011-11-25 A | 100% | 2006-09-08 | 2011-11-25 | 1365d? |  | GP; G1; C1; G3new | 69960h | 69960h | Rel-8 | Paolo | GELTE |  | Nokia, Nokia Siemens Networks |  |  | GELTE |
| 7654 | 2472.1 | G1 part of GERAN support for GERAN - 3G Long Term Evolution interworking | 641d? | 2006-09-08 A | 2009-02-20 A | 100% | 2006-09-08 | 2009-02-20 | 641d? | finish no earlier than 2009-02-20 | G1 | 5128h | 5128h | Rel-8 | Paolo | GELTE |  | Nokia, Nokia Siemens Networks |  |  |  |
| 7655 | 2472.2 | G2 part of GERAN support for GERAN - 3G Long Term Evolution interworking | 641d? | 2006-09-08 A | 2009-02-20 A | 100% | 2006-09-08 | 2009-02-20 | 641d? | finish no earlier than 2009-02-20 | G2 | 5128h | 5128h | Rel-8 | Paolo | GELTE |  | Nokia, Nokia Siemens Networks |  |  |  |
| 7656 | 2472.3 | CT1 part of GERAN support for GERAN - 3G Long Term Evolution interworking | 641d? | 2006-09-08 A | 2009-02-20 A | 100% | 2006-09-08 | 2009-02-20 | 641d? | finish no earlier than 2009-02-20 | C1 | 5128h | 5128h | Rel-8 | Paolo | GELTE |  | Nokia, Nokia Siemens Networks |  |  |  |
| 7657 | 2472.4 | Testing for GERAN support for GERAN - 3G Long Term Evolution interworking | 1363d? | 2006-09-08 A | 2011-11-25 A | 100% | 2006-09-08 | 2011-11-25 | 1363d? | finish no earlier than 2011-11-25 | G3new | 10896h | 10896h | Rel-8 | Ingbert | GELTE |  | Renesas Mobile |  |  |  |
| 7658 | 2473 | U-TDOA Enhancement | 131d? | 2007-05-18 A | 2007-11-16 A | 100% | 2007-05-18 | 2007-11-16 | 131d? | finish no earlier than 2007-05-18 | GP | 1048h | 1048h | Rel-8 | Paolo | GUTEN |  | TruePosition |  |  | GUTEN |
| 7659 | 2474 | **GAN Enhancements** | 873.08d? | 2007-05-15 A | 2009-09-04 A | 100% | 2007-05-15 | 2009-09-04 | 604.2d? |  | GP | 9432h | 9432h | Rel-8 | Paolo | GANENH |  | T-Mobile |  |  | GANENH |
| 7660 | 2474.1 | Update to GAN specifications | 126d? | 2007-08-31 A | 2008-02-22 A | 100% | 2007-08-31 | 2008-02-22 | 126d? | finish no earlier than 2008-02-22 | GP | 1008h | 1008h | Rel-8 | Paolo | GANENH-SPEC |  | T-Mobile |  |  | GANENH-SPEC |
| 7661 | 2474.2 | Update TS 51.010 Mobile Station (MS) Conformance Specification for GAN Enhancements | 526d? | 2007-05-15 A | 2009-09-04 A | 100% | 2007-05-15 | 2009-09-04 | 526d? | finish no earlier than 2009-09-04 | G3new | 4208h | 4208h | Rel-8 | Ingbert | GANENH-MStest |  | T-Mobile |  |  | GANENH-MStest |
| 7662 | 2475 | **AoIP (A-interface over IP)** | 3382.38d? | 2000-01-03 A | 2008-12-11 A | 100% | 2000-01-03 | 2008-12-11 | 2335d? |  | GP; S4; C4; C1; C3 | 119396h | 119396h | Rel-8 | Paolo | AoIP | 21 | China Mobile, Ericsson |  |  | AoIP |
| 7663 | 2475.1 | GERAN aspects of AoIP | 2321d? | 2000-01-03 A | 2008-11-21 A | 100% | 2000-01-03 | 2008-11-21 | 2321d? | finish no earlier than 2008-11-21 | GP | 18560h | 18560h | Rel-8 | Paolo | AoIP | 21 | China Mobile, Ericsson | 40 |  |  |
| 7664 | 2475.2 | Media Requirements for CS over IP based User Plane | 386.25d? | 2007-12-05 A | 2008-12-11 A | 100% | 2007-12-05 | 2008-12-11 | 267d? | finish no earlier than 2008-12-11 | S4 | 1996.09h | 1996.09h | Rel-8 | Paolo | AoIP-CSoIP | 21 | China Mobile, Ericsson | 40 |  | AoIP-CSoIP |

Notes:
- 7639: Linked to Feature UID_20029 (RANimp)
- 7640: RP#46 completed. Testing for UID_360013 / Impacted TSs and TRs: 34.108; 34.121-1; 34.121-2; 34.123-1; 34.123-2 / WI rapporteur e-mail: leif.mattisson@ericsson.com
- 7641: RP#45 completed. Testing for UID_370036 / Impacted TSs and TRs: 34.108; 34.123-1; 34.123-2; 34.123-3 / WI rapporteur e-mail: leif.mattisson@ericsson.com
- 7642: RP#49 completed. Testing for Rel-7 UID_340039 Improved L2 support for high data rates and Rel-8 UID_370036 Improved L2 for uplink / Impacted TSs and TRs: 34.108; 34.123-1; 34.123-2; 34.123-3 / WI rapporteur e-mail: Xiaozhong Chen (chenxiaozhong@datangmobile.cn)
- 7643: RP#44 completed. Testing for UID_380075 / Impacted TSs and TRs: 34.108; 34.122; 34.123-1; 34.123-2; 34.123-3 / WI rapporteur e-mail: ma.zijiang@zte.com.cn
- 7644: RP#48 completed. Testing for UID_400052 / Impacted TSs and TRs: 34.108; 34.121-1; 34.121-2; 34.123-1; 34.123-2; 34.123-3 / WI rapporteur e-mail: Shubhang Vora (svora@qualcomm.com)
- 7645: RP#48 completed. Testing for UID_370037 / Impacted TSs and TRs: 34.108; 34.121-1; 34.121-2; 34.123-1; 34.123-2; 34.123-3 / WI rapporteur e-mail: jarkko.hellsten@nokia.com
- 7646: RP#46 completed. Testing for Receiver Type3i in 25.101 UE radio Tx and Rx FDD / Impacted TSs and TRs: 34.108; 34.121-1; 34.121-2 / WI rapporteur e-mail: Ashok Kumar Narayanaswamy (anarayan@qualcomm.com)
- 7647: RP#49 completed. Testing for UID_380076 / Impacted TSs and TRs: 34.108; 34.123-1; 34.123-2; 34.123-3 / WI rapporteur e-mail: Xiaozhong Chen (chenxiaozhong@datangmobile.cn)
- 7648: RP#49 completed. Testing for UID_390028 / Impacted TSs and TRs: 34.108; 34.123-1; 34.123-2; 34.123-3 / WI rapporteur e-mail: huang.he4@zte.com.cn
- 7649: PR#48 completed. Testing for UID_400050 / Impacted TSs and TRs: 34.108; 34.122; 34.123-1; 34.123-2; 34.123-3 / WI rapporteur e-mail: huang.chun2@zte.com.cn
- 7650: RP#47 completed. Testing for UID_390030 / Impacted TSs and TRs: 34.108; 34.121-1; 34.121-2; 34.123-1; 34.123-2; 34.123-3 / WI rapporteur e-mail: Shubhang Vora (svora@qualcomm.com)
- 7651: RP#42 completed. WID updated RP-070493=>RP-081124 (changed WI title "MBSFN Downlink Optimized Broadcast (DOB) 3.84 Mcps TDD" => "3.84Mcps TDD MBSFN Integrated Mobile Broadcast"). / Impacted TSs and TRs: 25.102; 25.105; 25.123; 25.201; 25.221; 25.222; 25.223; 25.224; 25.304; 25.306; 25.331; 25.346; 25.402; 25.433 / WI rapporteur e-mail: Lars.Lindbom@ericsson.com
- 7652: RP#47 completed. Testing for Rel-8 MBSFN-DOB UID_360008 / Impacted TSs and TRs: 34.108; 34.122; 34.123-1; 34.123-2; 34.123-3 / WI rapporteur e-mail: Phil Young (pyoung@ipwireless.com)
- 7653: GP#41 completed. GP#52 completed MS conformance testing / Impacted TSs and TRs: 44.018; 44.060; 45.002; 45.008; 45.010; 48.008; 48.018; 51.010 / WI rapporteur e-mail: sergio.parolari@nsn.com, vlora.rexhepi@nokia.com
- 7654: GP#41 completed / Impacted TSs and TRs: 43.055; 43.129; 43.246; 45.002; 45.008; 45.010 / WI rapporteur e-mail: sergio.parolari@nsn.com, vlora.rexhepi@nokia.com
- 7655: GP#41 completed / Impacted TSs and TRs: 44.018; 44.060; 48.008; 48.018 / WI rapporteur e-mail: sergio.parolari@nsn.com, vlora.rexhepi@nokia.com
- 7656: - / Impacted TSs and TRs: 24.008 / WI rapporteur e-mail: sergio.parolari@nsn.com, vlora.rexhepi@nokia.com
- 7657: GP#52 completed / Impacted TSs and TRs: 51.010 / WI rapporteur e-mail: deepa.kamath@renesasmobile.com
- 7658: GP#36 completed U-TDOA (Uplink Time Difference of Arrival) / Impacted TSs and TRs: 43.059; 45.008; 48.071 / WI rapporteur e-mail: Terry Brooks (terri.brooks@trueposition.com)
- 7659: GP#37 completed. GP#43 completed Testing / WI rapporteur e-mail: mohammed.versi@t-mobile.com
- 7660: GP#37 completed / Impacted TSs and TRs: 43.318; 44.318 / WI rapporteur e-mail: mohammed.versi@t-mobile.com
- 7661: GP#43 completed / Impacted TSs and TRs: 51.010 / WI rapporteur e-mail: mohammed.versi@t-mobile.com
- 7662: GP#40/TSG#42 completed . Triggered by TR 43.903 Study on A-interface over IP (AINTIP) UID_50589. / WI rapporteur e-mail: wangshuaiyu@chinamobile.com, paul.schliwa-bertling@ericsson.com
- 7663: GP#40 completed. GP#39 updated WID GP-080901=>GP-081362. / Impacted TSs and TRs: 48.001; 48.002; 48.008; 48.020; 49.008; 48.103 / WI rapporteur e-mail: wangshuaiyu@chinamobile.com, paul.schliwa-bertling@ericsson.com
- 7664: SP#42 completed / Impacted TSs and TRs: 26.102; 26.103; 26.202 / WI rapporteur e-mail: Karl.Hellwig@Ericsson.com

| ID | WBS | Task | Type | Duration | Start | Finish | Complete | Baseline start | Baseline finish | Baseline duration | Constraint | Resources | Work | Actual work | Acronym | PCG approved | WI rapporteur name | Release | TSG approved | MCC resp | Acronym_3GU_Export | Impacted TSs and TRs | Status Report | TSG stopped | Special Focus Doc | PCG stopped |
| --- | --- | --- | --- | --- | --- | --- | --- | --- | --- | --- | --- | --- | --- | --- | --- | --- | --- | --- | --- | --- | --- | --- | --- | --- | --- | --- |
| 7665 | 2475.3 | **Core Network Impacts for A-Interface User Plane over IP** |  | 196.75d? | 2008-05-30 A | 2008-12-05 A | 100% | 2008-05-30 | 2008-12-05 | 136d? |  | C4; C1; C3 | 5440h | 5440h | AoIP-CN | 21 | Ericsson | Rel-8 | 40 | Kimmo | AoIP-CN |  |  |  |  |  |
| 7666 | 2475.3.1 | CT4 part of Core Network Impacts for A-Interface User Plane over IP |  | 136d? | 2008-05-30 A | 2008-12-05 A | 100% | 2008-05-30 | 2008-12-05 | 136d? | start no earlier than 2008-05-30 | C4 | 1088h | 1088h | AoIP-CN | 21 | Ericsson | Rel-8 | 40 | Kimmo |  | 23.205; 23.153; 23.231; 29.232 |  |  |  |  |
| 7667 | 2475.3.2 | CT1 part of Core Network Impacts for A-Interface User Plane over IP |  | 68d? | 2008-05-30 A | 2008-12-05 A | 100% | 2008-05-30 | 2008-12-05 | 68d? | finish no earlier than 2008-12-05 | C1 | 544h | 544h | AoIP-CN | 21 | Ericsson | Rel-8 | 40 | Frederic |  | 23.009 |  |  |  |  |
| 7668 | 2475.3.3 | CT3 part of Core Network Impacts for A-Interface User Plane over IP |  | 68d? | 2008-05-30 A | 2008-12-05 A | 100% | 2008-05-30 | 2008-12-05 | 68d? | finish no earlier than 2008-12-05 | C3 | 544h | 544h | AoIP-CN | 21 | Ericsson | Rel-8 | 40 | Adrian |  | 29.007 |  |  |  |  |
| 7669 | 2476 | New multicarrier BTS class |  | 261d? | 2007-08-31 A | 2008-08-29 A | 100% | 2007-08-31 | 2008-08-29 | 261d? | finish no earlier than 2008-08-29 | G1 | 2088h | 2088h | MCBTS |  | Alcatel-Lucent | Rel-8 |  | Paolo | MCBTS | 45.005; 45.050; 51.021 |  |  |  |  |
| 7670 | 2477 | **Support for Additional Navigation Satellite Systems (ANSS) for LCS** |  | 217.5d? | 2008-05-16 A | 2008-12-11 A | 100% | 2008-05-16 | 2008-12-11 | 150d? |  | S1; G2; R2 | 5784h | 5784h | ANSS |  | Qualcomm | Rel-8 |  | Paolo | ANSS |  |  |  |  |  |
| 7671 | 2477.1 | Stage 1 for ANSS for LCS |  | 1d? | 2008-12-11 A | 2008-12-11 A | 100% | 2008-12-11 | 2008-12-11 | 1d? | start no earlier than 2008-12-11 | S1 | 8h | 8h | ANSS | 22 |  | Rel-8 | 42 | Alain |  | 22.071 |  |  |  |  |
| 7672 | 2477.2 | GERAN2 part of Support for Additional Navigation Satellite Systems (ANSS) for LCS |  | 136d? | 2008-05-16 A | 2008-11-21 A | 100% | 2008-05-16 | 2008-11-21 | 136d? | start no earlier than 2008-05-16 | G2 | 1088h | 1088h | ANSS |  | Qualcomm | Rel-8 |  | Paolo |  | 43.059; 44.031; 49.031; 44.071; 48.031; 51.010 |  |  |  |  |
| 7673 | 2477.3 | RAN2 part of Support for Additional Navigation Satellite Systems (ANSS) for LCS |  | 136d? | 2008-05-30 A | 2008-12-05 A | 100% | 2008-05-30 | 2008-12-05 | 136d? | finish no earlier than 2008-12-08 | R2 | 1088h | 1088h | RANimp-ANSS | 21 | Qualcomm | Rel-8 | 40 | Yong-Jun | RANimp-ANSS | 25.305; 25.306; 25.331; 25.413; 25.423; 25.433; 25.453 | RP-080813 |  |  |  |
| 7674 | 2478 | **Conformance testing for the Latency Reductions feature** |  | 769.38d? | 2008-02-22 A | 2010-03-05 A | 100% | 2008-02-22 | 2010-03-05 | 532d? |  | G1; G3new | 14848h | 14848h | CTLATRED | 21 | Ericsson | Rel-8 |  | Paolo | CTLATRED |  |  |  |  |  |
| 7675 | 2478.1 | MS conformance testing for the Latency Reductions feature |  | 532d? | 2008-02-22 A | 2010-03-05 A | 100% | 2008-02-22 | 2010-03-05 | 532d? | finish no earlier than 2010-03-05 | G3new | 4248h | 4248h | CTLATRED-MStest | 21 | Ericsson | Rel-8 |  | Ingbert | CTLATRED-MStest | 51.010 |  |  |  |  |
| 7676 | 2478.2 | BTS conformance testing for the Latency Reductions feature |  | 261d? | 2008-02-22 A | 2009-02-20 A | 100% | 2008-02-22 | 2009-02-20 | 261d? | finish no earlier than 2009-02-20 | G1 | 2088h | 2088h | CTLATRED-BTStest | 21 | Ericsson | Rel-8 |  | Paolo | CTLATRED-BTStest | 51.021 |  |  |  |  |
| 7677 | 2479 | MS conformance testing of changes introduced by WI "Support of Packet-switched Handover for GERAN A/Gb mode" |  | 196d? | 2008-02-22 A | 2008-11-21 A | 100% | 2008-02-22 | 2008-11-21 | 196d? | finish no earlier than 2008-11-21 | G3new | 1568h | 1568h | PSHCT-MStest | 21 | Rohde & Schwarz | Rel-8 |  | Ingbert | PSHCT-MStest | 51.010 |  |  |  |  |
| 7678 | 2480 | (Small) Technical Enhancements and Improvements for Rel-8 |  | 666.5d? | 2007-01-01 A | 2008-12-11 A | 100% | 2007-01-01 | 2008-12-11 | 509d? | finish no earlier than 2008-12-11 | SP; CP; RP; GP | 16288h | 16288h | TEI8 |  |  | Rel-8 |  | All | TEI8 |  |  |  |  |  |
| 7679 | 2481 | (IETF) (Small) Technical Enhancements and Improvements for Rel-8 |  | 650d? | 2007-01-01 A | 2012-09-07 A | 100% | 2007-01-01 | 2012-09-07 | 650d? | finish no earlier than 2012-09-07 | C1-IETF | 5200h | 5200h | TEI8_IETF | 27 | christer.holmberg@ericsson.com | Rel-8 | 52 | Frederic | TEI8_IETF | RFC 6714 (was draft-ietf-simple-msrp-cema) |  |  |  |  |
| 7680 | 2482 | Test - (Small) Technical Enhancements and Improvements for Rel-8 |  | 993.6d? | 2007-03-07 A | 2010-12-24 A | 100% | 2007-03-07 | 2010-12-24 | 993.6d? | finish no earlier than 2010-12-24 | R5; G3new | 15897.6h | 15897.6h | TEI8_Test | 21 |  | Rel-8 | 40 | Ingbert | TEI8_Test |  |  |  |  |  |
| 7681 | 2483 | **Deleted - All-IP Network** |  | 648.25d? | 2004-06-28 A | 2006-03-15 A | 100% | 2004-06-28 | 2006-03-15 | 448d? |  | S1 | 7168h | 7168h | AIPN |  | NTT DoCoMo | Rel-8 |  | Alain | AIPN |  |  | SP-38 |  |  |
| 7682 | 2483.1 | Deleted - Stage 1 |  | 448d? | 2004-06-28 A | 2006-03-15 A | 100% | 2004-06-28 | 2006-03-15 | 448d? | finish no earlier than 2006-03-15 | S1 | 3584h | 3584h | AIPN |  | NTT DoCoMo | Rel-8 |  | Alain |  | 22.258 |  | SP-38 |  |  |
| 7683 | 2484 | Deleted - was Rel-7 - LCS for 3GPP Interworking WLAN | milestone | 0d? | 2007-09-28 A | 2007-09-28 A | 100% | 2007-09-28 | 2007-09-28 | 0d? | start no earlier than 2007-09-28 | S2 |  |  | LCS4_IWLAN |  | LG Electronics | Rel-8 | 34 | Maurice | LCS4_IWLAN | 23.234; 23.271; 23.167 |  | SP-35 | WLAN |  |
| 7684 | 2485 | Deleted - never approved- FBI Phase 2 | milestone | 0d | 2007-09-28 A | 2007-09-28 A | 100% | 2007-09-28 | 2007-09-28 | 0d | start no earlier than 2007-09-28 | S2 |  |  | FBI2 |  | Nokia Siemens Networks | Rel-8 |  | Maurice | FBI2 |  |  | SP-38 |  |  |
| 7685 | 2486 | Deleted -Enhancements to BS30 Bearer service for Videotelephony | milestone | 0d? | 2007-03-15 A | 2007-03-15 A | 100% | 2007-03-15 | 2007-03-15 | 0d? | finish no earlier than 2007-03-15 | S1 |  |  | BS30 |  |  | Rel-8 |  | Alain | BS30 | 22.002; 22.004; 22.101; 22.105; 24.008 |  | SP-38 |  |  |
| 7686 | 2487 | Deleted - IMS Enhancements Rel-8 |  | 106.5d? | 2007-09-03 A | 2007-12-14 A | 100% | 2007-09-03 | 2007-12-14 | 75d? |  | S1 | 600h | 600h | IMS8 |  | Telecom Italia | Rel-8 | 37 | Alain | IMS8 |  |  | SP-38 |  |  |
| 7687 | 2488 | **Deleted - Contact Manager Conformance Test specifications** |  | 679.12d? | 2008-06-02 A | 2010-03-19 A | 100% | 2008-06-02 | 2010-03-19 | 471d? |  | C6 | 11304h | 11304h | eUPHBOOK-Test | 21 | Comprion, Gemalto | Rel-8 | 40 | Xavier | eUPHBOOK-Test |  |  | CP-47 |  | PCG-24 |
| 7688 | 2488.1 | Deleted - Contact Manager for 3GPP UICC applications test specifications |  | 471d? | 2008-06-02 A | 2010-03-19 A | 100% | 2008-06-02 | 2010-03-19 | 471d? | finish no earlier than 2010-03-19 | C6 | 3768h | 3768h | eUPHBOOK-Test | 21 | Comprion | Rel-8 | 40 | Xavier |  | 31.320 (external interface for communication with the ME) |  | CP-47 |  | PCG-24 |
| 7689 | 2488.2 | Deleted - Contact Manager API for Java™ Card test specification |  | 471d? | 2008-06-02 A | 2010-03-19 A | 100% | 2008-06-02 | 2010-03-19 | 471d? | finish no earlier than 2010-03-19 | C6 | 3768h | 3768h | eUPHBOOK-Test | 21 | Gemalto | Rel-8 | 40 | Xavier |  | 31.321 (internal interface (API)) |  | CP-47 |  | PCG-24 |
| 7690 | 2489 | Deleted - MS conformance testing of Support of Conversational Services in A/Gb mode via the PS domain |  | 401d? | 2008-02-25 A | 2009-09-04 A | 100% | 2008-02-25 | 2009-09-04 | 401d? | finish no earlier than 2009-09-04 | G3new | 3208h | 3208h | SCSAGBCT-MStest | 21 | Nokia | Rel-8 |  | Ingbert | SCSAGBCT-MStest | 51.010 |  | GP-43 |  | PCG-23 |
| 7691 | 2490 | Release 8 Studies | milestone | 0d? | 2005-10-07 A | 2005-10-07 A | 100% | 2005-10-07 | 2010-11-12 | 1332d? | start no earlier than 2000-01-03 | CP; GP; RP; SP |  |  |  |  |  | Rel-8 |  | All |  |  |  |  |  |  |
| 7692 | 2491 | Study on Customised Alerting Tone (CAT) Requirements |  | 245d? | 2005-10-07 A | 2006-09-14 A | 100% | 2005-10-07 | 2006-09-14 | 245d? | start no earlier than 2005-10-07 | S1 | 1960h | 1960h | FS_CAT |  | China Mobile | Rel-8 |  | Alain | FS_CAT | 22.982 |  |  |  |  |
| 7693 | 2492 | Study on Facilitating Machine to Machine Communication in GSM and UMTS (M2M) |  | 350d? | 2005-11-04 A | 2007-03-08 A | 100% | 2005-11-04 | 2007-03-08 | 350d? | finish no earlier than 2006-06-16 | S1 | 2800h | 2800h | FS_M2M |  | Siemens | Rel-8 |  | Alain | FS_M2M | 22.868 |  |  | MTC, M2M |  |
| 7694 | 2493 | Study on Network Composition |  | 526d? | 2005-12-07 A | 2007-12-12 A | 100% | 2005-12-07 | 2007-12-12 | 526d? | finish no earlier than 2006-09-27 | S1 | 4208h | 4208h | FS_NetComp |  | Nokia Siemens Networks | Rel-8 |  | Alain | FS_NetComp | 22.980 |  |  |  |  |
| 7695 | 2494 | Study on Requirements of IMS Multimedia Conferencing |  | 330d? | 2006-06-08 A | 2007-09-12 A | 100% | 2006-06-08 | 2007-09-12 | 330d? | finish no earlier than 2007-03-21 | S1 | 2640h | 2640h | FS_IMSconf |  | China Mobile | Rel-8 |  | Alain | FS_IMSconf | 22.948 |  |  |  |  |
| 7696 | 2495 | Study on support of a Public Warning System |  | 200.75d? | 2007-09-03 A | 2008-03-14 A | 100% | 2007-09-03 | 2008-03-14 | 140d? |  | S1 | 1120h | 1120h | FS_PWS |  | T-Mobile | Rel-8 |  | Alain | FS_PWS | 22.968 |  |  | Public Safety (I-A) |  |
| 7697 | 2496 | Study on Paging Permission with Access Control |  | 256d? | 2006-09-28 A | 2007-09-20 A | 100% | 2006-09-28 | 2007-09-20 | 256d? | finish no earlier than 2007-09-20 | S1 | 2048h | 2048h | FS_PPAC |  | NTT DoCoMo | Rel-8 |  | Alain | FS_PPAC | 22.908 |  |  |  |  |
| 7698 | 2497 | Study on Non-3GPP access Network Selection Principles (NSP) |  | 392d? | 2006-12-06 A | 2008-06-05 A | 100% | 2006-12-06 | 2008-06-05 | 392d? | finish no earlier than 2007-11-19 | S1 | 3136h | 3136h | FS_N3GtoNSP |  | Telefónica O2 | Rel-8 | 34 | Alain | FS_N3GtoNSP | 22.912 |  |  |  |  |
| 7699 | 2498 | Study on Value Added Services for Short Message Service |  | 263d? | 2006-12-06 A | 2007-12-07 A | 100% | 2006-12-06 | 2007-12-07 | 263d? | finish no earlier than 2007-12-07 | S1 | 2104h | 2104h | FS_VAS4SMS |  | China Mobile | Rel-8 | 34 | Alain | FS_VAS4SMS | 22.942 |  |  |  |  |
| 7700 | 2499 | Study on Service continuity between mobile and WLAN networks |  | 262d? | 2006-12-06 A | 2007-12-06 A | 100% | 2006-12-06 | 2007-12-06 | 262d? | finish no earlier than 2008-12-25 | S1 | 2096h | 2096h | FS_SMLSWLAN |  | NEC | Rel-8 | 34 | Alain | FS_SMLSWLAN | 22.937 |  |  | WLAN |  |
| 7701 | 2500 | Study on Services Alignment and Migration |  | 331d? | 2006-12-06 A | 2008-03-12 A | 100% | 2006-12-06 | 2008-03-12 | 331d? | finish no earlier than 2007-09-20 | S1 | 2648h | 2648h | FS_ServAl |  | Telefónica O2 | Rel-8 | 37 | Alain | FS_ServAl | 22.983 |  |  |  |  |

Notes:
- 7665: CP#42 completed. Updated WID CP-080278=>CP-080722 / WI rapporteur e-mail: philip.hodges@ericsson.com
- 7666: CP#42 completed. Updated WID CP-080278=>CP-080722 / WI rapporteur e-mail: philip.hodges@ericsson.com
- 7667: CP#42 completed. Updated WID CP-080278=>CP-080722 / WI rapporteur e-mail: philip.hodges@ericsson.com
- 7668: CP#42 completed. Updated WID CP-080278=>CP-080722 / WI rapporteur e-mail: philip.hodges@ericsson.com
- 7669: GP#39 completed / WI rapporteur e-mail: thomas.bitzer@alcatel-lucent.de
- 7670: GP#40 completed / WI rapporteur e-mail: Mungal Dhanda
- 7671: SP#42 completed by 22.071 CR0077
- 7672: GP#40 completed / WI rapporteur e-mail: Mungal Dhanda
- 7673: RP#42 WI closed at 95%. Considers Rel-9 performance requirements / WI rapporteur e-mail: Etienne Chaponniere (echaponn@qualcomm.com)
- 7674: GP#45 completed / WI rapporteur e-mail: mats.y.samuelsson@ericsson.com, hakan.e.grunditz@ericsson.com
- 7675: GP#45 completed / WI rapporteur e-mail: hakan.e.grunditz@ericsson.com
- 7676: GP#41 completed / WI rapporteur e-mail: mats.y.samuelsson@ericsson.com
- 7677: GP#40 completed / WI rapporteur e-mail: Franz.Segerer@ROHDE-SCHWARZ.COM
- 7678: SP#42 completed
- 7679: CP#57 completed / WI rapporteur e-mail: christer.holmberg@ericsson.com
- 7680: -
- 7681: SP#38 stopped. 25/07/08 Moved UID_31059 Study on All-IP Network (FS_AIPN/was AIPFS) to Rel-7 out of the stopped Rel-8 Feature UID_31067 Deleted - All-IP Network (AIPN) / WI rapporteur e-mail: c.masyu@nttdocomo.co.jp
- 7682: 22.258 withdrawn, superseded by 22.278 (UID 320022). SP#38 stopped / WI rapporteur e-mail: c.masyu@nttdocomo.co.jp
- 7683: SP#35 stopped / WI rapporteur e-mail: dhshim@lge.com
- 7684: SP#38 stopped
- 7685: SP#38 stopped (no support) / WI rapporteur e-mail: andre.jarvis@three.co.uk
- 7686: SP#38 stopped
- 7687: CP#47 work stopped/abandoned / WI rapporteur e-mail: Udo Willenbrink, Jacques Seif
- 7688: CP#47 work stopped/abandoned / WI rapporteur e-mail: Udo Willenbrink (uwillenbrink@comprion.com )
- 7689: CP#47 work stopped/abandoned / WI rapporteur e-mail: jacques.seif@gemalto.com
- 7690: GP#43 work stopped/abandoned (completion 0%) / WI rapporteur e-mail: arsi.heino@nokia.com
- 7691: -
- 7692: Spin-off Rel-8 Feature Customized Alerting Tone (CAT) Service UID_340029 / WI rapporteur e-mail: Qing Huang (huangqing@chinamobile.com)
- 7693: SP#35 completed. Spin-off SA3 Study on Security Aspects of Remote Provisioning and Change of Subscription for M2M (UID_370053). SP#40 Spin-off new Feature UID_410030 (NIMTC) / WI rapporteur e-mail: Juergen Merkel
- 7694: SP#38 completed / WI rapporteur e-mail: joerg.swetina@neclab.eu
- 7695: SP#37 completed. Spin-off New Feature UID_370026 Value-Added Services for Short Message Service (VAS4SMS) / WI rapporteur e-mail: Qing Huang (huangqing@chinamobile.com)
- 7696: SP#39 completed. Spin-off Rel-9 Feature UID_380057 (PWS) / WI rapporteur e-mail: mark.younge@t-mobile.com
- 7697: SP#37 completed. Spin-off new Feature UID_370084 (PPACR) / WI rapporteur e-mail: Katsuhiro NOGUCHI (noguchi@nttdocomo.co.jp)
- 7698: SP#38 completed. Spin-off New Feature UID_380062 (N3GTONSP). SP#40 WID updated SP-060930=>SP-080318. TR re-approved with new # 22.812=>22.912 / WI rapporteur e-mail: chris.friel@O2.com
- 7699: SP#38 completed. Spin-off New Feature UID_370026 (VAS4SM) / WI rapporteur e-mail: Qing Huang (huangqing@chinamobile.com)
- 7700: SP#38 completed / WI rapporteur e-mail: joerg.swetina@neclab.eu
- 7701: SP#39 completed. Spin-off Rel-9 Feature UID_330017 Services Alignment and Migration (ServAl) / WI rapporteur e-mail: chris.friel@O2.com

| ID | WBS | Task | Duration | Start | Finish | Complete | Baseline start | Baseline finish | Baseline duration | Constraint | Resources | Work | Actual work | Acronym | WI rapporteur name | WI rapporteur e-mail | Release | MCC resp | Acronym_3GU_Export | Impacted TSs and TRs | PCG approved | TSG approved | Special Focus Doc | Status Report | PCG stopped | TSG stopped |
| --- | --- | --- | --- | --- | --- | --- | --- | --- | --- | --- | --- | --- | --- | --- | --- | --- | --- | --- | --- | --- | --- | --- | --- | --- | --- | --- |
| 7702 | 2501 | **Study on 3GPP System Architecture Evolution** | 1616.75d? | 2004-12-03 A | 2009-03-12 A | 100% | 2004-12-03 | 2009-03-12 | 1115d? |  | S2; S3 | 34064h | 34064h | FS_SAE | Vodafone | chris.pudney@vodafone.com | Rel-8 | Maurice | FS_SAE |  |  |  |  |  |  |  |
| 7703 | 2501.1 | Stage 2 Interim conclusion for RAN Work to start | 990d? | 2004-12-03 A | 2008-09-18 A | 100% | 2004-12-03 | 2008-09-18 | 990d? | finish no earlier than 2005-09-23 | S2 | 7920h | 7920h | FS_SAE | Vodafone | chris.pudney@vodafone.com | Rel-8 | Maurice |  | 23.882 |  |  |  |  |  |  |
| 7704 | 2501.2 | Stage 2 study on 3GPP architectural development | 704d? | 2006-01-09 A | 2008-09-18 A | 100% | 2006-01-09 | 2008-09-18 | 704d? | finish no earlier than 2007-09-28 | S2 | 5632h | 5632h | FS_SAE | Vodafone | chris.pudney@vodafone.com | Rel-8 | Maurice |  | 23.882 |  |  |  |  |  |  |
| 7705 | 2501.3 | Security study for Inter-access mobility between non-3GPP and 3GPP system | 334d? | 2007-09-03 A | 2009-03-12 A | 100% | 2007-09-03 | 2009-03-12 | 334d? | finish no earlier than 2009-03-12 | S3 | 2672h | 2672h | FS_SAE | Nokia | dajiang.zhang@nokia.com | Rel-8 | Mirko |  | 33.821; 33.822 |  |  |  |  |  |  |
| 7706 | 2502 | Study on Stage 2 aspects of IMS Service Brokering | 589d? | 2006-06-19 A | 2008-09-18 A | 100% | 2006-06-19 | 2008-09-18 | 589d? | finish no earlier than 2008-09-18 | S2 | 4712h | 4712h | FS_ISB_ST2 | Telcordia | raquel@research.telcordia.com | Rel-8 | Maurice | FS_ISB_ST2 | 23.810 |  |  |  |  |  |  |
| 7707 | 2503 | Study on IMS utilizing multicast bearer services | 447d? | 2006-03-22 A | 2007-12-06 A | 100% | 2006-03-22 | 2007-12-06 | 447d? | finish no earlier than 2007-12-03 | S2 | 3576h | 3576h | FS_MLTICAST-IMS | Nokia Siemens Networks |  | Rel-8 | Maurice | FS_MLTICAST-IMS | 23.847 |  |  |  |  |  |  |
| 7708 | 2504 | Study on Multimedia Session Continuity | 291d? | 2007-04-26 A | 2008-06-05 A | 100% | 2007-04-26 | 2008-06-05 | 291d? | finish no earlier than 2008-06-05 | S2 | 2328h | 2328h | FS_MMSC | LG Electronics |  | Rel-8 | Maurice | FS_MMSC | 23.893 |  |  |  |  |  |  |
| 7709 | 2505 | **Study on centralized IMS service control** | 525d? | 2006-10-23 A | 2008-03-12 A | 100% | 2006-10-23 | 2008-03-12 | 363d? |  | S2; S1 | 10856h | 10856h | FS_ICS | Ericsson | peter.bleckert@ericsson.com | Rel-8 | Alain | FS_ICS |  | 21 | 38 |  |  |  |  |
| 7710 | 2505.1 | Study on centralized IMS services requirements | 268d? | 2007-03-05 A | 2008-03-12 A | 100% | 2007-03-05 | 2008-03-12 | 268d? | start no earlier than 2007-03-05 | S1 | 2144h | 2144h | FS_ICS-S1 | NEC | joerg.swetina@neclab.eu | Rel-8 | Alain | FS_ICS-S1 | 22.892 |  | 37 |  |  |  |  |
| 7711 | 2505.2 | Study on centralized IMS services control | 363d? | 2006-10-23 A | 2008-03-12 A | 100% | 2006-10-23 | 2008-03-12 | 363d? | finish no earlier than 2008-02-21 | S2 | 2904h | 2904h | FS_IMS_CSC | Alcatel-Lucent | andy.bennett@alcatel-lucent.com | Rel-8 | Maurice | FS_IMS_CSC | 23.892 |  |  |  |  |  |  |
| 7712 | 2506 | Study on Architecture of IMS based Customized Alerting Tone (CAT) | 208d? | 2007-12-04 A | 2008-09-18 A | 100% | 2007-12-04 | 2008-09-18 | 208d? | finish no earlier than 2008-09-08 | S2 | 1664h | 1664h | FS_CAT-St2 | China Mobile | WANG, Jing (wangjing@chinamobilecom) | Rel-8 | Maurice | FS_CAT-St2 | 23.872 | 21 | 38 |  |  |  |  |
| 7713 | 2507 | Study on Home (e)NodeB Security | 321d? | 2007-12-20 A | 2009-03-12 A | 100% | 2007-12-20 | 2009-03-12 | 321d? | finish no earlier than 2009-03-10 | S3 | 2568h | 2568h | FS_HNB_Sec | Huawei | yangyanmei@huawei.com | Rel-8 | Mirko | FS_HNB_Sec | 33.820 | 21 | 38 | HNB |  |  |  |
| 7714 | 2508 | Study on Transferring of emergency call data – in-band modem solution | 265d? | 2006-12-07 A | 2007-12-12 A | 100% | 2006-12-07 | 2007-12-12 | 265d? | finish no earlier than 2008-09-18 | S4 | 2120h | 2120h | eCALLIBMS | Airbiquity | lhong@airbiquity.com | Rel-8 | Paolo | eCALLIBMS | 26.967 |  |  | Public Safety (I-A) |  |  |  |
| 7715 | 2509 | Study on Element Operations Systems Function (EOSF) definition | 266d? | 2007-06-07 A | 2008-06-12 A | 100% | 2007-06-07 | 2008-06-12 | 266d? | finish no earlier than 2008-12-11 | S5 | 2128h | 2128h | OAM7-NIM-EOSF | China Mobile | Li Jian (lijian@chinamobile.com) | Rel-8 | Mirko | OAM7-NIM-EOSF | 32.819 |  |  |  |  |  |  |
| 7716 | 2510 | Study on SA5 MTOSI XML Harmonization | 351d? | 2006-05-10 A | 2007-09-12 A | 100% | 2006-05-10 | 2007-09-12 | 351d? | finish no earlier than 2007-12-14 | S5 | 2808h | 2808h | OAM8-NIM-XML | Nortel | jduguay@nortel.com | Rel-8 | Mirko | OAM8-NIM-XML | 32.818 |  |  |  |  |  |  |
| 7717 | 2511 | Study on Common Profile Storage (CPS) Framework of User Data for network services and management | 244d? | 2006-07-03 A | 2007-06-07 A | 100% | 2006-07-03 | 2007-06-07 | 244d? | finish no earlier than 2007-06-07 | S5 | 1952h | 1952h | OAM7-CPS | T-Mobile | istvan.aba@t-mobile.at | Rel-8 | Mirko | OAM7-CPS | 32.808 |  |  |  |  |  |  |
| 7718 | 2512 | Study on Management for LTE and SAE | 526d? | 2006-12-07 A | 2008-12-11 A | 100% | 2006-12-07 | 2008-12-11 | 526d? | finish no earlier than 2008-12-11 | S5 | 4208h | 4208h | FS_OAM_LTE_SAE | Ericsson | robert.petersen@ericsson.com | Rel-8 | Mirko | FS_OAM_LTE_SAE | 32.816 |  | 34 |  |  |  |  |
| 7719 | 2513 | Study on Charging Aspects of 3GPP System Evolution | 179d? | 2007-04-02 A | 2007-12-06 A | 100% | 2007-04-02 | 2007-12-06 | 179d? | finish no earlier than 2007-12-06 | S5 | 1432h | 1432h | FS_SAEcharg | Nokia Siemens Networks | Gerald.Goermer@nsn.com | Rel-8 | Mirko | FS_SAEcharg | 32.820 |  |  |  |  |  |  |
| 7720 | 2514 | Study on AS-MRFC media server control protocol | 583d? | 2006-03-22 A | 2008-06-13 A | 100% | 2006-03-22 | 2008-06-13 | 583d? | finish no earlier than 2008-06-13 | C1 | 4664h | 4664h | MRFC | Hewlett-Packard | mark.syrett@hp.com | Rel-8 | Frederic | MRFC | 24.880 |  |  |  |  |  |  |
| 7721 | 2515 | Study on IMS Restoration Procedures | 310d? | 2007-03-26 A | 2008-05-30 A | 100% | 2007-03-26 | 2008-05-30 | 310d? | finish no earlier than 2008-05-30 | C4 | 2480h | 2480h | FS_IMS_RP | Ericsson | german.blanco@ericsson.com | Rel-8 | Kimmo | FS_IMS_RP | 23.820 |  |  |  |  |  |  |
| 7722 | 2516 | Study on IMS Application Server Service Data Descriptions for AS interoperability | 261d? | 2007-09-14 A | 2008-09-12 A | 100% | 2007-09-14 | 2008-09-12 | 261d? | finish no earlier than 2008-09-12 | C4 | 2088h | 2088h | FS_IMS_ASIO | Alcatel-Lucent | Jean-Jacques Trottin | Rel-8 | Kimmo | FS_IMS_ASIO | 29.864 |  |  |  |  |  |  |
| 7723 | 2517 | Study on Customized Alerting Tone (CAT) solution for voice and video call in CS domain | 378d? | 2007-09-14 A | 2008-09-12 A | 100% | 2007-09-14 | 2008-09-12 | 261d? |  | C4 | 626.4h | 626.4h | FS_CAT_VVC_CS | China Mobile | zhanghao@chinamobile.com | Rel-8 | Kimmo | FS_CAT_VVC_CS | 29.882 |  |  |  |  |  |  |
| 7724 | 2518 | Study on InterWorking Function between MAP based and Diameter based interfaces | 266d? | 2007-11-30 A | 2008-12-05 A | 100% | 2007-11-30 | 2008-12-05 | 266d? | finish no earlier than 2008-12-05 | C4 | 2128h | 2128h | FS_MAP2Diam | Huawei | liming49985@huawei.com | Rel-8 | Kimmo | FS_MAP2Diam | 29.805 | 21 | 38 |  |  |  |  |
| 7725 | 2519 | Study on Scope of future HSPA Evolution for 1.28 Mcps TDD | 186d? | 2007-09-14 A | 2008-05-30 A | 100% | 2007-09-14 | 2008-05-30 | 186d? | finish no earlier than 2008-05-30 | R1 | 1488h | 1488h | FS_RAN-LCRTDDHSPAEvo | RITT | Xu Fei | Rel-8 | Patrick | FS_RAN-LCRTDDHSPAEvo | 25.824 |  | 37 |  | RP-080290 |  |  |
| 7726 | 2520 | Study on Synchronized E-DCH for UTRA FDD | 126d? | 2007-09-14 A | 2008-03-07 A | 100% | 2007-09-14 | 2008-03-07 | 126d? | finish no earlier than 2008-03-14 | R1 | 1008h | 1008h | FS_RAN-UplinkSync | Nokia Siemens Networks | Karri.Ranta-aho@nsn.com | Rel-8 | Patrick | FS_RAN-UplinkSync | 25.823 |  | 37 |  | RP-080068 |  |  |
| 7727 | 2521 | Study on Improved network controlled mobility between LTE and 3GPP2/mobile WiMAX radio technologies | 131d? | 2007-06-04 A | 2007-12-03 A | 100% | 2007-06-04 | 2007-12-03 | 131d? | finish no earlier than 2007-12-03 | R4 | 1048h | 1048h | FS_RAN-LTEmob | Motorola | hao.bi@Motorola.com | Rel-8 | Issam | FS_RAN-LTEmob | 36.938 |  |  |  | RP-070827 |  |  |
| 7728 | 2522 | Study on 3G Home NodeB/eNodeB | 325d? | 2007-03-05 A | 2008-05-30 A | 100% | 2007-03-05 | 2008-05-30 | 325d? | finish no earlier than 2008-05-30 | R4 | 2600h | 2600h | FS_RAN-HNBeNB | Motorola | howard.thomas@motorola.com | Rel-8 | Issam | FS_RAN-HNBeNB | 25.820 |  |  | HNB | RP-080289 |  |  |
| 7729 | 2523 | Study on A-interface over IP | 126d? | 2007-08-31 A | 2008-02-22 A | 100% | 2007-08-31 | 2008-02-22 | 126d? | finish no earlier than 2008-02-22 | GP | 1008h | 1008h | AINTIP | China Mobile, Ericsson | paul.schliwa-bertling@ericsson.com | Rel-8 | Paolo | AINTIP | 43.903 |  |  |  |  |  |  |
| 7730 | 2524 | Study on Multi-User Reusing-One-Slot | 782d? | 2007-11-16 A | 2010-11-12 A | 100% | 2007-11-16 | 2010-11-12 | 782d? | finish no earlier than 2010-11-12 | GP | 6248h | 6248h | MUROS | Nokia Siemens Networks | juergen.hofmann@nsn.com | Rel-8 | Paolo | MUROS | 45.914 |  |  |  |  |  |  |
| 7731 | 2525 | Study on Optimized Transmit Pulse Shape for Downlink EGPRS2-B | 657d? | 2007-11-16 A | 2010-05-21 A | 100% | 2007-11-16 | 2010-05-21 | 657d? | finish no earlier than 2010-05-27 | G1 | 5248.44h | 5248.44h | WIDER | Research In Motion, Nokia Siemens Networks | jdwyer@RIM.COM and eddie.riddington@nsn.com | Rel-8 | Paolo | WIDER | 45.913 |  |  |  |  |  |  |
| 7732 | 2526 | Deleted - Study on Mobility between 3GPP-WLAN Interworking and 3GPP Systems | 393d? | 2007-03-20 A | 2008-09-18 A | 100% | 2007-03-20 | 2008-09-18 | 393d? | finish no earlier than 2008-09-18 | S2 | 3144h | 3144h | FS_SM3GWLAN | Orange |  | Rel-8 | Maurice | FS_SM3GWLAN | withdrawn 23.827 |  |  | WLAN |  | PCG-21 | SP-41 |
| 7733 | 2527 | Deleted - equals 340035 -FS on Service continuity between mobile and WLAN networks | 75d? | 2007-09-03 A | 2007-12-14 A | 100% | 2007-09-03 | 2007-12-14 | 75d? | finish no earlier than 2007-12-14 | S1 | 600h | 600h | FSSCMobToW | BT | mike.meyerstein@bt.com | Rel-8 | Alain | FSSCMobToW | 22.937 |  | 37 |  |  | PCG-21 | SP-39 |
| 7734 | 2528 | Deleted - Study on Evaluation of LCS Control Plane Solution for EPS | 100d? | 2008-01-14 A | 2008-05-30 A | 100% | 2008-01-14 | 2008-05-30 | 100d? | finish no earlier than 2009-03-20 | S2 | 800h | 800h | FS_LCS_EPS | SiRF |  | Rel-8 | Maurice | FS_LCS_EPS | 23.891 |  | 38 |  |  | PCG-21 | SP-40 |
| 7735 | 2529 | Deleted - Study on HS-PDSCH serving cell change enhancements | 60d? | 2007-12-17 A | 2008-03-07 A | 100% | 2007-12-17 | 2008-03-07 | 60d? | finish no earlier than 2008-06-12 | R4 | 480h | 480h | FS_RAN-HSPDSCH | Qualcomm |  | Rel-8 | Issam | FS_RAN-HSPDSCH | none | 21 | 38 |  | RP-080070 | PCG-21 | RP-39 |
| 7736 | 2530 | Deleted - Study on Dual-Cell HSDPA operation | 261d? | 2007-08-15 A | 2009-03-06 A | 100% | 2007-08-15 | 2009-03-06 | 261d? | finish no earlier than 2009-03-06 | R1 | 2088h | 2088h | FS_RAN-DCHS | Qualcomm | Josef Blanz | Rel-8 | Patrick | FS_RAN-DCHS | withdrawn 25.825 v100 | 21 | 39 |  | RP-090066 | PCG-22 | RP-43 |
| 7737 | 2531 | --- RELEASE 7 --- | 679d? | 2005-05-02 A | 2007-12-06 A | 100% | 2005-05-02 | 2007-12-06 | 679d? | start no earlier than 2000-01-01 | CP; GP; RP; SP | 21728h | 21728h |  |  |  | Rel-7 | All |  |  |  |  |  |  |  |  |

Notes:
- 7702: SP#43 completed
- 7703: SP#41 completed
- 7704: SP#41 completed
- 7705: SP#43 completed
- 7706: SP#41 completed. No spin-off activity proposed. [Note: IMS Service Brokering enhancements UID_31088 moved back from R8 to R7 to give a home to 22228CR0036_(Rel-7)_S1-051232. Hence, Rel-7 ISB has Stage 1 only (and is misaligned with Rel-7 Stages 2/3.]
- 7707: SP#38 completed
- 7708: SP#40 completed
- 7709: SP#39 completed
- 7710: SP#39 completed
- 7711: SP#39 completed
- 7712: SP#41 completed as Rel-8
- 7713: SP#43 completed. Linked to RAN4 Study on 3G Home NodeB/eNodeB (UID_350039) and to SA5 Study on Self-Organizing Networks (SON) related OAM interfaces for Home NodeB (UID_360007)
- 7714: SP#38 completed. Spin-off WID UID_34042 (eCall_Phase2)
- 7715: SP#40 completed. WID updated SP-050608=>SP-070307
- 7716: SP#37 completed. WID updated SP-050295=>SP-070305
- 7717: SP#36 completed. Spin-off New Feature UID_400034 User Data Convergence (UDC)
- 7718: SP#42 completed
- 7719: SP#38 completed
- 7720: CP#40 completed. Spin-off New Feature UID_380035 (MRFC_TS)
- 7721: CP#40 completed. Spin-off WID UID_400012 (IMS_RP)
- 7722: CP#41 completed. Linked to SA5 Study on Common Profile Storage framework UID_320006. Spin-off WID UID_410003 (IMS_ASIO)
- 7723: CP#41 completed. Spin-off WID under Feature CAT UID_340029
- 7724: CP#42 completed. Spin-off implementation Building Block UID_410007 (MAP2Diam) under the SAES Feature UID_320005
- 7725: RP#40 completed
- 7726: RP#39 completed
- 7727: RP#38 completed
- 7728: RP#40 completed
- 7729: GP#37 completed. Spin-off implementation Feature AoIP (A-interface over IP) UID_50591
- 7730: GP#48 completed as Rel-8. Spin-off implementation WI UID_420002 VAMOS (Voice services over Adaptive Multi-user channels on One Slot)
- 7731: GP#46 completed
- 7732: SP#41 stopped. Draft TR 23.827 content implemented in TS 23.327.
- 7733: SP#39 stopped
- 7734: SP#40 spin-off Feature UID_400038 (LCS_CPS_EPS). SP#40 FS stopped
- 7735: RP#39 stopped (no TR produced). Spin-off HS-DSCH Serving Cell Change Enhancements (UID_39003)
- 7736: RP#43 stopped (draft TR 25.825 v100 withdrawn). Conclusions in RP-090318 (RAN1 findings of the UTRA Multi-Carrier Evolution study). RP#42 New WI approved on Dual-Cell HSDPA operation on adjacent carriers (UID_400052)
- 7737: -

| ID | WBS | Task | Type | Duration | Start | Finish | Complete | Baseline start | Baseline finish | Baseline duration | Constraint | Resources | Work | Actual work | Acronym | WI rapporteur name | WI rapporteur e-mail | Release | MCC resp | Acronym_3GU_Export | TSG stopped | PCG approved | TSG approved | Status Report | Special Focus Doc |
| --- | --- | --- | --- | --- | --- | --- | --- | --- | --- | --- | --- | --- | --- | --- | --- | --- | --- | --- | --- | --- | --- | --- | --- | --- | --- |
| 7738 | 2532 | **Identification of Communication Services in IMS** |  | 896.75d? | 2005-05-02 A | 2007-09-14 A | 100% | 2005-05-02 | 2007-09-14 | 620d? |  | S2; S1; C1; S5 | 29048h | 29048h | ServID | Ericsson | stephen.terrill@ericsson.com | Rel-7 | Maurice | ServID |  |  |  |  |  |
| 7739 | 2532.1 | TR on ServID |  | 232d? | 2005-05-02 A | 2006-03-21 A | 100% | 2005-05-02 | 2006-03-21 | 232d? | finish no earlier than 2006-03-20 | S2 | 1856h | 1856h | ServID | Ericsson | stephen.terrill@ericsson.com | Rel-7 | Maurice |  |  |  |  |  |  |
| 7740 | 2532.2 | Stage 1,2 of ServID |  | 144d? | 2005-11-11 A | 2006-05-31 A | 100% | 2005-11-11 | 2006-05-31 | 144d? | start no earlier than 2005-11-11 | S1; S2 | 2304h | 2304h | ServID | Ericsson | stephen.terrill@ericsson.com | Rel-7 | Maurice |  |  |  |  |  |  |
| 7741 | 2532.3 | Stage 3 of ServID |  | 250d? | 2006-03-31 A | 2007-03-15 A | 100% | 2006-03-31 | 2007-03-15 | 250d? | finish no earlier than 2007-03-15 | C1 | 2000h | 2000h | ServID | Ericsson | christer.holmberg@ericsson.com | Rel-7 | Frederic |  |  |  |  |  |  |
| 7742 | 2532.4 | Charging of ServID |  | 381d? | 2006-03-31 A | 2007-09-14 A | 100% | 2006-03-31 | 2007-09-14 | 381d? | finish no earlier than 2007-09-14 | S5 | 3048h | 3048h | ServID | Orange | alain.bibas@orange-ft.com | Rel-7 | Mirko |  |  |  |  |  |  |
| 7743 | 2533 | **Supporting Globally Routable User Agent URIs in IMS** |  | 599.5d? | 2005-11-14 A | 2007-06-15 A | 100% | 2005-11-14 | 2007-06-15 | 415d? |  | S2; S1; C1 | 14920h | 14920h | GRUU | Research In Motion | Adrian Buckley (abuckley@rim.com) | Rel-7 | Maurice | GRUU |  |  |  |  |  |
| 7744 | 2533.1 | Deleted - TR on GRUU |  | 219d? | 2005-11-14 A | 2006-09-14 A | 100% | 2005-11-14 | 2006-09-14 | 219d? | finish no earlier than 2006-09-14 | S2 | 1752h | 1752h | GRUU | Research In Motion | Adrian Buckley (abuckley@rim.com) | Rel-7 | Maurice |  | SP-32 |  |  |  |  |
| 7745 | 2533.2 | Stage 1,2 of GRUU |  | 65d? | 2006-07-03 A | 2006-09-29 A | 100% | 2006-07-03 | 2006-09-29 | 65d? | start no earlier than 2006-07-03 | S1; S2 | 1040h | 1040h | GRUU | Research In Motion | Adrian Buckley (abuckley@rim.com) | Rel-7 | Maurice |  |  |  |  |  |  |
| 7746 | 2533.3 | Stage 3 of GRUU |  | 271d? | 2006-06-02 A | 2007-06-15 A | 100% | 2006-06-02 | 2007-06-15 | 271d? | finish no earlier than 2007-06-15 | C1 | 2168h | 2168h | GRUU | CableLabs | Bernie McKibben (b.mckibben@cablelabs.com) | Rel-7 | Frederic |  |  |  |  |  |  |
| 7747 | 2534 | **Multimedia Telephony Service for IMS** |  | 4203.75d? | 2006-02-01 A | 2017-03-15 A | 100% | 2006-02-01 | 2007-06-15 | 357d? |  | S1; C1; S4 | 81952h | 81952h | MTSI | Ericsson | peter.bleckert@ericsson.com | Rel-7 | Alain | MTSI |  | 35 | 69 |  |  |
| 7748 | 2534.1 | Stage 1 of MTSI |  | 173d? | 2006-02-01 A | 2006-09-29 A | 100% | 2006-02-01 | 2006-09-29 | 173d? | start no earlier than 2006-02-01 | S1 | 1384h | 1384h | MTSI-REQ | Ericsson | peter.bleckert@ericsson.com | Rel-7 | Alain | MTSI-REQ |  |  |  |  |  |
| 7749 | 2534.2 | Stage 3 of MTSI |  | 330d? | 2006-03-10 A | 2007-06-14 A | 100% | 2006-03-10 | 2007-06-14 | 330d? | finish no earlier than 2007-06-15 | C1 | 2640h | 2640h | MTSI | Ericsson | christer.holmberg@ericsson.com | Rel-7 | Frederic | MTSI |  |  |  |  |  |
| 7750 | 2534.3 | Media handling and interaction in MTSI |  | 262d? | 2006-03-15 A | 2007-03-15 A | 100% | 2006-03-15 | 2007-03-15 | 262d? | finish no earlier than 2007-03-15 | S4 | 2096h | 2096h | MTSI-MHI | Ericsson | olle.franceschi@ericsson.com | Rel-7 | Paolo | MTSI-MHI |  |  |  |  |  |
| 7751 | 2534.4 | UE Conformance Test Aspects - Multimedia Telephony Services for IMS (MTSI) over fixed access |  | 393d? | 2015-09-15 A | 2017-03-15 A | 100% |  |  |  | finish no earlier than 2017-03-15 | R5 | 3144h | 3144h | MTSI_FIXED_ACCESS-UEConTest | Telecom Italia |  | Rel-7 |  |  |  | 35 | 69 |  |  |
| 7752 | 2534.5 | UE Conformance Test Aspects – Multimedia Telephony Services for IMS (MTSI) over WLAN |  | 329d? | 2015-09-15 A | 2016-12-15 A | 100% |  |  |  | finish no earlier than 2016-12-15 | R5 | 2632h | 2632h | MTSI_WLAN-UEConTest | Ericsson |  | Rel-7 |  |  |  | 35 | 69 |  |  |
| 7753 | 2534.6 | Deleted - duplicates UID7039 - IMS Multimedia Telephony Service | milestone | 0d? | 2007-06-15 A | 2007-06-15 A | 100% | 2007-06-15 | 2007-06-15 | 0d? | start no earlier than 2007-06-15 | S1 |  |  | MMTEL | Ericsson | peter.bleckert@ericsson.com | Rel-7 | Alain | MMTEL | SP-32 |  |  |  |  |
| 7754 | 2535 | Multimedia Telephony Service for IMS (MTSI) - UE Conformance Testing |  | 560.25d | 2007-09-19 A | 2009-03-12 A | 100% | 2007-09-19 | 2009-03-12 | 387d | finish no earlier than 2009-03-13 | R5 | 1664h | 1664h | MTSI-UEConTest | Ericsson, Motorola | Leif.Mattisson@ericsson.com, Jacob.John@motorola.com | Rel-7 | Ingbert | MTSI-UEConTest |  |  |  | RP-090056 |  |
| 7755 | 2536 | TISPAN requirements for Multimedia Telephony with PSTN/ISDN simulation services |  | 58d? | 2007-09-18 A | 2007-12-06 A | 100% | 2007-09-18 | 2007-12-06 | 58d? | start no earlier than 2007-09-18 | S1 | 464h | 464h | TMMTEL7 |  |  | Rel-7 | Alain | TMMTEL7 |  |  | 37 |  |  |
| 7756 | 2537 | **Maintenance of TISPAN release 1 common IMS** |  | 258.75d? | 2007-07-02 A | 2008-03-07 A | 100% | 2007-07-02 | 2008-03-07 | 180d? |  | S2 | 5808h | 5808h | MCIMSTR1 | Ericsson | Raymond Forbes | Rel-7 | Maurice | MCIMSTR1 |  | 21 | 38 |  |  |
| 7757 | 2537.1 | SA1 aspects of MCIMSTR1 |  | 58d? | 2007-09-18 A | 2007-12-06 A | 100% | 2007-09-18 | 2007-12-06 | 58d? | finish no earlier than 2007-12-06 | S1 | 464h | 464h | MCIMSTR1-S1 | Telecom Italia | Marco.DeLuca1@telecomitalia.it | Rel-7 | Alain | MCIMSTR1-S1 |  | 21 | 38 |  |  |
| 7758 | 2537.2 | SA2 aspects of MCIMSTR1 |  | 58d? | 2007-09-18 A | 2007-12-06 A | 100% | 2007-09-18 | 2007-12-06 | 58d? | finish no earlier than 2007-12-06 | S2 | 464h | 464h | MCIMSTR1-S2 | Ericsson | Raymond Forbes | Rel-7 | Maurice | MCIMSTR1-S2 |  | 21 | 38 |  |  |
| 7759 | 2537.3 | SA1,SA2 part of Maintenance of TISPAN release 1 common IMS |  | 114d? | 2007-07-02 A | 2007-12-06 A | 100% | 2007-07-02 | 2007-12-06 | 114d? | finish no earlier than 2007-12-06 | S2; S1 | 1824h | 1824h | IMS_Comm_Mtce7 | BT, Ericsson | Dick Knight, Raymond Forbes | Rel-7 | Maurice | IMS_Comm_Mtce7 |  | 21 | 38 |  |  |
| 7760 | 2537.4 | Maintenance of TISPAN R1 |  | 86d? | 2007-11-09 A | 2008-03-07 A | 100% | 2007-11-09 | 2008-03-07 | 86d? | start no earlier than 2007-11-09 | C1; C3; C4 | 2064h | 2064h | MAINT_R1 | Alcatel-Lucent | Keith Drage (drage@alcatel-lucent.com) | Rel-7 | Frederic | MAINT_R1 |  | 21 | 38 |  |  |
| 7761 | 2538 | **PS domain and IMS impacts for supporting IMS Emergency calls (EMC1)** |  | 4245.75d? | 2000-09-18 A | 2011-12-09 A | 100% | 2000-09-18 | 2011-12-09 | 2934d? |  | S2; S1; C1; C4; IETF | 185422h | 185422h | EMC1 | Siemens | Rainer Liebhart | Rel-7 | Maurice | EMC1 |  |  |  |  | Public Safety (I-A) |
| 7762 | 10.1.1 | Service Requirements for IP-based emergency calls |  | 985d | 2000-09-18 A | 2004-06-25 A | 100% | 2000-09-18 | 2004-06-25 | 985d | finish no earlier than 2004-06-25 | S1 | 7880h | 7880h | EMC1 | Siemens | Rainer Liebhart | Rel-7 | Alain |  |  |  |  |  | Public Safety (I-A) |
| 7763 | 2538.2 | Study on Stage 2 for IMS-level solution |  | 668d? | 2003-02-26 A | 2005-09-16 A | 100% | 2003-02-26 | 2005-09-16 | 668d? | finish no earlier than 2005-09-16 | S2 | 5344h | 5344h | EMC1 | Siemens | Rainer Liebhart | Rel-7 | Maurice |  |  |  |  |  | Public Safety (I-A) |
| 7764 | 2538.3 | Study on Stage 2 for GPRS-level solution |  | 301d? | 2004-10-14 A | 2005-12-08 A | 100% | 2004-10-14 | 2005-12-08 | 301d? | finish no earlier than 2005-12-08 | S2 | 2408h | 2408h | EMC1 | Siemens | Rainer Liebhart | Rel-7 | Maurice |  |  |  |  |  | Public Safety (I-A) |
| 7765 | 2538.4 | Stage 2 Specification Phase - IMS-level |  | 200d? | 2005-09-05 A | 2006-06-09 A | 100% | 2005-09-05 | 2006-06-09 | 200d? | finish no earlier than 2006-06-09 | S2 | 1600h | 1600h | EMC1 | Siemens | Rainer Liebhart | Rel-7 | Maurice |  |  |  |  |  | Public Safety (I-A) |
| 7766 | 2538.5 | Deleted - Stage 2 Specification Phase - GPRS-level | milestone | 0d? | 2007-03-02 A | 2007-03-02 A | 100% | 2007-03-02 | 2007-03-02 | 0d? | start no earlier than 2007-03-02 | S2 |  |  | EMC1 | Siemens | Rainer Liebhart | Rel-7 | Maurice |  | SP-32 |  |  |  | Public Safety (I-A) |

Notes:
- 7738: WID approved SP#28. WID updated SP#32
- 7739: - / Impacted TSs and TRs: 23.816
- 7740: - / Impacted TSs and TRs: 22.228; 23.228; 23.203
- 7741: CP#32 approved WID / Impacted TSs and TRs: 23.218; 24.229
- 7742: - / Impacted TSs and TRs: 32.260; 32.298; 32.299
- 7743: SP#29 approved WID
- 7744: Abandoned
- 7745: SP#29 approved WID / Impacted TSs and TRs: 22.228; 23.228; 23.218; 24.229
- 7746: CP#32 approved WID / Impacted TSs and TRs: 24.229
- 7747: -
- 7748: - / Impacted TSs and TRs: 22.173
- 7749: - / Impacted TSs and TRs: 24.173
- 7750: - / Impacted TSs and TRs: 26.114
- 7751: tested: REL-7 SA/CT WI MTSI;1/1/16: Compl:0%->5%¦22/3/16: Compl:5%->15%1/7/16: Compl:15%->30% ¦21
- 7752: tested: REL-7 WI MTSI¦1/1/16: Compl:0%->5%1/1/16: WID: RP-151334->RP-15177022/3/16: Compl:5%->10%
- 7753: - / Impacted TSs and TRs: 22.173
- 7754: RP#43 completed. Linked UID_7038 (MTSI) / Impacted TSs and TRs: 34.123-1; 34.123-2; 34.123-3; 34.229-1; 34.229-2
- 7755: - / Impacted TSs and TRs: 22.273 (EI 181 002 maintenance)
- 7756: - / Impacted TSs and TRs: http://www.3gpp.org/specs/TISPAN-IMS-ansfer.htm
- 7757: - / Impacted TSs and TRs: 22.173; 22.273
- 7758: - / Impacted TSs and TRs: 23.406; 23.417; 23.508.23.509; 23.511
- 7759: SP#38 completed / Impacted TSs and TRs: 22.173; 22.273; 22.401; 23.406; 23.417; 23.508; 23.509; 23.511
- 7760: CP#39 completed / Impacted TSs and TRs: 24.404; 24.405; 24.406; 24.407; 24.408; 24.410; 24.411; 24.416; 29.421; 24.423; 24.428; 24.429; 29.433; 24.441; 24.403; 29.427; 24.430; 29.412
- 7761: - / Impacted TSs and TRs: EMC1
- 7762: - / Impacted TSs and TRs: 22.101
- 7763: - / Impacted TSs and TRs: 23.867
- 7764: - / Impacted TSs and TRs: 23.867
- 7765: - / Impacted TSs and TRs: 23.060; 23.167; 23.203; 23.221; 23.228; 23.234; 23.271; 23.406
- 7766: -

| ID | WBS | Task | Type | Duration | Start | Finish | Complete | Baseline start | Baseline finish | Baseline duration | Constraint | Resources | Work | Actual work | Acronym | WI rapporteur name | WI rapporteur e-mail | Release | MCC resp | Special Focus Doc | Impacted TSs and TRs | PCG approved | TSG approved | TSG stopped | Acronym_3GU_Export | Created at | Status Report |
| --- | --- | --- | --- | --- | --- | --- | --- | --- | --- | --- | --- | --- | --- | --- | --- | --- | --- | --- | --- | --- | --- | --- | --- | --- | --- | --- | --- |
| 7767 | 10.1 | **Emergency Call Enhancements for IP& PS Based Calls – stage 3** |  | 2237.5d? | 2006-01-09 A | 2011-12-09 A | 100% | 2006-01-09 | 2011-12-09 | 1549d? |  | C1; C4; IETF | 50829.8h | 50829.8h | EMC1 | Ericsson | alf.heidermark@ericsson.com | Rel-7 | Frederic | Public Safety (I-A) |  |  |  |  |  |  |  |
| 7768 | 10.1.2 | CT1 IMS aspects to support IMS Emergency sessions |  | 350.82d | 2006-01-09 A | 2007-06-15 A | 100% | 2006-01-09 | 2007-06-15 | 350.82d | finish no earlier than 2007-06-15 | C1 | 2806.56h | 2806.56h | EMC1 | Ericsson | alf.heidermark@ericsson.com | Rel-7 | Frederic | Public Safety (I-A) | 24.229 |  |  |  |  |  |  |
| 7769 | 2538.6.2 | (IETF) CT1 IMS aspects to support IMS Emergency sessions |  | 452d? | 2006-01-09 A | 2011-12-09 A | 100% | 2006-01-09 | 2011-12-09 | 452d? | finish no earlier than 2011-12-09 | C1-IETF | 3608h | 3608h | EMC1 | Keith Drage |  | Rel-7 | Frederic | Public Safety (I-A) | RFC 6442 (was draft-ietf-sipcore-location-conveyance) | 27 | 52 |  |  |  |  |
| 7770 | 10.1.2 | Deleted - CT3 IMS aspects to support IMS Emergency sessions |  | 95d | 2006-05-08 A | 2006-09-15 A | 100% | 2006-05-08 | 2006-09-15 | 95d | finish no earlier than 2006-09-15 | C3 | 760h | 760h | EMC1 | Ericsson | alf.heidermark@ericsson.com | Rel-7 | Adrian | Public Safety (I-A) | 29.163 |  |  | CP-33 |  |  |  |
| 7771 | 10.1.5 | Deleted - CT3 PS domain aspects to support IMS Emergency sessions |  | 95d | 2006-05-08 A | 2006-09-15 A | 100% | 2006-05-08 | 2006-09-15 | 95d | start no earlier than 2006-05-08 | C3 | 760h | 760h | EMC1 | Ericsson | alf.heidermark@ericsson.com | Rel-7 | Adrian | Public Safety (I-A) | 29.061 |  |  | CP-33 |  |  |  |
| 7772 | 10.1.5 | CT1 PS domain aspects to support IMS Emergency sessions |  | 349.9d | 2006-01-09 A | 2007-06-15 A | 100% | 2006-01-09 | 2007-06-15 | 349.9d | finish no earlier than 2007-06-15 | C1 | 2799.2h | 2799.2h | EMC1 | Ericsson | alf.heidermark@ericsson.com | Rel-7 | Frederic | Public Safety (I-A) | 24.008; 24.234 |  |  |  |  |  |  |
| 7773 | 10.1.5 | CT4 PS domain aspects to support IMS Emergency sessions |  | 365d | 2006-01-09 A | 2007-06-01 A | 100% | 2006-01-09 | 2007-06-01 | 365d | finish no earlier than 2007-06-01 | C4 | 2920h | 2920h | EMC1-GPRSc4 | Ericsson | alf.heidermark@ericsson.com | Rel-7 | Kimmo | Public Safety (I-A) | 29.060 |  |  |  | EMC1-GPRSc4 |  |  |
| 7774 | 2539 | IMS Support of Conferencing |  | 355d? | 2005-11-04 A | 2007-03-15 A | 100% | 2005-11-04 | 2007-03-15 | 355d? | finish no earlier than 2007-03-15 | C1 | 2840h | 2840h | IMSconf | Alcatel-Lucent | Keith Drage (drage@alcatel-lucent.com) | Rel-7 | Frederic |  | 24.147; 24.229 |  |  |  | IMSconf |  |  |
| 7775 | 2540 | Performance Characterization of VoIMS over HSDPA\EUL channels |  | 713d? | 2005-03-15 A | 2007-12-06 A | 100% | 2005-03-15 | 2007-12-06 | 713d? | finish no earlier than 2007-12-06 | S4 | 5704h | 5704h | VoIMS-PCVoIMS | Alcatel-Lucent | mcgowan@alcatel-lucent.com | Rel-7 | Paolo |  | 26.935 |  |  |  | VoIMS-PCVoIMS |  |  |
| 7776 | 2541 | **WLAN-UMTS Interworking Phase 2** |  | 537.5d? | 2004-01-05 A | 2005-06-07 A | 100% | 2004-01-05 | 2005-06-07 | 371d? |  | S1; S2 | 6856h | 6856h | WLAN2 | Telenor | frederic.paint@telenor.com | Rel-7 | Alain | WLAN | 33.234 (SP-36 SA3 CRs approved) |  |  |  | WLAN2, WLAN-SC |  |  |
| 7777 | 2541.1 | Stage 1 on Session Continuity |  | 115d? | 2004-01-05 A | 2004-06-11 A | 100% | 2004-01-05 | 2004-06-11 | 115d? | start no earlier than 2004-01-05 | S1 | 920h | 920h | WLAN2 |  |  | Rel-7 | Alain | WLAN | 22.234 |  |  |  |  | SP-24 |  |
| 7778 | 2541.2 | Stage 2 on Session Continuity: covered by SAE | milestone | 0d? | 2005-06-07 A | 2005-06-07 A | 100% | 2005-06-07 | 2005-06-07 | 0d? | finish no earlier than 2005-06-07 | S2 |  |  | WLAN2 |  |  | Rel-7 | Maurice | WLAN |  |  |  |  |  |  |  |
| 7779 | 2542 | **WLAN Interworking – Private Network access from WLAN 3GPP IP Access** |  | 364.5d? | 2005-10-10 A | 2006-09-26 A | 100% | 2005-10-10 | 2006-09-26 | 252d? |  | S2; C1; C3; C4 | 17704h | 17704h | WLANPNA | NEC | Toshiyuki Tamura (tamurato@aj.jp.nec.com) | Rel-7 | Maurice | WLAN |  |  |  |  | WLANPNA |  |  |
| 7780 | 2542.1 | WLAN-PNA - Stage 2 |  | 185d? | 2005-10-10 A | 2006-06-23 A | 100% | 2005-10-10 | 2006-06-23 | 185d? | start no earlier than 2005-10-10 | S2 | 1480h | 1480h | WLANPNA-st2 | NEC | Toshiyuki Tamura (tamurato@aj.jp.nec.com) | Rel-7 | Maurice | WLAN | 23.234; 33.234 |  |  |  | WLANPNA-st2 |  |  |
| 7781 | 2542.2 | **WLAN-PNA - Stage 3** |  | 246.5d? | 2006-02-01 A | 2006-09-26 A | 100% | 2006-02-01 | 2006-09-26 | 170d? |  | C1; C3; C4 | 8160h | 8160h | WLANPNA-st3 | NEC |  | Rel-7 | Frederic | WLAN |  |  |  |  | WLANPNA-st3 |  |  |
| 7782 | 2542.2.1 | CT1 aspets for WLAN-PNA |  | 170d? | 2006-02-01 A | 2006-09-26 A | 100% | 2006-02-01 | 2006-09-26 | 170d? | start no earlier than 2006-02-01 | C1 | 1360h | 1360h | WLANPNA-st3 | NEC |  | Rel-7 | Frederic | WLAN | 24.234 |  |  |  |  |  |  |
| 7783 | 2542.2.2 | CT3 aspets for WLAN-PNA |  | 170d? | 2006-02-01 A | 2006-09-26 A | 100% | 2006-02-01 | 2006-09-26 | 170d? | start no earlier than 2006-02-01 | C3 | 1360h | 1360h | WLANPNA-st3 | NEC |  | Rel-7 | Adrian | WLAN | 29.161 |  |  |  |  |  |  |
| 7784 | 2542.2.3 | Deleted - CT4 aspets for WLAN-PNA |  | 170d? | 2006-02-01 A | 2006-09-26 A | 100% | 2006-02-01 | 2006-09-26 | 170d? | start no earlier than 2006-02-01 | C4 | 1360h | 1360h | WLANPNA-st3 | NEC |  | Rel-7 | Kimmo | WLAN | 29.234 |  |  | CP-32 |  |  |  |
| 7785 | 2543 | **Enhancements to support QoS provisioning over 3GPP/WLAN Interworking** |  | 751.75d? | 2005-03-14 A | 2007-03-09 A | 100% | 2005-03-14 | 2007-03-09 | 520d? |  | S2; C4; C1 | 16680h | 16680h | WLANQOS | Samsung |  | Rel-7 | Maurice | WLAN |  |  |  |  | WLANQOS |  |  |
| 7786 | 2543.1 | Deleted - TR on support of QoS on WLAN |  | 232d? | 2005-03-14 A | 2006-01-31 A | 100% | 2005-03-14 | 2006-01-31 | 232d? | start no earlier than 2005-03-14 | S2 | 1856h | 1856h | WLANQOS | Samsung |  | Rel-7 | Maurice | WLAN | 23.836 |  |  | SP-32 |  |  |  |
| 7787 | 2543.2 | Stage 2 on support of QoS over 3GPP/WLAN interworking |  | 108d? | 2006-02-01 A | 2006-06-30 A | 100% | 2006-02-01 | 2006-06-30 | 108d? | start no earlier than 2006-02-01 | S2 | 864h | 864h | WLANQOS | Samsung |  | Rel-7 | Maurice | WLAN | 23.234 |  |  |  |  |  |  |
| 7788 | 2543.3 | Stage 3 CT4 on support of QoS over 3GPP/WLAN Interworking |  | 121d? | 2006-09-22 A | 2007-03-09 A | 100% | 2006-09-22 | 2007-03-09 | 121d? | finish no earlier than 2007-03-09 | C4 | 968h | 968h | WLANQOS | Huawei | zhang.peng@huawei.com | Rel-7 | Kimmo | WLAN | 29.234; 23.008 |  |  |  |  |  |  |
| 7789 | 2543.4 | Stage 3 CT1 on support of QoS over 3GPP/WLAN Interworking |  | 64d? | 2006-09-04 A | 2006-11-30 A | 100% | 2006-09-04 | 2006-11-30 | 64d? | finish no earlier than 2006-11-30 | C1 | 512h | 512h | WLANQOS | Huawei | zhang.peng@huawei.com | Rel-7 | Frederic | WLAN | 24.234 |  | 34 |  |  |  |  |
| 7790 | 2544 | **Location Services enhancements** |  | 1313.25d? | 2004-06-28 A | 2007-12-17 A | 100% | 2004-06-28 | 2007-12-17 | 906d? |  | S1; S2; GP; C4; R2 | 81525.6h | 81525.6h | LCS3 |  |  | Rel-7 | Alain |  |  |  |  |  | LCS3 |  |  |
| 7791 | 2544.1 | Stage 2 for LCS3 (including IMS emergency location aspects) |  | 446d? | 2004-12-31 A | 2006-09-15 A | 100% | 2004-12-31 | 2006-09-15 | 446d? | finish no earlier than 2006-09-15 | S2 | 3568h | 3568h | LCS3 | SiRF | brodilitz@sirf.com | Rel-7 | Maurice |  | 23.271 |  |  |  |  |  |  |
| 7792 | 2544.2 | LCS Enhancements related to Location-Based Services |  | 695d? | 2005-01-03 A | 2007-08-31 A | 100% | 2005-01-03 | 2007-08-31 | 695d? | finish no earlier than 2007-08-31 | GP | 5560h | 5560h | LCS3-LBS | SiRF | kjudge@sirf.com | Rel-7 | Paolo |  | 43.059; 44.031; 48.008; 49.031 |  |  |  | LCS3-LBS |  |  |
| 7793 | 2544.3 | CT4 aspects for LCS UEPos-LBS |  | 240d? | 2006-01-02 A | 2006-12-01 A | 100% | 2006-01-02 | 2006-12-01 | 240d? | finish no earlier than 2006-12-01 | C4 | 1920h | 1920h | LCS3-UEPos-LBS | SiRF | brodilitz@sirf.com | Rel-7 | Kimmo |  | 24.030; 24.080; 29.002 |  |  |  | LCS3-UEPos-LBS |  |  |
| 7794 | 2544.4 | UE positioning - Velocity |  | 394d? | 2005-03-15 A | 2006-09-15 A | 100% | 2005-03-15 | 2006-09-15 | 394d? | finish no earlier than 2006-09-15 | R2 | 3152h | 3152h | LCS3-UEPos-Velocity | SiRF | BRodilitz@SiRF.com | Rel-7 | Yong-Jun |  | 25.305; 25.331; 25.410; 25.413; 25.453 |  |  |  | LCS3-UEPos-Velocity |  | RP-060459 |
| 7795 | 2544.5 | Inclusion of Uplink TDOA UE positioning method in the UTRAN specifications |  | 849d? | 2004-09-15 A | 2007-12-17 A | 100% | 2004-09-15 | 2007-12-17 | 849d? | finish no earlier than 2007-12-17 | R2 | 6792h | 6792h | LCS3-UEPos-UTDOA | TruePosition | Robert Gross (rgross@polariswireless.com) | Rel-7 | Yong-Jun |  | 25.305; 25.453; new 25.111 |  |  |  | LCS3-UEPos-UTDOA |  | RP-070797 |

Notes:
- 7767: -
- 7768: -
- 7769: CP#54 completed
- 7770: Cancelled for Rel-7 and there is no corresponding Rel-8 WI
- 7771: Cancelled for Rel-7 and there is no corresponding Rel-8 WI
- 7772: -
- 7773: -
- 7774: CP#35 revised WID
- 7775: -
- 7776: Created at SP#27 because of WLAN items belonging to Rel-7. Acronym changed from "WLAN2, WLAN-SC"
- 7777: Acronym changed from "WLAN2, WLAN-SC"
- 7778: Acronym changed from "WLAN2, WLAN-SC"
- 7779: -
- 7780: Approved at SP#29
- 7781: Approved at CP#29
- 7782: Approved at CP#29
- 7783: Approved at CP#29
- 7784: CT4#31¦no impacts identified, therefore completed. CP-32 stopped
- 7785: Moved from FS section Feb 06. SP-30 updated WID
- 7786: SP#32 stopped
- 7787: SP#30 updated WID
- 7788: CP#33 approved WID
- 7789: CP#33 approved WID
- 7790: -
- 7791: SP#27 approved WID
- 7792: -
- 7793: -
- 7794: -
- 7795: -

| ID | WBS | Task | Duration | Start | Finish | Complete | Baseline start | Baseline finish | Baseline duration | Constraint | Resources | Work | Actual work | Acronym | WI rapporteur name | WI rapporteur e-mail | Release | MCC resp | Special Focus Doc | Acronym_3GU_Export | TSG stopped | TSG approved | Status Report | PCG approved |
| --- | --- | --- | --- | --- | --- | --- | --- | --- | --- | --- | --- | --- | --- | --- | --- | --- | --- | --- | --- | --- | --- | --- | --- | --- |
| 7796 | 2544.6 | **LCS for 3GPP Interworking WLAN** | 1012.75d? | 2004-06-28 A | 2007-03-02 A | 100% | 2004-06-28 | 2007-03-02 | 700d? |  | S1; S2 | 17501.6h | 17501.6h | LCS3-IWLAN | Telcordia | Mike Loushine | Rel-7 | Alain | WLAN | LCS3-IWLAN |  |  |  |  |
| 7797 | 2544.6.1 | FS on 3GPP system to WLAN Interworking with LCS | 512.7d? | 2004-06-28 A | 2006-06-30 A | 100% | 2004-06-28 | 2006-06-30 | 512.7d? | finish no earlier than 2005-09-29 | S1 | 4101.6h | 4101.6h | LCS3-IWLAN-FSs1 | Telcordia | Mike Loushine | Rel-7 | Alain |  | LCS3-IWLAN-FSs1 |  |  |  |  |
| 7798 | 2544.6.2 | Deleted - Study of work on an LCS architecture for I-WLAN. | 180d? | 2006-06-26 A | 2007-03-02 A | 100% | 2006-06-26 | 2007-03-02 | 180d? | finish no earlier than 2007-03-02 | S2 | 1440h | 1440h | LCS3-IWLAN-FSs2 | LG Electronics | dhshim@lge.com ; phede@lge.com | Rel-7 | Maurice |  | LCS3-IWLAN-FSs2 | SP-35 |  |  |  |
| 7799 | 2544.6.3 | Stage 2 for LCS architecture for I-WLAN | 95d? | 2006-10-23 A | 2007-03-02 A | 100% | 2006-10-23 | 2007-03-02 | 95d? | finish no earlier than 2007-03-02 | S2 | 760h | 760h | LCS3-IWLAN | LG Electronics | dhshim@lge.com ; phede@lge.com | Rel-7 | Maurice |  | LCS3-IWLAN |  | 34 |  |  |
| 7800 | 2544.7 | Deleted - UE positioning Rel-7 | 849d? | 2004-09-15 A | 2007-12-17 A | 100% | 2004-09-15 | 2007-12-17 | 849d? |  | RP | 6792h | 6792h | LCS3-UEpos |  |  | Rel-7 | Yong-Jun |  | LCS3-UEpos | RP-38 |  |  |  |
| 7801 | 2545 | **MBMS Enhancements** | 904d? | 2005-07-11 A | 2007-11-30 A | 100% | 2005-07-11 | 2007-11-30 | 625d? |  | S1; R1; C3 | 20844.6h | 20844.6h | MBMSE | China Mobile | liuhongyfw@chinamobile.com | Rel-7 | Alain |  | MBMSE |  |  |  |  |
| 7802 | 2545.1 | Stage 1 of MBMSE | 109d? | 2005-07-11 A | 2005-12-08 A | 100% | 2005-07-11 | 2005-12-08 | 109d? | finish no earlier than 2005-12-08 | S1 | 872h | 872h | MBMSE | China Mobile | liuhongyfw@chinamobile.com | Rel-7 | Alain |  |  |  | 34 |  |  |
| 7803 | 2545.2 | MBMS FDD Physical layer Enhancements | 117.29d? | 2006-12-15 A | 2007-06-04 A | 100% | 2006-12-15 | 2007-06-04 | 117.29d? | finish no earlier than 2007-06-04 | R1 | 938.32h | 938.32h | MBMSE-RANPhysFDD | Ericsson | Lars.Lindbom@ericsson.com | Rel-7 | Patrick |  | MBMSE-RANPhysFDD |  | 34 | RP-070290 |  |
| 7804 | 2545.3 | MBMS TDD Physical layer Enhancements | 117.29d? | 2006-12-15 A | 2007-06-04 A | 100% | 2006-12-15 | 2007-06-04 | 117.29d? | finish no earlier than 2007-06-04 | R1 | 938.32h | 938.32h | MBMSE-RANPhysTDD | IPWireless | Nicholas Anderson | Rel-7 | Patrick |  | MBMSE-RANPhysTDD |  | 34 | RP-070291 |  |
| 7805 | 2545.4 | MBMS Low Chip Rate TDD Physical Layer Enhancement | 127d? | 2007-03-16 A | 2007-09-10 A | 100% | 2007-03-16 | 2007-09-10 | 127d? | finish no earlier than 2007-09-10 | R1 | 1016h | 1016h | MBMSE-RANPhysLCRTDD | RITT | Lin Hui | Rel-7 | Patrick |  | MBMSE-RANPhysLCRTDD |  |  | RP-070292 |  |
| 7806 | 2545.5 | MBMS Mz interface | 260d? | 2006-12-04 A | 2007-11-30 A | 100% | 2006-12-04 | 2007-11-30 | 260d? | finish no earlier than 2007-05-11 | C3 | 2080h | 2080h | MBMSMz | Huawei | Deng Tingting (ttdeng@huawei.com) | Rel-7 | Adrian |  | MBMSMz |  | 34 |  |  |
| 7807 | 2546 | **MBMS - UE Conformance Testing** | 950.62d? | 2007-06-01 A | 2009-12-04 A | 100% | 2007-06-01 | 2009-12-04 | 657d? |  | R5 | 13848h | 13848h | MBMSE_UEConTest |  |  | Rel-7 | Ingbert |  | MBMSE_UEConTest |  | 40 |  | 21 |
| 7808 | 2546.1 | Conformance Test Aspects – MBMS TDD Physical layer Enhancements – MBSFN for HCR and VHCR TDD | 336d? | 2007-06-01 A | 2008-09-12 A | 100% | 2007-06-01 | 2008-09-12 | 336d? | start no earlier than 2007-06-01 | R5 | 2688h | 2688h | MBMSE-RANPhysTDD_UEConTest | IPWireless | tspeight@ipwireless.com | Rel-7 | Ingbert |  | MBMSE-RANPhysTDD_UEConTest |  |  | RP-080541 |  |
| 7809 | 2546.2 | Conformance Test Aspects – MBMS LCR TDD Physical Layer Enhancement | 342d? | 2008-05-30 A | 2009-09-18 A | 100% | 2008-05-30 | 2009-09-18 | 342d? | finish no earlier than 2009-09-18 | R5 | 2728h | 2728h | MBMSE-RANPhysLCRTDD_UEConTest | CATT | chenxiaozhong@datangmobile.cn | Rel-7 | Ingbert |  | MBMSE-RANPhysLCRTDD_UEConTest |  | 40 | RP-090715 | 21 |
| 7810 | 2546.3 | Conformance Test Aspects – MBSFN for FDD | 397d? | 2008-05-30 A | 2009-12-04 A | 100% | 2008-05-30 | 2009-12-04 | 397d? | finish no earlier than 2009-12-04 | R5 | 3176h | 3176h | MBMSE-UEConTest_RANPhysFDD | Huawei | Xiang Li (trica_li@huawei.com) | Rel-7 | Ingbert |  | MBMSE-UEConTest_RANPhysFDD |  | 40 | RP-091214 | 21 |
| 7811 | 2547 | MBMS User Service Extensions | 392d? | 2005-12-07 A | 2007-06-07 A | 100% | 2005-12-07 | 2007-06-07 | 392d? | finish no earlier than 2007-06-07 | S4 | 3136h | 3136h | MBMSUSE | Ericsson | Thorsten.Lohmar@ericsson.com | Rel-7 | Paolo |  | MBMSUSE |  |  |  |  |
| 7812 | 2548 | **Advanced Global Navigation Satellite System (AGNSS) concept** | 1201.25d? | 2004-06-28 A | 2007-08-31 A | 100% | 2004-06-28 | 2007-08-31 | 830d? |  | S1; S2; GP; R2 | 36129.6h | 36129.6h | LCS3-AGNSS | Alcatel | Michel.monnerat@thalesaleniaspace.com | Rel-7 | Alain |  | LCS3-AGNSS |  |  |  |  |
| 7813 | 2548.1 | Stage 1/2 for Towards AGNSS Concept | 1d? | 2007-02-16 A | 2007-02-16 A | 100% | 2007-02-16 | 2007-02-16 | 1d? | start no earlier than 2007-02-16 | S1; S2 | 16h | 16h | AGNSS | Alcatel | richard.couty@space.alcatel.fr | Rel-7 | Alain |  | AGNSS |  |  |  |  |
| 7814 | 2548.2 | Towards AGNSS Concept | 811.2d? | 2004-06-28 A | 2007-08-31 A | 100% | 2004-06-28 | 2007-08-31 | 811.2d? | finish no earlier than 2007-08-31 | GP | 6489.6h | 6489.6h | AGNSS-GP | Alcatel | richard.couty@space.alcatel.fr | Rel-7 | Paolo |  | AGNSS-GP |  |  |  |  |
| 7815 | 2548.3 | Global Navigation Satellite System (GNSS) in UTRAN | 383d? | 2005-12-15 A | 2007-06-04 A | 100% | 2005-12-15 | 2007-06-04 | 383d? | finish no earlier than 2007-06-04 | R2 | 3064h | 3064h | LCS3-GNSS-UTRAN | France Telecom | alain.abinakhoul@francetelecom.com | Rel-7 | Yong-Jun |  | LCS3-GNSS-UTRAN |  |  | RP-070482 |  |
| 7816 | 2549 | A-GPS Minimum Performance | 351d? | 2006-04-28 A | 2007-08-31 A | 100% | 2006-04-28 | 2007-08-31 | 351d? | finish no earlier than 2007-08-31 | G1; G3 | 5616h | 5616h | GAGR | Spirent | richard.catmur@spirentcom.com | Rel-7 | Paolo |  | GAGR |  |  |  |  |
| 7817 | 2550 | **Unstructured Supplementary Service Data (USSD) message delivery and transfer to USIM** | 544.75d? | 2004-03-05 A | 2005-08-12 A | 100% | 2004-03-05 | 2005-08-12 | 376d? |  | S1; C6 | 8778.4h | 8778.4h | USSD-USIM | Axalto | Christophe Dubois (cdubois@axalto.com) | Rel-7 | Alain |  | USSD-USIM |  |  |  |  |
| 7818 | 2550.1 | Stage 1 for USSD message delivery and transfer to USIM | 152d? | 2004-03-18 A | 2004-10-15 A | 100% | 2004-03-18 | 2004-10-15 | 152d? | start no earlier than 2004-03-18 | S1 | 1216h | 1216h | USSD-USIM | Axalto | Christophe Dubois (cdubois@axalto.com) | Rel-7 | Alain |  |  |  |  |  |  |
| 7819 | 2550.2 | Alignment with requirements regarding USSD usage | 193.3d? | 2004-03-05 A | 2005-08-12 A | 100% | 2004-03-05 | 2005-08-12 | 193.3d? | finish no earlier than 2005-08-12 | C6 | 1546.4h | 1546.4h | USSD-USIM | Axalto | Christophe Dubois (cdubois@axalto.com) | Rel-7 | Xavier |  |  |  |  |  |  |

Notes:
- 7796: -
- 7797: - / Impacted TSs and TRs: new 22.935
- 7798: SP#41 TR withdrawn. All work transferred to specs / Impacted TSs and TRs: 23.837
- 7799: - / Impacted TSs and TRs: 23.234; 23.271; 23.167
- 7800: -
- 7801: -
- 7802: - / Impacted TSs and TRs: 22.146; 22.246; 22.228
- 7803: - / Impacted TSs and TRs: 25.211; 25.212; 25.213; 25.101; 25.104; 25.331; 25.433; 25.346; 25.306
- 7804: - / Impacted TSs and TRs: 25.346; 25.221; 25.222; 25.223; 25.224; 25.306; 25.331; 25.402; 25.433; 25.102; 25.105; 25.123
- 7805: - / Impacted TSs and TRs: 25.346; 25.221; 25.222; 25.223; 25.224; 25.306; 25.331; 25.402; 25.433; 25.102; 25.105; 25.123
- 7806: - / Impacted TSs and TRs: 29.061
- 7807: Linked to Rel-7 Feature UID_31084 (MBMSE)
- 7808: RP#41 completed / Impacted TSs and TRs: 34.108; 34.122; 34.123-1/2/3
- 7809: RP#45 completed / Impacted TSs and TRs: 34.108; 34.123-1
- 7810: RP#46 completed / Impacted TSs and TRs: 34.108; 34.109; 34.121-1; 34.121-2; 34.123-1; 34.123-2; 34.123-3
- 7811: - / Impacted TSs and TRs: 26.346; 26.946
- 7812: -
- 7813: - / Impacted TSs and TRs: 22.071; 23.271
- 7814: GP#36 completed / Impacted TSs and TRs: 43.030; 43.059; 44.031; 44.035; 44.071; 48.008; 48.018; 48.031; 49.031
- 7815: - / Impacted TSs and TRs: 25.305; 25.331; 25.306; 25.413; 25.423; 25.433; 25.453; 25.302; 25.215; 25.401; 25.402; 25.450; 25.452
- 7816: - / Impacted TSs and TRs: 45.005; 51.010
- 7817: -
- 7818: - / Impacted TSs and TRs: 22.090
- 7819: - / Impacted TSs and TRs: 31.111; 31.115; 31.130

| ID | WBS | Task | Type | Duration | Start | Finish | Complete | Baseline start | Baseline finish | Baseline duration | Constraint | Resources | Work | Actual work | Acronym | WI rapporteur name | WI rapporteur e-mail | Release | MCC resp | Acronym_3GU_Export | Impacted TSs and TRs | PCG approved | TSG approved | TSG stopped |
| --- | --- | --- | --- | --- | --- | --- | --- | --- | --- | --- | --- | --- | --- | --- | --- | --- | --- | --- | --- | --- | --- | --- | --- | --- |
| 7820 | 2551 | **Combinational Services** |  | 428.75d? | 2005-01-17 A | 2006-03-06 A | 100% | 2005-01-17 | 2006-03-06 | 296d? |  | S1; S2; C1; S4 | 14648h | 14648h | CSICS | TeliaSonera | Robert.Frank@teliasonera.com | Rel-7 | Alain | CSICS |  |  |  |  |
| 7821 | 2551.1 | Stage 1 for CSICS |  | 104d? | 2005-01-17 A | 2005-06-09 A | 100% | 2005-01-17 | 2005-06-09 | 104d? | start no earlier than 2005-01-17 | S1 | 832h | 832h | CSICS | TeliaSonera | Robert.Frank@teliasonera.com | Rel-7 | Alain |  | 22.279 |  |  |  |
| 7822 | 2551.2 | Stage 2 for CSICS |  | 130d? | 2005-01-17 A | 2005-07-15 A | 100% | 2005-01-17 | 2005-07-15 | 130d? | start no earlier than 2005-01-17 | S2 | 1040h | 1040h | CSICS | TeliaSonera | Robert.Frank@teliasonera.com | Rel-7 | Maurice |  | 23.279 |  |  |  |
| 7823 | 2551.3 | Stage 3 for CSICS CN aspects |  | 221d? | 2005-05-02 A | 2006-03-06 A | 100% | 2005-05-02 | 2006-03-06 | 221d? | finish no earlier than 2006-03-06 | C1 | 1768h | 1768h | CSICS | Vodafone | peter.dawes@vodafone.com | Rel-7 | Frederic |  | 24.879; 24.279; 24.229; 24.008 |  |  |  |
| 7824 | 2551.4 | Stage 3 for codec aspects |  | 192d? | 2005-03-15 A | 2005-12-07 A | 100% | 2005-03-15 | 2005-12-07 | 192d? | finish no earlier than 2005-12-07 | S4 | 1536h | 1536h | CSICS-Codec | Ericsson | Per.Frojdh@ericsson.com | Rel-7 | Paolo | CSICS-Codec | 26.141; 26.235 |  |  |  |
| 7825 | 2552 | **CAMEL Trunk Triggers** |  | 365.75d? | 2004-12-17 A | 2005-12-05 A | 100% | 2004-12-17 | 2005-12-05 | 251d? |  | S1; C4 | 8032h | 8032h | TTCAMEL | Nortel | Amar Deol (deola@nortelnetworks.com) | Rel-7 | Alain | TTCAMEL |  |  |  |  |
| 7826 | 2552.1 | Stage 1 for CAMEL Trunk Triggers |  | 365.75d? | 2004-12-17 A | 2005-12-05 A | 100% | 2004-12-17 | 2005-12-05 | 251d? |  | S1 | 2008h | 2008h | TTCAMEL | Nortel | Amar Deol (deola@nortelnetworks.com) | Rel-7 | Alain |  | 22.078 |  |  |  |
| 7827 | 2552.2 | CAMEL Trunk Originated Trigger Detection Points |  | 251d? | 2004-12-17 A | 2005-12-05 A | 100% | 2004-12-17 | 2005-12-05 | 251d? | start no earlier than 2004-12-17 | C4 | 2008h | 2008h | CamelR7 | Nortel | David Hutton (dhutton@nortel.com) | Rel-7 | Kimmo | CamelR7 |  |  |  |  |
| 7828 | 2553 | **IMS Service Brokering enhancements** |  | 100.5d? | 2005-12-07 A | 2006-03-13 A | 100% | 2005-12-07 | 2006-03-13 | 69d? |  | S1 | 1104h | 1104h | ISB | Telcordia | jbakker@telcordia.com | Rel-7 | Alain | ISB | 22.228 |  |  |  |
| 7829 | 2553.1 | Stage 1 for ISB |  | 69d? | 2005-12-07 A | 2006-03-13 A | 100% | 2005-12-07 | 2006-03-13 | 69d? | finish no earlier than 2006-03-13 | S1 | 552h | 552h | ISB-s1 | Telcordia | jbakker@telcordia.com | Rel-7 | Alain | ISB-s1 | 22.228 |  |  |  |
| 7830 | 2554 | **Enhancements of VGCS for public authority officials** |  | 1059.5d? | 2004-08-27 A | 2007-06-15 A | 100% | 2004-08-27 | 2007-06-15 | 731d? |  | S1; C1; C4; G2 | 49312h | 49312h | EVGCS |  |  | Rel-7 | Alain | EVGCS | 43.068; 44.068; 24.008; 29.002 | 38 | 75 |  |
| 7831 | 2554.1 | Stage 1 for Enhancements of VGCS for public authority officials | milestone | 0d? | 2004-08-27 A | 2004-08-27 A | 100% | 2004-08-27 | 2004-08-27 | 0d? | finish no earlier than 2004-08-27 | S1 |  |  | EVGCS | Siemens | joerg.swetina@neclab.eu | Rel-7 | Alain |  | 42.068; 43.068 |  |  |  |
| 7832 | 2554.2 | **Architecture and protocol aspects** |  | 1059.5d? | 2004-08-27 A | 2007-06-15 A | 100% | 2004-08-27 | 2007-06-15 | 731d? |  | C1; C4 | 20752h | 20752h | EVGCS | Siemens | robert.zaus@nsn.com | Rel-7 | Frederic |  | 43.068; 44.068 |  |  |  |
| 7833 | 2554.2.1 | CT1 aspects of EVGCS |  | 731d? | 2004-08-27 A | 2007-06-15 A | 100% | 2004-08-27 | 2007-06-15 | 731d? | finish no earlier than 2006-09-15 | C1 | 5848h | 5848h | EVGCS | Siemens | robert.zaus@nsn.com | Rel-7 | Frederic |  | 43.068; 44.068; 24.008 |  |  |  |
| 7834 | 2554.2.2 | CT4 aspects of EVGCS |  | 401d? | 2004-08-27 A | 2006-03-10 A | 100% | 2004-08-27 | 2006-03-10 | 401d? | finish no earlier than 2006-03-10 | C4 | 3208h | 3208h | EVGCS | Siemens | robert.zaus@nsn.com | Rel-7 | Kimmo |  | 29.002 |  |  |  |
| 7835 | 2554.3 | GERAN2 aspects of EVGCS |  | 646d? | 2004-08-27 A | 2007-02-16 A | 100% | 2004-08-27 | 2007-02-16 | 646d? | finish no earlier than 2007-02-16 | G2 | 5168h | 5168h | EVGCS | Siemens | kenneth.isaacs@roke.co.uk | Rel-7 | Gert |  |  | 38 | 75 |  |
| 7836 | 2555 | **Improvements of VGCS for parallel use of services** |  | 757d? | 2005-03-15 A | 2007-03-15 A | 100% | 2005-03-15 | 2007-03-15 | 523d? |  | S1 | 12230.2h | 12230.2h | IVGCS |  |  | Rel-7 | Alain | IVGCS |  |  |  |  |
| 7837 | 2555.1 | Service Requirements for VGCS improvements |  | 62d? | 2005-03-15 A | 2005-06-08 A | 100% | 2005-03-15 | 2005-06-08 | 62d? | finish no earlier than 2005-06-08 | S1 | 496h | 496h | IVGCS | T-Mobile | kurt.bischinger@t-mobile.at | Rel-7 | Alain |  | 42.068 |  |  |  |
| 7838 | 2555.2 | Stage 2 modifications for VGCS improvements |  | 335d? | 2005-12-01 A | 2007-03-14 A | 100% | 2005-12-01 | 2007-03-14 | 335d? | start no earlier than 2005-12-01 | C1 | 2680h | 2680h | IVGCS | T-Mobile | kurt.bischinger@t-mobile.at | Rel-7 | Frederic |  | 43.068 |  |  |  |
| 7839 | 2555.3 | **Protocol aspects** |  | 486.75d? | 2005-12-01 A | 2007-03-15 A | 100% | 2005-12-01 | 2007-03-15 | 336d? |  | C1 | 5376h | 5376h | IVGCS | T-Mobile | Dieter Jacobsohn | Rel-7 | Frederic |  | 44.068 |  |  |  |
| 7840 | 2555.3.1 | CT1 aspects of IVGCS |  | 336d? | 2005-12-01 A | 2007-03-15 A | 100% | 2005-12-01 | 2007-03-15 | 336d? | finish no earlier than 2007-03-15 | C1 | 2688h | 2688h | IVGCS | T-Mobile |  | Rel-7 | Frederic |  | 43.068; 44.068 |  |  |  |
| 7841 | 2555.3.2 | Deleted - CT4 aspects of IVGCS | milestone | 0d? | 2007-03-09 A | 2007-03-09 A | 100% | 2007-03-09 | 2007-03-09 | 0d? | finish no earlier than 2007-03-09 | C4 |  |  | IVGCS-St3-c4 | T-mobile |  | Rel-7 | Kimmo | IVGCS-St3-c4 | 29.002 |  |  | CP-35 |
| 7842 | 2556 | **Open Service Access (OSA) Rel-7** |  | 845d? | 2005-03-15 A | 2007-06-08 A | 100% | 2005-03-15 | 2007-06-08 | 584d? |  | S1; C5 | 29776h | 29776h | OSA7 | AePONA | eamonn.murray@aepona.com | Rel-7 | Alain | OSA7 |  |  |  |  |
| 7843 | 2556.1 | **OSA Service Broker** |  | 649.25d? | 2005-03-15 A | 2006-12-01 A | 100% | 2005-03-15 | 2006-12-01 | 449d? |  | S1; C5 | 10176h | 10176h | OSA7-SB | AePONA | eamonn.murray@aepona.com | Rel-7 | Alain | OSA7-SB |  |  |  |  |
| 7844 | 2556.1.1 | Service Requirements for OSA Service Broker |  | 62d? | 2005-03-15 A | 2005-06-08 A | 100% | 2005-03-15 | 2005-06-08 | 62d? | finish no earlier than 2005-06-08 | S1 | 496h | 496h | OSA7 | AePONA | eamonn.murray@aepona.com | Rel-7 | Alain |  | 22.127 |  |  |  |
| 7845 | 2556.1.2 | Stage 2 OSA API Service Brokering |  | 225.75d? | 2006-04-28 A | 2006-12-01 A | 100% | 2006-04-28 | 2006-12-01 | 156d? |  | C5 | 1248h | 1248h | OSA7 | AePONA | damian.oneill@aepona.com | Rel-7 | Kimmo |  | 23.198 |  |  |  |
| 7846 | 2556.1.3 | Stage 3 OSA API Service Brokering |  | 156d? | 2006-04-28 A | 2006-12-01 A | 100% | 2006-04-28 | 2006-12-01 | 156d? | finish no earlier than 2006-12-01 | C5 | 1248h | 1248h | OSA7 | AePONA | damian.oneill@aepona.com | Rel-7 | Kimmo |  | 29.198-16 |  |  |  |

Notes:
- 7820: -
- 7821: -
- 7822: -
- 7823: -
- 7824: -
- 7825: -
- 7826: -
- 7827: -
- 7828: No CR submitted in rel-8 (according to CR database).
- 7829: No Rel-8 changes
- 7830: Moved from Rel-6 UID_50563 Enhancements of VGCS in public networks for communication of public authority officials
- 7831: Voice Group Call Service
- 7832: -
- 7833: -
- 7834: -
- 7835: -
- 7836: Voice Group Call Service
- 7837: -
- 7838: -
- 7839: Previous name (before CT32) was Architecture and protocol aspects
- 7840: -
- 7841: CT4#33 stage 2 solution is still open.
- 7842: -
- 7843: -
- 7844: -
- 7845: -
- 7846: -

| ID | WBS | Task | Type | Duration | Start | Finish | Complete | Baseline start | Baseline finish | Baseline duration | Constraint | Resources | Work | Actual work | Acronym | Impacted TSs and TRs | WI rapporteur name | WI rapporteur e-mail | Release | MCC resp | TSG approved | Acronym_3GU_Export | TSG stopped | Status Report |
| --- | --- | --- | --- | --- | --- | --- | --- | --- | --- | --- | --- | --- | --- | --- | --- | --- | --- | --- | --- | --- | --- | --- | --- | --- |
| 7847 | 2556.2 | **Rel-7 OSA Stage 2/3 enhancements** |  | 421.5d? | 2006-04-28 A | 2007-06-08 A | 100% | 2006-04-28 | 2007-06-08 | 291d? |  | C5 | 10256h | 10256h | OSA7 | 29.198/9; 23.198 | AePONA | damian.oneill@aepona.com | Rel-7 | Kimmo |  |  |  |  |
| 7848 | 2556.2.1 | Parlay X Message Broadcast Web Service |  | 156d? | 2006-04-28 A | 2006-12-01 A | 100% | 2006-04-28 | 2006-12-01 | 156d? | finish no earlier than 2006-12-01 | C5 | 1248h | 1248h | OSA7 | 29.199-15; 23.198 | ETRI |  | Rel-7 | Kimmo |  |  |  |  |
| 7849 | 2556.2.2 | Parlay X Geocoding Web Service |  | 156d? | 2006-04-28 A | 2006-12-01 A | 100% | 2006-04-28 | 2006-12-01 | 156d? | finish no earlier than 2006-12-01 | C5 | 1248h | 1248h | OSA7 | 29.199-16; 23.198 | ETRI |  | Rel-7 | Kimmo |  |  |  |  |
| 7850 | 2556.2.3 | Parlay X Application driven QoS Web Service |  | 226d? | 2006-04-28 A | 2007-03-09 A | 100% | 2006-04-28 | 2007-03-09 | 226d? | finish no earlier than 2007-03-09 | C5 | 1808h | 1808h | OSA7 | 29.199-17; 23.198 | BT |  | Rel-7 | Kimmo |  |  |  |  |
| 7851 | 2556.2.4 | Parlay-X Device Capabilities and Configuration |  | 162d? | 2006-10-26 A | 2007-06-08 A | 100% | 2006-10-26 | 2007-06-08 | 162d? | finish no earlier than 2007-06-09 | C5 | 1296h | 1296h | OSA7 | 29.199-18; 23.198 | Telenor |  | Rel-7 | Kimmo | 34 |  |  |  |
| 7852 | 2556.2.5 | Parlay-X Multimedia Streaming Session Management Web Service |  | 97d? | 2006-10-26 A | 2007-03-09 A | 100% | 2006-10-26 | 2007-03-09 | 97d? | start no earlier than 2006-10-26 | C5 | 776h | 776h | OSA7 | 29.199-19; 23.198 | Telenor |  | Rel-7 | Kimmo | 34 |  |  |  |
| 7853 | 2556.2.6 | Parlay-X Multimedia Multicast Control Web Service |  | 97d? | 2006-10-26 A | 2007-03-09 A | 100% | 2006-10-26 | 2007-03-09 | 97d? | start no earlier than 2006-10-26 | C5 | 776h | 776h | OSA7 | 29.199-20; 23.198 | ETRI |  | Rel-7 | Kimmo | 34 |  |  |  |
| 7854 | 2556.2.7 | OSA API Conference Call Control SCF |  | 97d? | 2006-10-26 A | 2007-03-09 A | 100% | 2006-10-26 | 2007-03-09 | 97d? | start no earlier than 2006-10-26 | C5 | 776h | 776h | OSA7 | 29.198-04-5; 23.198 | Ericsson |  | Rel-7 | Kimmo | 34 |  |  |  |
| 7855 | 2557 | **Selective Disabling of UE Capabilities** |  | 903.36d? | 2005-01-24 A | 2007-06-15 A | 100% | 2005-01-24 | 2007-06-15 | 624.36d? |  | S1; S2; C1 | 22341.5h | 22341.5h | SDoUE |  | Motorola |  | Rel-7 | Alain |  | SDoUE |  |  |
| 7856 | 2557.1 | Stage 1 of SDoUE |  | 393.6d? | 2005-01-24 A | 2006-12-08 A | 100% | 2005-01-24 | 2006-12-08 | 393.6d? | finish no earlier than 2006-12-08 | S1 | 3148.8h | 3148.8h | SDoUE-CR | 22.011 | Motorola |  | Rel-7 | Alain |  | SDoUE-CR |  |  |
| 7857 | 2557.2 | Deleted - TR on different possible architectures |  | 195d? | 2005-03-21 A | 2005-12-16 A | 100% | 2005-03-21 | 2005-12-16 | 195d? | finish no earlier than 2005-12-16 | S2 | 1560h | 1560h | SDoUE-FS | 23.805 abandonned at SP-30; descendant C1 24.305 | Vodafone | Gavin.Wong@vodafone.com | Rel-7 | Maurice |  | SDoUE-FS | SP-30 |  |
| 7858 | 2557.3 | Stage 3 of SDoUE |  | 331d? | 2006-03-10 A | 2007-06-15 A | 100% | 2006-03-10 | 2007-06-15 | 331d? | finish no earlier than 2007-06-15 | C1 | 2648h | 2648h | SDoUE | 24.305 | Ericsson | christian.herrero@ericsson.com | Rel-7 | Frederic |  |  |  |  |
| 7859 | 2558 | **Network selection enhancements (NSP)** |  | 474.25d? | 2006-03-15 A | 2007-06-15 A | 100% | 2006-03-15 | 2007-06-15 | 328d? |  | S1 | 6320h | 6320h | NSP |  | O2 | chris.friel@O2.com | Rel-7 | Alain |  | NSP |  |  |
| 7860 | 2558.1 | Stage 1 of NSP |  | 191d? | 2006-03-15 A | 2006-12-06 A | 100% | 2006-03-15 | 2006-12-06 | 191d? | start no earlier than 2006-03-15 | S1 | 1528h | 1528h | NSP-TS | 22.101; 22.011; 23.122; 24.008; 25.304; 31.102; 45.008 | O2 | chris.friel@O2.com | Rel-7 | Alain |  | NSP-TS |  |  |
| 7861 | 2558.2 | Procedural aspects of NSP |  | 271d? | 2006-06-02 A | 2007-06-15 A | 100% | 2006-06-02 | 2007-06-15 | 271d? | finish no earlier than 2007-06-15 | C1 | 2168h | 2168h | NSP-CR | 23.122; 24.008; 31.102 | Motorola | Andrew Howell | Rel-7 | Frederic |  | NSP-CR |  |  |
| 7862 | 2559 | Network selection enhancements (NSP) - UE Conformance Testing |  | 396d? | 2007-06-01 A | 2008-12-05 A | 100% | 2007-06-01 | 2008-12-05 | 396d? | finish no earlier than 2008-12-05 | R5 | 3168h | 3168h | NSP-CR_UEConTest | 34.108; 34.123-1; 34.123-2; 34.123-3 | Nokia | jarkko.hellsten@nokia.com | Rel-7 | Ingbert |  | NSP-CR_UEConTest |  | RP-080819 |
| 7863 | 2560 | **Access Class Barring and Overload Protection** |  | 940.25d? | 2004-03-15 A | 2006-09-08 A | 100% | 2004-03-15 | 2006-09-08 | 650d? |  | S2; C1 | 13968h | 13968h | ACBOP | 23.898 | Vodafone | chris.pudney@vodafone.com | Rel-7 | Maurice |  | ACBOP |  |  |
| 7864 | 2560.1 | TR on Stage 2 |  | 274d? | 2004-03-15 A | 2005-03-31 A | 100% | 2004-03-15 | 2005-03-31 | 274d? | finish no earlier than 2005-03-31 | S2 | 2192h | 2192h | ACBOP | 23.898 | NTT DoCoMo | Jean-Jacques Davidian (davidian@docomo.fr) | Rel-7 | Maurice |  |  |  |  |
| 7865 | 2560.2 | Stage 3 CN aspects of ACBOP |  | 172d? | 2005-06-06 A | 2006-01-31 A | 100% | 2005-06-06 | 2006-01-31 | 172d? | start no earlier than 2005-06-06 | C1 | 1376h | 1376h | ACBOP | 24.008 |  |  | Rel-7 | Frederic |  |  |  |  |
| 7866 | 2560.3 | Deleted - Potential impact on Iu interface Overload functionality | milestone | 0d? | 2004-03-15 A | 2004-03-15 A | 100% | 2004-03-15 | 2004-03-15 | 0d? | finish no earlier than 2004-03-15 | RP |  |  | ACBOP | 25.413 |  |  | Rel-7 | Issam |  |  | RP-25 |  |
| 7867 | 2560.4 | Deleted - Extra ACBOP information in RAN | milestone | 0d? | 2004-03-15 A | 2004-03-15 A | 100% | 2004-03-15 | 2004-03-15 | 0d? | finish no earlier than 2004-03-15 | RP |  |  | ACBOP | 25.331 |  |  | Rel-7 | Issam |  |  | RP-25 |  |
| 7868 | 2560.5 | Deleted - Extra ACBOP information in GERAN | milestone | 0d? | 2006-09-08 A | 2006-09-08 A | 100% | 2006-09-08 | 2006-09-08 | 0d? | start no earlier than 2006-09-08 | GP |  |  | ACBOP | 44.018 |  |  | Rel-7 | Paolo |  |  | RP-33 |  |
| 7869 | 2561 | **System enhancements for Fixed Broadband access to IMS** |  | 3062d? | 2003-11-05 A | 2011-12-09 A | 100% | 2003-11-05 | 2011-12-09 | 2117d? |  | S2; S3; S5; C1; C3; C4; IETF | 369944h | 369944h | FBI |  |  |  | Rel-7 | Maurice |  | FBI |  |  |
| 7870 | 2561.1 | **TISPAN Rel 1 related aspects** |  | 3062d? | 2003-11-05 A | 2011-12-09 A | 100% | 2003-11-05 | 2011-12-09 | 2117d? |  | S2; S3; C1; C3; C4; IETF | 239320h | 239320h | FBI-TIS1 |  |  |  | Rel-7 | Maurice |  | FBI-TIS1 |  |  |
| 7871 | 2561.1.1 | Stage 2 of FBI for TISPAN R1 |  | 365d? | 2004-10-14 A | 2006-03-08 A | 100% | 2004-10-14 | 2006-03-08 | 365d? | start no earlier than 2004-10-14 | S2 | 2920h | 2920h |  |  |  |  | Rel-7 | Maurice |  |  |  |  |

Notes:
- 7847: CP#34 updated WID CP-060607=>CP-070200
- 7848: -
- 7849: -
- 7850: -
- 7851: -
- 7852: -
- 7853: -
- 7854: -
- 7855: Moved from FS section Feb 06
- 7856: Moved from FS section Feb 06
- 7857: Moved from FS section Feb 06. Abandoned at SP-30
- 7858: -
- 7859: -
- 7860: -
- 7861: -
- 7862: RP#42 completed. Testing for Feature UID_7041 (NSP-CR)
- 7863: -
- 7864: -
- 7865: -
- 7866: -
- 7867: -
- 7868: -
- 7869: -
- 7870: -
- 7871: -

| ID | WBS | Task | Duration | Start | Finish | Complete | Baseline start | Baseline finish | Baseline duration | Constraint | Resources | Work | Actual work | WI rapporteur name | WI rapporteur e-mail | Release | MCC resp | PCG approved | TSG approved | Acronym | Acronym_3GU_Export | Special Focus Doc | TSG stopped |
| --- | --- | --- | --- | --- | --- | --- | --- | --- | --- | --- | --- | --- | --- | --- | --- | --- | --- | --- | --- | --- | --- | --- | --- |
| 7872 | 2561.1.2 | **Protocol impact of FBI for TISPAN R1** | 3062d? | 2003-11-05 A | 2011-12-09 A | 100% | 2003-11-05 | 2011-12-09 | 2117d? |  | S3; C1; C3; C4; IETF | 133840h | 133840h | Siemens | peter.leis@nsn.com | Rel-7 | Frederic |  |  |  |  |  |  |
| 7873 | 2561.1.2.1 | (IETF) CT aspects of FBI for TISPAN R1 | 2117d? | 2003-11-05 A | 2011-12-09 A | 100% | 2003-11-05 | 2011-12-09 | 2117d? | start no earlier than 2003-11-05 | C1-IETF; C3-IETF | 33872h | 33872h | Roland Jesske |  | Rel-7 | Frederic | 27 | 52 |  |  |  |  |
| 7874 | 2561.1.2.2 | CT1 aspects of FBI for TISPAN R1 | 802d? | 2003-11-05 A | 2006-11-30 A | 100% | 2003-11-05 | 2006-11-30 | 802d? | finish no earlier than 2006-11-30 | C1 | 6416h | 6416h | Siemens | peter.leis@nsn.com | Rel-7 | Frederic |  |  |  |  |  |  |
| 7875 | 2561.1.2.3 | CT3 aspects of FBI for TISPAN R1 | 808d? | 2003-11-05 A | 2006-12-08 A | 100% | 2003-11-05 | 2006-12-08 | 808d? | finish no earlier than 2006-12-08 | C3 | 6464h | 6464h | Siemens | peter.leis@nsn.com | Rel-7 | Adrian |  |  |  |  |  |  |
| 7876 | 2561.1.2.4 | CT4 aspects of FBI for TISPAN R1 | 301d? | 2006-01-13 A | 2007-03-09 A | 100% | 2006-01-13 | 2007-03-09 | 301d? | finish no earlier than 2007-03-09 | C4 | 2408h | 2408h | Siemens | peter.leis@nsn.com | Rel-7 | Kimmo |  |  | FBI-TIS1-st3-c4 | FBI-TIS1-st3-c4 |  |  |
| 7877 | 2561.1.3 | Security Enhancements for FBI | 118d? | 2005-06-28 A | 2005-12-08 A | 100% | 2005-06-28 | 2005-12-08 | 118d? | start no earlier than 2005-06-28 | S3 | 944h | 944h | Ericsson | Bengt.Sahlin@ericsson.com | Rel-7 | Mirko |  |  | FBI-ISE | FBI-ISE |  |  |
| 7878 | 2561.2 | **PacketCable Related aspects** | 421.5d? | 2006-02-01 A | 2007-03-14 A | 100% | 2006-02-01 | 2007-03-14 | 291d? |  | S2; S5; C1 | 12072h | 12072h | CableLabs | Bernie McKibben (b.mckibben@cablelabs.com) | Rel-7 | Maurice |  |  | FBI-PCBL | FBI-PCBL |  |  |
| 7879 | 2561.2.1 | Stage 1,2 of FBI for PacketCable | 228d? | 2006-02-01 A | 2006-12-15 A | 100% | 2006-02-01 | 2006-12-15 | 228d? | finish no earlier than 2006-12-15 | S2 | 1824h | 1824h | CableLabs | Bernie McKibben (b.mckibben@cablelabs.com) | Rel-7 | Maurice |  |  |  |  |  |  |
| 7880 | 2561.2.2 | Protocol impact of FBI for PacketCable | 228d? | 2006-05-01 A | 2007-03-14 A | 100% | 2006-05-01 | 2007-03-14 | 228d? | finish no earlier than 2007-03-15 | C1 | 1824h | 1824h |  |  | Rel-7 | Frederic |  |  |  |  |  |  |
| 7881 | 2561.2.3 | SA5 Charging aspects of FBI for PacketCable | 180d? | 2006-03-31 A | 2006-12-07 A | 100% | 2006-03-31 | 2006-12-07 | 180d? | finish no earlier than 2006-12-07 | S5 | 1440h | 1440h | CableLabs | Bernie McKibben (b.mckibben@cablelabs.com) | Rel-7 | Mirko |  |  | FBI-PCBL-CH | FBI-PCBL-CH |  |  |
| 7882 | 2562 | **Support of SMS over generic 3GPP IP access** | 1008.75d? | 2004-10-14 A | 2007-06-14 A | 100% | 2004-10-14 | 2007-06-14 | 696d? |  | S2; C4; C1 | 37544h | 37544h | Huawei | zhangwenlin@huawei.com | Rel-7 | Maurice |  |  | SMSIP | SMSIP | WLAN |  |
| 7883 | 2562.1 | FS on SMSIP | 173d? | 2004-10-14 A | 2005-06-13 A | 100% | 2004-10-14 | 2005-06-13 | 173d? | start no earlier than 2004-10-14 | S2 | 1384h | 1384h | Huawei | zhangwenlin@huawei.com | Rel-7 | Maurice |  |  |  |  | WLAN |  |
| 7884 | 2562.2 | Stage 2 for SMSIP | 333d? | 2005-06-08 A | 2006-09-15 A | 100% | 2005-06-08 | 2006-09-15 | 333d? | finish no earlier than 2006-09-15 | S2 | 2664h | 2664h | Huawei | zhangwenlin@huawei.com | Rel-7 | Maurice |  |  |  |  | WLAN |  |
| 7885 | 2562.3 | **Stage 3 for SMSIP** | 763.25d? | 2005-06-08 A | 2007-06-14 A | 100% | 2005-06-08 | 2007-06-14 | 527d? |  | C4; C1 | 16792h | 16792h | Nokia | jari.jansson@nokia.com | Rel-7 | Kimmo |  |  | SMSIP-St3 | SMSIP-St3 | WLAN |  |
| 7886 | 2562.3.1 | CT1 aspects for SMSIP | 527d? | 2005-06-08 A | 2007-06-14 A | 100% | 2005-06-08 | 2007-06-14 | 527d? | finish no earlier than 2007-06-15 | C1 | 4216h | 4216h | Nokia | jari.jansson@nokia.com | Rel-7 | Frederic |  |  |  |  | WLAN |  |
| 7887 | 2562.3.2 | CT4 aspects for SMSIP | 518d? | 2005-06-08 A | 2007-06-01 A | 100% | 2005-06-08 | 2007-06-01 | 518d? | finish no earlier than 2007-06-01 | C4 | 4144h | 4144h | Nokia | jari.jansson@nokia.com | Rel-7 | Kimmo |  |  | SMSIP-St3-c4 | SMSIP-St3-c4 | WLAN |  |
| 7888 | 2563 | **Evolution of Policy Control and Charging** | 1183.75d? | 2004-10-14 A | 2007-11-30 A | 100% | 2004-10-14 | 2007-11-30 | 817d? |  | S2; S5; C3; C1 | 54112h | 54112h | Nokia | balazs.bertenyi@nsn.com | Rel-7 | Maurice |  |  | PCC | PCC |  |  |
| 7889 | 2563.1 | Deleted - TR for PCC | 315d? | 2004-10-14 A | 2005-12-29 A | 100% | 2004-10-14 | 2005-12-29 | 315d? | finish no earlier than 2005-12-28 | S2 | 2520h | 2520h | Nokia | balazs.bertenyi@nsn.com | Rel-7 | Maurice |  |  |  |  |  | SP-33 |
| 7890 | 2563.2 | Stage 2 for PCC | 315d? | 2005-07-04 A | 2006-09-15 A | 100% | 2005-07-04 | 2006-09-15 | 315d? | finish no earlier than 2006-09-15 | S2 | 2520h | 2520h | Nokia | balazs.bertenyi@nsn.com | Rel-7 | Maurice |  |  |  |  |  |  |
| 7891 | 2563.3 | Evolution of policy control and flow based bearer level charging | 109d? | 2006-08-01 A | 2006-12-29 A | 100% | 2006-08-01 | 2006-12-29 | 109d? | start no earlier than 2006-08-01 | S2 | 872h | 872h | Nokia | balazs.bertenyi@nsn.com | Rel-7 | Maurice |  |  |  |  |  |  |
| 7892 | 2563.4 | SA5 Charging aspects of PCC | 316d? | 2006-03-31 A | 2007-06-15 A | 100% | 2006-03-31 | 2007-06-15 | 316d? | finish no earlier than 2007-06-15 | S5 | 2528h | 2528h | Orange | alain.bibas@orange-ft.com | Rel-7 | Mirko |  |  | PCC-CH | PCC-CH |  |  |
| 7893 | 2563.5 | Gx reference point for Policy and Charging Control | 521d? | 2005-12-02 A | 2007-11-30 A | 100% | 2005-12-02 | 2007-11-30 | 521d? | finish no earlier than 2007-09-14 | C3 | 4168h | 4168h | Siemens | Thomas.Belling@nsn.com | Rel-7 | Adrian |  |  | PCC-Gx | PCC-Gx |  |  |
| 7894 | 2563.6 | **Rx reference point for PCC CT3 aspects** | 755d? | 2005-12-02 A | 2007-11-30 A | 100% | 2005-12-02 | 2007-11-30 | 521d? |  | C3; C1 | 15360h | 15360h | Ericsson | j.javier.pastor@ericsson.com | Rel-7 | Adrian |  |  | PCC-Rx | PCC-Rx |  |  |
| 7895 | 2563.6.1 | PCC-Rx CT3 aspects | 521d? | 2005-12-02 A | 2007-11-30 A | 100% | 2005-12-02 | 2007-11-30 | 521d? | finish no earlier than 2007-09-14 | C3 | 4168h | 4168h | Ericsson | j.javier.pastor@ericsson.com | Rel-7 | Adrian |  |  | PCC-Rx-c3 | PCC-Rx-c3 |  |  |
| 7896 | 2563.6.2 | PCC-Rx CT1 aspects | 357d? | 2005-12-02 A | 2007-06-15 A | 100% | 2005-12-02 | 2007-06-15 | 357d? | finish no earlier than 2007-06-15 | C1 | 2856h | 2856h | Ericsson | j.javier.pastor@ericsson.com | Rel-7 | Frederic |  |  | PCC-Rx-Gx-c1 | PCC-Rx-Gx-c1 |  |  |

Notes:
- 7872: -
- 7873: CP#54 completed / Impacted TSs and TRs: RFC 6432 (was draft-jesske-dispatch-update3326-reason-responses)
- 7874: - / Impacted TSs and TRs: 24.819; 24.229
- 7875: - / Impacted TSs and TRs: 29.163; 29.209
- 7876: CT4#32: a set of CRs on FBI for cable labs / Impacted TSs and TRs: 29.229
- 7877: Duplicated entry ("ACCSEC2", "Access Security Enhancements", SP-040865) deleted by A.Sultan / Impacted TSs and TRs: 33.203
- 7878: -
- 7879: - / Impacted TSs and TRs: 22.228; 23.228
- 7880: -
- 7881: 03/2006 SP#31 WID approved / Impacted TSs and TRs: 32.240; 32.260; 32.298; 32.299
- 7882: SP#33 updated WID (removed MMS)
- 7883: SP#33 updated WID / Impacted TSs and TRs: 23.804
- 7884: SP#33 updated WID / Impacted TSs and TRs: 23.204
- 7885: CP#34 updated WID
- 7886: CP#34 updated WID / Impacted TSs and TRs: 23.040; 24.229
- 7887: CP#34 updated WID / Impacted TSs and TRs: 23.008; 29.002
- 7888: SP-29 approved WID. SP-31 updated WID adding SA5 charging. 23.125 will be discontinued from Rel-7.
- 7889: SP-30: S2 has no intention for TR completion / Impacted TSs and TRs: 23.803
- 7890: SP-29 approved WID. SP-31 updated WID. 23.125 will be discontinued from Rel-7. / Impacted TSs and TRs: 23.203
- 7891: SP-29 approved WID. SP-31 updated WID. 23.125 will be discontinued from Rel-7. / Impacted TSs and TRs: 23.207; 23.002; 23.228
- 7892: SP-31 updated WID with SA5 charging. / Impacted TSs and TRs: 32.250; 32.251; 32.298; 32.299
- 7893: - / Impacted TSs and TRs: 29.212 (not progressed to Rel-7: 29.210; 29.207; 29.208)
- 7894: WID approved at CP#30, Revised at CP#31, Revised at CP#33
- 7895: - / Impacted TSs and TRs: 29.213; 29.214 (not progressed to Rel-7: 29.209; 29.211)
- 7896: - / Impacted TSs and TRs: 24.229

| ID | WBS | Task | Type | Duration | Start | Finish | Complete | Baseline start | Baseline finish | Baseline duration | Constraint | Resources | Work | Actual work | Acronym | WI rapporteur name | WI rapporteur e-mail | Release | MCC resp | Special Focus Doc | Acronym_3GU_Export | Impacted TSs and TRs | TSG stopped | TSG approved |
| --- | --- | --- | --- | --- | --- | --- | --- | --- | --- | --- | --- | --- | --- | --- | --- | --- | --- | --- | --- | --- | --- | --- | --- | --- |
| 7897 | 2564 | **Voice Call Continuity between CS and IMS (incl. I-WLAN)** |  | 929d? | 2004-12-31 A | 2007-06-15 A | 100% | 2004-12-31 | 2007-06-15 | 641d? |  | S2; S1; S5; C1; C4 | 43592h | 43592h | VCC | Alcatel-Lucent | Keith Drage (drage@alcatel-lucent.com) | Rel-7 | Maurice | WLAN | VCC |  |  |  |
| 7898 | 2564.1 | TR for Voice Call Continuity between CS and IMS (incl. I-WLAN) |  | 245d? | 2004-12-31 A | 2005-12-08 A | 100% | 2004-12-31 | 2005-12-08 | 245d? | finish no earlier than 2005-12-08 | S2 | 1960h | 1960h |  | Alcatel-Lucent | andy.bennett@alcatel-lucent.com | Rel-7 | Maurice | WLAN |  | 23.806 |  |  |
| 7899 | 2564.2 | Stage 1 for Voice Call Continuity between CS and IMS (incl. I-WLAN) |  | 140d? | 2005-03-17 A | 2005-09-28 A | 100% | 2005-03-17 | 2005-09-28 | 140d? | finish no earlier than 2005-09-28 | S1 | 1120h | 1120h |  | Alcatel-Lucent | andy.bennett@alcatel-lucent.com | Rel-7 | Alain | WLAN |  | 22.101 |  |  |
| 7900 | 2564.3 | Stage 2 for Voice Call Continuity between CS and IMS (incl. I-WLAN) |  | 264d? | 2005-09-06 A | 2006-09-08 A | 100% | 2005-09-06 | 2006-09-08 | 264d? | finish no earlier than 2006-09-08 | S2 | 2112h | 2112h |  | Alcatel-Lucent | andy.bennett@alcatel-lucent.com | Rel-7 | Maurice | WLAN |  | 23.206 |  |  |
| 7901 | 2564.4 | SA5 Charging for Voice Call Continuity between CS and IMS (incl. I-WLAN) |  | 471.25d? | 2006-03-17 A | 2007-06-14 A | 100% | 2006-03-17 | 2007-06-14 | 325d? | finish no earlier than 2007-06-14 | S5 | 2600h | 2600h | VCC-CH | Orange | alain.bibas@orange-ft.com | Rel-7 | Mirko | WLAN | VCC-CH | 32.250; 32.260 |  |  |
| 7902 | 2564.5 | **Stage 3 for Voice Call Continuity between CS and IMS (incl. I-WLAN)** |  | 517.75d? | 2006-02-01 A | 2007-06-15 A | 100% | 2006-02-01 | 2007-06-15 | 358d? |  | C1; C4 | 10160h | 10160h |  | Alcatel-Lucent | Keith Drage (drage@alcatel-lucent.com) | Rel-7 | Frederic | WLAN |  |  |  |  |
| 7903 | 2564.5.1 | CT1 aspects of Stage 3 for Voice Call Continuity between CS and IMS (incl. I-WLAN) |  | 358d? | 2006-02-01 A | 2007-06-15 A | 100% | 2006-02-01 | 2007-06-15 | 358d? | finish no earlier than 2007-06-15 | C1 | 2864h | 2864h |  | Alcatel-Lucent | Keith Drage (drage@alcatel-lucent.com) | Rel-7 | Frederic | WLAN |  | 24.206; 24.216 |  |  |
| 7904 | 2564.5.2 | CT4 aspects of Stage 3 for Voice Call Continuity between CS and IMS (incl. I-WLAN) |  | 196d? | 2006-06-09 A | 2007-03-09 A | 100% | 2006-06-09 | 2007-03-09 | 196d? | start no earlier than 2006-06-09 | C4 | 1568h | 1568h | VCC-St3-c4 | Alcatel-Lucent | Keith Drage (drage@alcatel-lucent.com) | Rel-7 | Kimmo | WLAN | VCC-St3-c4 | 23.003 |  |  |
| 7905 | 2564.5.3 | Deleted - CT3 aspects of Stage 3 for Voice Call Continuity between CS and IMS (incl. I-WLAN) | milestone | 0d? | 2006-11-02 A | 2006-11-02 A | 100% | 2006-11-02 | 2006-11-02 | 0d? | finish no earlier than 2006-11-02 | C3 |  |  |  | Alcatel-Lucent | Keith Drage (drage@alcatel-lucent.com) | Rel-7 | Adrian | WLAN |  | 29.163 | CP-33 |  |
| 7906 | 2565 | **One Tunnel solution for optimization of Packet Data Traffic** |  | 604.75d? | 2006-03-27 A | 2007-10-31 A | 100% | 2006-03-27 | 2007-10-31 | 418d? |  | S2 | 7048h | 7048h | OPTUNEL | Nokia | antti.j.pasanen@nokia.com | Rel-7 | Maurice |  | OPTUNEL |  |  |  |
| 7907 | 2565.1 | Deleted - Study on Stage 2 for One Tunnel solution |  | 125d? | 2006-03-27 A | 2006-09-15 A | 100% | 2006-03-27 | 2006-09-15 | 125d? | finish no earlier than 2005-09-12 | S2 | 1000h | 1000h | OPTUNEL-Study | Nokia | antti.j.pasanen@nokia.com | Rel-7 | Maurice |  | OPTUNEL-Study | 23.809 | SP-34 |  |
| 7908 | 2565.2 | One Tunnel Deployment Guideline |  | 268d? | 2006-10-23 A | 2007-10-31 A | 100% | 2006-10-23 | 2007-10-31 | 268d? | finish no earlier than 2007-10-31 | S2 | 2144h | 2144h | OPTUNEL-Guide | Huawei | lan.liu@huawei.com | Rel-7 | Maurice |  | OPTUNEL-Guide | 23.919 |  | 34 |
| 7909 | 2565.3 | Stage 2 specification for One Tunnel solution |  | 70d? | 2006-09-11 A | 2006-12-15 A | 100% | 2006-09-11 | 2006-12-15 | 70d? | finish no earlier than 2006-12-15 | S2 | 560h | 560h | OPTUNEL-Stage2 | Nokia | antti.j.pasanen@nokia.com | Rel-7 | Maurice |  | OPTUNEL-Stage2 | 23.060 |  |  |
| 7910 | 2566 | **CSI Terminating Session handling** |  | 386.25d? | 2006-06-08 A | 2007-06-15 A | 100% | 2006-06-08 | 2007-06-15 | 267d? |  | S2; C1 | 6864h | 6864h | CSItermS | Samsung | Osok Song | Rel-7 | Maurice |  | CSItermS |  |  |  |
| 7911 | 2566.1 | Stage 2 of CStermS |  | 192d? | 2006-06-08 A | 2007-03-02 A | 100% | 2006-06-08 | 2007-03-02 | 192d? | start no earlier than 2006-06-08 | S2 | 1536h | 1536h |  | Samsung | Osok Song | Rel-7 | Maurice |  |  | 23.279 |  | 34 |
| 7912 | 2566.2 | Stage 3 of CStermS |  | 132d? | 2006-12-14 A | 2007-06-15 A | 100% | 2006-12-14 | 2007-06-15 | 132d? | finish no earlier than 2007-06-15 | C1 | 1056h | 1056h |  | Samsung | chenho.chin@samsung.com | Rel-7 | Frederic |  |  | 24.229; 24.279 |  | 34 |
| 7913 | 2566.3 | Deleted - duplicated with UID 340015 -Stage 3 CSI Terminating Session handling | milestone | 0d? | 2007-03-09 A | 2007-03-09 A | 100% | 2007-03-09 | 2007-03-09 | 0d? | start no earlier than 2007-03-09 | C1 |  |  |  | Samsung | chenho.chin@samsung.com | Rel-7 | Frederic |  |  | 24.229; 24.179; 24.279 | CP-34 | 34 |
| 7914 | 2567 | Liberty Alliance and 3GPP Security Interworking |  | 451d? | 2005-03-10 A | 2006-11-30 A | 100% | 2005-03-10 | 2006-11-30 | 451d? | finish no earlier than 2006-11-30 | S3 | 3608h | 3608h | LibSec | Nokia | Silke.Holtmanns@nokia.com | Rel-7 | Mirko |  | LibSec | 33.980 |  |  |
| 7915 | 2568 | Trust Requirements for Open Platforms in 3GPP |  | 499d? | 2005-01-03 A | 2006-11-30 A | 100% | 2005-01-03 | 2006-11-30 | 499d? | finish no earlier than 2006-11-30 | S3 | 3992h | 3992h | TrustOP | Nokia | Silke.Holtmanns@nokia.com | Rel-7 | Mirko |  | TrustOP | 33.905 |  |  |
| 7916 | 2569 | Development of UEA2 and UIA2 |  | 268d? | 2004-12-01 A | 2005-12-09 A | 100% | 2004-12-01 | 2005-12-09 | 268d? | finish no earlier than 2005-12-09 | S3 | 2144h | 2144h | AlgUEA2 | TeliaSonera | per.christoffersson@teliasonera.com | Rel-7 | Mirko |  | AlgUEA2 | 35.919; 35.215; 35.216; 35.217; 35.218 |  |  |
| 7917 | 2570 | Lawful Interception in the 3GPP Rel-7 architecture |  | 118d? | 2005-06-28 A | 2005-12-08 A | 100% | 2005-06-28 | 2005-12-08 | 118d? | start no earlier than 2005-06-28 | S3 | 944h | 944h | LI-7A | BMWI | berthold.wilhelm@regtp.de | Rel-7 | Mirko |  | LI-7A | 33.106; 33.107; 33.108 |  |  |
| 7918 | 2571 | Key establishment between a UICC and a terminal |  | 201.45d? | 2005-12-07 A | 2006-09-28 A | 100% | 2005-12-07 | 2006-09-28 | 201.45d? | finish no earlier than 2006-09-28 | S3 | 1611.6h | 1611.6h | KeyEstUTerm | Gemalto | mireille.pauliac@gemplus.com | Rel-7 | Mirko |  | KeyEstUTerm | 33.110 |  |  |
| 7919 | 2572 | NDS Authentication Framework Extension for Transport Layer Security |  | 50d? | 2006-09-28 A | 2006-12-06 A | 100% | 2006-09-28 | 2006-12-06 | 50d? | finish no earlier than 2006-09-28 | S3 | 400h | 400h | NDSAFTLS | Nokia | tiina.s.koskinen@nokia.com | Rel-7 | Mirko |  | NDSAFTLS | 33.310 |  |  |
| 7920 | 2573 | **Security enhancements** |  | 460.75d? | 2005-09-12 A | 2006-11-30 A | 100% | 2005-09-12 | 2006-11-30 | 319d? |  | S3; C1; C4 | 16376h | 16376h | SEC7 |  |  | Rel-7 | Mirko |  | SEC7 |  |  |  |
| 7921 | 2573.1 | HTTPS connection between a UICC and a NAF |  | 1d? | 2005-09-12 A | 2005-09-12 A | 100% | 2005-09-12 | 2005-09-12 | 1d? | start no earlier than 2005-09-12 | S3; C1 | 16h | 16h | SEC7-HSUN | Gemalto | JSeif@axalto.com, mireille.pauliac@gemplus.com | Rel-7 | Mirko |  | SEC7-HSUN | 33.918; 33.222; 24.109 |  |  |
| 7922 | 2573.2 | 2G GBA: 2G SIM usage in 3GPP GAA framework |  | 61d? | 2005-09-12 A | 2005-12-05 A | 100% | 2005-09-12 | 2005-12-05 | 61d? | finish no earlier than 2005-12-05 | S3 | 488h | 488h | SEC7-2GGBA | Nokia | Silke.Holtmanns@nokia.com | Rel-7 | Mirko |  | SEC7-2GGBA | 33.920; 33.220 |  |  |
| 7923 | 2573.3 | Generic Authentication Architecture usage extensions and optimizations |  | 319d? | 2005-09-12 A | 2006-11-30 A | 100% | 2005-09-12 | 2006-11-30 | 319d? | finish no earlier than 2006-11-30 | S3 | 2552h | 2552h | SEC7-GAA2 | Nokia | Silke.Holtmanns@nokia.com | Rel-7 | Mirko |  | SEC7-GAA2 | 33.220; 29.109; 24.109; (33.223 goes to R8) |  |  |

Notes:
- 7897: WID approved SP#27¦updated SP#28¦updated SP#32
- 7898: -
- 7899: -
- 7900: -
- 7901: 03/2006 SP#31 WID approved
- 7902: -
- 7903: -
- 7904: -
- 7905: -
- 7906: -
- 7907: TR for Info SP-33. SP-34: S2 Report intention to discontinue TR
- 7908: -
- 7909: -
- 7910: Triggered by the abandoned Study UID_32117
- 7911: -
- 7912: CP-34 approved WID. CP-35 updated WID
- 7913: CP-34 approved WID
- 7914: WID approved SP#27.
- 7915: WID approved SP#26.
- 7916: WID approved SP#26, Dependant on Funding Availability.
- 7917: -
- 7918: -
- 7919: TLS profile is moved to Rel-8
- 7920: -
- 7921: -
- 7922: -
- 7923: 33.223 goes to R8

| ID | WBS | Task | Duration | Start | Finish | Complete | Baseline start | Baseline finish | Baseline duration | Constraint | Resources | Work | Actual work | Acronym | WI rapporteur name | WI rapporteur e-mail | Release | MCC resp | Acronym_3GU_Export | Impacted TSs and TRs | PCG approved | TSG approved | TSG stopped |
| --- | --- | --- | --- | --- | --- | --- | --- | --- | --- | --- | --- | --- | --- | --- | --- | --- | --- | --- | --- | --- | --- | --- | --- |
| 7924 | 2573.4 | **SS7 TCAP security Gateway** | 349d? | 2005-09-12 A | 2006-08-14 A | 100% | 2005-09-12 | 2006-08-14 | 241d? |  | S3; C4 | 5664h | 5664h | SEC7-NDS-TCAPsec | Siemens | marc.blommaert.ext@nsn.com | Rel-7 | Mirko | SEC7-NDS-TCAPsec |  |  |  |  |
| 7925 | 2573.4.1 | SA3 aspects of SEC7-NDS-TCAPsec | 130d? | 2005-09-12 A | 2006-03-10 A | 100% | 2005-09-12 | 2006-03-10 | 130d? | finish no earlier than 2006-03-10 | S3 | 1040h | 1040h | SEC7-NDS-TCAPsec-SA3 | Siemens | marc.blommaert.ext@nsn.com | Rel-7 | Mirko | SEC7-NDS-TCAPsec-SA3 | 33.204 |  |  |  |
| 7926 | 2573.4.2 | TCAPsec Gateway | 96d? | 2006-04-03 A | 2006-08-14 A | 100% | 2006-04-03 | 2006-08-14 | 96d? | start no earlier than 2006-04-01 | C4 | 768h | 768h | SEC7-TCAP | Siemens | Ulrich.wiehe@gksag.de | Rel-7 | Kimmo | SEC7-TCAP | 29.204; 29.002 |  |  |  |
| 7927 | 2574 | IMS Stage 3 IETF Protocol Alignment | 589d? | 2004-12-10 A | 2007-03-14 A | 100% | 2004-12-10 | 2007-03-14 | 589d? | finish no earlier than 2007-03-15 | C1 | 4712h | 4712h | IMSProtoc |  |  | Rel-7 | Frederic | IMSProtoc | 24.930 | 36 | 71 |  |
| 7928 | 2575 | **Interoperability between VGCS/VBS and A/Gb flexibility** | 365.5d? | 2006-03-22 A | 2007-03-09 A | 100% | 2006-03-22 | 2007-03-09 | 253d? |  | C1; C4 | 7344h | 7344h | VGCSFlex | Siemens | robert.zaus@nsn.com | Rel-7 | Frederic | VGCSFlex |  |  |  |  |
| 7929 | 2575.1 | CT1 aspects of VGCSFlex | 159d? | 2006-03-22 A | 2006-10-30 A | 100% | 2006-03-22 | 2006-10-30 | 159d? | finish no earlier than 2006-10-30 | C1 | 1272h | 1272h |  | Siemens | robert.zaus@nsn.com | Rel-7 | Frederic |  | 43.068; 43.069 |  |  |  |
| 7930 | 2575.2 | CT4 aspects of VGCSFlex | 253d? | 2006-03-22 A | 2007-03-09 A | 100% | 2006-03-22 | 2007-03-09 | 253d? | finish no earlier than 2007-03-09 | C4 | 2024h | 2024h | VGCSFlex-c4 | Siemens | robert.zaus@nsn.com | Rel-7 | Kimmo | VGCSFlex-c4 | 29.002 |  |  |  |
| 7931 | 2576 | DIAMETER on the GGSN Gi interface | 586d? | 2004-09-10 A | 2006-12-08 A | 100% | 2004-09-10 | 2006-12-08 | 586d? | finish no earlier than 2006-12-08 | C3 | 4688h | 4688h | DIAMGi | Vodafone | Nico.Gabriele@vodafone.com | Rel-7 | Adrian | DIAMGi | 29.061 |  |  |  |
| 7932 | 2577 | DIAMETER on the PDG Wi interface | 586d? | 2004-09-10 A | 2006-12-08 A | 100% | 2004-09-10 | 2006-12-08 | 586d? | finish no earlier than 2006-12-08 | C3 | 4688h | 4688h | DIAMWi | Vodafone | Nico.Gabriele@vodafone.com | Rel-7 | Adrian | DIAMWi | 29.161 |  |  |  |
| 7933 | 2578 | Interworking between the 3GPP CS domain with BICC or ISUP as signalling protocol and external SIP-I networks | 478d? | 2006-09-22 A | 2008-07-22 A | 100% | 2006-09-22 | 2008-07-22 | 478d? | finish no earlier than 2007-09-14 | C3 | 3824h | 3824h | ExtSIPI | Siemens | Thomas.Belling@nsn.com | Rel-7 | Adrian | ExtSIPI | 29.164 |  |  |  |
| 7934 | 2579 | PDU multiplexing at Nb Interface with IP transport | 427d? | 2006-12-04 A | 2008-07-22 A | 100% | 2006-12-04 | 2008-07-22 | 427d? | start no earlier than 2006-12-04 | C3 | 3416h | 3416h | NbIPMux | Alcatel-Lucent | Jean.Rzeznik@alcatel-lucent.fr | Rel-7 | Adrian | NbIPMux | 29.414 |  | 34 |  |
| 7935 | 2580 | **Mp (MRFC - MRFP) interface** | 498d? | 2006-02-13 A | 2007-06-08 A | 100% | 2006-02-13 | 2007-06-08 | 345d? |  | C4; C1 | 9904h | 9904h | Mp | Ericsson | philip.hodges@ericsson.com | Rel-7 | Kimmo | Mp |  |  |  |  |
| 7936 | 2580.1 | CT1 aspects of Mp | 1d | 2006-02-13 A | 2006-02-13 A | 100% | 2006-02-13 | 2006-02-13 | 1d | finish no earlier than 2006-02-13 | C1 | 8h | 8h |  | Ericsson | philip.hodges@ericsson.com | Rel-7 | Frederic |  | 24.229 |  |  |  |
| 7937 | 2580.2 | Deleted - CT3 aspects of Mp | 1d | 2006-09-22 A | 2006-09-22 A | 100% | 2006-09-22 | 2006-09-22 | 1d | start no earlier than 2006-09-22 | C3 | 8h | 8h |  | Ericsson | philip.hodges@ericsson.com | Rel-7 | Adrian |  | 29.162 |  |  | CP-33 |
| 7938 | 2580.3 | Procedures description | 201d? | 2006-06-02 A | 2007-03-09 A | 100% | 2006-06-02 | 2007-03-09 | 201d? | finish no earlier than 2007-03-09 | C4 | 1608h | 1608h | Mp-PROCc4 | Huawei | Chencheng@huawei.com | Rel-7 | Kimmo | Mp-PROCc4 | 23.333 |  |  |  |
| 7939 | 2580.4 | Stage 3 for Mp (MRFC - MRFP) interface | 345d | 2006-02-13 A | 2007-06-08 A | 100% | 2006-02-13 | 2007-06-08 | 345d | finish no earlier than 2007-06-08 | C4 | 2760h | 2760h | Mp-St3c4 | Ericsson | philip.hodges@ericsson.com | Rel-7 | Kimmo | Mp-St3c4 | 29.333 |  |  |  |
| 7940 | 2581 | Routeing of MT-SMS via the HPLMN | 71d? | 2006-12-01 A | 2007-03-09 A | 100% | 2006-12-01 | 2007-03-09 | 71d? | finish no earlier than 2007-03-09 | C4; C1 | 1136h | 1136h | SMSviaH | Vodafone | Nick.Russell@vodafone.com | Rel-7 | Kimmo | SMSviaH | 23.040; 29.002 |  | 34 |  |
| 7941 | 2582 | Mobile Termination whilst the MS is moving to another MSC | 60d? | 2007-03-09 A | 2007-05-31 A | 100% | 2007-03-09 | 2007-05-31 | 60d? | start no earlier than 2007-03-09 | C4 | 480h | 480h | MTmovMS | Alcatel-Lucent | bruno.landais@alcatel-lucent.fr | Rel-7 | Kimmo | MTmovMS | 23.008; 23.012; 23.018; 23.078; 23.079; 29.002 |  |  |  |
| 7942 | 2583 | ISIM API for Java Card | 620d? | 2005-03-14 A | 2007-07-27 A | 100% | 2005-03-14 | 2007-07-27 | 620d? | finish no earlier than 2007-07-27 | C6 | 4960h | 4960h | APIJAVA | Sun | Sebastian Hans | Rel-7 | Xavier | APIJAVA | 31.103; 102 241 | 38 | 74 |  |
| 7943 | 2584 | Rel-7 (U)SIM API Testing (TS 31.213) | 211d? | 2009-05-30 A | 2010-03-19 A | 100% | 2009-05-30 | 2010-03-19 | 211d? | finish no earlier than 2010-03-12 | C6 | 1688h | 1688h | USIM_API_Test | Sagem Orga | gerrit.hartbrod@sagem-orga.com | Rel-7 | Xavier | USIM_API_Test | 31.213 | 23 | 44 |  |
| 7944 | 2585 | High speed interface between the UICC and the ME | 311d? | 2006-09-22 A | 2007-11-30 A | 100% | 2006-09-22 | 2007-11-30 | 311d? | finish no earlier than 2007-11-30 | C6 | 2488h | 2488h | HSI | Gemalto | jacques.seif@GEMALTO.COM | Rel-7 | Xavier | HSI | 31.101 |  |  |  |
| 7945 | 2586 | Video Codec Performance Requirements | 634d? | 2005-01-03 A | 2007-06-07 A | 100% | 2005-01-03 | 2007-06-07 | 634d? | finish no earlier than 2007-06-07 | S4 | 5072h | 5072h | VICPer | Siemens | juergen.pandel@siemens.com | Rel-7 | Paolo | VICPer | 26.234; 26.235; 26.346; 26.140; 26.902 |  |  |  |
| 7946 | 2587 | Dynamic and Interactive Multimedia Scenes | 583d? | 2005-03-15 A | 2007-06-07 A | 100% | 2005-03-15 | 2007-06-07 | 583d? | finish no earlier than 2007-06-07 | S4 | 4664h | 4664h | DIMS | Streamezzo | gaelle.martin-cocher@streamezzo.com | Rel-7 | Paolo | DIMS | 26.140; 26.142; 26.234; 26.244; 23.346 |  |  |  |
| 7947 | 2588 | 3G-324M Video Telephony Call Setup Times Improvements | 341d? | 2005-06-08 A | 2006-09-27 A | 100% | 2005-06-08 | 2006-09-27 | 341d? | finish no earlier than 2006-09-27 | S4 | 2728h | 2728h | VTCSTI | Vodafone | edward.hall@vodafone.co.uk | Rel-7 | Paolo | VTCSTI | 26.911 |  |  |  |

Notes:
- 7924: -
- 7925: -
- 7926: -
- 7927: TR 24.930: Signalling flows for the session setup in the IM CN subsystem based on Session Initiation Protocol (SIP)
- 7928: Voice Group Call Service
- 7929: -
- 7930: -
- 7931: -
- 7932: -
- 7933: -
- 7934: -
- 7935: -
- 7936: -
- 7937: CP#34: CT3 not involved in Mp interface definition
- 7938: -
- 7939: -
- 7940: WID approved in CP#34
- 7941: -
- 7942: -
- 7943: CP#47 completed. Update of Rel-6 (U)SIM API for Java Card Testing UID_43007 under Rel-6 UICC/USIM enhancements and interworking UID_1800
- 7944: Following ETSI publication of TS 102 600, expected to be completed at CT6 meeting 45
- 7945: -
- 7946: -
- 7947: -

| ID | WBS | Task | Duration | Start | Finish | Complete | Baseline start | Baseline finish | Baseline duration | Constraint | Resources | Work | Actual work | Acronym | WI rapporteur name | WI rapporteur e-mail | Release | MCC resp | Acronym_3GU_Export | TSG stopped |
| --- | --- | --- | --- | --- | --- | --- | --- | --- | --- | --- | --- | --- | --- | --- | --- | --- | --- | --- | --- | --- |
| 7948 | 2589 | **Optimizations for Multimedia Telephony over IMS** | 2d? | 2005-09-28 A | 2005-09-29 A | 100% | 2005-09-28 | 2005-09-28 | 0d? |  | S4 | 32h | 32h | OMTIMS | Ericsson | olle.franceschi@ericsson.com | Rel-7 | Paolo | OMTIMS |  |
| 7949 | 2589.1 | Deleted - Characterisation of Adaptive Jitter Management Performance for VoIP Services | 2d? | 2005-09-28 A | 2005-09-29 A | 100% | 2005-09-28 | 2005-09-28 | 0d? | finish no earlier than 2005-09-29 | S4 | 16h | 16h | OMTIMS-CAJMP | Lucent | dhuo@lucent.com | Rel-7 | Paolo | OMTIMS-CAJMP | SP-35 |
| 7950 | 2590 | End-to-End Multimedia Services Performance Metrics | 382d? | 2005-09-28 A | 2007-03-15 A | 100% | 2005-09-28 | 2007-03-15 | 382d? | finish no earlier than 2007-03-15 | S4 | 3056h | 3056h | E2EMSPM | China Mobile | zhangyanyf@chinamobile.com | Rel-7 | Paolo | E2EMSPM |  |
| 7951 | 2591 | Packet Switched Streaming Enhancements | 261d? | 2006-06-08 A | 2007-06-07 A | 100% | 2006-06-08 | 2007-06-07 | 261d? | finish no earlier than 2007-06-07 | S4 | 2088h | 2088h | PSSe | Ericsson | olle.franceschi@ericsson.com | Rel-7 | Paolo | PSSe |  |
| 7952 | 2592 | **Rel-7 Operations, Administration, Maintenance and Provisioning (OAM&P)** | 675.25d? | 2005-09-02 A | 2007-06-15 A | 100% | 2005-09-02 | 2007-06-26 | 472.86d? |  | S5 | 82616h | 82616h | OAM7 | Huawei | Christian.Toche@huawei.com | Rel-7 | Mirko | OAM7 |  |
| 7953 | 2592.1 | **Rel-7 Network Infrastructure Management** | 674.25d? | 2005-09-02 A | 2007-06-14 A | 100% | 2005-09-02 | 2007-06-14 | 465d? |  | S5 | 41800h | 41800h | OAM7-NIM |  |  | Rel-7 | Mirko | OAM7-NIM |  |
| 7954 | 2592.1.1 | Enhance NRM to accommodate NGN (IMS as basis of the Next Generation Network) | 465d? | 2005-09-02 A | 2007-06-14 A | 100% | 2005-09-02 | 2007-06-14 | 465d? | finish no earlier than 2007-06-14 | S5 | 3720h | 3720h |  | Motorola |  | Rel-7 | Mirko |  |  |
| 7955 | 2592.1.2 | Co-operative Element Management interface (CO-OP) (Study + Implementation) | 400d? | 2005-09-02 A | 2007-03-15 A | 100% | 2005-09-02 | 2007-03-15 | 400d? | finish no earlier than 2007-03-15 | S5 | 3200h | 3200h |  | Motorola |  | Rel-7 | Mirko |  |  |
| 7956 | 2592.1.3 | Network Management (NM) Itf-N performance criteria | 465d? | 2005-09-02 A | 2007-06-14 A | 100% | 2005-09-02 | 2007-06-14 | 465d? | finish no earlier than 2007-06-14 | S5 | 3720h | 3720h |  | China Mobile |  | Rel-7 | Mirko |  |  |
| 7957 | 2592.1.4 | Delta synchronization between IRP Manager and IRP Agent (Study + Implementation) | 465d? | 2005-09-02 A | 2007-06-14 A | 100% | 2005-09-02 | 2007-06-14 | 465d? | finish no earlier than 2007-06-14 | S5 | 3720h | 3720h |  | Siemens |  | Rel-7 | Mirko |  |  |
| 7958 | 2592.1.5 | Subscription Management (SuM) IRP Solution Sets | 330d? | 2005-09-02 A | 2006-12-07 A | 100% | 2005-09-02 | 2006-12-07 | 330d? | finish no earlier than 2006-12-07 | S5 | 2640h | 2640h |  | Ericsson |  | Rel-7 | Mirko |  |  |
| 7959 | 2592.1.6 | Integration Reference Point (IRP) Security Management | 400d? | 2005-09-02 A | 2007-03-15 A | 100% | 2005-09-02 | 2007-03-15 | 400d? | finish no earlier than 2007-03-15 | S5 | 3200h | 3200h |  | Huawei | Christian.Toche@huawei.com | Rel-7 | Mirko |  |  |
| 7960 | 2592.1.7 | Partial suspension of Itf-N during maintenance/testing (Study + Implementation) | 465d? | 2005-09-02 A | 2007-06-14 A | 100% | 2005-09-02 | 2007-06-14 | 465d? | finish no earlier than 2007-06-14 | S5 | 3720h | 3720h |  | Siemens |  | Rel-7 | Mirko |  |  |
| 7961 | 2592.1.8 | Deleted - Management of Legacy Equipment | 336d? | 2005-09-02 A | 2006-12-15 A | 100% | 2005-09-02 | 2006-12-15 | 336d? | finish no earlier than 2006-12-15 | S5 | 2688h | 2688h |  | Siemens |  | Rel-7 | Mirko |  | SP-35 |
| 7962 | 2592.1.9 | Deleted - Rules for Vendor Specific Extensions | 400d? | 2005-09-02 A | 2007-03-15 A | 100% | 2005-09-02 | 2007-03-15 | 400d? | finish no earlier than 2007-03-15 | S5 | 3200h | 3200h |  | Siemens |  | Rel-7 | Mirko |  | SP-35 |
| 7963 | 2592.1.10 | Backward and Forward Compatibility of IRP systems | 465d? | 2005-09-02 A | 2007-06-14 A | 100% | 2005-09-02 | 2007-06-14 | 465d? | finish no earlier than 2007-06-14 | S5 | 3720h | 3720h |  | Ericsson |  | Rel-7 | Mirko |  |  |
| 7964 | 2592.1.11 | Repeater Network Resource Model (NRM) definition | 214d? | 2006-02-13 A | 2006-12-07 A | 100% | 2006-02-13 | 2006-12-07 | 214d? | finish no earlier than 2006-12-07 | S5 | 1712h | 1712h |  | China Mobile |  | Rel-7 | Mirko |  |  |
| 7965 | 2592.1.12 | UTRAN radio channel power monitoring | 284d? | 2006-02-13 A | 2007-03-15 A | 100% | 2006-02-13 | 2007-03-15 | 284d? | finish no earlier than 2007-03-15 | S5 | 2272h | 2272h |  | China Mobile |  | Rel-7 | Mirko |  |  |
| 7966 | 2592.1.13 | Notification XML Schema | 71d? | 2006-12-07 A | 2007-03-15 A | 100% | 2006-12-07 | 2007-03-15 | 71d? | finish no earlier than 2007-03-15 | S5 | 568h | 568h |  | Huawei | Christian.Toche@huawei.com | Rel-7 | Mirko |  |  |
| 7967 | 2592.2 | **Rel-7 Performance Management** | 674.25d? | 2005-09-02 A | 2007-06-14 A | 100% | 2005-09-02 | 2007-06-14 | 465d? |  | S5 | 22992h | 22992h | OAM7-PM |  |  | Rel-7 | Mirko | OAM7-PM |  |
| 7968 | 2592.2.1 | Performance measurements definition for CN CS | 400d? | 2005-09-02 A | 2007-03-15 A | 100% | 2005-09-02 | 2007-03-15 | 400d? | finish no earlier than 2007-03-15 | S5 | 3200h | 3200h |  | China Mobile |  | Rel-7 | Mirko |  |  |
| 7969 | 2592.2.2 | Enhancement UTRAN performance measurements definition | 465d? | 2005-09-02 A | 2007-06-14 A | 100% | 2005-09-02 | 2007-06-14 | 465d? | finish no earlier than 2007-06-14 | S5 | 3720h | 3720h |  | China Mobile |  | Rel-7 | Mirko |  |  |
| 7970 | 2592.2.3 | Add TDD specific counters in Performance measurement | 330d? | 2005-09-02 A | 2006-12-07 A | 100% | 2005-09-02 | 2006-12-07 | 330d? | finish no earlier than 2006-12-15 | S5 | 2640h | 2640h |  | CATT |  | Rel-7 | Mirko |  |  |
| 7971 | 2592.2.4 | ATM bearer network Performance measurements | 400d? | 2005-09-02 A | 2007-03-15 A | 100% | 2005-09-02 | 2007-03-15 | 400d? | finish no earlier than 2007-03-15 | S5 | 3200h | 3200h |  | ZTE |  | Rel-7 | Mirko |  |  |
| 7972 | 2592.2.5 | Performance measurements definition for IMS | 465d? | 2005-09-02 A | 2007-06-14 A | 100% | 2005-09-02 | 2007-06-14 | 465d? | finish no earlier than 2007-06-14 | S5 | 3720h | 3720h |  | China Mobile |  | Rel-7 | Mirko |  |  |
| 7973 | 2592.2.6 | HSDPA performance measurements | 349d? | 2006-02-13 A | 2007-06-14 A | 100% | 2006-02-13 | 2007-06-14 | 349d? | finish no earlier than 2007-06-14 | S5 | 2792h | 2792h |  | China Mobile |  | Rel-7 | Mirko |  |  |

Notes:
- 7948: Aug2015: 99%->100 / Impacted TSs and TRs: 26.235; 26.236
- 7949: SP-35 stopped
- 7950: - / Impacted TSs and TRs: 26.944
- 7951: - / Impacted TSs and TRs: 26.234; 26.244
- 7952: OAM7 is an umbrella Feature also for OAM&P related TEI7 type of changes that are not part of any other dedicated feature/WI / Impacted TSs and TRs: 30.817
- 7953: -
- 7954: - / Impacted TSs and TRs: 32.731/2/3/5; 32.631/2/3/5
- 7955: - / Impacted TSs and TRs: 32.806; 32.814; 32.101
- 7956: - / Impacted TSs and TRs: 32.811
- 7957: - / Impacted TSs and TRs: 32.391/2/3/5
- 7958: - / Impacted TSs and TRs: 32.307/317/607/667/665; 32.101; 32.175
- 7959: - / Impacted TSs and TRs: 32.372/3/5; 32.111.32.30x.32.32x.32.33x.32.34x.32.35x.32.36x.32.41x.32.60x.32.61x.32.66x
- 7960: - / Impacted TSs and TRs: 32.381/2/3/5
- 7961: Request to TSG#35 to STOP the WI / Impacted TSs and TRs: new 32.xxx
- 7962: Request to TSG#35 to STOP the WI / Impacted TSs and TRs: 32.62n; For n = 1 to 5
- 7963: - / Impacted TSs and TRs: 32.154
- 7964: - / Impacted TSs and TRs: 32.721/2/3/5
- 7965: - / Impacted TSs and TRs: 32.405; 32.64n; For n = 1 to 5
- 7966: 12/2006 SP#34 WID approved / Impacted TSs and TRs: New 32.325/345/365/415; CR to 32.335/615/665
- 7967: -
- 7968: - / Impacted TSs and TRs: 32.407; 32.408
- 7969: - / Impacted TSs and TRs: 32.405
- 7970: - / Impacted TSs and TRs: 32.405
- 7971: - / Impacted TSs and TRs: No impact on 32.404; 32.405; 32.406; 32.407
- 7972: - / Impacted TSs and TRs: 32.404.32.409.32.437; 32.632/3/4/5
- 7973: - / Impacted TSs and TRs: 32.405

| ID | WBS | Task | Type | Duration | Start | Finish | Complete | Baseline start | Baseline finish | Baseline duration | Constraint | Resources | Work | Actual work | Acronym | WI rapporteur name | Release | MCC resp | Acronym_3GU_Export | TSG stopped | WI rapporteur e-mail | Status Report |
| --- | --- | --- | --- | --- | --- | --- | --- | --- | --- | --- | --- | --- | --- | --- | --- | --- | --- | --- | --- | --- | --- | --- |
| 7974 | 44.5 | **Rel-7 Trace Management** |  | 675.25d? | 2005-09-02 A | 2007-06-15 A | 100% | 2005-09-02 | 2007-06-26 | 472.86d? |  | S5 | 14096h | 14096h | OAM7-Trace | Vodafone | Rel-7 | Mirko | OAM7-Trace |  |  |  |
| 7975 | 2592.3.1 | End-to-end Service Level tracing for IMS |  | 350d? | 2005-11-11 A | 2007-03-15 A | 100% | 2005-11-11 | 2007-03-15 | 350d? | finish no earlier than 2007-03-15 | S5 | 2800h | 2800h |  | Vodafone | Rel-7 | Mirko |  | SP-31 |  |  |
| 7976 | 2592.3.2 | Trace record content for UTRAN TDD |  | 330d? | 2005-09-02 A | 2006-12-07 A | 100% | 2005-09-02 | 2006-12-07 | 330d? | finish no earlier than 2006-12-07 | S5 | 2640h | 2640h |  | Nokia | Rel-7 | Mirko |  |  |  |  |
| 7977 | 2592.3.3 | IRP for Subscriber and Equipment Trace Management |  | 465d? | 2005-09-02 A | 2007-06-14 A | 100% | 2005-09-02 | 2007-06-14 | 465d? | finish no earlier than 2007-06-14 | S5 | 3720h | 3720h |  | Nokia | Rel-7 | Mirko |  |  |  |  |
| 7978 | 2592.3.4 | Deleted - SIP enhancements for trace | milestone | 0d? | 2007-06-15 A | 2007-06-15 A | 100% | 2007-06-15 | 2007-06-26 | 0d? | start no earlier than 2007-06-15 | C1 |  |  |  |  | Rel-7 | Frederic |  | CP-32 |  |  |
| 7979 | 2592.3.5 | Deleted - duplicated with UID 35063 - IRP for Subscriber and Equipment Trace Management |  | 336d? | 2005-09-02 A | 2006-12-15 A | 100% | 2005-09-02 | 2006-12-15 | 336d? | finish no earlier than 2006-12-15 | S5 | 2688h | 2688h |  | Nokia | Rel-7 | Mirko |  | SP-33 |  |  |
| 7980 | 2593 | **Rel-7 Charging Management small Enhancements** |  | 402.75d? | 2006-05-22 A | 2007-06-14 A | 100% | 2006-05-22 | 2007-06-14 | 279d? |  | S5 | 5952h | 5952h | CH7 | Orange | Rel-7 | Mirko | CH7 |  | alain.bibas@orange-ft.com |  |
| 7981 | 2593.1 | Alternate Charged Party (ACP) for IMS |  | 279d? | 2006-05-22 A | 2007-06-14 A | 100% | 2006-05-22 | 2007-06-14 | 279d? | finish no earlier than 2007-06-14 | S5 | 2232h | 2232h | CH7-IMS-ACP | Lucent | Rel-7 | Mirko | CH7-IMS-ACP |  | njmazzarella@alcatel-lucent.com |  |
| 7982 | 2593.2 | Align 3GPP Charging with OMA PoC Enabler Release 2.0 |  | 186d? | 2006-09-28 A | 2007-06-14 A | 100% | 2006-09-28 | 2007-06-14 | 186d? | finish no earlier than 2007-06-14 | S5 | 1488h | 1488h | CH7-PoC | Siemens | Rel-7 | Mirko | CH7-PoC |  | Gerald.Goermer@nsn.com |  |
| 7983 | 8.5 | **Multiple-Input Multiple-Output (MIMO) antennas** |  | 1886d? | 2003-03-14 A | 2008-03-07 A | 100% | 2003-03-14 | 2008-03-07 | 1301d? |  | R1; R5 | 55848h | 55848h | MIMO | Alcatel-Lucent | Rel-7 | Patrick | MIMO |  | hchuang@Alcatel-Lucent.com |  |
| 7984 | 2594.1 | MIMO - Physical layer |  | 915d? | 2003-09-12 A | 2007-03-15 A | 100% | 2003-09-12 | 2007-03-15 | 915d? | finish no earlier than 2007-03-15 | R1 | 7320h | 7320h | MIMO-Phys | Alcatel-Lucent | Rel-7 | Patrick | MIMO-Phys |  | hchuang@Alcatel-Lucent.com | RP-070037 |
| 7985 | 2594.2 | MIMO - Layer 2,3 aspects |  | 915d? | 2003-09-12 A | 2007-03-15 A | 100% | 2003-09-12 | 2007-03-15 | 915d? | finish no earlier than 2007-03-15 | R2 | 7320h | 7320h | MIMO-L23 | Alcatel-Lucent | Rel-7 | Yong-Jun | MIMO-L23 |  | hchuang@Alcatel-Lucent.com | RP-070037 |
| 7986 | 2594.3 | MIMO - Iub/Iur Protocol Aspects |  | 1045d? | 2003-03-14 A | 2007-03-15 A | 100% | 2003-03-14 | 2007-03-15 | 1045d? | finish no earlier than 2007-03-15 | R3 | 8360h | 8360h | MIMO-IurIub | Alcatel-Lucent | Rel-7 | Juha | MIMO-IurIub |  | hchuang@Alcatel-Lucent.com | RP-070037 |
| 7987 | 2594.4 | MIMO - RF Radio Transmission/Reception, System Performance Requirements and Conformance Testing |  | 982d? | 2003-12-12 A | 2007-09-17 A | 100% | 2003-12-12 | 2007-09-17 | 982d? | finish no earlier than 2007-09-17 | R4 | 7856h | 7856h | MIMO-RF | Alcatel-Lucent | Rel-7 | Issam | MIMO-RF |  | ngm@Alcatel-Lucent.com | RP-070531 |
| 7988 | 2594.5 | **UE Conformance Testing for Multiple Input Multiple Output antennas (MIMO)** |  | 378d? | 2007-03-09 A | 2008-03-07 A | 100% | 2007-03-09 | 2008-03-07 | 261d? |  | R5 | 4176h | 4176h | MIMO-UEConTest | Qualcomm | Rel-7 | Ingbert | MIMO-UEConTest |  | svora@qualcomm.com |  |
| 7989 | 2594.5.1 | Conformance Test Aspects – Multiple Input Multiple Output Antennas (MIMO) for FDD |  | 261d? | 2007-03-09 A | 2008-03-07 A | 100% | 2007-03-09 | 2008-03-07 | 261d? | finish no earlier than 2008-03-07 | R5 | 2088h | 2088h | MIMO-UEConTest_FDD | Qualcomm | Rel-7 | Ingbert | MIMO-UEConTest_FDD |  | svora@qualcomm.com |  |
| 7990 | 2595 | **Rel-7 Improvements of the Radio Interface** |  | 1028.5d? | 2004-09-15 A | 2007-06-04 A | 100% | 2004-09-15 | 2007-06-04 | 709d? |  | RP; GP | 40520h | 40520h |  |  | Rel-7 | Issam |  |  |  |  |
| 7991 | 2595.1 | Extended UMTS 1.7/2.1 GHz |  | 198d? | 2006-03-15 A | 2006-12-15 A | 100% | 2006-03-15 | 2006-12-15 | 198d? | finish no earlier than 2006-12-15 | R4 | 1584h | 1584h | RInImp-UMTS1721Ext | Ericsson | Rel-7 | Issam | RInImp-UMTS1721Ext |  | johan.skold@ericsson.com | RP-060681 |
| 7992 | 2595.2 | UMTS 2.6 GHz 7.68 Mcps TDD |  | 67d? | 2006-06-15 A | 2006-09-15 A | 100% | 2006-06-15 | 2006-09-15 | 67d? | finish no earlier than 2006-09-15 | R4 | 536h | 536h | RInImp-UMTS26VHCRTDD | IPWireless | Rel-7 | Issam | RInImp-UMTS26VHCRTDD |  | Shin Horng Wong (shwong@ipwireless.com) | RP-060451 |
| 7993 | 2595.3 | UMTS 2.6 GHz |  | 195d? | 2004-09-15 A | 2005-06-14 A | 100% | 2004-09-15 | 2005-06-14 | 195d? | finish no earlier than 2005-06-14 | R4 | 1560h | 1560h | RInImp-UMTS2600 | Nokia | Rel-7 | Issam | RInImp-UMTS2600 |  | jussi.numminen@nokia.com | RP-050184 |
| 7994 | 2595.4 | UMTS 2.6 GHz TDD |  | 261d? | 2004-12-15 A | 2005-12-14 A | 100% | 2004-12-15 | 2005-12-14 | 261d? | finish no earlier than 2005-12-15 | R4 | 2088h | 2088h | RInImp-UMTS2600TDD | IPWireless | Rel-7 | Issam | RInImp-UMTS2600TDD |  | Shin Horng Wong (shwong@ipwireless.com) | RP-050661 |
| 7995 | 2595.5 | UMTS 900 MHz |  | 261d? | 2004-12-15 A | 2005-12-14 A | 100% | 2004-12-15 | 2005-12-14 | 261d? | finish no earlier than 2005-12-15 | R4 | 2088h | 2088h | RInImp-UMTS900 | Nortel | Rel-7 | Issam | RInImp-UMTS900 |  | Yannick Li (yli@nortelnetworks.com) | RP-050662 |
| 7996 | 2595.6 | UMTS 1700 MHz |  | 197d? | 2005-03-15 A | 2005-12-14 A | 100% | 2005-03-15 | 2005-12-14 | 197d? | finish no earlier than 2005-12-15 | R4 | 1576h | 1576h | RInImp-UMTS1700 | NTT DoCoMo | Rel-7 | Issam | RInImp-UMTS1700 |  | Takehiro Nakamura (nakamurata@nttdocomo.co.jp) | RP-050824 |
| 7997 | 2595.7 | UE Antenna Performance Evaluation Method and Requirements |  | 644d? | 2004-12-15 A | 2007-06-04 A | 100% | 2004-12-15 | 2007-06-04 | 644d? | finish no earlier than 2007-06-04 | R4; GP | 10304h | 10304h | RInImp-UEAnt | TeliaSonera | Rel-7 | Issam | RInImp-UEAnt |  | Christian.Bergljung@TeliaSonera.com | RP-070281 |
| 7998 | 2595.8 | Improved Performance Requirements for HSDPA UE based on Rx Diversity (type 1) & LMMSE equalizer (type 2) | milestone | 0d? | 2005-03-15 A | 2005-03-15 A | 100% | 2005-03-15 | 2005-03-15 | 0d? | finish no earlier than 2005-03-15 | R4 |  |  | RInImp-HSPerf-Type3 | Cingular | Rel-7 | Issam | RInImp-HSPerf-Type3 |  | Marc Grant | RP-060015 |

Notes:
- 7974: -
- 7975: 07/2005: OMA (Stage 1), Stage 2/3 SA5, CT1/3/4 / Impacted TSs and TRs: 32.101; 32.421; 32.422; 32.423
- 7976: - / Impacted TSs and TRs: 32.421; 32.422; 32.423
- 7977: - / Impacted TSs and TRs: 32.441; 32.442; 32.443; 32.445; 32.632; 32.633; 32.635
- 7978: combined with UID 11067
- 7979: - / Impacted TSs and TRs: 32.421.32.422.32.423; 3 new 32.4x1.2.3
- 7980: CH7 is an umbrella Feature also for OAM&P related TEI7 type of changes that are not part of any other dedicated feature/WI / Impacted TSs and TRs: 30.817
- 7981: - / Impacted TSs and TRs: 32.240; 32.260; 32.298; 32.299
- 7982: 09/2006 SP#33 WID approved / Impacted TSs and TRs: 32.240; 32.272; 32.299; 32.298
- 7983: Completed Sep 2007¦SR in RP-070037and RP-070531 / Impacted TSs and TRs: 25.876; 25.996
- 7984: Completed Sep 2007¦SR in RP-070037 / Impacted TSs and TRs: 25.211; 25.212; 25.213; 25.214; 25.215; 25.221
- 7985: Completed Sep 2007¦SR in RP-070037 / Impacted TSs and TRs: 25.876
- 7986: Completed Sep 2007¦SR in RP-070037
- 7987: Completed Sep 2007¦SR in RP-070531
- 7988: BB place holder for a number of RAN5 Tasks
- 7989: - / Impacted TSs and TRs: 34.108; 34.109; 34.121-1; 34.121-2; 34.123-1; 34.123-2; 34.123-3
- 7990: Generic feature
- 7991: RP#34 completed. Introduction of Band X (Extended UMTS 1.7/2.1 GHz) in 25.307 / Impacted TSs and TRs: 25.806; 25.101; 25.104; 25.133; 24.141; 25.331; 25.306; 25.307; 25.423; 25.461; 25.463; 34.121
- 7992: RP#33 completed / Impacted TSs and TRs: 25.102; 25.105; 25.123; 25.113; 25.142; 34.124
- 7993: RP#28 completed / Impacted TSs and TRs: 25.101; 25.104; 25.133; 25.141; 25.331; 25.942; 25.306; 25.307; 34.121
- 7994: RP#30 completed / Impacted TSs and TRs: 25.102; 25.105; 25.113; 25.123; 25.142; 25.331; 25.942; 25.306; 25.307; 34.122; 34.124
- 7995: RP#30 completed / Impacted TSs and TRs: 25.101; 25.104; 25.113; 25.133; 25.141; 25.331; 25.942; 25.306; 25.307; 34.121
- 7996: RP#30 completed / Impacted TSs and TRs: 25.101; 25.104; 25.113; 25.133; 25.141; 25.306; 25.307; 25.331; 34.121
- 7997: RP#36 completed / Impacted TSs and TRs: 25.101; new (25.914; 25.963)
- 7998: RP#27 completed / Impacted TSs and TRs: 25.101

| ID | WBS | Task | Type | Duration | Start | Finish | Complete | Baseline start | Baseline finish | Baseline duration | Constraint | Deadline | Resources | Work | Actual work | Acronym | WI rapporteur name | WI rapporteur e-mail | Release | MCC resp | Acronym_3GU_Export | Status Report | TSG stopped | PCG stopped | Created at |
| --- | --- | --- | --- | --- | --- | --- | --- | --- | --- | --- | --- | --- | --- | --- | --- | --- | --- | --- | --- | --- | --- | --- | --- | --- | --- |
| 7999 | 2595.9 | **Additional minimum UE performance requirement for non-HSDPA channels based on type 1 enhanced receiver (Rx Diversity)** |  | 473.25d? | 2005-09-15 A | 2006-12-15 A | 100% | 2005-09-15 | 2006-12-15 | 327d? |  |  | R4 | 7344h | 7344h | RInImp-RxDiv | Qualcomm | Serge Willenegger (sergew@qualcomm.com) | Rel-7 | Issam | RInImp-RxDiv |  |  |  |  |
| 8000 | 2595.9.1 | Additional minimum UE performance requirement for DL physical channels in support of DCH/HS-DSCH operation based on type 1 enhanced receiver (RX-Diversity) |  | 195d? | 2005-09-15 A | 2006-06-14 A | 100% | 2005-09-15 | 2006-06-14 | 195d? | finish no earlier than 2006-06-15 |  | R4 | 1560h | 1560h | RInImp-RxDiv-DCH | Cingular | Marc Grant | Rel-7 | Issam | RInImp-RxDiv-DCH | RP-060235 |  |  |  |
| 8001 | 2595.9.2 | Additional minimum UE performance requirement for downlink physical channels in support of MTCH and MCCH operation based on type 1 enhanced receiver (Rx-Diversity) |  | 198d? | 2006-03-15 A | 2006-12-15 A | 100% | 2006-03-15 | 2006-12-15 | 198d? | finish no earlier than 2006-12-15 |  | R4 | 1584h | 1584h | RInImp-RxDiv-MBMS | Qualcomm | Serge Willenegger (sergew@qualcomm.com) | Rel-7 | Issam | RInImp-RxDiv-MBMS | RP-060678 |  |  |  |
| 8002 | 2595.9.3 | Additional minimum UE performance requirement for downlink physical channels in support of E-DCH operation based on type 1 enhanced receiver (Rx-Diversity) |  | 198d? | 2006-03-15 A | 2006-12-15 A | 100% | 2006-03-15 | 2006-12-15 | 198d? | finish no earlier than 2006-12-15 |  | R4 | 1584h | 1584h | RInImp-RxDiv-EDCH | Qualcomm | Serge Willenegger (sergew@qualcomm.com) | Rel-7 | Issam | RInImp-RxDiv-EDCH | RP-060679 |  |  |  |
| 8003 | 2595.10 | Deleted Improved support of gaming over HSDPA/EDCH |  | 262d? | 2005-12-15 A | 2006-12-15 A | 100% | 2005-12-15 | 2006-12-15 | 262d? | finish no earlier than 2006-12-15 |  | R2 | 2096h | 2096h | RInImp-Gaming | Cingular | Don Zelmer (dz1069@att.com) | Rel-7 | Yong-Jun | RInImp-Gaming | RP-060680 | RP-34 |  |  |
| 8004 | 2595.11 | Deleted (not approved at PCG) - UMTS 2.6 GHz FDD DL External | milestone | 0d? | 2005-09-15 A | 2005-09-15 A | 100% | 2005-09-15 | 2005-09-15 | 0d? | finish no earlier than 2005-09-15 |  | R4 |  |  | RInImp-UMTS2600Ext | T-mobile | han.van.bussel@t-mobile.de | Rel-7 | Issam | RInImp-UMTS2600Ext |  | RP-31 | PCG-16 |  |
| 8005 | 2596 | **Rel-7 Improvements of the Radio Interface - UE Conformance Testing** |  | 1074d? | 2005-11-11 A | 2008-09-12 A | 100% | 2005-11-11 | 2008-09-12 | 741d? |  |  | R5 | 17568h | 17568h |  |  |  | Rel-7 | Ingbert |  |  |  |  |  |
| 8006 | 16.5.1 | UE Conformance Test for UMTS 2600 MHz |  | 146d | 2005-11-11 A | 2006-06-02 A | 100% | 2005-11-11 | 2006-06-02 | 146d | finish no earlier than 2006-06-02 | 2006-06-02 | R5 | 1168h | 1168h | RInImp-UMTS2600_Test | Nokia | Aleksi.Heino@nokia.com | Rel-7 | Ingbert | RInImp-UMTS2600_Test |  |  |  | Fri 7/11/05 |
| 8007 | 16.5.1 | UE Conformance Test for UMTS 900 MHz (band VIII) |  | 146d | 2005-11-11 A | 2006-06-02 A | 100% | 2005-11-11 | 2006-06-02 | 146d | finish no earlier than 2006-06-02 | 2006-06-02 | R5 | 1168h | 1168h | RInImp-UMTS900_Test | Qualcomm | hanye@qualcomm.com | Rel-7 | Ingbert | RInImp-UMTS900_Test |  |  |  | Fri 11/03/05 |
| 8008 | 2596.3 | Conformance Test Aspects – Improved Performance of HSDPA Receiver type 3 |  | 191d? | 2006-03-10 A | 2006-12-01 A | 100% | 2006-03-10 | 2006-12-01 | 191d? | finish no earlier than 2006-12-01 |  | R5 | 1528h | 1528h | RInImp-HSPerf-Type3_Test | Motorola | carolyn.taylor@motorola.com | Rel-7 | Ingbert | RInImp-HSPerf-Type3_Test |  |  |  |  |
| 8009 | 2596.4 | UE antenna Over The Air (OTA) conformance testing |  | 518d? | 2006-09-20 A | 2008-09-12 A | 100% | 2006-09-20 | 2008-09-12 | 518d? | finish no earlier than 2008-09-12 |  | R5 | 4144h | 4144h | RInImp-UEAnt_Test | Nokia | Aleksi.Heino@nokia.com | Rel-7 | Ingbert | RInImp-UEAnt_Test | RP-080535 |  |  |  |
| 8010 | 2596.5 | UE conformance testing for FDD Inter-Band Operation |  | 131d? | 2006-06-02 A | 2006-12-01 A | 100% | 2006-06-02 | 2006-12-01 | 131d? | finish no earlier than 2006-12-01 |  | R5 | 1048h | 1048h | RInImp-InterBand_Test | NEC, Motorola | Jacob.John@motorola.com | Rel-7 | Ingbert | RInImp-InterBand_Test |  |  |  |  |
| 8011 | 2596.6 | Conformance Test Aspects – Extended UMTS 1.7/2.1 GHz |  | 131d? | 2006-12-01 A | 2007-06-01 A | 100% | 2006-12-01 | 2007-06-01 | 131d? | finish no earlier than 2007-06-01 |  | R5 | 1048h | 1048h | RInImp-UEConTest_UMTS1721Ext | Motorola | carolyn.taylor@motorola.com | Rel-7 | Ingbert | RInImp-UEConTest_UMTS1721Ext | RP-070312 |  |  |  |
| 8012 | 2596.7 | Conformance Test Aspects – Minimum UE performance requirement for downlink physical channels in support of E-DCH operation based on type 1 enhanced receiver (Rx-Diversity) |  | 136d? | 2007-06-01 A | 2007-12-07 A | 100% | 2007-06-01 | 2007-12-07 | 136d? | finish no earlier than 2007-12-07 |  | R5 | 1088h | 1088h | RInImp-UEConTest_RxDivEDCH | Motorola | carolyn.taylor@motorola.com | Rel-7 | Ingbert | RInImp-UEConTest_RxDivEDCH | RP-070810 |  |  |  |
| 8013 | 2596.8 | Conformance Test Aspects – Minimum UE performance requirement for downlink physical channels in support of MTCGH and MCCH operation based on type 1 enhanced receiver (Rx-Diversity) |  | 201d? | 2007-06-01 A | 2008-03-07 A | 100% | 2007-06-01 | 2008-03-07 | 201d? | finish no earlier than 2008-03-07 |  | R5 | 1608h | 1608h | RInImp-UEConTest_RxDivMBMS | Ericsson | leif.mattisson@ericsson.com | Rel-7 | Ingbert | RInImp-UEConTest_RxDivMBMS | RP-080056 |  |  |  |
| 8014 | 2597 | **Rel-7 RAN improvements** |  | 945.5d? | 2004-12-15 A | 2007-06-15 A | 100% | 2004-12-15 | 2007-06-15 | 653d? |  |  | RP; S5 | 39512h | 39512h |  |  |  | Rel-7 |  |  |  |  |  |  |
| 8015 | 2597.1 | Optimization of channelisation code utilisation for 1.28 Mcps TDD |  | 523d? | 2004-12-15 A | 2006-12-15 A | 100% | 2004-12-15 | 2006-12-15 | 523d? | finish no earlier than 2006-12-15 |  | R1 | 4184h | 4184h | RANimp-RABSE-CodOptLCRTDD | UTStarcom | Ka Leong Lo (kaleong.lo@UTSTAR.COM) | Rel-7 | Patrick | RANimp-RABSE-CodOptLCRTDD | RP-060682 |  |  |  |
| 8016 | 2597.2 | Delay optimization for procedures applicable to CS and PS Connections |  | 394d? | 2005-03-15 A | 2006-09-15 A | 100% | 2005-03-15 | 2006-09-15 | 394d? | finish no earlier than 2006-09-15 |  | R2 | 3152h | 3152h | RANimp-DelayOpt | Nokia | juho.pirskanen@nokia.com | Rel-7 | Yong-Jun | RANimp-DelayOpt | RP-060453 |  |  |  |
| 8017 | 2597.3 | Improved support of IMS Realtime Services using HSDPA/HSUPA |  | 197d? | 2005-03-15 A | 2005-12-14 A | 100% | 2005-03-15 | 2005-12-14 | 197d? | start no earlier than 2005-03-15 |  | R2 | 1576h | 1576h | RANimp-IMSRealTime | Cingular | Don Zelmer (dz1069@att.com) | Rel-7 | Yong-Jun | RANimp-IMSRealTime | RP-050667 |  |  |  |
| 8018 | 2597.4 | UE Performance Requirements for MBMS (TDD) |  | 328d? | 2005-03-15 A | 2006-06-15 A | 100% | 2005-03-15 | 2006-06-15 | 328d? | finish no earlier than 2006-06-15 |  | R4 | 2624h | 2624h | MBMS-RAN-RF-TDD | IPwireless | shwong@ipwireless.com | Rel-7 | Issam | MBMS-RAN-RF-TDD | RP-060477 |  |  |  |
| 8019 | 2597.5 | Continuous connectivity for packet data users |  | 524d? | 2005-03-14 A | 2007-03-15 A | 100% | 2005-03-14 | 2007-03-15 | 524d? | finish no earlier than 2007-03-15 |  | R1 | 4192h | 4192h | RANimp-CPC | Siemens | Joern.Krause@siemens.com | Rel-7 | Patrick | RANimp-CPC | RP-070033 |  |  |  |
| 8020 | 2597.6 | Extended WCDMA Cell Range |  | 198d? | 2006-03-15 A | 2006-12-15 A | 100% | 2006-03-15 | 2006-12-15 | 198d? | finish no earlier than 2006-12-15 |  | R3 | 1584h | 1584h | RANimp-ExtCell | Ericsson | Muhammad Kazmi | Rel-7 | Juha | RANimp-ExtCell | RP-060685 |  |  |  |
| 8021 | 2597.7 | 7.68 Mcps TDD Enhanced Uplink |  | 198d? | 2006-03-15 A | 2006-12-15 A | 100% | 2006-03-15 | 2006-12-15 | 198d? | finish no earlier than 2006-12-15 |  | R1 | 1584h | 1584h | RANimp-VHCRTDD-EDCH | IPwireless | nanderson@ipwireless.com | Rel-7 | Patrick | RANimp-VHCRTDD-EDCH | RP-060684 |  |  |  |
| 8022 | 2597.8 | Enhanced CELL_FACH State in FDD |  | 181d? | 2006-09-25 A | 2007-06-04 A | 100% | 2006-09-25 | 2007-06-04 | 181d? | finish no earlier than 2007-06-04 |  | R2 | 1448h | 1448h | RANimp-EnhState | Nokia | juho.pirskanen@nokia.com | Rel-7 | Yong-Jun | RANimp-EnhState | RP-070286 |  |  |  |
| 8023 | 2597.9 | 64QAM for HSDPA (FDD) |  | 110d? | 2006-12-15 A | 2007-06-04 A | 100% | 2006-12-15 | 2007-06-04 | 110d? | finish no earlier than 2007-06-04 |  | R1 | 880h | 880h | RANimp-64QamDownlink | Ericsson | Johan.Bergman@ericsson.com | Rel-7 | Patrick | RANimp-64QamDownlink | RP-070287 |  |  |  |
| 8024 | 2597.10 | Improved L2 support for high data rates |  | 122d? | 2006-12-15 A | 2007-06-04 A | 100% | 2006-12-15 | 2007-06-04 | 122d? | finish no earlier than 2007-06-04 |  | R2 | 976h | 976h | RANimp-L2DataRates | Ericsson | Janne.Peisa@ericsson.com | Rel-7 | Yong-Jun | RANimp-L2DataRates | RP-070289 |  |  |  |
| 8025 | 2597.11 | Introduction of 16QAM in HSUPA (FDD) |  | 110d? | 2006-12-15 A | 2007-06-04 A | 100% | 2006-12-15 | 2007-06-04 | 110d? | finish no earlier than 2007-06-04 |  | R1 | 880h | 880h | RANimp-16QamUplink | Nokia | Karri.Ranta-aho@nsn.com | Rel-7 | Patrick | RANimp-16QamUplink | RP-070288 |  |  |  |

Notes:
- 7999: - / Impacted TSs and TRs: 25.101
- 8000: RP#32 completed / Impacted TSs and TRs: 25.101
- 8001: RP#34 completed / Impacted TSs and TRs: 25.101
- 8002: RP#34 completed / Impacted TSs and TRs: 25.101
- 8003: RP#34 stopped. SR in RP-060680
- 8004: This item was conditionnaly approved pending decision of PCG#16 who decided not to approve it / Impacted TSs and TRs: 25.101; 25.104; 25.133; 25.141; 25.331; 25.942; 25.306; 25.307; 34.121
- 8005: Linked to Feature UID_20028 (RInImp)
- 8006: RP#32 completed / Impacted TSs and TRs: 34.108; 34.121
- 8007: RP#32 completed / Impacted TSs and TRs: 34.108; 34.121
- 8008: RP#34 completed / Impacted TSs and TRs: 34.121; 34.108
- 8009: RP#41 completed (GERAN aspects might need to be included later) / Impacted TSs and TRs: 34.114
- 8010: RP#34 completed / Impacted TSs and TRs: 34.108; 34.123-1; 34.123-2; 34.123-3
- 8011: RP#36 completed / Impacted TSs and TRs: 34.108; 34.121-1; 34.121-2
- 8012: RP#38 completed
- 8013: RP#39 completed / Impacted TSs and TRs: 34.121-1; 34.121-2
- 8014: Generic feature
- 8015: RP#34 completed
- 8016: RP#33 completed / Impacted TSs and TRs: 25.815; 25.321; 25.322; 25.331
- 8017: RP#30 completed
- 8018: RP#32 completed / Impacted TSs and TRs: 25.102; 25.123
- 8019: RP#35 completed / Impacted TSs and TRs: 25.903; 25.201; 25.211; 25.212; 25.214; 25.308; 25.321; 25.331; 25.423; 25.433; 25.101; 25.133
- 8020: RP#34 completed / Impacted TSs and TRs: 25.133; 25.423; 25.425; 25.433; 25.435; 25.453; 25.331
- 8021: RP#34 completed / Impacted TSs and TRs: 25.201; 25.202; 25.221; 25.222; 25.223; 25.224; 25.225; 25.331; 23.321; 25.306; 25.302; 25.401; 25.420; 25.423; 25.427; 25.433; 25.102; 25.105; 25.142
- 8022: RP#36 completed / Impacted TSs and TRs: 25.308; 25.304; 25.306; 25.321; 25.331; 25.433; 25.435; 25.423; 25.425.
- 8023: RP#36 completed / Impacted TSs and TRs: 25.308; 25.211; 25.212; 25.213; 25.306; 25.331; 25.433; 25.435; 25.423; 25.425; 25.101; 25.104; 25.141
- 8024: RP#36 completed / Impacted TSs and TRs: 25.301; 25.308.25.306; 25.321; 25.322; 25.331; 25.433; 25.435; 25.423; 25.425; 25.999
- 8025: RP#36 completed / Impacted TSs and TRs: 25.319; 25.101; 25.104; 25.133; 25.141; 25.211; 25.212; 25.213; 25.214; 25.306; 25.321; 25.331; 25.423; 25.433

| ID | WBS | Task | Duration | Start | Finish | Complete | Baseline start | Baseline finish | Baseline duration | Constraint | Resources | Work | Actual work | Acronym | WI rapporteur name | WI rapporteur e-mail | Release | MCC resp | Status Report | Acronym_3GU_Export | PCG approved | TSG approved |
| --- | --- | --- | --- | --- | --- | --- | --- | --- | --- | --- | --- | --- | --- | --- | --- | --- | --- | --- | --- | --- | --- | --- |
| 8026 | 2597.12 | **Interface to control Tower Mounted Amplifiers (TMAs)** | 392.5d? | 2006-06-02 A | 2007-06-15 A | 100% | 2006-06-02 | 2007-06-15 | 271d? |  | R3; S5 | 5984h | 5984h | RANImp-TMA | Vodafone | alexej.kulakov@vodafone.com | Rel-7 | Juha | RP-070140 | RANImp-TMA |  |  |
| 8027 | 2597.12.1 | RAN3 part of Interface to control Tower Mounted Amplifiers (TMAs) | 298.25d? | 2006-06-02 A | 2007-03-16 A | 100% | 2006-06-02 | 2007-03-16 | 206d? |  | R3 | 840h | 840h |  | Vodafone | alexej.kulakov@vodafone.com | Rel-7 | Juha | RP-070140 |  |  |  |
| 8028 | 2597.12.2 | OAM aspects to Interface to control TMAs | 101d? | 2007-01-26 A | 2007-06-15 A | 100% | 2007-01-26 | 2007-06-15 | 101d? | finish no earlier than 2007-06-15 | S5 | 808h | 808h | RANImp-TMA-OAM | Vodafone | Adrian.Neal@vodafone.com | Rel-7 | Mirko |  | RANImp-TMA-OAM |  |  |
| 8029 | 2598 | **Rel-7 RAN improvements - UE Conformance Testing** | 1133.88d? | 2006-09-20 A | 2009-09-18 A | 100% | 2006-09-20 | 2009-09-18 | 784d? |  | R5 | 25472h | 25472h |  |  |  | Rel-7 | Ingbert |  |  |  |  |
| 8030 | 2598.1 | Conformance Test Aspects - 3.84 Mcps and 7.68 Mcps TDD Enhanced Uplink | 518d? | 2006-09-20 A | 2008-09-12 A | 100% | 2006-09-20 | 2008-09-12 | 518d? | finish no earlier than 2008-09-12 | R5 | 4144h | 4144h | RANimp-UEConTest_EDCHTDH | IPWireless | tspeight@ipwireless.com | Rel-7 | Ingbert | RP-080536 | RANimp-UEConTest_EDCHTDH |  |  |
| 8031 | 2598.2 | Conformance Test Aspects – 64QAM for HSDPA (FDD) | 257d? | 2007-03-09 A | 2008-03-03 A | 100% | 2007-03-09 | 2008-03-03 | 257d? | finish no earlier than 2008-03-03 | R5 | 2056h | 2056h | RANimp-UEConTest_64QamDownlink | Ericsson | leif.mattisson@ericsson.com | Rel-7 | Ingbert | RP-080059 | RANimp-UEConTest_64QamDownlink |  |  |
| 8032 | 2598.3 | Conformance Test Aspects – 16QAM for HSUPA (FDD) | 321d? | 2007-03-09 A | 2008-05-30 A | 100% | 2007-03-09 | 2008-05-30 | 321d? | finish no earlier than 2008-05-30 | R5 | 2568h | 2568h | RANimp-UEConTest_16QamUplink | Motorola | carolyn.taylor@motorola.com | Rel-7 | Ingbert | RP-080281 | RANimp-UEConTest_16QamUplink |  |  |
| 8033 | 2598.4 | Conformance Test Aspects – Improved L2 support for high data rates | 321d? | 2007-03-09 A | 2008-05-30 A | 100% | 2007-03-09 | 2008-05-30 | 321d? | finish no earlier than 2008-05-30 | R5 | 2568h | 2568h | RANimp-UEConTest_L2DataRates | Ericsson | leif.mattisson@ericsson.com | Rel-7 | Ingbert | RP-080256 | RANimp-UEConTest_L2DataRates |  |  |
| 8034 | 2598.5 | Conformance Test Aspects – Continuous connectivity for packet data users | 321d? | 2007-03-09 A | 2008-05-30 A | 100% | 2007-03-09 | 2008-05-30 | 321d? | finish no earlier than 2008-05-30 | R5 | 2568h | 2568h | RANimp-UEConTest_CPC | Nokia | jarkko.hellsten@nokia.com | Rel-7 | Ingbert | RP-080282 | RANimp-UEConTest_CPC |  |  |
| 8035 | 2598.6 | Conformance Test Aspects – Enhanced CELL_FACH state in FDD | 662d? | 2007-03-09 A | 2009-09-18 A | 100% | 2007-03-09 | 2009-09-18 | 662d? | finish no earlier than 2009-09-18 | R5 | 5296h | 5296h | RANimp-UEConTest_EnhancedCellFACHState | Nokia | jarkko.hellsten@nokia.com | Rel-7 | Ingbert | RP-090711 | RANimp-UEConTest_EnhancedCellFACHState |  |  |
| 8036 | 2599 | **7.68 Mcps TDD option** | 1134d? | 2004-09-15 A | 2007-09-14 A | 100% | 2004-09-15 | 2007-09-14 | 783d? |  | R1; R2; R3; R4; R5 | 49552h | 49552h | VHCRTDD | IPwireless | Martin Beale (mbeale@ipwireless.com) | Rel-7 | Patrick | RP-060684 | VHCRTDD |  |  |
| 8037 | 2599.1 | VHCRTDD: Stage 2 | 391d? | 2004-09-15 A | 2006-03-15 A | 100% | 2004-09-15 | 2006-03-15 | 391d? | finish no earlier than 2006-03-15 | R1 | 3128h | 3128h | VHCRTDD-Stage2 | IPwireless | Martin Beale (mbeale@ipwireless.com) | Rel-7 | Patrick | RP-060684 | VHCRTDD-Stage2 |  |  |
| 8038 | 2599.2 | VHCRTDD: Physical Layer | 391d? | 2004-09-15 A | 2006-03-15 A | 100% | 2004-09-15 | 2006-03-15 | 391d? | finish no earlier than 2006-03-15 | R1 | 3128h | 3128h | VHCRTDD-Phys | IPwireless | Martin Beale (mbeale@ipwireless.com) | Rel-7 | Patrick | RP-060684 | VHCRTDD-Phys |  |  |
| 8039 | 2599.3 | VHCRTDD: Layer 2 and layer 3 protocol aspects | 391d? | 2004-09-15 A | 2006-03-15 A | 100% | 2004-09-15 | 2006-03-15 | 391d? | finish no earlier than 2006-03-15 | R2 | 3128h | 3128h | VHCRTDD-L23 | IPwireless | drichards@ipwireless.com | Rel-7 | Yong-Jun | RP-060684 | VHCRTDD-L23 |  |  |
| 8040 | 2599.4 | VHCRTDD: UTRAN Iub/Iur Protocol Aspects | 391d? | 2004-09-15 A | 2006-03-15 A | 100% | 2004-09-15 | 2006-03-15 | 391d? | finish no earlier than 2006-03-15 | R3 | 3128h | 3128h | VHCRTDD-IurIub | IPwireless | Peter Legg (plegg@ipwireless.com) | Rel-7 | Juha | RP-060684 | VHCRTDD-IurIub |  |  |
| 8041 | 2599.5 | VHCRTDD: RF Radio Transmission/ Reception, System Performance Requirements and Conformance Testing | 457d? | 2004-09-15 A | 2006-06-15 A | 100% | 2004-09-15 | 2006-06-15 | 457d? | finish no earlier than 2006-06-15 | R4 | 3656h | 3656h | VHCRTDD-RF | IPwireless | Shin Horng Wong (shwong@ipwireless.com) | Rel-7 | Issam | RP-060684 | VHCRTDD-RF |  |  |
| 8042 | 2599.6 | Conformance Test Aspects - 7.68 Mcps TDD | 258d? | 2006-09-20 A | 2007-09-14 A | 100% | 2006-09-20 | 2007-09-14 | 258d? | finish no earlier than 2007-09-10 | R5 | 2064h | 2064h | VHCRTDD-UEConTest | IPWireless | tspeight@ipwireless.com | Rel-7 | Ingbert | RP-070307 | VHCRTDD-UEConTest |  |  |
| 8043 | 2600 | **3.84 Mcps TDD Enhanced Uplink** | 569.5d? | 2005-03-15 A | 2006-09-15 A | 100% | 2005-03-15 | 2006-09-15 | 394d? |  | RP | 18384h | 18384h | EDCHTDD | IPwireless | nanderson@ipwireless.com | Rel-7 |  | RP-060462 | EDCHTDD |  |  |
| 8044 | 2600.1 | EDCHTDD: Stage 2 | 328d? | 2005-03-15 A | 2006-06-15 A | 100% | 2005-03-15 | 2006-06-15 | 328d? | finish no earlier than 2006-06-15 | R2 | 2624h | 2624h | EDCHTDD-Stage2 | IPwireless | nanderson@ipwireless.com | Rel-7 | Yong-Jun | RP-060462 | EDCHTDD-Stage2 |  |  |
| 8045 | 2600.2 | EDCHTDD: Physical Layer | 394d? | 2005-03-15 A | 2006-09-15 A | 100% | 2005-03-15 | 2006-09-15 | 394d? | finish no earlier than 2006-09-15 | R1 | 3152h | 3152h | EDCHTDD-Phys | IPwireless | nanderson@ipwireless.com | Rel-7 | Patrick | RP-060462 | EDCHTDD-Phys |  |  |
| 8046 | 2600.3 | EDCHTDD: Layer 2 and 3 Protocol Aspects | 394d? | 2005-03-15 A | 2006-09-15 A | 100% | 2005-03-15 | 2006-09-15 | 394d? | finish no earlier than 2006-09-15 | R2 | 3152h | 3152h | EDCHTDD-L23 | IPwireless | drichards@ipwireless.com | Rel-7 | Yong-Jun | RP-060462 | EDCHTDD-L23 |  |  |
| 8047 | 2600.4 | EDCHTDD: UTRAN Iub/Iur Protocol Aspects | 394d? | 2005-03-15 A | 2006-09-15 A | 100% | 2005-03-15 | 2006-09-15 | 394d? | finish no earlier than 2006-09-15 | R3 | 3152h | 3152h | EDCHTDD-IurIub | Interdigital | jim.miller@interdigital.com | Rel-7 | Juha | RP-060462 | EDCHTDD-IurIub |  |  |
| 8048 | 2600.5 | EDCHTDD: RF Radio Transmission/ Reception, System Performance Requirements and Conformance Testing | 394d? | 2005-03-15 A | 2006-09-15 A | 100% | 2005-03-15 | 2006-09-15 | 394d? | finish no earlier than 2006-09-15 | R4 | 3152h | 3152h | EDCHTDD-RF | IPwireless | Shin Horng Wong (shwong@ipwireless.com) | Rel-7 | Issam | RP-060462 | EDCHTDD-RF |  |  |
| 8049 | 2601 | **1.28 Mcps TDD Enhanced Uplink** | 945.5d? | 2006-03-15 A | 2008-09-12 A | 100% | 2006-03-15 | 2008-09-12 | 653d? |  | R1; R2; R3; R4; R5 | 35656h | 35656h | LCRTDD-EDCH | CATT | Haijing Hu | Rel-7 | Patrick | RP-070296 | LCRTDD-EDCH |  |  |
| 8050 | 2601.1 | 1.28 Mcps TDD Enhanced Uplink: Physical Layer | 262d? | 2006-03-15 A | 2007-03-15 A | 100% | 2006-03-15 | 2007-03-15 | 262d? | finish no earlier than 2007-03-15 | R1 | 2096h | 2096h | LCRTDD-EDCH-Phys | CATT | Ke Wang | Rel-7 | Patrick | RP-070038 | LCRTDD-EDCH-Phys |  |  |
| 8051 | 2601.2 | 1.28 Mcps TDD Enhanced Uplink: Layer 2 and 3 Protocol Aspects | 262d? | 2006-03-15 A | 2007-03-15 A | 100% | 2006-03-15 | 2007-03-15 | 262d? | finish no earlier than 2007-03-15 | R2 | 2096h | 2096h | LCRTDD-EDCH-L23 | CATT | Haiyang Quan | Rel-7 | Yong-Jun | RP-070038 | LCRTDD-EDCH-L23 |  |  |
| 8052 | 2601.3 | 1.28 Mcps TDD Enhanced Uplink: UTRAN Iub/Iur Protocol Aspects | 262d? | 2006-03-15 A | 2007-03-15 A | 100% | 2006-03-15 | 2007-03-15 | 262d? | finish no earlier than 2007-03-15 | R3 | 2096h | 2096h | LCRTDD-EDCH-IubIur | CATT | Yincheng Zhang | Rel-7 | Juha | RP-070038 | LCRTDD-EDCH-IubIur |  |  |
| 8053 | 2601.4 | 1.28 Mcps TDD Enhanced Uplink: RF Radio Transmission/ Reception, System Performance Requirements and Conformance Testing | 328d? | 2006-03-15 A | 2007-06-15 A | 100% | 2006-03-15 | 2007-06-15 | 328d? | finish no earlier than 2007-06-15 | R4 | 2624h | 2624h | LCRTDD-EDCH-RF | CATT | Yuexia Song (songyuexia@catt.cn) | Rel-7 | Issam | RP-070296 | LCRTDD-EDCH-RF |  |  |
| 8054 | 2601.5 | 1.28 Mcps TDD Enhanced Uplink - UE Conformance Testing | 371.75d? | 2007-09-20 A | 2008-09-12 A | 100% | 2007-09-20 | 2008-09-12 | 257d? | finish no earlier than 2008-09-11 | R5 | 624h | 624h | LCRTDD-EDCH-UEConTest | CATT | chenxiaozhong@datangmobile.cn | Rel-7 | Ingbert | RP-080539 | LCRTDD-EDCH-UEConTest |  |  |
| 8055 | 2602 | Conformance Test Aspects – Multiple Band and Multiple Frequency operation for LCR TDD | 263d? | 2010-09-17 A | 2011-09-16 A | 100% | 2010-09-17 | 2011-09-16 | 263d? | finish no earlier than 2011-12-09 | R5 | 2091.37h | 2091.37h | LCRTDD_MB_MF_UEConTest | CATR | Ms Jun Chen (chenjun@catr.cn) | Rel-7 | Ingbert | RP-110968 | LCRTDD_MB_MF_UEConTest | 25 | 49 |
| 8056 | 2603 | MS Antenna Performance Evaluation Method and Requirements | 731d? | 2005-01-28 A | 2007-11-16 A | 100% | 2005-01-28 | 2007-11-16 | 731d? | finish no earlier than 2007-11-16 | GP | 5848h | 5848h | APEMR | TeliaSonera | Ulf.Tegth@teliasonera.com | Rel-7 | Paolo |  | APEMR |  |  |

Notes:
- 8026: RP#35 completed
- 8027: RP#35 completed
- 8028: SP#36 completed / Impacted TSs and TRs: 32.642; 32.643; 32.645 – Align with RAN 25.466
- 8029: Linked to Feature UID_20029 (RANimp)
- 8030: RP#41 completed / Impacted TSs and TRs: 34.108; 34.122; 34.123-1; 34.123-2; 34.123-3
- 8031: RP#39 completed / Impacted TSs and TRs: 34.108; 34.121-1; 34.121-2; 34.123-1; 34.123-2; 34.123-3
- 8032: RP#40 completed / Impacted TSs and TRs: 34.108; 34.121-1; 34.121-2; 34.123-1; 34.123-2; 34.123-3
- 8033: RP#40 completed / Impacted TSs and TRs: 34.108; 34.123-1; 34.123-2; 34.123-3
- 8034: RP#40 completed / Impacted TSs and TRs: 34.108; 34.121-1; 34.121-2; 34.123-1; 34.123-2; 34.123-3
- 8035: RP#45 completed / Impacted TSs and TRs: 34.108; 34.123-1; 34.123-2; 34.123-3
- 8036: RP#31 completed
- 8037: RP#31 completed / Impacted TSs and TRs: 25.202
- 8038: RP#31 completed / Impacted TSs and TRs: 25.221; 25.222; 25.223; 25.224.25.225
- 8039: RP#31 completed / Impacted TSs and TRs: 25.301; 25.302; 25.305; 25.306; 25.321; 25.331
- 8040: RP#31 completed / Impacted TSs and TRs: 25.401; 25.420; 25.423; 25.425; 25.427; 25.430; 25.433; 25.435
- 8041: RP#32 completed / Impacted TSs and TRs: 25.102; 25.105; 25.123; 25.133; 25.142
- 8042: RP#37 completed / Impacted TSs and TRs: 34.108; 34.122; 34.123-1; 34.123-2; 34.123-3
- 8043: RP#33 completed
- 8044: RP#33 completed
- 8045: RP#33 completed / Impacted TSs and TRs: 25.201; 25.221.25.222; 25.223; 25.224; 25.225
- 8046: RP#33 completed / Impacted TSs and TRs: 25.301; 25.302; 25.306; 25.321; 25.331
- 8047: RP#33 completed / Impacted TSs and TRs: 25.401; 25.420; 25.423; 25.427; 25.430; 25.433; 25.435
- 8048: RP#33 completed / Impacted TSs and TRs: 25.102; 25.105; 25.123; 25.142
- 8049: RP#35 completed
- 8050: RP#35 completed / Impacted TSs and TRs: 25.201; 25.221; 25.222; 25.223; 25.224; 25.225
- 8051: RP#35 completed / Impacted TSs and TRs: 25.301; 25.302; 25.306; 25.321; 25.331
- 8052: RP#35 completed / Impacted TSs and TRs: 25.401; 25.420; 25.423; 25.425; 25.427; 25.430; 25.433; 25.435
- 8053: RP#36 completed / Impacted TSs and TRs: 25.102; 25.105; 25.123; 25.142
- 8054: RP#41 completed / Impacted TSs and TRs: 34.108; 34.122; 34.123-1/2/3
- 8055: RP#53 completed. Core specification was introduced via Rel-7 CR under TEI7 (RP#37 RP-070650) and via 2 Rel-8 work items: RInImp9-UMTS1880TDD and RInImp8-UMTS2300TDD. / Impacted TSs and TRs: UTRA 34.108; 34.123-1; 34.123-2; 34.123-3
- 8056: GP#36 completed for R7 / Impacted TSs and TRs: 25.914; 25.144; 45.005

| ID | WBS | Task | Type | Duration | Start | Finish | Complete | Baseline start | Baseline finish | Baseline duration | Constraint | Resources | Work | Actual work | Acronym | WI rapporteur name | WI rapporteur e-mail | Release | MCC resp | Acronym_3GU_Export | TSG stopped |
| --- | --- | --- | --- | --- | --- | --- | --- | --- | --- | --- | --- | --- | --- | --- | --- | --- | --- | --- | --- | --- | --- |
| 8057 | 2604 | **Lower 700 MHz Inclusion in the GERAN Specifications** |  | 563.25d? | 2005-01-03 A | 2006-06-30 A | 100% | 2005-01-03 | 2006-06-30 | 390d? |  | GP | 9372h | 9372h | GSM710 | UTC | dcotton@mtview.union-tel.com | Rel-7 | Paolo | GSM710 |  |
| 8058 | 2604.1 | Inclusion of the 698 – 746 MHz band into GERAN core specifications |  | 129d? | 2005-01-03 A | 2005-06-30 A | 100% | 2005-01-03 | 2005-06-30 | 129d? | finish no earlier than 2005-06-30 | G1 | 1032h | 1032h | GSM710-core |  |  | Rel-7 | Paolo | GSM710-core |  |
| 8059 | 2604.2 | **Aspects of GSM710** |  | 314.25d? | 2005-08-31 A | 2006-06-30 A | 100% | 2005-08-31 | 2006-06-30 | 217.5d? |  | G1; G3new | 5220h | 5220h | GSM-710-test |  |  | Rel-7 | Paolo | GSM-710-test |  |
| 8060 | 2604.2.1 | G1 aspects of GSM710 |  | 217.5d? | 2005-08-31 A | 2006-06-30 A | 100% | 2005-08-31 | 2006-06-30 | 217.5d? | finish no earlier than 2006-06-30 | G1 | 1740h | 1740h |  |  |  | Rel-7 | Paolo |  |  |
| 8061 | 2604.2.2 | G3 aspects of GSM710 |  | 217.5d? | 2005-08-31 A | 2006-06-30 A | 100% | 2005-08-31 | 2006-06-30 | 217.5d? | finish no earlier than 2006-06-30 | G3new | 1740h | 1740h |  |  |  | Rel-7 | Ingbert |  |  |
| 8062 | 2605 | **Support of Conversational Services in A/Gb mode via the PS domain** |  | 907.25d? | 2005-04-08 A | 2007-08-31 A | 100% | 2005-04-08 | 2007-08-31 | 626d? |  | GP | 15442.8h | 15442.8h | SCSAGB | Ericsson | gunnar.hedby@ericsson.com | Rel-7 | Paolo | SCSAGB |  |
| 8063 | 2605.1 | Minimise the transfer delay between the SGSN and the MS |  | 604.95d? | 2005-04-08 A | 2007-08-31 A | 100% | 2005-04-08 | 2007-08-31 | 604.95d? | finish no earlier than 2007-08-31 | GP | 4839.6h | 4839.6h | SCSAGB-MTD | Ericsson | gunnar.hedby@ericsson.com | Rel-7 | Paolo | SCSAGB-MTD |  |
| 8064 | 2605.2 | Definition of radio resource management functionality for Support of Conversational Services in A/Gb mode via the PS domain |  | 626d? | 2005-04-08 A | 2007-08-31 A | 100% | 2005-04-08 | 2007-08-31 | 626d? | finish no earlier than 2007-08-31 | G1 | 5008h | 5008h | SCSAGB-RRM | Ericsson | gunnar.hedby@ericsson.com | Rel-7 | Paolo | SCSAGB-RRM |  |
| 8065 | 2605.3 | Support of Conversational Services in A/Gb mode via the PS domain – RLC Non-Persistent mode |  | 101d? | 2006-06-30 A | 2006-11-17 A | 100% | 2006-06-30 | 2006-11-17 | 101d? | finish no earlier than 2006-11-17 | G2 | 808h | 808h | SCSAGB-RLCNP | Ericsson | gunnar.hedby@ericsson.com | Rel-7 | Gert | SCSAGB-RLCNP |  |
| 8066 | 2605.4 | Deleted- Radio Channel Support | milestone | 0d? | 2006-07-17 A | 2006-07-17 A | 100% | 2006-07-17 | 2006-07-17 | 0d? | start no earlier than 2006-07-17 | G2 |  |  | SCSAGB-RCHS | Ericsson | gunnar.hedby@ericsson.com | Rel-7 | Gert | SCSAGB-RCHS | SP-32 |
| 8067 | 2605.5 | Deleted- Modifications to FLO | milestone | 0d? | 2006-07-17 A | 2006-07-17 A | 100% | 2006-07-17 | 2006-07-17 | 0d? | start no earlier than 2006-07-17 | G2 |  |  | SCSAGB-FLO | Ericsson | gunnar.hedby@ericsson.com | Rel-7 | Gert | SCSAGB-FLO | SP-32 |
| 8068 | 2606 | **Addition of new frequency band to GSM (T-GSM810)** |  | 907.25d? | 2005-04-08 A | 2007-08-31 A | 100% | 2005-04-08 | 2007-08-31 | 626d? |  | GP | 12112h | 12112h | TGSM810 | Huawei | chende@huawei.com | Rel-7 | Paolo | TGSM810 |  |
| 8069 | 2606.1 | Changes to core specification |  | 106d? | 2005-04-08 A | 2005-09-02 A | 100% | 2005-04-08 | 2005-09-02 | 106d? | finish no earlier than 2005-09-02 | GP | 848h | 848h | TGSM810-Core | Huawei | chende@huawei.com | Rel-7 | Paolo | TGSM810-Core |  |
| 8070 | 2606.2 | Changes to MS testing specification |  | 626d? | 2005-04-08 A | 2007-08-31 A | 100% | 2005-04-08 | 2007-08-31 | 626d? | finish no earlier than 2007-08-31 | G3new | 5008h | 5008h | TGSM810-MStest | Huawei | chende@huawei.com | Rel-7 | Ingbert | TGSM810-MStest |  |
| 8071 | 2606.3 | Changes to BTS testing specification |  | 156d? | 2005-04-08 A | 2005-11-11 A | 100% | 2005-04-08 | 2005-11-11 | 156d? | finish no earlier than 2005-11-11 | G1 | 1248h | 1248h | TGSM810-BTStest | Huawei | chende@huawei.com | Rel-7 | Paolo | TGSM810-BTStest |  |
| 8072 | 2607 | **Handover of dedicated and shared resources while in Dual Transfer Mode** |  | 610d? | 2005-04-08 A | 2006-11-17 A | 100% | 2005-04-08 | 2006-11-17 | 421d? |  | GP | 12672h | 12672h | HODSRDTM | Nokia | rami.vaittinen@nokia.com | Rel-7 | Paolo | HODSRDTM |  |
| 8073 | 2607.1 | GERAN2 part of Handover of dedicated and shared resources while in Dual Transfer Mode |  | 321d? | 2005-04-08 A | 2006-06-30 A | 100% | 2005-04-08 | 2006-06-30 | 321d? | finish no earlier than 2006-06-30 | G2 | 2568h | 2568h | HODSRDTM-G2 | Nokia | rami.vaittinen@nokia.com | Rel-7 | Gert | HODSRDTM-G2 |  |
| 8074 | 2607.2 | Deleted - MS Conformance Testing |  | 421d? | 2005-04-08 A | 2006-11-17 A | 100% | 2005-04-08 | 2006-11-17 | 421d? | finish no earlier than 2006-11-17 | G3new | 3368h | 3368h | HODSRDTM-MStest | Nokia | rami.vaittinen@nokia.com | Rel-7 | Ingbert | HODSRDTM-MStest | GP-32 |
| 8075 | 2607.3 | Deleted - BTS conformance testing |  | 421d? | 2005-04-08 A | 2006-11-17 A | 100% | 2005-04-08 | 2006-11-17 | 421d? | finish no earlier than 2006-11-17 | G1 | 3368h | 3368h | HODSRDTM-BTStest | Nokia | rami.vaittinen@nokia.com | Rel-7 | Paolo | HODSRDTM-BTStest | GP-32 |
| 8076 | 2608 | **Mobile Station Receive Diversity (DARP Phase II)** |  | 762.25d? | 2005-11-11 A | 2007-11-16 A | 100% | 2005-11-11 | 2007-11-16 | 526d? |  | GP | 16360h | 16360h | MSRD2 | Nokia | kent.pedersen@nokia.com | Rel-7 | Paolo | MSRD2 |  |
| 8077 | 2608.1 | Performance Requirements for Mobile Station Receive Diversity, DARP Phase II |  | 331d? | 2005-11-11 A | 2007-02-16 A | 100% | 2005-11-11 | 2007-02-16 | 331d? | finish no earlier than 2007-02-16 | GP | 2648h | 2648h | MSRD2-PerfReq | Nokia | kent.pedersen@nokia.com | Rel-7 | Paolo | MSRD2-PerfReq |  |
| 8078 | 2608.2 | Capability signalling of Mobile Station Receive Diversity, DARP Phase II |  | 331d? | 2005-11-11 A | 2007-02-16 A | 100% | 2005-11-11 | 2007-02-16 | 331d? | finish no earlier than 2007-02-16 | GP | 2648h | 2648h | MSRD2-CapSig | Nokia | kent.pedersen@nokia.com | Rel-7 | Paolo | MSRD2-CapSig |  |
| 8079 | 2608.3 | Test Scenarios for Mobile Station Receive Diversity, DARP Phase II |  | 331d? | 2005-11-11 A | 2007-02-16 A | 100% | 2005-11-11 | 2007-02-16 | 331d? | finish no earlier than 2007-02-16 | GP | 2648h | 2648h | MSRD2-TestSc | Nokia | kent.pedersen@nokia.com | Rel-7 | Paolo | MSRD2-TestSc |  |
| 8080 | 2608.4 | MS conformance test of DARP Phase II (MSRD) |  | 526d? | 2005-11-11 A | 2007-11-16 A | 100% | 2005-11-11 | 2007-11-16 | 526d? | finish no earlier than 2007-11-16 | GP | 4208h | 4208h | MSRD2-Msconf | Nokia | kent.pedersen@nokia.com | Rel-7 | Ingbert | MSRD2-Msconf |  |

Notes:
- 8057: -
- 8058: Completed / Impacted TSs and TRs: 24.008; 43.022; 44.018; 44.118; 45; 001; 45.005;
- 8059: -
- 8060: - / Impacted TSs and TRs: 51.021
- 8061: - / Impacted TSs and TRs: 51.010
- 8062: Originally started Nov. 2003 as GP-030443
- 8063: -
- 8064: -
- 8065: - / Impacted TSs and TRs: 43.955; 43.064; 44.060; 45.001; 45.002; 45.003; 45.005; 45.010; 51.010; 51.021
- 8066: -
- 8067: -
- 8068: - / Impacted TSs and TRs: 45.005; 45.050; 24.008; 45.008; 45.001; 43.022; 43.030; 44.018; 44.060; 51.010-1; 51.021
- 8069: - / Impacted TSs and TRs: 45.005; 45.050; 24.008; 45.008; 45.001; 43.022; 43.030; 44.018; 44.060
- 8070: - / Impacted TSs and TRs: 51010-1
- 8071: - / Impacted TSs and TRs: 51021
- 8072: GP#30 completed. Started at GP#24
- 8073: GP#30 completed / Impacted TSs and TRs: 43.055; 44.018; 44.060
- 8074: Stopped, no work done. 12/2008 Marked as stopped ("deleted") / Impacted TSs and TRs: 51-010
- 8075: Stopped, no work done. 12/2008 Marked as stopped ("deleted") / Impacted TSs and TRs: 51.026
- 8076: GP#36 completed
- 8077: GP#33 completed / Impacted TSs and TRs: 45.005
- 8078: GP#33 completed / Impacted TSs and TRs: 24.008
- 8079: GP#33 completed / Impacted TSs and TRs: 45.005
- 8080: GP#36 completed / Impacted TSs and TRs: 51.010

| ID | WBS | Task | Type | Duration | Start | Finish | Complete | Baseline start | Baseline finish | Baseline duration | Constraint | Resources | Work | Actual work | Acronym | WI rapporteur name | WI rapporteur e-mail | Release | MCC resp | Acronym_3GU_Export | TSG stopped |
| --- | --- | --- | --- | --- | --- | --- | --- | --- | --- | --- | --- | --- | --- | --- | --- | --- | --- | --- | --- | --- | --- |
| 8081 | 2609 | **Downlink Dual Carrier** |  | 1371.12d? | 2006-01-20 A | 2009-09-04 A | 100% | 2006-01-20 | 2009-09-04 | 947d? |  | GP | 15446.6h | 15446.6h | GDCDL | Nokia Siemens Networks | leonardo.provvedi@roke.co.uk | Rel-7 | Paolo | GDCDL |  |
| 8082 | 2609.1 | Downlink Dual Carrier Stage 2 |  | 116d? | 2006-01-20 A | 2006-06-30 A | 100% | 2006-01-20 | 2006-06-30 | 116d? | finish no earlier than 2006-06-30 | G1 | 928h | 928h | GDCDL-Stage2 | Nokia Siemens Networks | leonardo.provvedi@roke.co.uk | Rel-7 | Paolo | GDCDL-Stage2 |  |
| 8083 | 2609.2 | Downlink Dual Carrier Stage 3 |  | 421d? | 2006-01-20 A | 2007-08-31 A | 100% | 2006-01-20 | 2007-08-31 | 421d? | finish no earlier than 2007-08-31 | G1 | 3368h | 3368h | GDCDL-Stage3 | Nokia Siemens Networks | leonardo.provvedi@roke.co.uk | Rel-7 | Paolo | GDCDL-Stage3 |  |
| 8084 | 2609.3 | Downlink Dual Carrier – MS Conformance Test |  | 446.82d? | 2006-01-20 A | 2009-09-04 A | 100% | 2006-01-20 | 2009-09-04 | 446.82d? | finish no earlier than 2009-09-04 | G3new | 3574.6h | 3574.6h | GDCDL-MStest | Nokia Siemens Networks | leonardo.provvedi@roke.co.uk | Rel-7 | Ingbert | GDCDL-MStest |  |
| 8085 | 2610 | Support of SIGTRAN in GERAN |  | 116d? | 2006-01-20 A | 2006-06-30 A | 100% | 2006-01-20 | 2006-06-30 | 116d? | finish no earlier than 2006-06-30 | GP | 928h | 928h | GSIGT | Ericsson | peter.ostrup@ericsson.com | Rel-7 | Ingbert | GSIGT |  |
| 8086 | 2611 | **Latency Reductions** |  | 443.25d? | 2006-06-30 A | 2007-08-31 A | 100% | 2006-06-30 | 2007-08-31 | 306d? |  | GP | 7344h | 7344h | LATRED | Ericsson | Hakan.Persson@Ericsson.com | Rel-7 | Paolo | LATRED |  |
| 8087 | 2611.1 | Improved Ack/Nack reporting |  | 306d? | 2006-06-30 A | 2007-08-31 A | 100% | 2006-06-30 | 2007-08-31 | 306d? | finish no earlier than 2007-08-31 | G2 | 2448h | 2448h | LATRED-ACKNAR | Ericsson | Hakan.Persson@Ericsson.com | Rel-7 | Gert | LATRED-ACKNAR |  |
| 8088 | 2611.2 | Reduced TTI |  | 306d? | 2006-06-30 A | 2007-08-31 A | 100% | 2006-06-30 | 2007-08-31 | 306d? | finish no earlier than 2007-08-31 | G2 | 2448h | 2448h | LATRED-REDTTI | Ericsson | Hakan.Persson@Ericsson.com | Rel-7 | Gert | LATRED-REDTTI |  |
| 8089 | 2612 | PS Handover between GERAN/UTRAN mode and GAN Mode |  | 166d? | 2006-06-30 A | 2007-02-16 A | 100% | 2006-06-30 | 2007-02-16 | 166d? | finish no earlier than 2007-02-16 | G2 | 1328h | 1328h | GUGAN | Ericsson | John.Diachina@Ericsson.com | Rel-7 | Gert | GUGAN |  |
| 8090 | 2613 | **Higher Uplink performance for GERAN Evolution** |  | 1777.12d? | 2006-09-08 A | 2011-05-20 A | 100% | 2006-09-08 | 2011-05-20 | 1227d? |  | GP | 37184h | 37184h | HUGE | Nokia Siemens Networks, Ericsson | eddie.riddington@nokia.com, stefan.g.eriksson@ericsson.com | Rel-7 | Paolo | HUGE |  |
| 8091 | 2613.1 | Stage 2 for HUGE |  | 261d? | 2006-09-08 A | 2007-09-07 A | 100% | 2006-09-08 | 2007-09-07 | 261d? | finish no earlier than 2007-09-07 | G1 | 2088h | 2088h | HUGE-Stage2 | Nokia Siemens Networks, Ericsson | eddie.riddington@nokia.com, stefan.g.eriksson@ericsson.com | Rel-7 | Paolo | HUGE-Stage2 |  |
| 8092 | 2613.2 | Layer 1 Support for HUGE |  | 381d? | 2006-09-08 A | 2008-02-22 A | 100% | 2006-09-08 | 2008-02-22 | 381d? | finish no earlier than 2008-02-22 | G1 | 3048h | 3048h | HUGE-Layer1 | Nokia Siemens Networks, Ericsson | eddie.riddington@nokia.com, stefan.g.eriksson@ericsson.com | Rel-7 | Paolo | HUGE-Layer1 |  |
| 8093 | 2613.3 | Layer 2/3 Support for HUGE |  | 256d? | 2006-09-08 A | 2007-08-31 A | 100% | 2006-09-08 | 2007-08-31 | 256d? | finish no earlier than 2007-08-31 | G2 | 2048h | 2048h | HUGE-Layer23 | Nokia Siemens Networks, Ericsson | eddie.riddington@nokia.com, stefan.g.eriksson@ericsson.com | Rel-7 | Gert | HUGE-Layer23 |  |
| 8094 | 2613.4 | Performance requirements for HUGE |  | 516d? | 2006-09-08 A | 2008-08-29 A | 100% | 2006-09-08 | 2008-08-29 | 516d? | finish no earlier than 2008-08-29 | G1 | 4128h | 4128h | HUGE-Perfreq | Nokia Siemens Networks, Ericsson | eddie.riddington@nokia.com, stefan.g.eriksson@ericsson.com | Rel-7 | Paolo | HUGE-Perfreq |  |
| 8095 | 2613.5 | BTS Conformance Test for HUGE |  | 782d? | 2006-09-08 A | 2009-09-04 A | 100% | 2006-09-08 | 2009-09-04 | 782d? | finish no earlier than 2009-09-04 | G1 | 6248h | 6248h | HUGE-BTStest | Nokia Siemens Networks, Ericsson | eddie.riddington@nokia.com, stefan.g.eriksson@ericsson.com | Rel-7 | Paolo | HUGE-BTStest |  |
| 8096 | 2613.6 | MS Conformance Test for HUGE |  | 1226d? | 2006-09-08 A | 2011-05-20 A | 100% | 2006-09-08 | 2011-05-20 | 1226d? | finish no earlier than 2011-05-20 | G3new | 9808h | 9808h | HUGE-Mstest | Nokia Siemens Networks, Ericsson | eddie.riddington@nokia.com, stefan.g.eriksson@ericsson.com | Rel-7 | Ingbert | HUGE-Mstest |  |
| 8097 | 2614 | **REduced symbol Duration, Higher Order modulation and Turbo coding (RED HOT) for downlink** |  | 1704.62d? | 2006-11-17 A | 2011-05-20 A | 100% | 2006-11-17 | 2011-05-20 | 1177d? |  | GP | 28808h | 28808h | REDHOT | Ericsson, Nokia Siemens Networks, Marvell | stefan.g.eriksson@ericsson.com | Rel-7 | Paolo | REDHOT |  |
| 8098 | 2614.1 | Stage 2 for REDHOT |  | 206d? | 2006-11-17 A | 2007-08-31 A | 100% | 2006-11-17 | 2007-08-31 | 206d? | finish no earlier than 2007-08-31 | G1 | 1648h | 1648h | REDHOT-Stage2 | Ericsson, Nokia Siemens Networks, Marvell | stefan.g.eriksson@ericsson.com | Rel-7 | Paolo | REDHOT-Stage2 |  |
| 8099 | 2614.2 | Stage 3 for REDHOT |  | 391d? | 2006-11-17 A | 2008-05-16 A | 100% | 2006-11-17 | 2008-05-16 | 391d? | finish no earlier than 2008-05-16 | G1 | 3128h | 3128h | REDHOT-Stage3 | Ericsson, Nokia Siemens Networks, Marvell | stefan.g.eriksson@ericsson.com | Rel-7 | Paolo | REDHOT-Stage3 |  |
| 8100 | 2614.3 | BTS Conformance Tests for REDHOT |  | 651d? | 2006-11-17 A | 2009-05-15 A | 100% | 2006-11-17 | 2009-05-15 | 651d? | finish no earlier than 2009-05-15 | G1 | 5208h | 5208h | REDHOT-BTStest | Ericsson, Nokia Siemens Networks, Marvell | stefan.g.eriksson@ericsson.com | Rel-7 | Paolo | REDHOT-BTStest |  |
| 8101 | 2614.4 | MS Conformance Tests for REDHOT |  | 1176d? | 2006-11-17 A | 2011-05-20 A | 100% | 2006-11-17 | 2011-05-20 | 1176d? | finish no earlier than 2011-05-20 | G3new | 9408h | 9408h | REDHOT-Mstest | Ericsson, Nokia Siemens Networks, Marvell | stefan.g.eriksson@ericsson.com | Rel-7 | Ingbert | REDHOT-Mstest |  |
| 8102 | 2615 | (Small) Technical Enhancements and Improvements for Rel-7 | milestone | 0d? | 2007-03-26 A | 2007-03-26 A | 100% | 2007-03-26 | 2007-03-26 | 0d? | start no earlier than 2007-03-26 | SP; CP; RP; GP |  |  | TEI7 |  |  | Rel-7 | All | TEI7 |  |
| 8103 | 2616 | Test - (Small) Technical Enhancements and Improvements for Rel-7 |  | 389d? | 2006-06-02 A | 2007-11-28 A | 100% | 2006-06-02 | 2007-11-28 | 389d? | finish no earlier than 2010-06-04 | R5 | 3112h | 3112h | TEI7_Test |  |  | Rel-7 | Ingbert | TEI7_Test |  |
| 8104 | 2617 | **Deleted - PS domain and IMS support for IMS Emergency sessions** |  | 0d? | 2006-06-23 A | 2006-06-23 A | 100% | 2006-06-23 | 2006-09-21 | 63.69d? |  | S2 |  |  | IMS-EMER | Nokia | curt.c.wong@nokia.com | Rel-7 | Maurice | IMS-EMER | SP-30 |
| 8105 | 2617.1 | Deleted - IMS aspects to support IMS Emergency sessions | milestone | 0d? | 2006-06-23 A | 2006-06-23 A | 100% | 2006-06-23 | 2006-09-21 | 0d? | start no earlier than 2006-06-23 | S2 |  |  |  | Nokia | curt.c.wong@nokia.com | Rel-7 | Maurice |  | SP-30 |
| 8106 | 2617.2 | Deleted - PS domain aspects to support IMS Emergency sessions | milestone | 0d? | 2006-06-23 A | 2006-06-23 A | 100% | 2006-06-23 | 2006-09-21 | 0d? | start no earlier than 2006-06-23 | S2 |  |  |  | Nokia | curt.c.wong@nokia.com | Rel-7 | Maurice |  | SP-30 |

Notes:
- 8081: GP#35 completed
- 8082: GP#30 completed / Impacted TSs and TRs: 43.055; 43.064
- 8083: GP#35 completed / Impacted TSs and TRs: 24.008; 44.018; 44.060; 45.001; 45.002; 45.005; 45.008
- 8084: GP#43 completed / Impacted TSs and TRs: 51.010
- 8085: GP#30 completed / Impacted TSs and TRs: 48.001; 48.006; 43.059; 49.031
- 8086: GP#35 completed / Impacted TSs and TRs: 45.001; 45.002; 45.003; 45.005; 45.010; 43.055; 43.064; 44.060; 51.010-1; 51.021
- 8087: GP#35 completed / Impacted TSs and TRs: 45.001; 45.002; 45.003; 45.005; 45.010; 43.055; 43.064; 44.060; 51.010-1; 51.021
- 8088: GP#35 completed / Impacted TSs and TRs: 45.001; 45.002; 45.003; 45.005; 45.010; 43.055; 43.064; 44.060; 51.010-1; 51.021
- 8089: GP#33 completed / Impacted TSs and TRs: 43.318; 44.318; 43.129; 25.306; 24.008; 44.060; 25.331; 51.010
- 8090: GP#39 completed
- 8091: GP#35 completed / Impacted TSs and TRs: 43.055; 43.064
- 8092: GP#37 completed / Impacted TSs and TRs: 45.001; 45.002; 45.003; 45.004; 45.008
- 8093: GP#35 completed / Impacted TSs and TRs: 24.008; 44.018; 44.060
- 8094: GP#39 completed / Impacted TSs and TRs: 45.005
- 8095: GP#43 completed / Impacted TSs and TRs: 51.021
- 8096: GP#50 completed / Impacted TSs and TRs: 51.010
- 8097: GP#38 completed
- 8098: GP#35 completed / Impacted TSs and TRs: 43.055; 43.064
- 8099: GP#38 completed / Impacted TSs and TRs: 24.008; 44.018; 44.060; 45.001; 45.002; 45.003; 45.004; 45.005; 45.008
- 8100: GP#42 completed / Impacted TSs and TRs: 51.021
- 8101: GP#50 completed / Impacted TSs and TRs: 51.010
- 8102: -
- 8103: -
- 8104: Approved at SP#29 / Impacted TSs and TRs: 23.867; 23.abc; 23.060; 23.002; 23.271
- 8105: Approved at SP#29 / Impacted TSs and TRs: 23.867; 23.abc; 23.060; 23.002; 23.271
- 8106: Approved at SP#29 / Impacted TSs and TRs: 23.867; 23.abc; 23.060; 23.002; 23.271

| ID | WBS | Task | Type | Duration | Start | Finish | Complete | Remaining | Baseline start | Baseline finish | Baseline duration | Total slack | Constraint | Resources | Work | Actual work | Acronym | Impacted TSs and TRs | Release | MCC resp | TSG stopped | Acronym_3GU_Export | WI rapporteur name | WI rapporteur e-mail | PCG approved | TSG approved | Special Focus Doc |
| --- | --- | --- | --- | --- | --- | --- | --- | --- | --- | --- | --- | --- | --- | --- | --- | --- | --- | --- | --- | --- | --- | --- | --- | --- | --- | --- | --- |
| 8107 | 16.7 | **Deleted - IMS Local services** |  | 0d? | 2006-01-06 A | 2006-01-06 | 99% | 0d? | 2006-01-06 | 2006-01-06 | 0d? | 0d |  | S2 |  |  | IMSLocal | 23.228 | Rel-7 | Maurice | SP-28 | IMSLocal |  |  |  |  |  |
| 8108 | 16.7.1 | Deleted - Stage 2 | milestone | 0d | 2006-01-06 A | 2006-01-06 A | 100% |  | 2006-01-06 | 2006-01-06 | 0d |  | start no earlier than 2006-01-06 | S2 |  |  |  |  | Rel-7 | Maurice | SP-26 |  |  |  |  |  |  |
| 8109 | 2618.2 | Deleted - Stage 3 for IMS Local services | milestone | 0d? | 2006-01-06 A | 2006-01-06 A | 100% |  | 2006-01-06 | 2006-01-06 | 0d? |  | finish no earlier than 2006-01-06 | C1 |  |  |  |  | Rel-7 | Frederic | SP-25 |  | Lucent | Keith Drage (drage@alcatel-lucent.com) |  |  |  |
| 8110 | 2619 | Deleted - IMS Phase 3 | milestone | 0d? | 2006-01-06 A | 2006-01-06 A | 100% |  | 2006-01-06 | 2006-01-06 | 0d? |  | start no earlier than 2006-01-06 | S2 |  |  |  |  | Rel-7 | Maurice | SP-25 |  |  |  |  |  |  |
| 8111 | 2620 | Deleted - Improvements of Radio Interface | milestone | 0d? | 2004-09-15 A | 2004-09-15 A | 100% |  | 2004-09-15 | 2004-09-15 | 0d? |  | start no earlier than 2004-09-15 | RP |  |  |  |  | Rel-7 | Issam | SP-24 |  |  |  | 36 | 70 |  |
| 8112 | 2621 | Deleted: Generic User Profile Phase 2 | milestone | 0d | 2005-08-08 A | 2006-03-22 A | 100% |  | 2005-08-08 | 2006-06-30 | 0d |  |  | C4 |  |  |  |  | Rel-7 | Kimmo | SP-27 |  |  |  |  |  |  |
| 8113 | 30.4 | Deleted - Stage 3 - Common objects | milestone | 0d | 2005-08-08 A | 2005-08-08 A | 100% |  | 2005-08-08 | 2006-06-30 | 0d |  | finish no earlier than 2006-06-30 | C4 |  |  |  | 24.241 | Rel-7 | Kimmo | SP-27 |  |  |  |  |  |  |
| 8114 | 2623 | Release 7 Studies |  | 841d? | 2004-06-28 A | 2007-09-17 A | 100% |  | 2004-06-28 | 2007-09-17 | 841d? |  |  | CP; GP; RP; SP | 26912h | 26912h |  |  | Rel-7 | All |  |  |  |  |  |  |  |
| 8115 | 2624 | Study on Multimedia Telephony Capabilities for IMS |  | 399.75d? | 2005-07-11 A | 2006-07-31 A | 100% |  | 2005-07-11 | 2006-07-31 | 276d? |  |  | S1 | 2145.6h | 2145.6h | MITE | 22.973 | Rel-7 | Alain |  | MITE | Ericsson | peter.bleckert@ericsson.com |  |  |  |
| 8116 | 2625 | Study on Behaviour of Multi system UEs |  | 384d? | 2004-06-28 A | 2005-12-15 A | 100% |  | 2004-06-28 | 2005-12-15 | 384d? |  | start no earlier than 2004-06-28 | S1 | 3072h | 3072h | BMSU | 22.936 | Rel-7 | Alain |  | BMSU | Qualcomm | dwilliams@qualcomm.com |  |  |  |
| 8117 | 2626 | Study on Combining CS calls and IMS sessions |  | 189d? | 2004-06-28 A | 2005-03-17 A | 100% |  | 2004-06-28 | 2005-03-17 | 189d? |  | start no earlier than 2004-06-28 | S1 | 1512h | 1512h | IRTSD-CS_IMS | 22.979 | Rel-7 | Alain |  | IRTSD-CS_IMS | TeliaSonera | robert.frank@teliasonera.com |  |  |  |
| 8118 | 2627 | Study on All-IP Network |  | 188d? | 2004-06-28 A | 2005-03-16 A | 100% |  | 2004-06-28 | 2005-03-16 | 188d? |  | start no earlier than 2004-06-28 | S1 | 1504h | 1504h | FS_AIPN | 22.978 | Rel-7 | Alain |  | FS_AIPN | NTT DoCoMo | Shin-ichi Isobe (isobes@nttdocomo.co.jp) |  |  |  |
| 8119 | 2628 | Study on Videotelephony teleservice |  | 334.5d? | 2005-03-01 A | 2006-01-17 A | 100% |  | 2005-03-01 | 2006-01-17 | 231d? |  |  | S1 | 1848h | 1848h | VidTel | 22.903 | Rel-7 | Alain |  | VidTel | T-Mobile | michael.kurz@t-mobile.at |  |  |  |
| 8120 | 2629 | Study on Network Selection Principles |  | 278.5d? | 2005-03-15 A | 2005-12-08 A | 100% |  | 2005-03-15 | 2005-12-08 | 193d? |  |  | S1 | 1544h | 1544h | NetSel | 22.811 | Rel-7 | Alain |  | NetSel | O2 | chris.friel@O2.com |  |  |  |
| 8121 | 2630 | Study on Multimedia Priority Service |  | 851d? | 2003-03-28 A | 2006-06-30 A | 100% |  | 2003-03-28 | 2006-06-30 | 851d? |  | finish no earlier than 2005-12-16 | S1 | 6808h | 6808h | PRIOR-MM | 22.953 | Rel-7 | Alain |  | PRIOR-MM | Telcordia | James Garrahan (jgarraha@telcordia.com) |  |  | Public Safety (I-A) |
| 8122 | 2631 | Study on Transferring of emergency Call data |  | 190d? | 2005-07-11 A | 2006-03-31 A | 100% |  | 2005-07-11 | 2006-03-31 | 190d? |  | finish no earlier than 2005-12-08 | S1 | 1520h | 1520h | eCALL | 22.967 | Rel-7 | Alain |  | eCALL | Motorola | jian.j.wu@motorola.com |  |  | Public Safety (I-A) |
| 8123 | 2632 | Study on Enhancement of E2E QoS |  | 281.4d? | 2004-06-28 A | 2005-09-15 A | 100% |  | 2004-06-28 | 2005-09-15 | 281.4d? |  | finish no earlier than 2005-12-01 | S2 | 2251.2h | 2251.2h | QoS7 | 23.802 | Rel-7 | Maurice |  | QoS7 | Huawei | Robert Jaksa |  |  |  |
| 8124 | 2633 | Study on SOAP/HTTP IRP Solution Sets |  | 330d? | 2005-09-02 A | 2006-12-07 A | 100% |  | 2005-09-02 | 2006-12-07 | 330d? |  | finish no earlier than 2006-12-07 | S5 | 2640h | 2640h | OAM7-NIM-XML | 32.809 | Rel-7 | Mirko |  | OAM7-NIM-XML | Nortel | Suzèle Lariven (lariven@nortel.com) |  |  |  |
| 8125 | 2634 | Study on Itf-N Implementation Conformance Statement (ICS) template |  | 400d? | 2005-09-02 A | 2007-03-15 A | 100% |  | 2005-09-02 | 2007-03-15 | 400d? |  | finish no earlier than 2007-03-15 | S5 | 3200h | 3200h | OAM7-NIM-ICS | 32.812 | Rel-7 | Mirko |  | OAM7-NIM-ICS | China Mobile | Li Yewen (liyewen@chinamobile.com) |  |  |  |
| 8126 | 2635 | Study on IRP Information Model |  | 400d? | 2005-09-02 A | 2007-03-15 A | 100% |  | 2005-09-02 | 2007-03-15 | 400d? |  | finish no earlier than 2007-03-15 | S5 | 3200h | 3200h | OAM7-NIM-IM | 32.810 | Rel-7 | Mirko |  | OAM7-NIM-IM | Motorola | trevor.pirt@motorola.com |  |  |  |
| 8127 | 2636 | Study on Bandwidth Saving at Nb Interface with IP transport |  | 261d? | 2006-03-10 A | 2007-03-09 A | 100% |  | 2006-03-10 | 2007-03-09 | 261d? |  | finish no earlier than 2007-03-09 | C3 | 2088h | 2088h | BSNbIP | 29.814 | Rel-7 | Adrian |  | BSNbIP | Siemens | Thomas.Belling@siemens.com |  |  |  |
| 8128 | 2637 | Study on Routeing of MT-SMS via the HPLMN |  | 301d? | 2005-10-07 A | 2006-12-01 A | 100% |  | 2005-10-07 | 2006-12-01 | 301d? |  | finish no earlier than 2006-12-01 | C4 | 2408h | 2408h | SMS7 | 23.840 | Rel-7 | Kimmo |  | SMS7 | Vodafone | Nick.Russell@vodafone.com |  |  |  |
| 8129 | 2638 | Feasibility Study on the TCAPsec Gateway concept |  | 96d? | 2005-10-28 A | 2006-03-10 A | 100% |  | 2005-10-28 | 2006-03-10 | 96d? |  | finish no earlier than 2006-03-10 | C4 | 768h | 768h | FS_SEC7-TCAP | 29.800 | Rel-7 | Kimmo |  | FS_SEC7-TCAP | Siemens | Ulrich.wiehe@gksag.de |  |  |  |
| 8130 | 2639 | Study on using M2PA in 3GPP network |  | 318d? | 2006-03-22 A | 2007-06-08 A | 100% |  | 2006-03-22 | 2007-06-08 | 318d? |  | finish no earlier than 2007-06-08 | C4 | 2544h | 2544h | FS-M2PA | 29.801 | Rel-7 | Kimmo |  | FS-M2PA | China Mobile | zhaoyuyi@chinamobile.com |  |  |  |

Notes:
- 8107: -
- 8108: DAB - Not yet required in SA2 as it exists in previous releases
- 8109: -
- 8110: -
- 8111: Stage 2 description of Interim conclusion
- 8112: Created at TSG#27 by A. Sultan because of the move to Rel-7 of "Common Objects".
- 8113: No progress in CN4#26. This have to be moved to Rel-7. It was deleted from WID
- 8114: -
- 8115: Spin-off Feature UID_7038 (MTSI)
- 8116: -
- 8117: -
- 8118: 07/08 Moved to Rel-7 as Study out of stopped Rel-8 Feature UID_31067 All-IP Network (AIPN)
- 8119: -
- 8120: Spin-off Feature Network selection enhancements (NSP-CR) UID_7041
- 8121: Spin-off Feature PRIOR UID_340044
- 8122: -
- 8123: -
- 8124: SP#34 completed
- 8125: SP#35 completed
- 8126: SP#35 completed
- 8127: Moved to FS at CT32 (in line with slides)
- 8128: Previously known as "Study of a SMS Centre for MT SMS"
- 8129: TR 29.800 content moved to TS 29.204 under implementation WI UID_310005 TCAPsec Gateway
- 8130: -

| ID | WBS | Task | Type | Duration | Start | Finish | Complete | Baseline start | Baseline finish | Baseline duration | Constraint | Resources | Work | Actual work | Acronym | Impacted TSs and TRs | WI rapporteur name | WI rapporteur e-mail | Release | MCC resp | Acronym_3GU_Export | Status Report | TSG stopped | Special Focus Doc |
| --- | --- | --- | --- | --- | --- | --- | --- | --- | --- | --- | --- | --- | --- | --- | --- | --- | --- | --- | --- | --- | --- | --- | --- | --- |
| 8131 | 2640 | **Study on Support of (G)MSC-S - (G)MSC-S Nc Interface based on the SIP-I protocol** |  | 505.25d? | 2006-05-15 A | 2007-09-14 A | 100% | 2006-05-15 | 2007-09-14 | 350d? |  | C4; C3 | 10600h | 10600h | NcSIP | 29.802 | Vodafone | david.hutton@vodafone.com | Rel-7 | Kimmo | NcSIP |  |  |  |
| 8132 | 2640.1 | CT4 aspects of NcSIP |  | 275d? | 2006-05-15 A | 2007-06-01 A | 100% | 2006-05-15 | 2007-06-01 | 275d? | finish no earlier than 2007-06-01 | C4 | 2200h | 2200h |  | 29.802 | Vodafone | david.hutton@vodafone.com | Rel-7 | Kimmo |  |  |  |  |
| 8133 | 2640.2 | CT3 aspects of NcSIP |  | 350d? | 2006-05-15 A | 2007-09-14 A | 100% | 2006-05-15 | 2007-09-14 | 350d? | finish no earlier than 2007-09-14 | C3 | 2800h | 2800h |  | 29.802 | Ericsson | ragnar.huslende@ericsson.com | Rel-7 | Adrian |  |  |  |  |
| 8134 | 2641 | Study on Evolved UTRA and UTRAN |  | 458d? | 2004-12-15 A | 2006-09-15 A | 100% | 2004-12-15 | 2006-09-15 | 458d? | finish no earlier than 2006-09-15 | RP | 3664h | 3664h | RANFS-Evo | 25.912 | NTT DoCoMo | nakamurata@NTTDOCOMO.CO.JP | Rel-7 | Issam | RANFS-Evo | RP-060472 |  |  |
| 8135 | 2642 | Study on Performance Evaluation of the UE behaviour in high speed trains with speeds up to 350 kmph |  | 328d? | 2005-03-15 A | 2006-06-15 A | 100% | 2005-03-15 | 2006-06-15 | 328d? | finish no earlier than 2006-06-15 | R4 | 2624h | 2624h | RANFS-HSTrains | none | Vodafone | Mike.vogel@vodafone.com,tim.frost@vodafone.com | Rel-7 | Issam | RANFS-HSTrains | RP-060412 |  |  |
| 8136 | 2643 | Study on UTRA Tower Mounted Amplifier (FDD) |  | 195d? | 2005-06-15 A | 2006-03-14 A | 100% | 2005-06-15 | 2006-03-14 | 195d? | finish no earlier than 2006-03-15 | R4 | 1560h | 1560h | RANFS-TMA | 25.818 | Ericsson | Klas.Sjerling@ericsson.com | Rel-7 | Issam | RANFS-TMA | RP-060035 |  |  |
| 8137 | 2644 | Study on Continuous connectivity for packet data users |  | 132d? | 2005-03-15 A | 2005-09-14 A | 100% | 2005-03-15 | 2005-09-14 | 132d? | finish no earlier than 2005-09-15 | R1 | 1056h | 1056h | RANFS-cont-packet | none | Siemens | joerg.gustrau@siemens.com | Rel-7 | Patrick | RANFS-cont-packet | RP-050427 |  |  |
| 8138 | 2645 | Study on Improvement of the Multimedia Broadcast Multicast Service (MBMS) in UTRAN |  | 262d? | 2005-12-15 A | 2006-12-15 A | 100% | 2005-12-15 | 2006-12-15 | 262d? | finish no earlier than 2006-12-15 | R2 | 2096h | 2096h | RANFS-MBMSImp | 25.905 | LG Electronics | leego@lge.com | Rel-7 | Yong-Jun | RANFS-MBMSImp | RP-060692 |  |  |
| 8139 | 2646 | Deleted - Study on Performance Improvements in Small Cells using HSDPA/EDCH |  | 131d? | 2005-12-15 A | 2006-06-15 A | 100% | 2005-12-15 | 2006-06-15 | 131d? | finish no earlier than 2006-06-15 | R1; R4 | 2096h | 2096h | SMALLCELLS | none | Cingular | Marc Grant | Rel-7 | Issam | SMALLCELLS | RP-060263 | SP-69 | Small cell |
| 8140 | 2647 | Study on Further Improved Performance Requirements for UMTS/HSDPA UE (FDD) |  | 383d? | 2005-12-15 A | 2007-06-04 A | 100% | 2005-12-15 | 2007-06-04 | 383d? | finish no earlier than 2007-06-04 | R4 | 3064h | 3064h | RANFS-IC | 25.963 | Cingular | Marc Grant | Rel-7 | Issam | RANFS-IC | RP-070499 |  |  |
| 8141 | 2648 | Study on Scope of future FDD HSPA Evolution |  | 394d? | 2006-03-15 A | 2007-09-17 A | 100% | 2006-03-15 | 2007-09-17 | 394d? | finish no earlier than 2007-09-17 | RP | 3152h | 3152h | RANFS-HSPAEvo | 25.999 | Cingular | Don Zelmer (dz1069@att.com) | Rel-7 | Issam | RANFS-HSPAEvo | RP-070533 |  |  |
| 8142 | 2649 | Study on Dynamically reconfiguring a FDD UE receiver to reduce power consumption when desired Quality of Service is met | milestone | 0d? | 2007-06-22 A | 2007-06-22 A | 100% | 2007-06-22 | 2007-06-22 | 0d? |  | R4 |  |  | FSUEPow | 25.906 | Nokia | Chris.callender@nokia.com, tiina.s.koskinen@nokia.com | Rel-7 | Issam | FSUEPow | RP-070534 |  |  |
| 8143 | 2650 | Study on Future GERAN Evolution |  | 486d? | 2005-04-08 A | 2007-02-16 A | 100% | 2005-04-08 | 2007-02-16 | 486d? | finish no earlier than 2007-02-16 | GP | 3888h | 3888h | FGE | 45.912 | Nokia | eddie.riddington@nokia.com | Rel-7 | Paolo | FGE |  |  |  |
| 8144 | 2651 | Study on GAN Enhancements | milestone | 0d? | 2007-08-31 A | 2007-08-31 A | 100% | 2007-08-31 | 2007-08-31 | 0d? | start no earlier than 2007-08-31 | GP |  |  | EGAN | 43.902 | T-Mobile | janne.linkola@t-mobile.com | Rel-7 | Paolo | EGAN |  |  |  |
| 8145 | 2652 | Deleted - Study on IMS with real time services deployment |  | 457.75d? | 2004-06-28 A | 2005-09-12 A | 100% | 2004-06-28 | 2005-09-12 | 316d? |  | S1 | 2528h | 2528h | IRTSD |  |  |  | Rel-7 | Alain | IRTSD |  | SP-30 |  |
| 8146 | 2653 | Deleted - Covered by SI - Personal Network (PN) and Personal Area Network (PAN) | milestone | 0d? | 2005-12-08 A | 2005-12-08 A | 100% | 2005-12-08 | 2005-12-20 | 0d? | start no earlier than 2005-12-08 | S1 |  |  | PNPAN |  | Vodafone | armin.toepfer@vodafone.com | Rel-7 | Alain | PNPAN |  | SP-30 |  |
| 8147 | 2654 | Deleted - Study on Customised Alerting Tone (CAT) Requirements (was duplicated) | milestone | 0d? | 2006-06-30 A | 2006-06-30 A | 100% | 2006-06-30 | 2006-06-30 | 0d? | start no earlier than 2006-06-30 | S1 |  |  |  |  |  |  | Rel-7 | Alain |  |  | SP-31 |  |
| 8148 | 2655 | Deleted - IMS security extensions (covered by UID33027) | milestone | 0d? | 2005-12-08 A | 2005-12-08 A | 100% | 2005-12-08 | 2005-12-08 | 0d? | start no earlier than 2005-12-08 | S3 |  |  | IMS-SE |  | Ericsson | Bengt.Sahlin@ericsson.com | Rel-7 | Mirko | IMS-SE |  | SP-30 |  |
| 8149 | 2656 | **Deleted - Study on applicability of GALILEO for LCS** |  | 0d? | 2005-06-30 A | 2005-06-30 A | 100% | 2005-06-30 | 2005-06-30 | 0d? |  | S2 |  |  | Galileo |  |  |  | Rel-7 | Maurice | Galileo |  | SP-25 |  |
| 8150 | 2656.1 | Deleted - TR on Stage 2 | milestone | 0d? | 2005-06-30 A | 2005-06-30 A | 100% | 2005-06-30 | 2005-06-30 | 0d? | finish no earlier than 2005-06-30 | S2 |  |  |  |  |  |  | Rel-7 | Maurice |  |  | SP-25 |  |
| 8151 | 2656.2 | Deleted - GERAN review of the TR | milestone | 0d? | 2005-06-30 A | 2005-06-30 A | 100% | 2005-06-30 | 2005-06-30 | 0d? | start no earlier than 2005-06-30 | GP |  |  |  |  |  |  | Rel-7 | Paolo |  |  | SP-26 |  |
| 8152 | 2657 | Deleted - Study on Stage 2 (IMS services using CS bearers) |  | 316d? | 2004-06-28 A | 2005-09-12 A | 100% | 2004-06-28 | 2005-09-12 | 316d? | finish no earlier than 2005-09-12 | S2 | 2528h | 2528h | IRTSD-IMSCS | 23.899 | Nortel | Mark Watson | Rel-7 | Maurice | IRTSD-IMSCS |  | SP-30 |  |
| 8153 | 2658 | **Deleted - VoIMS bearer related enhancements** |  | 0d? | 2006-07-21 A | 2006-07-21 A | 100% | 2006-07-21 | 2006-07-21 | 0d? |  | S2 |  |  | VoIMS |  |  |  | Rel-7 | Maurice | VoIMS |  | SP-32 |  |
| 8154 | 2658.1 | Deleted - Study on enhancement of radio performance for VoIMS | milestone | 0d? | 2006-07-21 A | 2006-07-21 A | 100% | 2006-07-21 | 2006-07-21 | 0d? | start no earlier than 2006-07-21 | S2 |  |  |  | 23.807 | Nortel | Laurence Lautier (lautierl@nortel.com) | Rel-7 | Maurice |  |  | SP-32 |  |
| 8155 | 2659 | Deleted - Study on IMS enhancements and optimizations for real time communication. |  | 430d? | 2005-10-10 A | 2007-06-01 A | 100% | 2005-10-10 | 2007-06-01 | 430d? | finish no earlier than 2007-06-01 | S2 | 3440h | 3440h | IMS-RT | 23.818 | Ericsson | stephen.terrill@ericsson.com | Rel-7 | Maurice | IMS-RT |  | SP-35 |  |
| 8156 | 2660 | Deleted - Study on Terminating Session handling |  | 255d? | 2006-01-09 A | 2006-12-29 A | 100% | 2006-01-09 | 2006-12-29 | 255d? | finish no earlier than 2006-12-29 | S2 | 2040h | 2040h | CSIterm | 23.819 | Samsung |  | Rel-7 | Maurice | CSIterm |  | SP-32 |  |
| 8157 | 2661 | Deleted eCALLIBMS - Study on Transferring of emergency call data – in-band modem solution (moved to Rel-8) | milestone | 0d? | 2007-06-22 A | 2007-06-22 A | 100% | 2007-06-22 | 2007-06-22 | 0d? | start no earlier than 2007-06-22 | S4 |  |  |  | 26.967 | Airbiquity | lhong@airbiquity.com | Rel-7 | Paolo |  |  | SP-38 | Public Safety (I-A) |
| 8158 | 2662 | Deleted - Study on IRP usage scenarios |  | 330d? | 2005-09-02 A | 2006-12-07 A | 100% | 2005-09-02 | 2006-12-07 | 330d? | finish no earlier than 2006-12-07 | S5 | 2640h | 2640h | OAM-Study | 32.8xy | Lucent |  | Rel-7 | Mirko | OAM-Study |  | SP-32 |  |
| 8159 | 2663 | Deleted - Study on Interference Cancellation for UTRA FDD UE (covered by UID 20053) |  | 1d? | 2007-03-28 A | 2007-03-28 A | 100% | 2007-03-28 | 2007-03-28 | 1d? | start no earlier than 2007-03-28 | R4 | 8h | 8h | RANFS-InterfCanc |  |  |  | Rel-7 | Issam | RANFS-InterfCanc |  | SP-38 |  |
| 8160 | 2664 | Deleted - Study on enhanced support of Video Telephony | milestone | 0d? | 2006-06-30 A | 2006-06-30 A | 100% | 2006-06-30 | 2006-06-30 | 0d? | start no earlier than 2006-06-30 | GP |  |  | VIDGER |  | Ericsson | stefan.g.eriksson@ericsson.com | Rel-7 | Paolo | VIDGER |  | SP-32 |  |
| 8161 | 2665 | --- RELEASE 6 --- |  | 915d? | 2002-06-28 A | 2005-12-30 A | 100% | 2002-06-28 | 2005-12-30 | 915d? |  | NP; GP; RP; SP; TP | 36600h | 36600h |  |  |  |  | Rel-6 | All |  |  |  |  |

Notes:
- 8131: -
- 8132: -
- 8133: -
- 8134: RP#33 (Sep 2006) completed. SR in RP-060472
- 8135: RP#32 (Jun 2006) completed. SR in RP-060412
- 8136: RP#31 (Mar 2006) completed. SR in RP-060035
- 8137: RP#29 (Sep 2006) completed. SR in RP-050427
- 8138: RP#34 completed
- 8139: RP#32 (Jun 2006) stopped at 0% completion
- 8140: RP#36 (May 2007) completed. SR in RP-070499
- 8141: RP#37 (Sep 2007) completed. SR in RP-070533
- 8142: RP#37 (Sep 2007) completed. SR in RP-070534
- 8143: GP#33 completed
- 8144: GP#35 completed
- 8145: -
- 8146: -
- 8147: Awaiting MCC SA3 input
- 8148: -
- 8149: -
- 8150: -
- 8151: -
- 8152: SP-30: S2 has no intention for TR completion
- 8153: Created by MCC to group all VoIMS related items, after consultation of chairs
- 8154: WID approved SP#28. SA2#52 stopped
- 8155: abandoned at 65%
- 8156: SP#32 Jun 2006 Study abandoned => spin-off Implementation work UID_320029
- 8157: SP-38 stopped
- 8158: -
- 8159: Deleted. Same as FS on Further Improved Performance Requirements for UMTS/HSDPA UE (FDD)
- 8160: FS CLOSED at G#28 (no input)
- 8161: -

| ID | WBS | Task | Type | Duration | Start | Finish | Complete | Baseline start | Baseline finish | Baseline duration | Constraint | Resources | Work | Actual work | Release | Acronym | WI rapporteur name | WI rapporteur e-mail | MCC resp | Acronym_3GU_Export | Impacted TSs and TRs | Created at | TSG stopped |
| --- | --- | --- | --- | --- | --- | --- | --- | --- | --- | --- | --- | --- | --- | --- | --- | --- | --- | --- | --- | --- | --- | --- | --- |
| 8162 | 8 | **Rel-6 Improvements of Radio Interface** |  | 2383d? | 2000-08-14 A | 2006-12-01 A | 100% | 2000-08-14 | 2006-12-01 | 1645d? |  | R2; R4; R5 | 87632h | 87632h | Rel-6 |  |  |  |  |  |  |  |  |
| 8163 | 2666.1 | Improved support of IMS Realtime Services using HSDPA/EDCH |  | 197d? | 2005-03-15 A | 2005-12-14 A | 100% | 2005-03-15 | 2005-12-14 | 197d? | finish no earlier than 2005-12-14 | R2 | 1576h | 1576h | Rel-6 | RInImp-IMSRealTime | Cingular | Don Zelmer (dz1069@att.com) | Yong-Jun | RInImp-IMSRealTime |  |  |  |
| 8164 | 2666.2 | Improving Receiver Performance Requirements for the FDD UE |  | 401d | 2002-03-08 A | 2003-09-19 A | 100% | 2002-03-08 | 2003-09-19 | 401d | start no earlier than 2002-03-08 | R4 | 3208h | 3208h | Rel-6 | RInImp-UERecPerf | Intel | shimon.moshavi@INTEL.COM | Issam | RInImp-UERecPerf | 25.101 |  |  |
| 8165 | 8.2 | **Base station classification for FDD** |  | 873d | 2000-08-14 A | 2002-12-04 A | 100% | 2000-08-14 | 2002-12-04 | 603d |  | R4 | 9648h | 9648h | Rel-6 | RInImp-BSClass-FDD |  |  | Issam | RInImp-BSClass-FDD |  |  |  |
| 8166 | 8.2.1 | FDD Base station classification |  | 603d | 2000-08-14 A | 2002-12-04 A | 100% | 2000-08-14 | 2002-12-04 | 603d | finish no earlier than 2002-12-04 | R4 | 4824h | 4824h | Rel-6 |  | Nokia | antti.toskala@nokia.com | Issam |  | 25.104; 25.141 |  |  |
| 8167 | 2666.4 | UMTS-850 |  | 266d | 2002-12-06 A | 2003-12-12 A | 100% | 2002-12-06 | 2003-12-12 | 266d | finish no earlier than 2003-12-15 | R4 | 2128h | 2128h | Rel-6 | RInImp-UMTS850 | Cingular | Don Zelmer (dz1069@att.com) | Issam | RInImp-UMTS850 | 25.101; 25.104; 25.133; 25.141; 25.307; 25.331; 25.942 |  |  |
| 8168 | 2666.5 | DS-CDMA introduction in the 800 MHz band |  | 196d | 2003-03-14 A | 2003-12-12 A | 100% | 2003-03-14 | 2003-12-12 | 196d | finish no earlier than 2003-12-15 | R4 | 1568h | 1568h | Rel-6 | RInImp-UMTS800 | NTT DoCoMo | Takehiro Nakamura (nakamurata@nttdocomo.co.jp) | Issam | RInImp-UMTS800 | 25.101; 25.104; 25.133; 25.141; 25.307; 25.331 |  |  |
| 8169 | 2666.6 | UMTS 1.7/2.1 GHz | milestone | 0d? | 2003-03-14 A | 2003-03-14 A | 100% | 2003-03-14 | 2003-03-14 | 0d? |  | R4 |  |  | Rel-6 | RInImp-UMTS1721 | Nokia | jussi.numminen@NOKIA.COM | Issam | RInImp-UMTS1721 | 25.101; 25.104; 25.133; 25.141; 25.307; 25.331 |  |  |
| 8170 | 2666.7 | Conformance Test Aspects – UMTS 1.7/2.1 GHz Band |  | 191d? | 2006-03-10 A | 2006-12-01 A | 100% | 2006-03-10 | 2006-12-01 | 191d? | finish no earlier than 2006-12-01 | R5 | 1528h | 1528h | Rel-6 | RInImp-UMTS1721_Test | Motorola | carolyn.taylor@motorola.com | Ingbert | RInImp-UMTS1721_Test | TS34.121; TS34.108 |  |  |
| 8171 | 2666.8 | **Improved Receiver Performance Requirements for HSDPA** |  | 1030.5d | 2003-09-19 A | 2006-06-09 A | 100% | 2003-09-19 | 2006-06-09 | 711d |  | R4; R5 | 28496h | 28496h | Rel-6 | RInImp-HSPerf | Nokia | jussi.numminen@NOKIA.COM | Issam | RInImp-HSPerf |  |  |  |
| 8172 | 2666.8.1 | Improved Minimum Performance Requirements for HSDPA UE categories 7 and 8 |  | 655.5d | 2004-09-15 A | 2006-06-09 A | 100% | 2004-09-15 | 2006-06-09 | 453d |  | R4 | 3624h | 3624h | Rel-6 | RInImp-HSPerf-10code | Nokia | jussi.numminen@nokia.com | Issam | RInImp-HSPerf-10code | 25.101 |  |  |
| 8173 | 2666.8.2 | Testing of Improved Minimum Performance for HSDPA |  | 650d | 2003-09-19 A | 2006-03-16 A | 100% | 2003-09-19 | 2006-03-16 | 650d | finish no earlier than 2006-03-16 | R5 | 5200h | 5200h | Rel-6 | RInImp-HSPerf-10Code_Test | Motorola | carolyn.taylor@motorola.com | Ingbert | RInImp-HSPerf-10Code_Test | 34.108; 34.121; 34.122; 34.123-1; 34.123-2; 34.123-3 | 19/9/2003 |  |
| 8174 | 2666.8.3 | Performance Requirements of Receive Diversity for HSDPA |  | 387d | 2003-12-15 A | 2005-06-07 A | 100% | 2003-12-15 | 2005-06-07 | 387d |  | R4 | 3096h | 3096h | Rel-6 | RInImp-HSPerf-RxDiv | NTT DoCoMo | Takehiro Nakamura (nakamurata@nttdocomo.co.jp) | Issam | RInImp-HSPerf-RxDiv | 25.101 |  |  |
| 8175 | 2666.8.4 | Testing of Performance of Receiver diversity for HSDPA |  | 650d | 2003-09-19 A | 2006-03-16 A | 100% | 2003-09-19 | 2006-03-16 | 650d | finish no earlier than 2006-03-16 | R5 | 5200h | 5200h | Rel-6 | RInImp-HSPerf-RxDiv_Test | Motorola | carolyn.taylor@motorola.com | Ingbert | RInImp-HSPerf-RxDiv_Test | 34.108; 34.121; 34.122; 34.123-1; 34.123-2; 34.123-3 | 19/9/2003 |  |
| 8176 | 2667 | **Rel-6 RAN Feasibility Studies** |  | 1733.75d? | 2000-08-14 A | 2005-03-14 A | 100% | 2000-08-14 | 2005-03-14 | 1196d? |  | RP | 43048h | 43048h | Rel-6 |  |  |  |  |  |  |  |  |
| 8177 | 2667.1 | FS of the improved access to UE measurement data for CRNC to support TDD RRM |  | 270d? | 2002-12-06 A | 2003-12-18 A | 100% | 2002-12-06 | 2003-12-18 | 270d? | finish no earlier than 2003-09-19 | R3 | 2160h | 2160h | Rel-6 | RANimp-RRMopt-FSUEMsD | Interdigital | jim.miller@interdigital.com | Juha | RANimp-RRMopt-FSUEMsD | 25.801; 25.423 | SP-24 |  |
| 8178 | 2667.2 | FS on Radio link performance enhancements |  | 1067d | 2000-08-14 A | 2004-09-14 A | 100% | 2000-08-14 | 2004-09-14 | 1067d | finish no earlier than 2004-09-14 | R1 | 8536h | 8536h | Rel-6 | RInImp-Rlperf | Nokia | antti.toskala@nokia.com | Patrick | RInImp-Rlperf | 25.899 |  |  |
| 8179 | 2667.3 | FS on Improvement of inter-frequency and inter-system measurements for 1.28 Mcps TDD |  | 461d | 2001-12-14 A | 2003-09-19 A | 100% | 2001-12-14 | 2003-09-19 | 461d | start no earlier than 2001-12-14 | R1 | 3688h | 3688h | Rel-6 | RInImp-IfIsMLCR | Samsung | Li Xiao Qiang (xqli@samsung.co.kr) | Patrick | RInImp-IfIsMLCR | 25.888 |  |  |
| 8180 | 2667.4 | FS for the analysis of OFDM for UTRAN enhancement |  | 526d | 2002-06-10 A | 2004-06-14 A | 100% | 2002-06-10 | 2004-06-14 | 526d | start no earlier than 2002-06-10 | R1 | 4208h | 4208h | Rel-6 | RInImp-FSOFDM | Nortel | Sarah Boumendil | Patrick | RInImp-FSOFDM | 25.892 |  |  |
| 8181 | 2667.5 | FS on Uplink Enhancements for Dedicated Transport Channels |  | 396d | 2002-09-06 A | 2004-03-12 A | 100% | 2002-09-06 | 2004-03-12 | 396d | finish no earlier than 2004-03-12 | R1 | 3168h | 3168h | Rel-6 | RInImp-FSUpDTrCh | Nokia | Karri.Ranta-aho@nsn.com | Patrick | RInImp-FSUpDTrCh | 25.896 |  |  |
| 8182 | 2667.6 | FS on Analysis on Higher Chip Rates for UTRA TDD evolutions |  | 528d | 2002-09-06 A | 2004-09-14 A | 100% | 2002-09-06 | 2004-09-14 | 528d | finish no earlier than 2004-09-14 | R1 | 4224h | 4224h | Rel-6 | RInImp-FSVHCRTDD | IPWireless | mbeale@ipwireless.com | Patrick | RInImp-FSVHCRTDD | 25.895 |  |  |
| 8183 | 2667.7 | FS on Low Output Powers for general purpose FDD BSs |  | 128d | 2003-06-13 A | 2004-03-12 A | 100% | 2003-06-13 | 2004-03-12 | 128d | finish no earlier than 2004-03-12 | R3 | 1024h | 1024h | Rel-6 | RInImp-FSLoPw | Telefónica | Ana Burgos (burgos_a@tsm.es) | Juha | RInImp-FSLoPw | 25.807 |  |  |
| 8184 | 2667.8 | FS on Uplink enhancements for UTRA TDD |  | 462d | 2003-06-06 A | 2005-03-14 A | 100% | 2003-06-06 | 2005-03-14 | 462d | finish no earlier than 2005-03-14 | R1 | 3696h | 3696h | Rel-6 | RInImp-FSUpEnhTDD | Interdigital | Marian.Rudolf@InterDigital.com | Patrick | RInImp-FSUpEnhTDD | 25.804 |  |  |
| 8185 | 8.8 | FS on UE antenna efficiency test methods performance requirements (2) |  | 131d | 2002-03-08 A | 2002-09-06 A | 100% | 2002-03-08 | 2002-09-06 | 131d | finish no earlier than 2002-09-06 | R4 | 1048h | 1048h | Rel-6 | RInImp-UEAnTM2 | Allgon | Alf Ahlström (alf.ahlstrom@pwav.com) | Issam | RInImp-UEAnTM2 |  |  |  |
| 8186 | 9.4 | Deleted - FS on the evolution of the UTRAN architecture |  | 592d | 2002-09-09 A | 2004-12-14 A | 100% | 2002-09-09 | 2004-12-14 | 592d | finish no earlier than 2004-12-15 | R3 | 4736h | 4736h | Rel-6 | RANimp-FSEvo | Nokia | woonhee.hwang@nsn.com, Antti.Toskala@nokia.com | Juha | RANimp-FSEvo |  |  | RP-26 |

Notes:
- 8162: -
- 8163: -
- 8164: -
- 8165: -
- 8166: -
- 8167: Introduction of UMTS850 (Band V) in 25.307
- 8168: Introduction of UMTS800 in 25.307
- 8169: Introduction of UMTS1700/2100 (Band IV)
- 8170: -
- 8171: -
- 8172: Approved at RP#25 as RP-040375
- 8173: -
- 8174: -
- 8175: -
- 8176: -
- 8177: -
- 8178: Study finished at RP#25
- 8179: -
- 8180: -
- 8181: -
- 8182: Study finished at RP#25
- 8183: -
- 8184: -
- 8185: The RInImp-UEAnTM FS was re-opened at TSG RP#15 upon request from WG4
- 8186: Study Closed, work will continue within the FS on evolved UTRA and UTRAN

| ID | WBS | Task | Type | Duration | Start | Finish | Complete | Baseline start | Baseline finish | Baseline duration | Constraint | Deadline | Resources | Work | Actual work | Acronym | WI rapporteur name | WI rapporteur e-mail | Release | MCC resp | Acronym_3GU_Export | Impacted TSs and TRs | Created at | TSG stopped |
| --- | --- | --- | --- | --- | --- | --- | --- | --- | --- | --- | --- | --- | --- | --- | --- | --- | --- | --- | --- | --- | --- | --- | --- | --- |
| 8187 | 2668 | **FDD Enhanced Uplink** |  | 1324.5d | 2004-03-15 A | 2007-09-14 A | 100% | 2004-03-15 | 2007-09-14 | 915d |  |  | R2; R1; R3; R4; R5 | 49800h | 49800h | EDCH | Ericsson | Joakim Bergström | Rel-6 | Yong-Jun | EDCH |  |  |  |
| 8188 | 2668.1 | FDD Enhanced Uplink - Stage 2 |  | 197d | 2004-03-15 A | 2004-12-14 A | 100% | 2004-03-15 | 2004-12-14 | 197d | finish no earlier than 2004-12-14 |  | R2 | 1576h | 1576h | EDCH-Stage2 |  |  | Rel-6 | Yong-Jun | EDCH-Stage2 | 25.309 |  |  |
| 8189 | 2668.2 | FDD Enhanced Uplink - Physical Layer |  | 261d | 2004-03-15 A | 2005-03-14 A | 100% | 2004-03-15 | 2005-03-14 | 261d | finish no earlier than 2005-03-14 |  | R1 | 2088h | 2088h | EDCH-Phys | Nokia | Karri.Ranta-aho@nsn.com | Rel-6 | Patrick | EDCH-Phys | 25.211; 25.212; 25.213; 25.214; 25.215 |  |  |
| 8190 | 2668.3 | FDD Enhanced Uplink - Layer 2 and 3 Protocol Aspects |  | 261d | 2004-03-15 A | 2005-03-14 A | 100% | 2004-03-15 | 2005-03-14 | 261d | finish no earlier than 2005-03-14 |  | R2 | 2088h | 2088h | EDCH-L23 | Ericsson | Joakim Bergström | Rel-6 | Yong-Jun | EDCH-L23 | 25.301; 25.302; 25.306; 25.321; 25.331 |  |  |
| 8191 | 2668.4 | FDD Enhanced Uplink - UTRAN Iub/Iur Protocol Aspects |  | 261d | 2004-03-15 A | 2005-03-14 A | 100% | 2004-03-15 | 2005-03-14 | 261d | finish no earlier than 2005-03-14 |  | R3 | 2088h | 2088h | EDCH-IurIub | Nortel | Saso Stojanovski | Rel-6 | Juha | EDCH-IurIub | 25.401; 25.420; 25.423; 25.430; 25.433 |  |  |
| 8192 | 2668.5 | FDD Enhanced Uplink - RF Radio Transmission/ Reception, System Performance Requirements and Conformance Testing |  | 74d | 2004-03-15 A | 2004-06-24 A | 100% | 2004-03-15 | 2004-06-24 | 74d |  |  | R4 | 592h | 592h | EDCH-RF | Ericsson | thomas.unshelm@ericsson.com | Rel-6 | Issam | EDCH-RF | 25.101; 25.104; 25.133; 25.141 |  |  |
| 8193 | 2668.6 | Conformance Test Aspects – FDD Enhanced Uplink |  | 596d | 2005-06-03 A | 2007-09-14 A | 100% | 2005-06-03 | 2007-09-14 | 596d | finish no earlier than 2007-09-14 | 2006-06-02 | R5 | 4768h | 4768h | EDCH_Test | Ericsson | Leif.Mattisson@ericsson.com | Rel-6 | Ingbert | EDCH_Test | 34.108; 34.109; 34.121; 34.123-1; 34.123-2; 34.123-3 | Fri 03/06/05 |  |
| 8194 | 2669 | **Rel-6 RAN improvements** |  | 950.75d? | 2002-09-09 A | 2005-03-14 A | 100% | 2002-09-09 | 2005-03-14 | 656d? |  |  | RP; S5 | 36720h | 36720h |  |  |  | Rel-6 |  |  |  |  |  |
| 8195 | 9.2 | **RAB support enhancement** |  | 758.25d? | 2003-03-14 A | 2005-03-14 A | 100% | 2003-03-14 | 2005-03-14 | 522d? |  |  | R2 | 9360h | 9360h |  | Nokia | Jussi Kähtävä (juha.mikola@nokia.com) | Rel-6 | Yong-Jun |  | 25.862 |  |  |
| 8196 | 2669.1.1 | Optimization of downlink channelisation code utilisation |  | 262d | 2004-03-12 A | 2005-03-14 A | 100% | 2004-03-12 | 2005-03-14 | 262d | finish no earlier than 2005-03-14 |  | R1 | 2096h | 2096h | RANimp-RABSE-CodeOptFDD | Nortel | Sarah Boumendil | Rel-6 | Patrick | RANimp-RABSE-CodeOptFDD |  |  |  |
| 8197 | 2669.1.2 | optimization of channelisation code utilisation for 3.84 Mcps TDD |  | 261d | 2004-03-15 A | 2005-03-14 A | 100% | 2004-03-15 | 2005-03-14 | 261d | finish no earlier than 2005-03-15 |  | R1 | 2088h | 2088h | RANimp-RABSE-CodOptTDD | IPWireless | Nicholas Anderson | Rel-6 | Patrick | RANimp-RABSE-CodOptTDD |  |  |  |
| 8198 | 2669.1.3 | HS-DPCCH ACK/NACK Enhancement |  | 65d? | 2004-09-15 A | 2004-12-14 A | 100% | 2004-09-15 | 2004-12-14 | 65d? | finish no earlier than 2004-12-15 |  | R1 | 520h | 520h | RANimp-RABSE-ACKNACK | Nokia | Jussi Kähtävä (juha.mikola@nokia.com) | Rel-6 | Patrick | RANimp-RABSE-ACKNACK | 25.212; 25.214; 24.331; 25.433 |  |  |
| 8199 | 2669.1.4 | Deleted - Iu enhancements for IMS support in RAN |  | 320d? | 2003-03-14 A | 2004-06-03 A | 100% | 2003-03-14 | 2004-06-03 | 320d? | start no earlier than 2003-03-14 |  | R3 | 2560h | 2560h | RANimp-RABSE-IuEnhIMS | Nortel | Philippe.Godin@nortelnetworks.com | Rel-6 | Juha | RANimp-RABSE-IuEnhIMS |  |  | RP-24 |
| 8200 | 2669.1.5 | Deleted - Improvement of RRM across RNS and RNS/BSS | milestone | 0d? | 2003-12-05 A | 2003-12-05 A | 100% | 2003-12-05 | 2003-12-05 | 0d? | finish no earlier than 2003-12-05 |  | R3 |  |  | RANimp-RRM1 | Nokia | antti.toskala@nokia.com | Rel-6 | Juha | RANimp-RRM1 |  |  | RP-23 |
| 8201 | 9.1 | Beamforming Enhancements |  | 66d | 2003-09-19 A | 2003-12-19 A | 100% | 2003-09-19 | 2003-12-19 | 66d | finish no earlier than 2004-03-12 |  | R1 | 528h | 528h | RANimp-BFE | Nokia | Jussi Kähtävä (juha.mikola@nokia.com) | Rel-6 | Patrick | RANimp-BFE | 24.215; 25.423; 25.425; 25.433; 25.435 |  |  |
| 8202 | 2669.3 | **Rel-6 RRM optimization for Iur and Iub** |  | 182.25d | 2003-09-19 A | 2004-03-12 A | 100% | 2003-09-19 | 2004-03-12 | 126d |  |  | R3 | 2016h | 2016h | RANimp-RRMopt-UEMsD | Ericsson | Gert-Jan.van.Lieshout@eln.ericsson.se | Rel-6 | Juha | RANimp-RRMopt-UEMsD |  |  |  |
| 8203 | 2669.3.1 | Improved access to UE measurement data for CRNC to support TDD RRM |  | 126d | 2003-09-19 A | 2004-03-12 A | 100% | 2003-09-19 | 2004-03-12 | 126d | finish no earlier than 2004-03-15 |  | R3 | 1008h | 1008h |  | Interdigital | jim.miller@interdigital.com | Rel-6 | Juha |  | 25.423 |  | RP-22 |
| 8204 | 2669.4 | **Remote Control of Electrical Tilting Antennas** |  | 572.75d? | 2003-03-14 A | 2004-09-16 A | 100% | 2003-03-14 | 2004-09-16 | 395d? |  |  | R3; S5 | 10624h | 10624h | RANimp-TiltAnt | Vodafone | Andreas.Hauser@vodafone.com | Rel-6 | Juha | RANimp-TiltAnt |  |  |  |
| 8205 | 2669.4.1 | Tilting Antenna - RAN aspects |  | 393d? | 2003-03-14 A | 2004-09-14 A | 100% | 2003-03-14 | 2004-09-14 | 393d? | finish no earlier than 2004-09-14 |  | R3 | 3144h | 3144h |  | Vodafone | Andreas.Hauser@vodafone.com | Rel-6 | Juha |  | 25.460; 25.461; 25.462; 25.463 |  |  |
| 8206 | 2669.4.2 | OAM&P impacts |  | 145d | 2004-02-27 A | 2004-09-16 A | 100% | 2004-02-27 | 2004-09-16 | 145d | finish no earlier than 2004-09-16 |  | S5 | 1160h | 1160h | RANimp-TiltAnt-OAM | Vodafone | Adrian.Neal@vodafone.com | Rel-6 | Mirko | RANimp-TiltAnt-OAM | 32.804; 32.64x | SP-24 |  |
| 8207 | 2669.5 | Network Assisted Cell Change (NACC) from UTRAN to GERAN - network-side aspects |  | 462d? | 2002-09-09 A | 2004-06-15 A | 100% | 2002-09-09 | 2004-06-15 | 462d? | finish no earlier than 2004-06-15 |  | R3 | 3696h | 3696h | RANimp-NACC | Vodafone | Brendan.McWilliams@gb.vodafone.co.uk | Rel-6 | Juha | RANimp-NACC |  |  |  |
| 8208 | 12 | **Location Services enhancements 2** |  | 1483d? | 2001-01-15 A | 2004-12-16 A | 100% | 2001-01-15 | 2004-12-16 | 1024d? |  |  | S2; S5; N4; R2; R4; R5; OMA | 175184h | 175184h | LCS2 | Nokia | Jan Kåll | Rel-6 | Maurice | LCS2 |  |  |  |
| 8209 | 12.1 | **Improvement on Le interface** |  | 945.5d? | 2002-06-17 A | 2004-12-15 A | 100% | 2002-06-17 | 2004-12-15 | 653d? |  |  | S2; OMA | 15096h | 15096h |  | Nokia | Jan Kåll | Rel-6 | Maurice |  |  |  |  |
| 8210 | 2670.1.1 | Stage 2 for Improvement on Le interface |  | 331d? | 2002-06-17 A | 2003-09-22 A | 100% | 2002-06-17 | 2003-09-22 | 331d? | start no earlier than 2002-06-17 |  | S2 | 2648h | 2648h |  | Nokia | Jan Kåll | Rel-6 | Maurice |  | 23.002.23.271 |  |  |
| 8211 | 2670.1.2 | Stage 3 - impacts MLP (Mobile Location Protocol) |  | 250d? | 2004-01-01 A | 2004-12-15 A | 100% | 2004-01-01 | 2004-12-15 | 250d? | finish no earlier than 2004-12-15 |  | OMA | 2000h | 2000h |  | OMA | OMA-LIAISON@mail.openmobilealliance.org | Rel-6 |  |  |  |  |  |

Notes:
- 8187: -
- 8188: -
- 8189: -
- 8190: -
- 8191: -
- 8192: -
- 8193: -
- 8194: Generic feature
- 8195: building block without particular end date
- 8196: -
- 8197: WIDS modified in RP#26, RP-040551
- 8198: Approved at RP#25 as RP-040390
- 8199: Closed RP#24 due to the lack of progress
- 8200: abandoned RP-23
- 8201: -
- 8202: -
- 8203: -
- 8204: -
- 8205: Finished at RP#25
- 8206: SP#25 09/2004 completed
- 8207: -
- 8208: -
- 8209: -
- 8210: -
- 8211: -

| ID | WBS | Task | Type | Duration | Start | Finish | Complete | Baseline start | Baseline finish | Baseline duration | Constraint | Resources | Work | Actual work | WI rapporteur name | WI rapporteur e-mail | Release | MCC resp | Acronym | Acronym_3GU_Export | TSG stopped |
| --- | --- | --- | --- | --- | --- | --- | --- | --- | --- | --- | --- | --- | --- | --- | --- | --- | --- | --- | --- | --- | --- |
| 8212 | 12.2 | **Enhanced support for anonymity and user privacy** |  | 923.75d? | 2002-07-08 A | 2004-12-15 A | 100% | 2002-07-08 | 2004-12-15 | 638d? |  | S2; OMA | 14248h | 14248h | Nokia | Jan Kåll | Rel-6 | Maurice |  |  |  |
| 8213 | 2670.2.1 | Stage 2 for Enhanced support for anonymity and user privacy |  | 255d? | 2002-07-08 A | 2003-06-27 A | 100% | 2002-07-08 | 2003-06-27 | 255d? | finish no earlier than 2003-06-27 | S2 | 2040h | 2040h | Nokia | Jan Kåll | Rel-6 | Maurice |  |  |  |
| 8214 | 2670.2.2 | Stage 3 - impacts MLP and RLP |  | 250d? | 2004-01-01 A | 2004-12-15 A | 100% | 2004-01-01 | 2004-12-15 | 250d? | finish no earlier than 2004-12-15 | OMA | 2000h | 2000h | OMA | OMA-LIAISON@mail.openmobilealliance.org | Rel-6 |  |  |  |  |
| 8215 | 12.3 | **Enhanced inter-GMLC interface** |  | 938.25d? | 2002-06-24 A | 2004-12-15 A | 100% | 2002-06-24 | 2004-12-15 | 648d? |  | S2; OMA | 14888h | 14888h | Nokia | Jan Kåll | Rel-6 | Maurice |  |  |  |
| 8216 | 2670.3.1 | Stage 2 for Enhanced inter-GMLC interface |  | 315d? | 2002-06-24 A | 2003-09-05 A | 100% | 2002-06-24 | 2003-09-05 | 315d? | finish no earlier than 2003-09-05 | S2 | 2520h | 2520h | Nokia | Jan Kåll | Rel-6 | Maurice |  |  |  |
| 8217 | 2670.3.2 | Stage 3 - definition of RLP and PCP |  | 250d? | 2004-01-01 A | 2004-12-15 A | 100% | 2004-01-01 | 2004-12-15 | 250d? | finish no earlier than 2004-12-15 | OMA | 2000h | 2000h | OMA | OMA-LIAISON@mail.openmobilealliance.org | Rel-6 |  |  |  |  |
| 8218 | 12.4 | **Location Services support for IMS public identities** |  | 684.5d? | 2003-02-24 A | 2004-12-15 A | 100% | 2003-02-24 | 2004-12-15 | 473d? |  | S2; OMA | 11488h | 11488h | Nokia | Jan Kåll | Rel-6 | Maurice |  |  |  |
| 8219 | 2670.4.1 | Stage 2 for Location Services support for IMS public identities |  | 240d? | 2003-02-24 A | 2004-01-23 A | 100% | 2003-02-24 | 2004-01-23 | 240d? | finish no earlier than 2004-01-23 | S2 | 1920h | 1920h | Nokia | Jan Kåll | Rel-6 | Maurice |  |  |  |
| 8220 | 2670.4.2 | OMA Stage 3 for Location Services support for IMS public identities - impacts MLP, RLP and PCP |  | 250d? | 2004-01-01 A | 2004-12-15 A | 100% | 2004-01-01 | 2004-12-15 | 250d? | finish no earlier than 2004-12-15 | OMA | 2000h | 2000h | OMA | OMA-LIAISON@mail.openmobilealliance.org | Rel-6 |  |  |  |  |
| 8221 | 12.5 | **New area event for location service triggering reports** |  | 960d? | 2002-06-03 A | 2004-12-15 A | 100% | 2002-06-03 | 2004-12-15 | 663d? |  | S2; N4; OMA | 22024h | 22024h | Nokia | Jan Kåll | Rel-6 | Maurice |  |  |  |
| 8222 | 2670.5.1 | Stage 2 for New area event for location service triggering reports |  | 280d? | 2002-06-03 A | 2003-06-27 A | 100% | 2002-06-03 | 2003-06-27 | 280d? | finish no earlier than 2003-06-27 | S2 | 2240h | 2240h | Nokia | Jan Kåll | Rel-6 | Maurice |  |  |  |
| 8223 | 2670.5.2 | Stage 3 for UE-CN signalling |  | 234d? | 2003-10-09 A | 2004-08-31 A | 100% | 2003-10-09 | 2004-08-31 | 234d? | start no earlier than 2003-10-09 | N4 | 1872h | 1872h | Nokia |  | Rel-6 | Kimmo |  |  |  |
| 8224 | 2670.5.3 | Stage 3 for New area event for location service triggering reports - impacts MLP, RLP and PCP |  | 250d? | 2004-01-01 A | 2004-12-15 A | 100% | 2004-01-01 | 2004-12-15 | 250d? | finish no earlier than 2004-12-15 | OMA | 2000h | 2000h | OMA | OMA-LIAISON@mail.openmobilealliance.org | Rel-6 |  |  |  |  |
| 8225 | 12.7 | **UE positioning for Location Services enhancements 2** |  | 1386.75d? | 2001-01-15 A | 2004-09-14 A | 100% | 2001-01-15 | 2004-09-14 | 957d? |  | R2; R4; R5 | 36456h | 36456h |  |  | Rel-6 | Issam | LCS2-UEpos | LCS2-UEpos |  |
| 8226 | 12.8 | Open SMLC-SRNC Interface within the UTRAN to support UTRAN Rel-4 positioning methods |  | 1012.75d? | 2001-01-15 A | 2003-09-19 A | 100% | 2001-01-15 | 2003-09-19 | 700d? | finish no earlier than 2003-09-19 | R2 | 5600h | 5600h | Siemens | Meik.Kottkamp@siemens.com | Rel-6 | Yong-Jun | LCS-Rel4Pos | LCS-Rel4Pos |  |
| 8227 | 2670.6.2 | A-GPS minimum performance specification |  | 333d? | 2003-06-06 A | 2004-09-14 A | 100% | 2003-06-06 | 2004-09-14 | 333d? | finish no earlier than 2004-09-14 | R4; R5 | 5328h | 5328h | AT&T Wireless | donglin.shen@attws.com | Rel-6 | Issam | LCS-UEPos-AGPSPerf | LCS-UEPos-AGPSPerf |  |
| 8228 | 12.7.2 | Deleted - FS on Enhancements to OTDOA Positioning using advanced blanking methods |  | 320d | 2002-07-01 A | 2003-09-19 A | 100% | 2002-07-01 | 2003-09-19 | 320d | finish no earlier than 2003-09-19 | R2 | 2560h | 2560h | Cambridge Positioning Systems | david.bartlett@cursor-system.com | Rel-6 | Yong-Jun | LCS2-UEpos-FSBlank | LCS2-UEpos-FSBlank | RP-38 |
| 8229 | 2670.6.4 | Deleted - UE positioning enhancements - other methods | milestone | 0d? | 2003-09-26 A | 2003-09-26 A | 100% | 2003-09-26 | 2003-09-26 | 0d? | finish no earlier than 2003-09-26 | R2 |  |  | Siemens | Meik.Kottkamp@siemens.com | Rel-6 | Yong-Jun | LCS2-UEpos-enh | LCS2-UEpos-enh | RP-24 |
| 8230 | 2670.7 | LCS charging |  | 455d? | 2003-03-21 A | 2004-12-16 A | 100% | 2003-03-21 | 2004-12-16 | 455d? | start no earlier than 2003-03-21 | S5 | 3640h | 3640h | France Telecom | alain.bibas@orange-ft.com | Rel-6 | Mirko | LCS2-CH | LCS2-CH |  |
| 8231 | 14 | **Rel-6 Security enhancements** |  | 1474.75d? | 2001-01-03 A | 2004-11-26 A | 100% | 2001-01-03 | 2004-11-26 | 1018d? |  | S3 | 28824h | 28824h | Vodafone | Peter.Howard@vodafone.com | Rel-6 | Mirko | SEC16 | SEC1, Rel-6 |  |
| 8232 | 14.1 | **Enhanced HE control of security (including positive authentication reporting)** |  | 1031.5d | 2001-01-03 A | 2003-09-25 A | 100% | 2001-01-03 | 2003-09-25 | 712d |  | S3 | 14064h | 14064h | Vodafone | Peter.Howard@vodafone.com | Rel-6 | Mirko |  |  |  |
| 8233 | 14.1.1 | Deleted - SEC1 Stage 2 (Enhanced HE control of security) |  | 378d | 2001-01-03 A | 2002-06-14 A | 100% | 2001-01-03 | 2002-06-14 | 378d | finish no earlier than 2002-06-14 | S3 | 3024h | 3024h |  |  | Rel-6 | Mirko |  |  | SP-16 |
| 8234 | 14.1.3 | **Rel-6 Network Domain Security** |  | 482.5d | 2002-06-17 A | 2003-09-25 A | 100% | 2002-06-17 | 2003-09-25 | 334d |  | S3 | 5344h | 5344h | Telenor | Geir-myrdahl.koien@telenor.com | Rel-6 | Mirko | SEC1-NDS | SEC1-NDS |  |
| 8235 | 14.1.3.1 | Rel-6 IP network layer security (NDS/IP) |  | 334d | 2002-06-17 A | 2003-09-25 A | 100% | 2002-06-17 | 2003-09-25 | 334d | finish no earlier than 2003-09-25 | S3 | 2672h | 2672h |  |  | Rel-6 | Mirko | SEC1-NDS-IP | SEC1-NDS-IP |  |
| 8236 | 2671.2 | Network Domain Security; Authentication Framework (NDS/AF) |  | 521d? | 2002-02-15 A | 2004-02-13 A | 100% | 2002-02-15 | 2004-02-13 | 521d? | finish no earlier than 2004-02-13 | S3 | 4168h | 4168h | Nokia | tommi.viitanen@nokia.com | Rel-6 | Mirko | SEC1-NDS-AF | SEC1-NDS-AF |  |
| 8237 | 2671.3 | Key Management of group keys for Voice Group Call Services |  | 306d | 2003-09-26 A | 2004-11-26 A | 100% | 2003-09-26 | 2004-11-26 | 306d | finish no earlier than 2004-11-26 | S3 | 2448h | 2448h | Vodafone | benno.tietz@vodafone.com | Rel-6 | Mirko | SECGKYV | SECGKYV |  |
| 8238 | 2672 | Network Domain Security; MAP application layer security (NDS/MAPsec) |  | 127d? | 2004-07-06 A | 2004-12-29 A | 100% | 2004-07-06 | 2004-12-29 | 127d? | finish no earlier than 2003-12-26 | S3 | 1016h | 1016h | Vodafone | Peter.Howard@vodafone.com | Rel-6 | Mirko | MAPSEC | MAPSEC |  |

Notes:
- 8212: -
- 8213: - / Impacted TSs and TRs: 23.002.23.271
- 8214: -
- 8215: -
- 8216: - / Impacted TSs and TRs: 23.002.23.271
- 8217: -
- 8218: -
- 8219: - / Impacted TSs and TRs: 23.002.23.271
- 8220: -
- 8221: -
- 8222: - / Impacted TSs and TRs: 23.002.23.271
- 8223: Current stage 3 fullfills stage 2
- 8224: -
- 8225: -
- 8226: - / Impacted TSs and TRs: 25.305; 25.401; 25.450; 25.452; 25.453
- 8227: RP#25 completed (FDD) / Impacted TSs and TRs: new 25.171; 34.171 (testing)
- 8228: RP#38 Work stopped / Impacted TSs and TRs: new 25.894
- 8229: RP#24 Work stopped
- 8230: SP#26 completed / Impacted TSs and TRs: new 32.271
- 8231: SP#9 approved WID. Acronym changed from "SEC1, Rel-6"
- 8232: SP#9 approved WID S3-000490 (Enhanced home control of security by HE) / Impacted TSs and TRs: 33.102
- 8233: Marked as stopped 12/2008
- 8234: SP#9 approved WID S3-000606 (Network Domain Security) / Impacted TSs and TRs: 33.102; 33.103; 33.105
- 8235: SP#9 approved WID S3-000626 (Access security for IP-based services) / Impacted TSs and TRs: 33.210
- 8236: SP#19 approved WID / Impacted TSs and TRs: 33.810
- 8237: - / Impacted TSs and TRs: 42.068; 43.068; 44.068; 42.069; 43.069; 44.069; 31.102; 24.008; 48.008; 42.009; 43.020; New TSs (55.236; 55.205) MILENAGE algorithms
- 8238: SP#19 approved WID. Marked as closed 12/2008 (was marked 20% complete) / Impacted TSs and TRs: 33.200

| ID | WBS | Task | Type | Duration | Start | Finish | Complete | Baseline start | Baseline finish | Baseline duration | Constraint | Resources | Work | Actual work | Acronym | Release | MCC resp | Acronym_3GU_Export | Impacted TSs and TRs | WI rapporteur name | WI rapporteur e-mail | TSG stopped |
| --- | --- | --- | --- | --- | --- | --- | --- | --- | --- | --- | --- | --- | --- | --- | --- | --- | --- | --- | --- | --- | --- | --- |
| 8239 | 16 | **IMS Phase 2** |  | 2665.75d? | 2000-08-28 A | 2007-09-14 A | 100% | 2000-08-28 | 2007-09-14 | 1840d? |  | S1; S2; S3; S5; NP; R5 | 210576h | 210576h | IMS2 | Rel-6 | Alain | IMS2 |  |  |  |  |
| 8240 | 2673.1 | Enhancements to the Cx and Sh interfaces |  | 323d? | 2003-06-06 A | 2004-08-31 A | 100% | 2003-06-06 | 2004-08-31 | 323d? | finish no earlier than 2004-08-31 | N4 | 2584h | 2584h | IMS2-CCR | Rel-6 | Kimmo | IMS2-CCR |  |  |  |  |
| 8241 | 2673.2 | Conformance Test Aspects – IMS Call Control Rel-6 enhancements |  | 396d? | 2006-03-10 A | 2007-09-14 A | 100% | 2006-03-10 | 2007-09-14 | 396d? | finish no earlier than 2007-09-14 | R5 | 3168h | 3168h | IMS2_CCR_Test | Rel-6 | Ingbert | IMS2_CCR_Test | 34.229-1; 34.229-2; 34.229-3; 34.108 | Ericsson | Jacob.John@motorola.com, Leif.Mattisson@ericsson.com |  |
| 8242 | 16.12 | **IMS Group Management** |  | 1036.75d? | 2002-03-14 A | 2004-12-08 A | 100% | 2002-03-14 | 2004-12-08 | 715d? |  | S1 | 12680h | 12680h | IMSGM | Rel-6 | Alain | IMSGM |  | Nokia | juha.kalliokulju@nokia.com |  |
| 8243 | 16.12.1 | Stage 1 - TS on IMS group management |  | 193d | 2002-03-14 A | 2002-12-09 A | 100% | 2002-03-14 | 2002-12-09 | 193d | finish no earlier than 2002-12-09 | S1 | 1544h | 1544h |  | Rel-6 | Alain |  |  | Nokia | juha.kalliokulju@nokia.com |  |
| 8244 | 2673.3.2 | Stage 2 for IMS Group Management |  | 158d? | 2003-05-26 A | 2003-12-31 A | 100% | 2003-05-26 | 2003-12-31 | 158d? | finish no earlier than 2003-12-31 | S2 | 1264h | 1264h |  | Rel-6 | Maurice |  | 23.228 |  |  |  |
| 8245 | 2673.3.3 | Stage 3 for IMS Group management (e.g. chat) |  | 519d? | 2002-12-13 A | 2004-12-08 A | 100% | 2002-12-13 | 2004-12-08 | 519d? | finish no earlier than 2004-12-08 | N1 | 4152h | 4152h |  | Rel-6 | Frederic |  |  | Lucent | Keith Drage (drage@alcatel-lucent.com) |  |
| 8246 | 2673.4 | **IMS Conferencing** |  | 793.25d? | 2002-11-04 A | 2004-12-08 A | 100% | 2002-11-04 | 2004-12-08 | 548d? |  | N1 | 10960h | 10960h |  | Rel-6 | Frederic |  |  |  |  |  |
| 8247 | 2673.4.1 | Stage 2 for IMS Conferencing |  | 303d? | 2002-11-04 A | 2003-12-31 A | 100% | 2002-11-04 | 2003-12-31 | 303d? | finish no earlier than 2003-12-31 | S2 | 2424h | 2424h |  | Rel-6 | Maurice |  | 23.228 |  |  |  |
| 8248 | 2673.4.2 | Stage 3 for IMS Conferencing |  | 519d? | 2002-12-13 A | 2004-12-08 A | 100% | 2002-12-13 | 2004-12-08 | 519d? | finish no earlier than 2004-12-08 | N1 | 4152h | 4152h |  | Rel-6 | Frederic |  |  | Lucent | Keith Drage (drage@alcatel-lucent.com) |  |
| 8249 | 16.11 | **IMS Messaging** |  | 1437.5d? | 2002-03-14 A | 2005-12-30 A | 100% | 2002-03-14 | 2005-12-30 | 992d? |  | S1 | 23912h | 23912h | IMSM | Rel-6 | Alain | IMSM |  | Nokia | juha.kalliokulju@nokia.com |  |
| 8250 | 16.11.1 | TR on support of messaging in the IMS |  | 193d | 2002-03-14 A | 2002-12-09 A | 100% | 2002-03-14 | 2002-12-09 | 193d | finish no earlier than 2002-12-09 | S1 | 1544h | 1544h | IMSM-TR | Rel-6 | Alain | IMSM-TR | New 22.940 | Nokia | juha.kalliokulju@nokia.com |  |
| 8251 | 2673.5.2 | Stage 1 22.340 |  | 23d? | 2002-11-11 A | 2002-12-11 A | 100% | 2002-11-11 | 2002-12-11 | 23d? | finish no earlier than 2002-12-11 | S1 | 184h | 184h | IMSM-TS | Rel-6 | Alain | IMSM-TS | 22.340 | Nokia | juha.kalliokulju@nokia.com |  |
| 8252 | 2673.5.3 | CRs to 22.140 & 22.228 |  | 263d? | 2002-03-14 A | 2003-03-17 A | 100% | 2002-03-14 | 2003-03-17 | 263d? | finish no earlier than 2003-03-17 | S1 | 2104h | 2104h | IMSM-CR | Rel-6 | Alain | IMSM-CR | 22.140.22.228 | Nokia | juha.kalliokulju@nokia.com |  |
| 8253 | 16.11.3 | Stage 2 for IMS Messaging |  | 477d | 2002-11-04 A | 2004-08-31 A | 100% | 2002-11-04 | 2004-08-31 | 477d | finish no earlier than 2004-08-31 | S2 | 3816h | 3816h |  | Rel-6 | Maurice |  | 23.228 |  |  |  |
| 8254 | 2673.5.5 | Stage 3 for IMS Messaging |  | 519d? | 2002-12-13 A | 2004-12-08 A | 100% | 2002-12-13 | 2004-12-08 | 519d? | finish no earlier than 2004-12-08 | N1 | 4152h | 4152h |  | Rel-6 | Frederic |  |  | Lucent | Keith Drage (drage@alcatel-lucent.com) |  |
| 8255 | 2673.5.6 | SIP/SIMPLE Instant messaging |  | 522d? | 2004-01-01 A | 2005-12-30 A | 100% | 2004-01-01 | 2005-12-30 | 522d? | finish no earlier than 2005-06-30 | OMA | 4176h | 4176h |  | Rel-6 |  |  |  |  | OMA-LIAISON@mail.openmobilealliance.org |  |
| 8256 | 2673.6 | **Additional SIP Capabilities support not covered by Rel-5** |  | 983.75d? | 2002-11-11 A | 2005-06-17 A | 100% | 2002-11-11 | 2005-06-17 | 680d? |  | N1 | 13392h | 13392h |  | Rel-6 | Frederic |  |  |  |  |  |
| 8257 | 2673.6.1 | Stage 2 for add SIP cap (e.g. forking) |  | 335d? | 2002-11-11 A | 2004-02-20 A | 100% | 2002-11-11 | 2004-02-20 | 335d? | finish no earlier than 2004-02-20 | S2 | 2680h | 2680h |  | Rel-6 | Maurice |  | 23.228 |  |  |  |
| 8258 | 2673.6.2 | Stage 3 for Additional SIP Capabilities |  | 454d? | 2002-12-13 A | 2004-09-08 A | 100% | 2002-12-13 | 2004-09-08 | 454d? | finish no earlier than 2004-09-08 | N1 | 3632h | 3632h |  | Rel-6 | Frederic |  |  | Lucent | Keith Drage (drage@alcatel-lucent.com) |  |
| 8259 | 2673.6.3 | Procedured associated with IMS-ALG |  | 205d? | 2004-09-06 A | 2005-06-17 A | 100% | 2004-09-06 | 2005-06-17 | 205d? | start no earlier than 2004-09-06 | N1 | 1640h | 1640h |  | Rel-6 | Frederic |  |  |  |  |  |
| 8260 | 2673.7 | Review additional SIP Capabilities against IMS |  | 454d? | 2002-12-13 A | 2004-09-08 A | 100% | 2002-12-13 | 2004-09-08 | 454d? | finish no earlier than 2004-09-08 | N1 | 3632h | 3632h |  | Rel-6 | Frederic |  |  | Lucent | Keith Drage (drage@alcatel-lucent.com) |  |
| 8261 | 16.5 | **Interworking between IMS and IP networks** |  | 1619.75d? | 2000-08-28 A | 2004-12-08 A | 100% | 2000-08-28 | 2004-12-08 | 1118d? |  | N3 | 31712h | 31712h | IMS-CCR-IWIP | Rel-6 | Gwiho | IMS-CCR-IWIP | 23.821; 29.061; 29.162 | BT | nigel.holland@bt.com |  |
| 8262 | 16.5.1 | Interworking for 3GPP_SIP and IETF_SIP |  | 730d | 2000-08-28 A | 2003-06-13 A | 100% | 2000-08-28 | 2003-06-13 | 730d | finish no earlier than 2003-06-13 | N3 | 5840h | 5840h |  | Rel-6 | Gwiho |  | New 29.962 | Siemens | Thomas.Belling@nsn.com |  |
| 8263 | 16.5.2 | Interworking for IPv6 to IPv4 |  | 1118d | 2000-08-28 A | 2004-12-08 A | 100% | 2000-08-28 | 2004-12-08 | 1118d | finish no earlier than 2004-12-08 | N3 | 8944h | 8944h |  | Rel-6 | Gwiho |  | 29.163 |  |  |  |
| 8264 | 2673.8.3 | Interworking for IPv6 to IPv4 (SIP / SDP aspects) |  | 87d? | 2004-05-11 A | 2004-09-08 A | 100% | 2004-05-11 | 2004-09-08 | 87d? | finish no earlier than 2004-09-08 | N1 | 696h | 696h |  | Rel-6 | Frederic |  |  |  |  |  |
| 8265 | 16.8.1 | stage 3 of interworking with non-IMS IP networks |  | 911d | 2001-03-14 A | 2004-09-08 A | 100% | 2001-03-14 | 2004-09-08 | 911d | finish no earlier than 2004-09-08 | N1 | 7288h | 7288h |  | Rel-6 | Frederic |  |  |  |  |  |
| 8266 | 16.6.1 | Interworking between IMS and CS networks |  | 1345.25d? | 2000-08-28 A | 2004-03-18 A | 100% | 2000-08-28 | 2004-03-18 | 929d? | finish no earlier than 2004-03-18 | N3 | 7432h | 7432h | IMS-CCR-IWCS | Rel-6 | Gwiho | IMS-CCR-IWCS | 29.163; 29.061; 24.228; and New CN4 specification | Vodafone | Brendan.McWilliams@gb.vodafone.co.uk |  |
| 8267 | 16.10 | Mn interface (IM-MGW to MGCF) enhancements (CN4 Part) |  | 418d | 2001-08-07 A | 2004-09-01 A | 100% | 2001-08-07 | 2004-09-01 | 418d | finish no earlier than 2004-09-01 | N4 | 3344h | 3344h | IMS-CCR-Mn | Rel-6 | Kimmo | IMS-CCR-Mn |  |  |  |  |
| 8268 | 2673.11 | Study of subscriber and operators relationship in IMS and related ISIM requirements for Rel 6” |  | 20d? | 2002-11-15 A | 2002-12-12 A | 100% | 2002-11-15 | 2002-12-12 | 20d? | finish no earlier than 2002-12-12 | S1 | 160h | 160h |  | Rel-6 | Alain |  |  | Nokia | juha.kalliokulju@nokia.com |  |
| 8269 | 2673.12 | Lawful Interception in Rel-6 architecture |  | 269d? | 2002-12-09 A | 2003-12-18 A | 100% | 2002-12-09 | 2003-12-18 | 269d? | finish no earlier than 2003-12-18 | S3 | 2152h | 2152h | SEC1-LI | Rel-6 | Mirko | SEC1-LI, Rel-6 | 33.106; 33.107; 33.108 | Reg TP, Nortel | berthold.wilhelm@regtp.de, Ron Ryan |  |
| 8270 | 2673.13 | IMS Subscription and access scenarios |  | 130d? | 2002-12-16 A | 2003-06-13 A | 100% | 2002-12-16 | 2003-06-13 | 130d? | start no earlier than 2002-12-16 | S1 | 1040h | 1040h |  | Rel-6 | Alain |  | 22.800 | TeliaSonera | FRANK, Robert |  |
| 8271 | 2673.14 | IMS charging |  | 455d? | 2003-03-21 A | 2004-12-16 A | 100% | 2003-03-21 | 2004-12-16 | 455d? | finish no earlier than 2004-12-16 | S5 | 3640h | 3640h | IMS2-CH | Rel-6 | Mirko | IMS2-CH | 32.260 | Ericsson | Patrik TEPPO |  |
| 8272 | 2673.15 | IMS Management objects |  | 306d? | 2004-09-03 A | 2005-11-04 A | 100% | 2004-09-03 | 2005-11-04 | 306d? | finish no earlier than 2005-03-04 | N1 | 2448h | 2448h |  | Rel-6 | Frederic |  | 24.167 |  |  |  |
| 8273 | 2673.16 | Deleted - Stage 2 of IMS Phase 2 | milestone | 0d? | 2003-09-19 A | 2003-09-19 A | 100% | 2003-09-19 | 2003-09-19 | 0d? | finish no earlier than 2003-09-19 | S2 |  |  |  | Rel-6 | Maurice |  |  |  |  | SP-21 |

Notes:
- 8239: -
- 8240: Shared public user identities need to be solved. If email approval CR is accepted. Work 100% done.
- 8241: -
- 8242: -
- 8243: -
- 8244: -
- 8245: Depends on CN decision on CPCP in Rel-6. Complete, if unresolved IETF dependencies are dropped (-> LS to CN plenary)
- 8246: -
- 8247: -
- 8248: Depends on CN decision on IETF dependenciES in CP-150Rel-6. Higher figure if CPCP is dropped (-> LS to CN plenary)
- 8249: -
- 8250: -
- 8251: -
- 8252: -
- 8253: -
- 8254: -
- 8255: Updated according to SP-040232
- 8256: -
- 8257: -
- 8258: -
- 8259: -
- 8260: -
- 8261: [DAB 14.02.02] - end date pushed back to March 2003
- 8262: [DAB - 20.08.03] - CN Part of TR Complete @ CN#20
- 8263: -
- 8264: -
- 8265: -
- 8266: [DAB - 25.05.04] - CN3 consider this work to be complete
- 8267: TISPAN issue is open
- 8268: -
- 8269: Acronym changed from "SEC1-LI, Rel6"
- 8270: -
- 8271: SP#26 12/2004 completed
- 8272: -
- 8273: -

| ID | WBS | Task | Type | Duration | Start | Finish | Complete | Baseline start | Baseline finish | Baseline duration | Constraint | Resources | Work | Actual work | Acronym | WI rapporteur name | WI rapporteur e-mail | Release | MCC resp | Acronym_3GU_Export | Impacted TSs and TRs | Created at | TSG stopped |
| --- | --- | --- | --- | --- | --- | --- | --- | --- | --- | --- | --- | --- | --- | --- | --- | --- | --- | --- | --- | --- | --- | --- | --- |
| 8274 | 2674 | **3GPP Enablers for services like Push to Talk over Cellular (PoC)** |  | 663.75d? | 2003-09-08 A | 2005-06-09 A | 100% | 2003-09-08 | 2005-06-09 | 459d? |  | S2; S4; S5 | 18040h | 18040h | PoC | Ericsson | Shabnam Sultana | Rel-6 | Maurice | PoC |  |  |  |
| 8275 | 2674.1 | Feasibility Study on 3GPP Enablers for services like Push to Talk over Cellular (PoC) |  | 322d? | 2003-09-08 A | 2004-11-30 A | 100% | 2003-09-08 | 2004-11-30 | 322d? | finish no earlier than 2004-11-30 | S2 | 2576h | 2576h |  | Ericsson | Shabnam Sultana | Rel-6 | Maurice |  | 23.979 | SP-24 |  |
| 8276 | 2674.2 | Dependencies on OMA PoC |  | 303d? | 2004-01-01 A | 2005-02-28 A | 100% | 2004-01-01 | 2005-02-28 | 303d? | finish no earlier than 2004-12-30 | OMA | 2424h | 2424h |  |  | OMA-LIAISON@mail.openmobilealliance.org | Rel-6 |  |  |  | SP-24 |  |
| 8277 | 2674.3 | Selection of one or more PoC codec(s) for PoC |  | 69d? | 2004-09-13 A | 2004-12-16 A | 100% | 2004-09-13 | 2004-12-16 | 69d? | start no earlier than 2004-09-13 | S4 | 552h | 552h |  |  |  | Rel-6 | Paolo |  | 26.235; 26.236 | SP-25 |  |
| 8278 | 2674.4 | PoC charging |  | 184d? | 2004-09-27 A | 2005-06-09 A | 100% | 2004-09-27 | 2005-06-09 | 184d? | finish no earlier than 2005-06-09 | S5 | 1472h | 1472h | PoC-CH | Siemens | Gerald.Goermer@nsn.com | Rel-6 | Mirko | PoC-CH | 32.272 |  |  |
| 8279 | 2675 | Study on Interworking aspects and migration scenarios for IPv4 based IMS Implementations |  | 210d? | 2003-09-08 A | 2004-06-25 A | 100% | 2003-09-08 | 2004-06-25 | 210d? | finish no earlier than 2004-06-25 | S2 | 1680h | 1680h | IPv4IMS | Siemens | Alexander Milinski | Rel-6 | Maurice | IPv4IMS | 23.981 |  |  |
| 8280 | 16.3 | **Interoperability and Commonality between IMS using different IP-connectivity Networks** |  | 469d? | 2002-09-16 A | 2003-12-12 A | 100% | 2002-09-16 | 2003-12-12 | 325d? |  | S2 | 9176h | 9176h | IMSCOOP |  |  | Rel-6 | Maurice | IMSCOOP | 23.864 |  |  |
| 8281 | 16.3.1 | Stage 2 for Interoperability |  | 272d | 2002-09-16 A | 2003-09-30 A | 100% | 2002-09-16 | 2003-09-30 | 272d | finish no earlier than 2003-09-30 | S2 | 2176h | 2176h |  | Nokia | balazs.bertenyi@nsn.com | Rel-6 | Maurice |  | 23.864 |  |  |
| 8282 | 2676.2 | Stage 2 for commonality |  | 265d? | 2002-09-16 A | 2003-09-19 A | 100% | 2002-09-16 | 2003-09-19 | 265d? | start no earlier than 2002-09-16 | S2 | 2120h | 2120h |  | Nokia | balazs.bertenyi@nsn.com | Rel-6 | Maurice |  | 23.864 |  |  |
| 8283 | 16.3.2 | Stage 3 for Interoperability and Commonality between IMS using different IP-connectivity Networks |  | 305d | 2002-10-14 A | 2003-12-12 A | 100% | 2002-10-14 | 2003-12-12 | 305d | finish no earlier than 2003-12-12 | N1 | 2440h | 2440h |  | Lucent | Keith Drage (drage@alcatel-lucent.com) | Rel-6 | Frederic |  |  |  |  |
| 8284 | 17 | **Support of Push Services** |  | 1192d | 2001-01-03 A | 2004-02-27 A | 100% | 2001-01-03 | 2004-02-27 | 823d |  | S1 | 11390.6h | 11390.6h | PUSH | NTT Comware | Yoshinori Kitada | Rel-6 | Alain | PUSH | 23.976 |  |  |
| 8285 | 17.1 | Stage 1 for Support of Push Services |  | 378d | 2001-01-03 A | 2002-06-14 A | 100% | 2001-01-03 | 2002-06-14 | 378d | finish no earlier than 2002-06-14 | S1 | 3024h | 3024h |  |  |  | Rel-6 | Alain |  |  |  |  |
| 8286 | 17.3 | TR 23.976 on Push Architecture |  | 340d | 2002-11-11 A | 2004-02-27 A | 100% | 2002-11-11 | 2004-02-27 | 340d | finish no earlier than 2004-02-27 | S2 | 2720h | 2720h |  | Research In Motion | Nick Alfano | Rel-6 | Maurice |  | 23.976 |  |  |
| 8287 | 18 | **Rel-6 Multimedia Messaging (MMS) enhancements** |  | 1254.25d? | 2002-08-15 A | 2005-12-07 A | 100% | 2002-08-15 | 2005-12-07 | 865d? |  | T2; S1; S4; S5; OMA | 59616h | 59616h | MMS6 | Siemens | Josef.Laumen@SAL.SIEMENS.DE | Rel-6 | Kimmo | MMS6 |  |  |  |
| 8288 | 18.1 | **Definition of service requirements for MMS6** |  | 414.25d? | 2002-11-15 A | 2003-12-19 A | 100% | 2002-11-15 | 2003-12-19 | 286d? |  | S1 | 4576h | 4576h | MMS6-SR |  |  | Rel-6 | Alain | MMS6-SR | 22.140 |  |  |
| 8289 | 2678.1.1 | Definition of service requirements charging |  | 286d? | 2002-11-15 A | 2003-12-19 A | 100% | 2002-11-15 | 2003-12-19 | 286d? | finish no earlier than 2003-12-20 | S1 | 2288h | 2288h |  | Siemens | Josef.Laumen@SAL.SIEMENS.DE | Rel-6 | Alain |  | 22.140 |  |  |
| 8290 | 18.2 | Technical realization of MMS6 |  | 591d | 2002-09-06 A | 2004-12-10 A | 100% | 2002-09-06 | 2004-12-10 | 591d | finish no earlier than 2004-12-10 | T2 | 4728h | 4728h |  | Siemens | Josef.Laumen@SAL.SIEMENS.DE | Rel-6 | Kimmo |  | 23.140 |  |  |
| 8291 | 18.3 | OMA dependencies |  | 446d | 2003-08-15 A | 2005-04-29 A | 100% | 2003-08-15 | 2005-04-29 | 446d | finish no earlier than 2004-12-10 | OMA | 3568h | 3568h |  |  |  | Rel-6 | Kimmo |  | OMA specs |  |  |
| 8292 | 18.4 | MMS formats and codecs for MMS6 |  | 865d | 2002-08-15 A | 2005-12-07 A | 100% | 2002-08-15 | 2005-12-07 | 865d | finish no earlier than 2005-12-07 | S4 | 6920h | 6920h | MMS6-Codec | Nokia | roberto.castagno@nokia.com | Rel-6 | Paolo | MMS6-Codec | 26.140; 26.936 |  |  |
| 8293 | 2678.5 | Handling of private addressing schemes in MMS |  | 263d | 2003-12-10 A | 2004-12-10 A | 100% | 2003-12-10 | 2004-12-10 | 263d | finish no earlier than 2004-12-10 | T2 | 2104h | 2104h |  | T-Mobile | Steffen.Habermann@T-MOBILE.DE | Rel-6 | Kimmo |  | 23.140 |  |  |
| 8294 | 2678.6 | MMS charging |  | 390d? | 2003-03-21 A | 2004-09-16 A | 100% | 2003-03-21 | 2004-09-16 | 390d? | start no earlier than 2003-03-21 | S5 | 3120h | 3120h | MMS6-CH |  |  | Rel-6 | Mirko | MMS6-CH | 32.270 |  |  |
| 8295 | 2678.7 | Deleted - FS Multiple MMS Relay/Server Architecture | milestone | 0d | 2004-12-10 A | 2004-12-10 A | 100% | 2004-12-10 | 2004-12-10 | 0d | finish no earlier than 2004-12-10 | T2 |  |  |  | Telefónica Móviles | Juan Gorospe (gorospe_j@tsm.es) | Rel-6 | Kimmo |  | probably Annex to 23.140 |  | TP-26 |
| 8296 | 19 | **Rel-6 MExE enhancements** |  | 472.25d | 2002-03-08 A | 2003-06-06 A | 100% | 2002-03-08 | 2003-06-06 | 326d |  | T2 | 7328h | 7328h | MEXE6 |  |  | Rel-6 | Kimmo | MEXE6 |  |  |  |
| 8297 | 19.1 | MExE Rel-6 Improvements and Investigations |  | 264d | 2002-03-08 A | 2003-03-12 A | 100% | 2002-03-08 | 2003-03-12 | 264d | finish no earlier than 2003-03-12 | T2 | 2112h | 2112h | MEXE6-ENHANC | TTPCom | Lars Brenk ( (lsb_ttpcom@HOTMAIL.COM) | Rel-6 | Kimmo | MEXE6-ENHANC |  |  |  |
| 8298 | 19.2 | MExE Run-Time Independent Framework Feasibility Study |  | 326d | 2002-03-08 A | 2003-06-06 A | 100% | 2002-03-08 | 2003-06-06 | 326d | finish no earlier than 2003-06-06 | T2 | 2608h | 2608h | MEXE6-RTIF | Nokia Siemens Networks | balazs.bertenyi@nokia.com | Rel-6 | Kimmo | MEXE6-RTIF | 22.857 |  |  |
| 8299 | 21 | Subscription Management |  | 650d | 2002-09-20 A | 2005-03-17 A | 100% | 2002-09-20 | 2005-03-17 | 650d | finish no earlier than 2005-03-17 | S5 | 5200h | 5200h | SuM | T-Mobile | istvan.aba@t-mobile.at | Rel-6 | Mirko | SuM | 32.140/1; 32.171/2/5; 32.803 |  |  |

Notes:
- 8274: -
- 8275: -
- 8276: Updated according to SP-040232
- 8277: Completed
- 8278: SP#28 06/2005 completed
- 8279: -
- 8280: -
- 8281: No contributions assumed that no more will be done in 3GPP hence work may need to be done in 3GPP2
- 8282: -
- 8283: -
- 8284: Changed from FS to actual support of Push
- 8285: -
- 8286: -
- 8287: -
- 8288: -
- 8289: -
- 8290: -
- 8291: -
- 8292: -
- 8293: -
- 8294: SP#25 09/2004 completed
- 8295: originally it was intended to create a FS TR but most likely the work will become an Annex of 23.140
- 8296: -
- 8297: -
- 8298: -
- 8299: SP#27 03/2005 completed

| ID | WBS | Task | Duration | Start | Finish | Complete | Baseline start | Baseline finish | Baseline duration | Constraint | Resources | Work | Actual work | Acronym | WI rapporteur name | WI rapporteur e-mail | Release | MCC resp | Acronym_3GU_Export |
| --- | --- | --- | --- | --- | --- | --- | --- | --- | --- | --- | --- | --- | --- | --- | --- | --- | --- | --- | --- |
| 8300 | 22 | **Presence Capability** | 1786.5d? | 2001-03-19 A | 2005-12-07 A | 100% | 2001-03-19 | 2005-12-07 | 1233d? |  | S1; S2; S3; S4; N1; N3; N4; OMA | 111784h | 111784h | PRESNC | Motorola | Mark Cataldo | Rel-6 | Alain | PRESNC |
| 8301 | 22.1 | Stage 1 for Presence Capability | 610d | 2001-03-19 A | 2003-07-18 A | 100% | 2001-03-19 | 2003-07-18 | 610d | finish no earlier than 2003-07-18 | S1 | 4880h | 4880h |  | Motorola | Mark Cataldo | Rel-6 | Alain |  |
| 8302 | 22.2 | Stage 2 for Presence Capability | 268d | 2001-09-12 A | 2002-09-20 A | 100% | 2001-09-12 | 2002-09-20 | 268d | finish no earlier than 2002-09-20 | S2 | 2144h | 2144h |  | Nokia | balazs.bertenyi@nsn.com | Rel-6 | Maurice |  |
| 8303 | 22.3 | Stage 3 for Presence Capability | 703d | 2002-04-01 A | 2004-12-08 A | 100% | 2002-04-01 | 2004-12-08 | 703d | finish no earlier than 2004-12-08 | N1; N4 | 11248h | 11248h |  | Lucent | Keith Drage (drage@alcatel-lucent.com) | Rel-6 | Frederic |  |
| 8304 | 2681.4 | Stage 3 (CN3 Part Pk interface) | 770d? | 2002-04-01 A | 2005-03-11 A | 100% | 2002-04-01 | 2005-03-11 | 770d? | finish no earlier than 2005-03-11 | N3 | 6160h | 6160h |  | Lucent | Keith Drage (drage@alcatel-lucent.com) | Rel-6 | Gwiho |  |
| 8305 | 2681.5 | Media Codecs and Formats for IMS Messaging and Presence | 650d? | 2003-06-12 A | 2005-12-07 A | 100% | 2003-06-12 | 2005-12-07 | 650d? | finish no earlier than 2005-12-07 | S4 | 5200h | 5200h | PRESNC-COFIMP | Nokia | harri.honko@nokia.com | Rel-6 | Paolo | PRESNC-COFIMP |
| 8306 | 22.4 | Security aspects of Presence Capability | 79d | 2002-08-26 A | 2002-12-12 A | 100% | 2002-08-26 | 2002-12-12 | 79d | finish no earlier than 2002-12-12 | S3 | 632h | 632h |  | Ericsson | krister.boman@erv.ericsson.se | Rel-6 | Mirko |  |
| 8307 | 2681.7 | SIMPLE Presence | 326d? | 2004-01-01 A | 2005-03-31 A | 100% | 2004-01-01 | 2005-03-31 | 326d? | finish no earlier than 2004-12-30 | OMA | 2608h | 2608h |  |  | OMA-LIAISON@mail.openmobilealliance.org | Rel-6 |  |  |
| 8308 | 25 | **Enhanced A/Gb feasibility study** | 73.5d? | 2002-08-30 A | 2002-11-08 A | 100% | 2002-08-30 | 2002-11-08 | 51d? |  | GP | 3264h | 3264h | AGbEnFS | Vodafone | jose-luis.carrizo@vodafone.co.uk | Rel-6 | Paolo | AGbEnFS |
| 8309 | 25.1 | **Feasibility study on A/Gb enhancements** | 73.5d? | 2002-08-30 A | 2002-11-08 A | 100% | 2002-08-30 | 2002-11-08 | 51d? |  | G2 | 2856h | 2856h | AGbEnFS-FS | Vodafone | jose-luis.carrizo@vodafone.co.uk | Rel-6 | Gert | AGbEnFS-FS |
| 8310 | 25.1.1 | Requirements for the support of conversational services | 51d | 2002-08-30 A | 2002-11-08 A | 100% | 2002-08-30 | 2002-11-08 | 51d | finish no earlier than 2002-11-08 | GP | 408h | 408h |  |  |  | Rel-6 | Paolo |  |
| 8311 | 2682.1.2 | Identification of the different building blocks for the provision of conversational services on the existing A/Gb protocol stack | 51d? | 2002-08-30 A | 2002-11-08 A | 100% | 2002-08-30 | 2002-11-08 | 51d? | finish no earlier than 2002-11-08 | GP | 408h | 408h |  |  |  | Rel-6 | Paolo |  |
| 8312 | 2682.1.3 | Outline of impact and feasibility of these building blocks and their different solutions | 51d? | 2002-08-30 A | 2002-11-08 A | 100% | 2002-08-30 | 2002-11-08 | 51d? | finish no earlier than 2002-11-08 | GP | 408h | 408h |  |  |  | Rel-6 | Paolo |  |
| 8313 | 25.1.4 | Impact on 3GPP architecture and requirement to co-ordinatge with other TSGs (CN, SA) | 51d | 2002-08-30 A | 2002-11-08 A | 100% | 2002-08-30 | 2002-11-08 | 51d | finish no earlier than 2002-11-08 | GP | 408h | 408h |  |  |  | Rel-6 | Paolo |  |
| 8314 | 25.1.5 | Standardisation effort | 51d | 2002-08-30 A | 2002-11-08 A | 100% | 2002-08-30 | 2002-11-08 | 51d | finish no earlier than 2002-11-08 | GP | 408h | 408h |  |  |  | Rel-6 | Paolo |  |
| 8315 | 25.1.6 | Dependency to other features of Enhanced A/Gb feasibility study | 51d | 2002-08-30 A | 2002-11-08 A | 100% | 2002-08-30 | 2002-11-08 | 51d | finish no earlier than 2002-11-08 | GP | 408h | 408h |  |  |  | Rel-6 | Paolo |  |
| 8316 | 26 | **Flexible Layer One for GERAN** | 1694.12d | 2000-01-03 A | 2004-06-25 A | 100% | 2000-01-03 | 2004-06-25 | 1171d |  | GP; S3 | 86648h | 86648h | FLOGER | Nokia | benoist.sebire@nokia.com | Rel-6 | Paolo | FLOGER |
| 8317 | 26.1 | **Realisation of a Flexible Layer One** | 1628.88d | 2000-01-03 A | 2004-04-23 A | 100% | 2000-01-03 | 2004-04-23 | 1126d |  | GP | 42816h | 42816h | FLOGER-Real | Nokia | benoist.sebire@nokia.com | Rel-6 | Paolo | FLOGER-Real |
| 8318 | 26.1.1 | Technical Report on Realisation of a Flexible Layer One | 471d | 2002-04-19 A | 2004-02-06 A | 100% | 2002-04-19 | 2004-02-06 | 471d | finish no earlier than 2004-02-06 | GP | 3768h | 3768h |  | Nokia | benoist.sebire@nokia.com | Rel-6 | Paolo |  |
| 8319 | 26.1.2 | Architecture in 45.001 and 43.051 | 526d | 2002-04-19 A | 2004-04-23 A | 100% | 2002-04-19 | 2004-04-23 | 526d | finish no earlier than 2004-04-23 | G1 | 4208h | 4208h |  | Nokia | benoist.sebire@nokia.com | Rel-6 | Paolo |  |
| 8320 | 26.1.3 | Multiplexing in 45.002 | 526d | 2002-04-19 A | 2004-04-23 A | 100% | 2002-04-19 | 2004-04-23 | 526d | finish no earlier than 2004-04-23 | G1 | 4208h | 4208h |  | Nokia | benoist.sebire@nokia.com | Rel-6 | Paolo |  |
| 8321 | 26.1.4 | Channel Coding in 45.003 for Realisation of a Flexible Layer One | 526d | 2002-04-19 A | 2004-04-23 A | 100% | 2002-04-19 | 2004-04-23 | 526d | finish no earlier than 2004-04-23 | G1 | 4208h | 4208h |  | Nokia | benoist.sebire@nokia.com | Rel-6 | Paolo |  |
| 8322 | 26.1.5 | Performance Requirements in 45.005 for Realisation of a Flexible Layer One | 1126d | 2000-01-03 A | 2004-04-23 A | 100% | 2000-01-03 | 2004-04-23 | 1126d | finish no earlier than 2004-04-23 | G1 | 9000h | 9000h |  | Nokia | benoist.sebire@nokia.com | Rel-6 | Paolo |  |
| 8323 | 26.1.6 | Radio subsystem link control in 45.008 for Realisation of a Flexible Layer One | 526d | 2002-04-19 A | 2004-04-23 A | 100% | 2002-04-19 | 2004-04-23 | 526d | finish no earlier than 2004-04-23 | G1 | 4208h | 4208h |  | Nokia | benoist.sebire@nokia.com | Rel-6 | Paolo |  |
| 8324 | 26.1.7 | Requirements in 44.004 | 526d | 2002-04-19 A | 2004-04-23 A | 100% | 2002-04-19 | 2004-04-23 | 526d | finish no earlier than 2004-04-23 | G2 | 4208h | 4208h |  | Nokia | benoist.sebire@nokia.com | Rel-6 | Gert |  |

Notes:
- 8300: merged "Presence Service Enhancements" (UID31028, PRES1) to this feature as no answer was provided on why Presence and Presence Encmts had same target completion date
- 8301: TP#16 moved Stage 1 to Rel-6 TS 22.141 (existed already in Rel-5) / Impacted TSs and TRs: 22.141
- 8302: - / Impacted TSs and TRs: 23.002; 24.229; New 23.141
- 8303: Dependency to 2 IETF drafts, no known work at the moment / Impacted TSs and TRs: New N1 (24.141; 24.841); N4 (29.002; 29.228; 29.230; 29.328)
- 8304: - / Impacted TSs and TRs: 29.061; 29.161
- 8305: - / Impacted TSs and TRs: 26.141; 26.936
- 8306: SP#17 approved WID S3-020429
- 8307: SP#24 OMA LS_in update in SP-040232 OMA dependencies on 3GPP deliverables
- 8308: - / Impacted TSs and TRs: None
- 8309: - / Impacted TSs and TRs: None
- 8310: - / Impacted TSs and TRs: None
- 8311: - / Impacted TSs and TRs: None
- 8312: - / Impacted TSs and TRs: None
- 8313: - / Impacted TSs and TRs: None
- 8314: - / Impacted TSs and TRs: None
- 8315: - / Impacted TSs and TRs: None
- 8316: -
- 8317: -
- 8318: -
- 8319: -
- 8320: -
- 8321: -
- 8322: -
- 8323: -
- 8324: -

| ID | WBS | Task | Type | Duration | Start | Finish | Complete | Baseline start | Baseline finish | Baseline duration | Constraint | Resources | Work | Actual work | Acronym | WI rapporteur name | WI rapporteur e-mail | Release | MCC resp | Acronym_3GU_Export | Impacted TSs and TRs | TSG stopped |
| --- | --- | --- | --- | --- | --- | --- | --- | --- | --- | --- | --- | --- | --- | --- | --- | --- | --- | --- | --- | --- | --- | --- |
| 8325 | 26.2 | **Signalling and protocol support for a Flexible Layer One** |  | 827.5d | 2002-04-19 A | 2004-06-25 A | 100% | 2002-04-19 | 2004-06-25 | 571d |  | G2 | 13704h | 13704h | FLOGER-SigPro | Nokia | benoist.sebire@nokia.com | Rel-6 | Gert | FLOGER-SigPro |  |  |
| 8326 | 26.2.1 | Modifications to RLC/MAC in 44.060 and 44.160 |  | 571d | 2002-04-19 A | 2004-06-25 A | 100% | 2002-04-19 | 2004-06-25 | 571d | finish no earlier than 2004-06-25 | G2 | 4568h | 4568h |  | Nokia | benoist.sebire@nokia.com | Rel-6 | Gert |  |  |  |
| 8327 | 26.2.2 | Modifications to RRC in 44.118 and 44.018 |  | 571d | 2002-04-19 A | 2004-06-25 A | 100% | 2002-04-19 | 2004-06-25 | 571d | finish no earlier than 2004-06-25 | G2 | 4568h | 4568h |  | Nokia | benoist.sebire@nokia.com | Rel-6 | Gert |  |  |  |
| 8328 | 26.3 | **Security for a Flexible Layer One** |  | 515.75d | 2002-04-19 A | 2003-08-29 A | 100% | 2002-04-19 | 2003-08-29 | 356d |  | S3; G2 | 11392h | 11392h | FLOGER-SecFLO | Nokia | benoist.sebire@nokia.com | Rel-6 | Mirko | FLOGER-SecFLO |  |  |
| 8329 | 26.3.1 | Ciphering in 44.060, 44.160, 44.018, 44.118 |  | 356d | 2002-04-19 A | 2003-08-29 A | 100% | 2002-04-19 | 2003-08-29 | 356d | finish no earlier than 2003-08-29 | S3; G2 | 5696h | 5696h |  | Nokia | benoist.sebire@nokia.com | Rel-6 | Mirko |  | 44.060; 44.160; 44.018; 44.118 |  |
| 8330 | 26.4 | **Deleted - GERAN MS Conformance test for the Flexible Layer One - DELETE** |  | 0d | 2004-02-06 A | 2004-02-06 A | 100% | 2004-02-06 | 2004-02-06 | 0d |  | G4; G5 |  |  | FLOGER-Msconf | Nokia | benoist.sebire@nokia.com | Rel-6 | Paolo | FLOGER-Msconf |  | GP-27 |
| 8331 | 26.4.1 | Deleted at TSG #27 - MS Test in 51.010 | milestone | 0d | 2004-02-06 A | 2004-02-06 A | 100% | 2004-02-06 | 2004-02-06 | 0d | finish no earlier than 2004-02-06 | G4; G5 |  |  |  | Nokia | benoist.sebire@nokia.com | Rel-6 | Paolo |  |  | GP-22 |
| 8332 | 26.5 | **Deleted - GERAN BTS Conformance test for the Flexible Layer One - DELETE** |  | 0d | 2004-02-06 A | 2004-02-06 A | 100% | 2004-02-06 | 2004-02-06 | 0d |  | G3new |  |  | FLOGER-BTSconf | Nokia | benoist.sebire@nokia.com | Rel-6 | Ingbert | FLOGER-BTSconf |  | GP-27 |
| 8333 | 26.5.1 | Deleted at TGS #27 - BTS Test in 51.021 - DELETE | milestone | 0d | 2004-02-06 A | 2004-02-06 A | 100% | 2004-02-06 | 2004-02-06 | 0d | finish no earlier than 2004-02-06 | G3new |  |  |  | Nokia | benoist.sebire@nokia.com | Rel-6 | Ingbert |  |  | GP-22 |
| 8334 | 27 | Uplink TDOA feasibility study |  | 151d | 2001-11-30 A | 2002-06-28 A | 100% | 2001-11-30 | 2002-06-28 | 151d | finish no earlier than 2002-06-28 | GP | 1208h | 1208h | TDOAF | TruePosition | Bob Gross (rlgross@trueposition.com) | Rel-6 | Paolo | TDOAF | 45.811 |  |
| 8335 | 28 | **Multimedia Broadcast and Multicast Service** |  | 2582d? | 2001-05-11 A | 2008-03-07 A | 100% | 2001-05-11 | 2008-03-07 | 1781d? |  | S1; S2; S3; S4; S5; N1; N3; R2; R4; R5; T1; GP; G2; G3new | 391176h | 391176h | MBMS |  |  | Rel-6 | Alain | MBMS |  |  |
| 8336 | 28.1 | Stage 1 for Multimedia Broadcast and Multicast Service |  | 232d | 2001-05-11 A | 2002-04-01 A | 100% | 2001-05-11 | 2002-04-01 | 232d | finish no earlier than 2002-04-01 | S1 | 1856h | 1856h |  |  |  | Rel-6 | Alain |  | 22.146; 22.101 |  |
| 8337 | 28.2 | **Stage 2 for Multimedia Broadcast and Multicast Service** |  | 938.25d | 2001-09-24 A | 2004-03-17 A | 100% | 2001-09-24 | 2004-03-17 | 648d |  | S2 | 10408h | 10408h |  |  |  | Rel-6 | Maurice |  |  |  |
| 8338 | 28.2.1 | TR on MBMS Architectural Study |  | 240d | 2001-09-24 A | 2002-08-23 A | 100% | 2001-09-24 | 2002-08-23 | 240d | finish no earlier than 2002-08-23 | S2 | 1920h | 1920h |  |  |  | Rel-6 | Maurice |  | 23.846 |  |
| 8339 | 28.2.2 | Stage 2 MBMS Specification Work |  | 413d | 2002-08-19 A | 2004-03-17 A | 100% | 2002-08-19 | 2004-03-17 | 413d | finish no earlier than 2004-03-17 | S2 | 3304h | 3304h |  |  |  | Rel-6 | Maurice |  | 23.246 |  |
| 8340 | 28.4 | Support of the MBMS in CN protocols |  | 647d | 2002-06-18 A | 2004-12-08 A | 100% | 2002-06-18 | 2004-12-08 | 647d | finish no earlier than 2004-12-08 | N1 | 5176h | 5176h |  |  |  | Rel-6 | Frederic |  |  |  |
| 8341 | 2685.4 | Gmb interface for MBMS (CN3 part) |  | 334d | 2003-08-29 A | 2004-12-08 A | 100% | 2003-08-29 | 2004-12-08 | 334d | finish no earlier than 2004-12-08 | N3 | 2672h | 2672h |  |  |  | Rel-6 | Gwiho |  | 29.061 |  |
| 8342 | 28.5 | Security aspects of MBMS |  | 710d | 2002-07-01 A | 2005-03-18 A | 100% | 2002-07-01 | 2005-03-18 | 710d | finish no earlier than 2005-03-18 | S3 | 5680h | 5680h |  |  | adrian.escott@three.co.uk | Rel-6 | Mirko |  | New 33.246 |  |
| 8343 | 2685.6 | MBMS Charging |  | 108d? | 2005-01-11 A | 2005-06-09 A | 100% | 2005-01-11 | 2005-06-09 | 108d? | start no earlier than 2005-01-11 | S5 | 864h | 864h | MBMS-CH |  |  | Rel-6 | Mirko | MBMS-CH | 32.273 |  |
| 8344 | 28.1 | **MBMS User Services** |  | 1076d? | 2003-05-13 A | 2006-03-16 A | 100% | 2003-05-13 | 2006-03-16 | 743d? |  | S1; S4 | 19520h | 19520h |  |  |  | Rel-6 | Alain |  |  |  |
| 8345 | 28.1 | Stage 1 for MBMS User Services |  | 233d | 2003-05-13 A | 2004-04-01 A | 100% | 2003-05-13 | 2004-04-01 | 233d | start no earlier than 2003-05-13 | S1 | 1864h | 1864h |  |  |  | Rel-6 | Alain |  | 22.246 |  |
| 8346 | 2685.7.2 | Definition of MBMS user services, media codecs, formats and transport/application protocols using MBMS |  | 721d? | 2003-06-12 A | 2006-03-16 A | 100% | 2003-06-12 | 2006-03-16 | 721d? | finish no earlier than 2006-03-16 | S4 | 5768h | 5768h | MBMS-TSMBMS | Nokia | igor.curcio@nokia.com | Rel-6 | Paolo | MBMS-TSMBMS | 26.346; 26.936; 26.946 |  |
| 8347 | 28.3 | **Introduction of MBMS in RAN** |  | 1401.25d? | 2002-01-01 A | 2005-09-14 A | 100% | 2002-01-01 | 2005-09-14 | 967d? |  | R2; R4 | 23728h | 23728h | MBMS-RAN | Nokia | juho.pirskanen@nokia.com | Rel-6 | Yong-Jun | MBMS-RAN |  |  |
| 8348 | 2685.8.1 | Introduction of MBMS in RAN (physical & upper layers, access network interfaces) |  | 771d? | 2002-01-01 A | 2004-12-14 A | 100% | 2002-01-01 | 2004-12-14 | 771d? | finish no earlier than 2004-12-14 | R2 | 6168h | 6168h |  | Nokia | juho.pirskanen@nokia.com | Rel-6 | Yong-Jun |  | 25.346; 25.304; 25.321; 25.322; 25.323 |  |
| 8349 | 2685.8.2 | UE Performance Requirements for MBMS |  | 261d? | 2004-09-15 A | 2005-09-14 A | 100% | 2004-09-15 | 2005-09-14 | 261d? | finish no earlier than 2005-09-15 | R4 | 2088h | 2088h | MBMS-RAN-RF | Ericsson | Torgny.Palenius@ericsson.com | Rel-6 | Issam | MBMS-RAN-RF | 25.101; 25.133 |  |

Notes:
- 8325: -
- 8326: -
- 8327: -
- 8328: -
- 8329: -
- 8330: -
- 8331: -
- 8332: -
- 8333: -
- 8334: -
- 8335: SP#13 Title renamed
- 8336: -
- 8337: -
- 8338: -
- 8339: -
- 8340: -
- 8341: -
- 8342: SP#17 approved WID S3-020433
- 8343: SP#28 completed
- 8344: -
- 8345: -
- 8346: -
- 8347: -
- 8348: -
- 8349: RP#25 approved WID RP-040370

| ID | WBS | Task | Type | Duration | Start | Finish | Complete | Baseline start | Baseline finish | Baseline duration | Constraint | Deadline | Resources | Work | Actual work | Acronym | Release | MCC resp | Acronym_3GU_Export | Impacted TSs and TRs | WI rapporteur name | WI rapporteur e-mail | Created at | TSG stopped |
| --- | --- | --- | --- | --- | --- | --- | --- | --- | --- | --- | --- | --- | --- | --- | --- | --- | --- | --- | --- | --- | --- | --- | --- | --- |
| 8350 | 2685.9 | **MBMS UE Conformance Testing** |  | 755d? | 2006-03-10 A | 2008-03-07 A | 100% | 2006-03-10 | 2008-03-07 | 521d? |  |  | R5; T1 | 34400h | 34400h | MBMS-UEConTest | Rel-6 | Ingbert | MBMS-UEConTest |  |  |  |  |  |
| 8351 | 16.5.1 | RF/RRM Conformance Test Aspects – MBMS (FDD) |  | 461d | 2006-06-02 A | 2008-03-07 A | 100% | 2006-06-02 | 2008-03-07 | 461d | finish no earlier than 2008-03-07 | 2006-06-02 | R5; T1 | 7376h | 7376h | MBMS-RAN-RF_Test | Rel-6 | Ingbert | MBMS-RAN-RF_Test | 34.108; 34.109; 34.121-1; 34.121-2 | Ericsson | leif.mattisson@ericsson.com | Fri 11/03/05 |  |
| 8352 | 2685.9.2 | Conformance Test Aspects - MBMS for 3.84 Mcps and 7.68 Mcps TDD |  | 318d? | 2006-09-20 A | 2007-12-07 A | 100% | 2006-09-20 | 2007-12-07 | 318d? | finish no earlier than 2007-12-07 |  | R5; T1 | 5088h | 5088h | MBMS-UEConTest_TDH | Rel-6 | Ingbert | MBMS-UEConTest_TDH | 34.108; 34.122; 34.123-1; 34.123-2; 34.123-3 | IPWireless | Timothy Speight (tspeight@ipwireless.com) |  |  |
| 8353 | 2685.9.3 | Signalling Conformance Test Aspects – MBMS for LCR TDD |  | 318d? | 2006-09-20 A | 2007-12-07 A | 100% | 2006-09-20 | 2007-12-07 | 318d? | finish no earlier than 2007-12-07 |  | R5; T1 | 5088h | 5088h | MBMS-UEConTest_SIGTDL | Rel-6 | Ingbert | MBMS-UEConTest_SIGTDL | 34.108; 34.123-1; 34.123-2; 34.123-3 | Datang | zhaojian@datangmobile.cn |  |  |
| 8354 | 2685.9.4 | Conformance Test Aspects – MBMS |  | 396d? | 2006-03-10 A | 2007-09-14 A | 100% | 2006-03-10 | 2007-09-14 | 396d? | finish no earlier than 2007-09-14 |  | R5; T1 | 6336h | 6336h | MBMS_Test | Rel-6 | Ingbert | MBMS_Test | 34.108; 34.123-1; 34.123-2; 34.123-3 | Qualcomm | Shubhang Vora (svora@qualcomm.com) |  |  |
| 8355 | 16.5.1 | Conformance Test Aspects - 1.28 Mcps TDD MBMS RF/RRM |  | 136d | 2007-06-01 A | 2007-12-07 A | 100% | 2007-06-01 | 2007-12-07 | 136d | finish no earlier than 2007-12-07 | 2006-06-02 | R5; T1 | 2176h | 2176h | MBMS-UEConTest_RFTDL | Rel-6 | Ingbert | MBMS-UEConTest_RFTDL | 34.108; 34.109; 34.122 | Datang | chenxiaozhong@datangmobile.cn | Fri 11/03/05 |  |
| 8356 | 28.6 | **Support of MBMS in GERAN** |  | 1292.5d? | 2001-08-30 A | 2005-01-28 A | 100% | 2001-08-30 | 2005-01-28 | 892d? |  |  | GP; G2; G3new | 87400h | 87400h | MBMS-GERAN | Rel-6 | Paolo | MBMS-GERAN |  |  |  |  |  |
| 8357 | 28.6.1 | MBMS Impact on the logical and physical channels |  | 631d | 2002-08-30 A | 2005-01-28 A | 100% | 2002-08-30 | 2005-01-28 | 631d | finish no earlier than 2005-01-28 |  | GP | 5048h | 5048h |  | Rel-6 | Paolo |  |  |  |  |  |  |
| 8358 | 28.6.4 | MBMS Re-synchronisation at cell change |  | 631d | 2002-08-30 A | 2005-01-28 A | 100% | 2002-08-30 | 2005-01-28 | 631d | finish no earlier than 2005-01-28 |  | G2 | 5048h | 5048h |  | Rel-6 | Gert |  |  |  |  |  |  |
| 8359 | 2685.10.3 | Simultaneous support of MBMS services |  | 631d? | 2002-08-30 A | 2005-01-28 A | 100% | 2002-08-30 | 2005-01-28 | 631d? | finish no earlier than 2005-01-28 |  | GP | 5048h | 5048h |  | Rel-6 | Paolo |  |  |  |  |  |  |
| 8360 | 2685.10.4 | Simultaneous support of MBMS and non-MBMS services |  | 892d? | 2001-08-30 A | 2005-01-28 A | 100% | 2001-08-30 | 2005-01-28 | 892d? | finish no earlier than 2005-01-28 |  | GP | 7136h | 7136h |  | Rel-6 | Paolo |  |  |  |  |  |  |
| 8361 | 2685.10.5 | MBMS Resynchronization at cell change |  | 892d? | 2001-08-30 A | 2005-01-28 A | 100% | 2001-08-30 | 2005-01-28 | 892d? | finish no earlier than 2005-01-28 |  | GP | 7136h | 7136h |  | Rel-6 | Paolo |  |  |  |  |  |  |
| 8362 | 28.6.5 | MBMS Decision making process between point-to-point or point-to-multipoint configurations |  | 631d | 2002-08-30 A | 2005-01-28 A | 100% | 2002-08-30 | 2005-01-28 | 631d | finish no earlier than 2005-01-28 |  | GP | 5048h | 5048h |  | Rel-6 | Paolo |  |  |  |  |  |  |
| 8363 | 28.6.6 | MBMS channel allocations procedures to multiple MSs |  | 631d | 2002-08-30 A | 2005-01-28 A | 100% | 2002-08-30 | 2005-01-28 | 631d | finish no earlier than 2005-01-28 |  | GP | 5048h | 5048h |  | Rel-6 | Paolo |  |  |  |  |  |  |
| 8364 | 28.6.7 | MBMS Changes to the Gb interface |  | 631d | 2002-08-30 A | 2005-01-28 A | 100% | 2002-08-30 | 2005-01-28 | 631d | finish no earlier than 2005-01-28 |  | GP | 5048h | 5048h |  | Rel-6 | Paolo |  |  |  |  |  |  |
| 8365 | 28.6.8 | GERAN specific changes to the Iu-ps interface for MBMS |  | 631d | 2002-08-30 A | 2005-01-28 A | 100% | 2002-08-30 | 2005-01-28 | 631d | finish no earlier than 2005-01-28 |  | GP | 5048h | 5048h |  | Rel-6 | Paolo |  |  |  |  |  |  |
| 8366 | 28.6.9 | Interaction between MBMS and Iu-flex |  | 631d | 2002-08-30 A | 2005-01-28 A | 100% | 2002-08-30 | 2005-01-28 | 631d | finish no earlier than 2005-01-28 |  | GP | 5048h | 5048h |  | Rel-6 | Paolo |  |  |  |  |  |  |
| 8367 | 28.6.10 | MBMS Security aspects |  | 631d | 2002-08-30 A | 2005-01-28 A | 100% | 2002-08-30 | 2005-01-28 | 631d | finish no earlier than 2005-01-28 |  | GP | 5048h | 5048h |  | Rel-6 | Paolo |  |  |  |  |  |  |
| 8368 | 2685.10.12 | MBMS-GERAN - MS conformance tests |  | 786d? | 2002-01-25 A | 2005-01-28 A | 100% | 2002-01-25 | 2005-01-28 | 786d? | finish no earlier than 2005-01-28 |  | G3new | 6288h | 6288h |  | Rel-6 | Ingbert |  |  |  |  |  |  |
| 8369 | 2685.10.13 | Deleted - MS conformance tests - G5 | milestone | 0d? | 2003-06-27 A | 2003-06-27 A | 100% | 2003-06-27 | 2003-06-27 | 0d? | start no earlier than 2003-06-27 |  | G5 |  |  |  | Rel-6 | Paolo |  |  |  |  |  | GP-19 |
| 8370 | 29 | **Speech Recognition and Speech Enabled Services** |  | 1600d? | 2001-10-08 A | 2005-12-30 A | 100% | 2001-10-08 | 2005-12-30 | 1105d? |  |  | S1; S2; S4; OMA | 46696h | 46696h | SRSES | Rel-6 | Alain | SRSES |  |  |  |  |  |
| 8371 | 29.1 | Speech Enabled Services Based on Distributed Speech Recognition (DSR) |  | 115d | 2001-10-08 A | 2002-03-15 A | 100% | 2001-10-08 | 2002-03-15 | 115d | finish no earlier than 2002-03-15 |  | S1 | 920h | 920h | DSR | Rel-6 | Alain | DSR | 22.977; 22.941; 23.207; 22.243 | Qualcomm | Dwilliams@qualcomm.com |  |  |
| 8372 | 29.2 | TR on Architectural impacts |  | 212d | 2003-05-12 A | 2004-03-02 A | 100% | 2003-05-12 | 2004-03-02 | 212d | finish no earlier than 2004-03-02 |  | S2 | 1696h | 1696h |  | Rel-6 | Maurice |  | 23.877 |  |  |  |  |
| 8373 | 2686.3 | Codec Work to Support Speech Recognition Framework for Automated Voice Services |  | 568d? | 2002-10-15 A | 2004-12-16 A | 100% | 2002-10-15 | 2004-12-16 | 568d? | finish no earlier than 2004-12-16 |  | S4 | 4544h | 4544h | SRSES-Codec | Rel-6 | Paolo | SRSES-Codec | 26.235; 26.236; 26.243; 26.177; 26.943 | Motorola | David Pearce (bdp003@motorola.com) |  |  |
| 8374 | 2686.4 | Multimodal support |  | 522d? | 2004-01-01 A | 2005-12-30 A | 100% | 2004-01-01 | 2005-12-30 | 522d? | finish no earlier than 2005-06-30 |  | OMA | 4176h | 4176h |  | Rel-6 | Paolo |  |  |  | OMA-LIAISON@mail.openmobilealliance.org | SP-24 |  |
| 8375 | 2686.5 | Deleted - SES codec negotiation at Session Description Protocol (SDP) | milestone | 0d? | 2003-06-04 A | 2003-06-04 A | 100% | 2003-06-04 | 2003-06-04 | 0d? | start no earlier than 2003-06-04 |  | N1 |  |  |  | Rel-6 | Frederic |  |  |  |  |  | NP-23 |

Notes:
- 8350: -
- 8351: -
- 8352: -
- 8353: -
- 8354: -
- 8355: -
- 8356: -
- 8357: -
- 8358: -
- 8359: -
- 8360: -
- 8361: -
- 8362: -
- 8363: -
- 8364: -
- 8365: -
- 8366: -
- 8367: -
- 8368: -
- 8369: -
- 8370: -
- 8371: -
- 8372: -
- 8373: -
- 8374: -
- 8375: Abandoned NP-23

| ID | WBS | Task | Type | Duration | Start | Finish | Complete | Baseline start | Baseline finish | Baseline duration | Constraint | Resources | Work | Actual work | Acronym | Release | MCC resp | Acronym_3GU_Export | WI rapporteur name | WI rapporteur e-mail | Created at | TSG stopped | Special Focus Doc |
| --- | --- | --- | --- | --- | --- | --- | --- | --- | --- | --- | --- | --- | --- | --- | --- | --- | --- | --- | --- | --- | --- | --- | --- |
| 8376 | 30 | **Generic User Profile Rel-6** |  | 1287.25d | 2001-10-08 A | 2005-03-03 A | 100% | 2001-10-08 | 2005-03-03 | 889d |  | S1; S3; N4 | 38519.8h | 38519.8h | GUP | Rel-6 | Alain | GUP |  |  |  |  |  |
| 8377 | 30.1 | Stage 1 - Requirements for Generic User Profile |  | 430d | 2001-10-08 A | 2003-05-30 A | 100% | 2001-10-08 | 2003-05-30 | 430d | finish no earlier than 2002-12-09 | S1 | 3440h | 3440h |  | Rel-6 | Alain |  | T-Mobile | kurt.bischinger@t-mobile.at |  |  |  |
| 8378 | 30.3 | Stage 2 - Architecture |  | 355d | 2002-01-28 A | 2003-06-06 A | 100% | 2002-01-28 | 2003-06-06 | 355d | finish no earlier than 2003-06-06 | S2 | 2840h | 2840h |  | Rel-6 | Maurice |  | Nokia | harri.o.koskinen@nokia.com |  |  |  |
| 8379 | 30.2 | Stage 2 - Data Description Method |  | 586d | 2002-12-05 A | 2005-03-03 A | 100% | 2002-12-05 | 2005-03-03 | 586d | finish no earlier than 2005-03-03 | N4 | 4688h | 4688h |  | Rel-6 | Kimmo |  | T-Mobile | kurt.bischinger@t-mobile.at |  |  |  |
| 8380 | 30.5 | Stage 3 - Network |  | 468.98d | 2003-05-19 A | 2005-03-03 A | 100% | 2003-05-19 | 2005-03-03 | 468.98d | finish no earlier than 2005-03-03 | N4 | 3751.84h | 3751.84h |  | Rel-6 | Kimmo |  |  |  |  |  |  |
| 8381 | 30.6 | Security aspects of GUP |  | 308d | 2002-07-16 A | 2003-09-18 A | 100% | 2002-07-16 | 2003-09-18 | 308d | finish no earlier than 2003-09-18 | S3 | 2464h | 2464h |  | Rel-6 | Mirko |  | Lucent | Bradley Owen (bvowen@lucent.com) |  |  |  |
| 8382 | 31 | **Digital Rights Management** |  | 998.25d? | 2001-10-08 A | 2004-05-28 A | 100% | 2001-10-08 | 2004-05-28 | 690d? |  | S1; OMA | 15672h | 15672h | DRM | Rel-6 | Alain | DRM |  |  |  |  |  |
| 8383 | 31.1 | Requirements for Digital Rights Management |  | 179d | 2001-10-08 A | 2002-06-13 A | 100% | 2001-10-08 | 2002-06-13 | 179d | finish no earlier than 2002-06-13 | S1 | 1432h | 1432h |  | Rel-6 | Alain |  | Openwave | nicholas.wood@openwave.com |  |  |  |
| 8384 | 2688.2 | Stage 2 for Digital Rights Management |  | 107d? | 2004-01-01 A | 2004-05-28 A | 100% | 2004-01-01 | 2004-05-28 | 107d? | finish no earlier than 2004-05-28 | OMA | 856h | 856h |  | Rel-6 |  |  |  | OMA-LIAISON@mail.openmobilealliance.org | SP-24 |  |  |
| 8385 | 2688.3 | Stage 3 for Digital Rights Management |  | 107d? | 2004-01-01 A | 2004-05-28 A | 100% | 2004-01-01 | 2004-05-28 | 107d? | finish no earlier than 2004-05-28 | OMA | 856h | 856h |  | Rel-6 |  |  |  | OMA-LIAISON@mail.openmobilealliance.org | SP-24 |  |  |
| 8386 | 31.3 | Security for Digital Rights Management |  | 186d | 2002-06-17 A | 2003-03-03 A | 100% | 2002-06-17 | 2003-03-03 | 186d | finish no earlier than 2003-03-03 | OMA | 1488h | 1488h |  | Rel-6 |  |  |  |  |  |  |  |
| 8387 | 2688.5 | Deleted - Monitoring of Stages 2 and 3 progress (actual work to be done by OMA) | milestone | 0d? | 2003-03-21 A | 2003-03-21 A | 100% | 2003-03-21 | 2003-03-21 | 0d? | start no earlier than 2002-08-19 | S1 |  |  |  | Rel-6 | Alain |  |  |  |  | SP-19 |  |
| 8388 | 32 | **WLAN-UMTS Interworking Rel-6** |  | 2164.38d? | 2000-01-03 A | 2005-09-22 A | 100% | 2000-01-03 | 2005-09-22 | 1495d? |  | S1; S2; S3; S5; N1; N3; N4; T3 | 129192h | 129192h | WLAN | Rel-6 | Alain | WLAN | Telenor | frederic.paint@telenor.com |  |  | WLAN |
| 8389 | 32.1 | Technical Report on WLAN-UMTS Interworking |  | 1302.62d? | 2000-01-03 A | 2003-06-13 A | 100% | 2000-01-03 | 2003-06-13 | 901d? | finish no earlier than 2003-06-13 | S1 | 7200h | 7200h | WLAN-TR | Rel-6 | Alain | WLAN-TR | T-mobile | Mark.Younge@t-mobile.com |  |  | WLAN |
| 8390 | 2689.2 | Stage 1 for WLAN-UMTS Interworking Rel-6 |  | 541.5d? | 2003-01-06 A | 2004-06-11 A | 100% | 2003-01-06 | 2004-06-11 | 375d? |  | S1 | 920h | 920h | WLAN-TS | Rel-6 | Alain | WLAN-TS | Telenor | frederic.paint@telenor.com | SP-24 |  | WLAN |
| 8391 | 32.2 | Architecture Definition for scenarii 2 and 3 |  | 571d | 2002-03-25 A | 2004-05-31 A | 100% | 2002-03-25 | 2004-05-31 | 571d | finish no earlier than 2004-05-31 | S2 | 4568h | 4568h |  | Rel-6 | Maurice |  |  |  |  |  | WLAN |
| 8392 | 32.3 | Security aspects of WLAN-UMTS Interworking |  | 125d | 2002-09-30 A | 2003-03-21 A | 100% | 2002-09-30 | 2003-03-21 | 125d | finish no earlier than 2003-03-21 | S3 | 1000h | 1000h |  | Rel-6 | Mirko |  | Ericsson, BT | luis.lopez-soria@ece.ericsson.se, colin.blanchard@bt.com |  |  | WLAN |
| 8393 | 2689.5 | Stage 3 - CN4 aspects |  | 334d? | 2003-05-23 A | 2004-09-01 A | 100% | 2003-05-23 | 2004-09-01 | 334d? | finish no earlier than 2004-09-01 | N4 | 2672h | 2672h | WLAN-IW | Rel-6 | Kimmo | WLAN-IW | Nokia | raquel.rodriguez@nokia.com |  |  | WLAN |
| 8394 | 2689.6 | Stage 3 - CN3 aspects (Wi Interface for Scenario 3) |  | 355d? | 2003-05-23 A | 2004-09-30 A | 100% | 2003-05-23 | 2004-09-30 | 355d? | start no earlier than 2003-05-23 | N3 | 2840h | 2840h |  | Rel-6 | Gwiho |  |  |  | SP-24 |  | WLAN |
| 8395 | 2689.7 | Stage 3 for scenario 2 |  | 339d? | 2003-05-23 A | 2004-09-08 A | 100% | 2003-05-23 | 2004-09-08 | 339d? | finish no earlier than 2004-09-08 | N1 | 2712h | 2712h |  | Rel-6 | Frederic |  |  |  |  |  | WLAN |
| 8396 | 2689.8 | Stage 3 for scenario 3 |  | 404d? | 2003-05-23 A | 2004-12-08 A | 100% | 2003-05-23 | 2004-12-08 | 404d? | finish no earlier than 2004-12-08 | N1 | 3232h | 3232h |  | Rel-6 | Frederic |  |  |  | SP-24 |  | WLAN |
| 8397 | 2689.9 | WLAN charging |  | 655d? | 2003-03-21 A | 2005-09-22 A | 100% | 2003-03-21 | 2005-09-22 | 655d? | finish no earlier than 2005-09-22 | S5 | 5240h | 5240h | WLAN-CH | Rel-6 | Mirko | WLAN-CH | Nokia | Benni ALEXANDER |  |  | WLAN |
| 8398 | 2689.10 | USIM enhancements for WLAN Interworking |  | 391d? | 2003-09-05 A | 2005-03-04 A | 100% | 2003-09-05 | 2005-03-04 | 391d? | finish no earlier than 2005-03-04 | T3 | 3128h | 3128h |  | Rel-6 | Xavier |  | Axalto | Jabellan@axalto.com |  |  | WLAN |
| 8399 | 33 | **Priority Service** |  | 502.25d? | 2002-05-30 A | 2003-09-26 A | 100% | 2002-05-30 | 2003-09-26 | 347d? |  | S1 | 6464h | 6464h | PRIOR1 | Rel-6 | Alain | PRIOR1 | Telcordia | James Garrahan (jgarraha@telcordia.com) |  |  | Public Safety (I-A) |
| 8400 | 33.1 | Feasibility Study on Priority Service |  | 1d | 2002-06-14 A | 2002-06-14 A | 100% | 2002-06-14 | 2002-06-14 | 1d | finish no earlier than 2002-06-14 | S1 | 8h | 8h | PRIOR-FS | Rel-6 | Alain | PRIOR-FS | Telcordia | James Garrahan (jgarraha@telcordia.com) |  |  | Public Safety (I-A) |
| 8401 | 33.2 | Stage 1 - Requirements for Priority Service |  | 340d | 2002-05-30 A | 2003-09-17 A | 100% | 2002-05-30 | 2003-09-17 | 340d | finish no earlier than 2003-09-17 | S1 | 2720h | 2720h | PRIOR-SR | Rel-6 | Alain | PRIOR-SR | Telcordia | James Garrahan (jgarraha@telcordia.com) |  |  | Public Safety (I-A) |
| 8402 | 2690.3 | Priority service implementation guide |  | 131d? | 2003-03-28 A | 2003-09-26 A | 100% | 2003-03-28 | 2003-09-26 | 131d? | finish no earlier than 2003-09-26 | S1 | 1048h | 1048h |  | Rel-6 | Alain |  | Telcordia | James Garrahan (jgarraha@telcordia.com) |  |  | Public Safety (I-A) |

Notes:
- 8376: -
- 8377: - / Impacted TSs and TRs: 22.240; 22.228
- 8378: - / Impacted TSs and TRs: 23.240
- 8379: TR approved in CN#26 / Impacted TSs and TRs: 23.241
- 8380: - / Impacted TSs and TRs: 29.240
- 8381: SP#19 approved WID / Impacted TSs and TRs: 33.102; 33.203; 33.210
- 8382: Foreseen start and completion dates introduced by MCC (no indication at all on the WID)
- 8383: -
- 8384: -
- 8385: -
- 8386: SA3 acknowledge role in WI at SA3#20. Active contribution S3#24, S3#25. S3 WID approved SP#17
- 8387: Replaced by UID 60005 and 60006
- 8388: -
- 8389: - / Impacted TSs and TRs: 22.934
- 8390: - / Impacted TSs and TRs: 22.101; 22.105
- 8391: - / Impacted TSs and TRs: 23.234
- 8392: SP#17 approved WID S3-020451 / Impacted TSs and TRs: 21.133; 33.106; 33.107; 33.108; 33.200; 33.203; 33.210; New 33.234
- 8393: WID approved at CN#19 / Impacted TSs and TRs: 29.234; 29.061
- 8394: - / Impacted TSs and TRs: 29.161
- 8395: -
- 8396: -
- 8397: - / Impacted TSs and TRs: 32.252
- 8398: - / Impacted TSs and TRs: 31.102
- 8399: -
- 8400: - / Impacted TSs and TRs: 22.950
- 8401: -
- 8402: - / Impacted TSs and TRs: 22.952

| ID | WBS | Task | Type | Duration | Start | Finish | Complete | Baseline start | Baseline finish | Baseline duration | Constraint | Deadline | Resources | Work | Actual work | Acronym | WI rapporteur name | WI rapporteur e-mail | Release | MCC resp | Acronym_3GU_Export | Created at | TSG stopped |
| --- | --- | --- | --- | --- | --- | --- | --- | --- | --- | --- | --- | --- | --- | --- | --- | --- | --- | --- | --- | --- | --- | --- | --- |
| 8403 | 34 | **Network Sharing** |  | 1186.75d? | 2003-01-20 A | 2006-03-10 A | 100% | 2003-01-20 | 2006-03-10 | 820d? |  |  | S1; S2; N1; R2; R5 | 44936h | 44936h | NTShar | T-Mobile | michele.zarri@t-mobile.co.uk | Rel-6 | Alain | NTShar |  |  |
| 8404 | 34.1 | Technical Report on Network Sharing |  | 345.75d? | 2003-01-20 A | 2003-12-19 A | 100% | 2003-01-20 | 2003-12-19 | 240d? |  |  | S1 | 1920h | 1920h | NTShar-TR | T-Mobile | michele.zarri@t-mobile.co.uk | Rel-6 | Alain | NTShar-TR |  |  |
| 8405 | 2691.2 | Stage 1 - CRs to implement Network Sharing |  | 240d? | 2003-01-20 A | 2003-12-19 A | 100% | 2003-01-20 | 2003-12-19 | 240d? | finish no earlier than 2003-12-19 |  | S1 | 1920h | 1920h | NTSharCR | T-Mobile | michele.zarri@t-mobile.co.uk | Rel-6 | Alain | NTSharCR |  |  |
| 8406 | 2691.3 | Stage 2 for Network Sharing |  | 372d? | 2003-02-27 A | 2004-07-30 A | 100% | 2003-02-27 | 2004-07-30 | 372d? | finish no earlier than 2004-07-30 |  | S2 | 2976h | 2976h |  | T-Mobile | michele.zarri@t-mobile.co.uk | Rel-6 | Maurice |  |  |  |
| 8407 | 2691.4 | Network sharing - stage 3 |  | 404d? | 2003-05-23 A | 2004-12-08 A | 100% | 2003-05-23 | 2004-12-08 | 404d? | finish no earlier than 2004-12-08 |  | N1 | 3232h | 3232h |  | T-Mobile | michele.zarri@t-mobile.co.uk | Rel-6 | Frederic |  |  |  |
| 8408 | 2691.5 | Enhancement of the support of network sharing in the UTRAN | milestone | 0d | 2003-09-19 A | 2003-09-19 A | 100% | 2003-09-19 | 2003-09-19 | 0d |  |  | R2 |  |  | NTShar-UTRANEnh | TeliaSonera | Anders.Dahlen@TeliaSonera.com | Rel-6 | Yong-Jun | NTShar-UTRANEnh |  |  |
| 8409 | 16.5.1 | Conformance Test Aspects – Network Sharing |  | 261d | 2005-03-11 A | 2006-03-10 A | 100% | 2005-03-11 | 2006-03-10 | 261d | finish no earlier than 2006-03-10 | 2006-03-10 | R5 | 2088h | 2088h | NTShar-UTRANEnh_Test | TeliaSonera | Niklas.Wiren@TeliaSonera.com | Rel-6 | Ingbert | NTShar-UTRANEnh_Test | Fri 11/03/05 |  |
| 8410 | 35 | **QoS Improvements** |  | 909.25d? | 2002-07-15 A | 2004-12-08 A | 100% | 2002-07-15 | 2004-12-08 | 628d? |  |  | S2; N3 | 18152h | 18152h | QoS1 | Nokia |  | Rel-6 | Maurice | QoS1 |  |  |
| 8411 | 35.1 | FS on Dynamic Policy control enhancements for end-to-end QoS |  | 465d | 2002-07-15 A | 2004-04-23 A | 100% | 2002-07-15 | 2004-04-23 | 465d | finish no earlier than 2004-04-23 |  | S2 | 3720h | 3720h |  | Nortel | Claire Mousset | Rel-6 | Maurice |  |  |  |
| 8412 | 2692.2 | Definition of the Gq interface |  | 214d? | 2003-07-01 A | 2004-04-23 A | 100% | 2003-07-01 | 2004-04-23 | 214d? | finish no earlier than 2004-04-23 |  | S2 | 1712h | 1712h |  |  | Janne Rinne | Rel-6 | Maurice |  |  |  |
| 8413 | 2692.3 | Gq interface specification for Dynamic Policy control enhancements – Stage 3 |  | 334d | 2003-08-29 A | 2004-12-08 A | 100% | 2003-08-29 | 2004-12-08 | 334d | finish no earlier than 2004-12-08 |  | N3 | 2672h | 2672h |  | Nokia | Anna.Sillanpaai@nokia.com | Rel-6 | Gwiho |  |  |  |
| 8414 | 36 | **Subscriber certificates** |  | 1054.25d? | 2002-02-25 A | 2004-12-08 A | 100% | 2002-02-25 | 2004-12-08 | 728d? |  |  | S3; S2; N1; N4; T3; OMA | 44512h | 44512h | SEC1-SC | Nokia | valtteri.niemi@nokia.com | Rel-6 | Mirko | SEC1-SC |  |  |
| 8415 | 36.1 | Stage 1 of Subscriber certificates |  | 144d | 2002-02-25 A | 2002-09-12 A | 100% | 2002-02-25 | 2002-09-12 | 144d | finish no earlier than 2002-09-12 |  | S3 | 1152h | 1152h |  | Nokia | valtteri.niemi@nokia.com | Rel-6 | Mirko |  |  |  |
| 8416 | 36.2 | Architecture review |  | 24d | 2002-10-14 A | 2002-11-14 A | 100% | 2002-10-14 | 2002-11-14 | 24d | finish no earlier than 2002-11-14 |  | S2 | 192h | 192h |  | Nokia |  | Rel-6 | Maurice |  |  |  |
| 8417 | 2693.3 | Stage 3 for Subscriber certificates |  | 313d? | 2003-09-19 A | 2004-11-30 A | 100% | 2003-09-19 | 2004-11-30 | 313d? | finish no earlier than 2004-11-30 |  | N4; T3 | 5008h | 5008h |  | Nokia | Lauri Laitinen | Rel-6 | Kimmo |  |  |  |
| 8418 | 2693.4 | Stage 3 Ua & Ub interfaces |  | 288d? | 2003-11-03 A | 2004-12-08 A | 100% | 2003-11-03 | 2004-12-08 | 288d? | finish no earlier than 2004-12-08 |  | N1 | 2304h | 2304h |  | Nokia |  | Rel-6 | Frederic |  |  |  |
| 8419 | 2693.5 | OMA dependencies on Subscriber certificates |  | 114d? | 2004-01-01 A | 2004-06-08 A | 100% | 2004-01-01 | 2004-06-08 | 114d? | finish no earlier than 2004-06-08 |  | OMA | 912h | 912h |  | Nokia | OMA-LIAISON@mail.openmobilealliance.org | Rel-6 |  |  | SP-24 |  |
| 8420 | 2694 | **Rel-6 Open Service Access (OSA) enhancements** |  | 892.75d? | 2002-10-31 A | 2005-03-10 A | 100% | 2002-10-31 | 2005-03-10 | 616d? |  |  | N5 | 22576h | 22576h | OSA3 | Alcatel | Chelo.Abarca@alcatel.fr | Rel-6 | Kimmo | OSA3 |  |  |
| 8421 | 2694.1 | Scope of the Open Service Access Release 6 |  | 66d? | 2003-03-28 A | 2003-06-27 A | 100% | 2003-03-28 | 2003-06-27 | 66d? | finish no earlier than 2003-06-27 |  | S1 | 528h | 528h |  |  |  | Rel-6 | Alain |  |  |  |
| 8422 | 2694.2 | OSA Stage 2 |  | 150d? | 2004-08-13 A | 2005-03-10 A | 100% | 2004-08-13 | 2005-03-10 | 150d? | finish no earlier than 2005-03-10 |  | N5 | 1200h | 1200h |  |  |  | Rel-6 | Kimmo |  |  |  |
| 8423 | 2694.3 | Multi Media Messaging function |  | 487d? | 2002-10-31 A | 2004-09-10 A | 100% | 2002-10-31 | 2004-09-10 | 487d? | finish no earlier than 2004-09-10 |  | N5 | 3896h | 3896h |  |  |  | Rel-6 | Kimmo |  |  |  |
| 8424 | 2694.4 | Policy management extensions |  | 292d? | 2002-10-31 A | 2003-12-12 A | 100% | 2002-10-31 | 2003-12-12 | 292d? | finish no earlier than 2003-12-12 |  | N5 | 2336h | 2336h |  |  |  | Rel-6 | Kimmo |  |  |  |
| 8425 | 2694.5 | TS on Presence and Availability Management (from the PRESNC WI) |  | 367d? | 2002-10-31 A | 2004-03-26 A | 100% | 2002-10-31 | 2004-03-26 | 367d? | finish no earlier than 2004-03-26 |  | N5 | 2936h | 2936h |  |  |  | Rel-6 | Kimmo |  |  |  |
| 8426 | 2694.6 | OSA interfaces at different levels of abstractions (Parlay X, Web services) |  | 305d? | 2003-07-14 A | 2004-09-10 A | 100% | 2003-07-14 | 2004-09-10 | 305d? | finish no earlier than 2004-09-10 |  | N5 | 2440h | 2440h |  |  |  | Rel-6 | Kimmo |  |  |  |
| 8427 | 2694.7 | Introduction of migration support mechanism |  | 290d? | 2002-10-31 A | 2003-12-10 A | 100% | 2002-10-31 | 2003-12-10 | 290d? | finish no earlier than 2003-12-12 |  | N5 | 2320h | 2320h |  |  |  | Rel-6 | Kimmo |  |  |  |
| 8428 | 2694.8 | Framework Function for Federation |  | 225d? | 2003-02-03 A | 2003-12-12 A | 100% | 2003-02-03 | 2003-12-12 | 225d? | finish no earlier than 2003-12-12 |  | N5 | 1800h | 1800h |  |  |  | Rel-6 | Kimmo |  |  |  |
| 8429 | 2694.9 | OMA potential overlaps with 3GPP OSA Stage 3 (Web services) |  | 196d? | 2003-12-18 A | 2004-09-16 A | 100% | 2003-12-18 | 2004-09-16 | 196d? | start no earlier than 2003-12-18 |  | OMA | 1568h | 1568h |  |  |  | Rel-6 |  |  | SP-24 |  |
| 8430 | 2694.10 | Deleted - TR on Presence and Availability Management (from the PRESNC WI) | milestone | 0d? | 2004-09-17 A | 2004-09-17 A | 100% | 2004-09-17 | 2004-09-17 | 0d? | start no earlier than 2004-09-17 |  | N5 |  |  |  |  |  | Rel-6 | Kimmo |  |  | NP-24 |

Notes:
- 8403: -
- 8404: - / Impacted TSs and TRs: 22.951
- 8405: - / Impacted TSs and TRs: 22.011; 22.101; 22.115; 22.129
- 8406: - / Impacted TSs and TRs: 23.002; 23.060; 23.221; 23.236; new 23.251; 23.851
- 8407: - / Impacted TSs and TRs: 23.008; 23.122; 24.007; 24.008; 29.018
- 8408: - / Impacted TSs and TRs: 25.401; 25.413; 25.331; 25.304
- 8409: - / Impacted TSs and TRs: 34.108; 34.123-1; 34.123-2; 34.123-3
- 8410: - / Impacted TSs and TRs: 23.107; 23.207; 23.221
- 8411: - / Impacted TSs and TRs: 23.917 withdrawn (Contenall in 23.207)
- 8412: - / Impacted TSs and TRs: 23.207
- 8413: [DAB - 25.05.04] - Delayed to Sept - possibly Dec 2004 / Impacted TSs and TRs: 29.207; 29.208; 29.209
- 8414: SP#14 approved WID
- 8415: - / Impacted TSs and TRs: New (33.220; 33.221; 33.222; 33.246; 33.919)
- 8416: -
- 8417: Finished in CN4#26 / Impacted TSs and TRs: 23.003; 23.008; 29.109; 29.230; T3 31.102; 31.103; 31.111
- 8418: - / Impacted TSs and TRs: 24.109
- 8419: Updated according to SP-040420
- 8420: CN#25: Updated WID NP-040351 replaces NP-040144. / Impacted TSs and TRs: 22.127; 23.198; 29.198; 29.199; 29.998
- 8421: -
- 8422: Inherited by CN5 from SA2 at TSG#25 Sep 2004. SA2's 23.127 (OSA/VHE Stage 2) replaced from Rel-6 onwards by a new CN5 TS 23.198 (Stage 2 OSA-only). / Impacted TSs and TRs: 23.198 OSA Stage 2-ONLY replaces 23.127 (OSA/VHE) from Rel-6 onwards
- 8423: - / Impacted TSs and TRs: 29.198-15
- 8424: - / Impacted TSs and TRs: 29.198; 29.998
- 8425: N5#26: Split WI into TS & TR. / Impacted TSs and TRs: 29.198-14
- 8426: - / Impacted TSs and TRs: 29.199
- 8427: - / Impacted TSs and TRs: 29.198; 29.998
- 8428: - / Impacted TSs and TRs: 29.198; 29.998
- 8429: TSG#25 Approved CN5 29.199 Parlay X Web services. Ongoing 3GPP/OMA co-ordination to avoid OMA producing conflicting/OVERLAPING specs (NP-040283/SP-040493).
- 8430: N5#26:TR Completion 09/04¦consistent with CN1 delayed Rel-6 completion.

| ID | WBS | Task | Duration | Start | Finish | Complete | Baseline start | Baseline finish | Baseline duration | Constraint | Resources | Work | Actual work | Acronym | WI rapporteur name | WI rapporteur e-mail | Release | MCC resp | Acronym_3GU_Export | TSG stopped |
| --- | --- | --- | --- | --- | --- | --- | --- | --- | --- | --- | --- | --- | --- | --- | --- | --- | --- | --- | --- | --- |
| 8431 | 39 | **Addition of frequency bands to GSM (TAPS)** | 979.75d | 2002-06-28 A | 2005-01-28 A | 100% | 2002-06-28 | 2005-01-28 | 676d |  | GP | 16640h | 16640h | TAPS | Nokia | Torben Themsen | Rel-6 | Paolo | TAPS |  |
| 8432 | 39.1 | **Addition of frequency bands to GSM – Changes to core specs** | 37.25d | 2002-11-15 A | 2002-12-20 A | 100% | 2002-11-15 | 2002-12-20 | 26d |  | G1 | 416h | 416h | TAPS-Specs | Nokia | Torben Themsen | Rel-6 | Paolo | TAPS-Specs |  |
| 8433 | 39.1.1 | Changes to core specs | 26d | 2002-11-15 A | 2002-12-20 A | 100% | 2002-11-15 | 2002-12-20 | 26d | finish no earlier than 2002-12-20 | G1 | 208h | 208h |  | Nokia | Torben Themsen | Rel-6 | Paolo |  |  |
| 8434 | 39.2 | **Deleted - Addition of frequency bands to GSM – Changes for conformance tests** | 979.75d | 2002-06-28 A | 2005-01-28 A | 100% | 2002-06-28 | 2005-01-28 | 676d |  | G4 | 10816h | 10816h | TAPS-Conf | Nokia | Torben Themsen | Rel-6 | Paolo | TAPS-Conf | GP-23 |
| 8435 | 39.2.1 | Deleted - 51.010-1 Add testing | 676d | 2002-06-28 A | 2005-01-28 A | 100% | 2002-06-28 | 2005-01-28 | 676d | finish no earlier than 2005-01-28 | G4 | 5408h | 5408h |  | Nokia | Torben Themsen | Rel-6 | Paolo |  | GP-23 |
| 8436 | 40 | **Seamless support of streaming services in A/Gb mode** | 2063.88d? | 2000-01-03 A | 2005-06-17 A | 100% | 2000-01-03 | 2005-06-17 | 1426d? |  | GP; S3 | 70312h | 70312h | SSStrea | Vodafone | José Luis Carrizo Martínez | Rel-6 | Paolo | SSStrea |  |
| 8437 | 40.1 | **Identification of requirements for streaming** | 66.25d? | 2003-06-27 A | 2003-08-29 A | 100% | 2003-06-27 | 2003-08-29 | 46d? |  | G1 | 736h | 736h |  | Vodafone | José Luis Carrizo Martínez | Rel-6 | Paolo |  |  |
| 8438 | 2696.1.1 | Requirements for streaming | 46d? | 2003-06-27 A | 2003-08-29 A | 100% | 2003-06-27 | 2003-08-29 | 46d? | finish no earlier than 2003-08-29 | G1 | 368h | 368h |  | Vodafone | José Luis Carrizo Martínez | Rel-6 | Paolo |  |  |
| 8439 | 40.2 | **Performance study of cell change mechanisms** | 1382.38d? | 2000-01-03 A | 2003-08-29 A | 100% | 2000-01-03 | 2003-08-29 | 956d? |  | G1 | 30568h | 30568h |  | Vodafone | José Luis Carrizo Martínez | Rel-6 | Paolo |  |  |
| 8440 | 2696.2.1 | Performance of NACC | 956d? | 2000-01-03 A | 2003-08-29 A | 100% | 2000-01-03 | 2003-08-29 | 956d? | finish no earlier than 2003-08-29 | G1 | 7640h | 7640h |  | Vodafone | José Luis Carrizo Martínez | Rel-6 | Paolo |  |  |
| 8441 | 2696.2.2 | Performance of cell change in DTM for the PS domain | 956d? | 2000-01-03 A | 2003-08-29 A | 100% | 2000-01-03 | 2003-08-29 | 956d? | finish no earlier than 2003-08-29 | G1 | 7640h | 7640h |  | Vodafone | José Luis Carrizo Martínez | Rel-6 | Paolo |  |  |
| 8442 | 2696.2.3 | Handover for Seamless support of streaming services in A/Gb mode | 956d? | 2000-01-03 A | 2003-08-29 A | 100% | 2000-01-03 | 2003-08-29 | 956d? | finish no earlier than 2003-08-29 | G1 | 7640h | 7640h |  | Vodafone | José Luis Carrizo Martínez | Rel-6 | Paolo |  |  |
| 8443 | 40.3 | **Reduction of service interruption times and packet loss during mobility procedures** | 747.75d? | 2003-06-27 A | 2005-06-17 A | 100% | 2003-06-27 | 2005-06-17 | 516d? |  | G2 | 10800h | 10800h |  | Vodafone | José Luis Carrizo Martínez | Rel-6 | Gert |  |  |
| 8444 | 2696.3.1 | optimizations of existing mechanisms/procedures | 106d? | 2003-06-27 A | 2003-11-21 A | 100% | 2003-06-27 | 2003-11-21 | 106d? | finish no earlier than 2003-11-21 | G2 | 848h | 848h |  | Vodafone | José Luis Carrizo Martínez | Rel-6 | Gert |  |  |
| 8445 | 2696.3.2 | Inter-system NACC | 106d? | 2003-06-27 A | 2003-11-21 A | 100% | 2003-06-27 | 2003-11-21 | 106d? | finish no earlier than 2003-11-21 | G2 | 848h | 848h |  | Vodafone | José Luis Carrizo Martínez | Rel-6 | Gert |  |  |
| 8446 | 2696.3.3 | PS Handover (within GERAN and between GERAN and UTRAN) | 516d? | 2003-06-27 A | 2005-06-17 A | 100% | 2003-06-27 | 2005-06-17 | 516d? | finish no earlier than 2003-11-21 | G2 | 4128h | 4128h |  | Vodafone | José Luis Carrizo Martínez | Rel-6 | Gert |  |  |
| 8447 | 2696.3.4 | Dependency to other features of Reduction of service interruption times and packet loss during mobility procedures | 106d? | 2003-06-27 A | 2003-11-21 A | 100% | 2003-06-27 | 2003-11-21 | 106d? | finish no earlier than 2003-11-21 | G2 | 848h | 848h |  | Vodafone | José Luis Carrizo Martínez | Rel-6 | Gert |  |  |
| 8448 | 40.5 | **Deleted - MS conformance testing for Seamless support of streaming services in A/Gb mode** | 44.5d? | 2003-12-19 A | 2004-01-30 A | 100% | 2003-12-19 | 2004-01-30 | 31d? |  | G3new | 496h | 496h |  | Vodafone | José Luis Carrizo Martínez | Rel-6 | Ingbert |  | GP-27 |
| 8449 | 2696.4.1 | Deleted - MS conformance tests for Seamless support of streaming services in A/Gb mode | 31d? | 2003-12-19 A | 2004-01-30 A | 100% | 2003-12-19 | 2004-01-30 | 31d? | finish no earlier than 2004-01-30 | G4; G5 | 496h | 496h |  | Vodafone | José Luis Carrizo Martínez | Rel-6 | Ingbert |  | GP-27 |
| 8450 | 2696.5 | GERAN A/Gb mode security enhancements | 612d? | 2002-09-26 A | 2005-01-28 A | 100% | 2002-09-26 | 2005-01-28 | 612d? | finish no earlier than 2005-01-28 | S3 | 4896h | 4896h |  | Vodafone | peter.howard@vodafone.com | Rel-6 | Mirko |  |  |
| 8451 | 41 | Performance characterisation of default codecs for PS conversational multimedia application | 455d | 2002-09-13 A | 2004-06-10 A | 100% | 2002-09-13 | 2004-06-10 | 455d | finish no earlier than 2004-06-10 | S4 | 3640h | 3640h | CODCAR | Nokia | pasi.s.ojala@nokia.com | Rel-6 | Paolo | CODCAR |  |
| 8452 | 43 | Study on Privacy Capability | 83d | 2003-11-10 A | 2004-03-03 A | 100% | 2003-11-10 | 2004-03-03 | 83d | start no earlier than 2003-11-10 | S1 | 664h | 664h | PrivCap | Lucent | Michael Boote (mboote@alcatel-lucent.com) | Rel-6 | Alain | PrivCap |  |
| 8453 | 44 | **Rel-6 Operations, Administration, Maintenance and Provisioning (OAM&P)** | 944.5d? | 2002-09-12 A | 2005-03-11 A | 100% | 2002-09-12 | 2005-03-11 | 652d? |  | S5 | 42635.5h | 42635.5h | OAM6 |  |  | Rel-6 | Mirko | OAM6 |  |
| 8454 | 44.1 | Principles, high level Requirements and Architecture | 526d | 2002-09-12 A | 2004-09-16 A | 100% | 2002-09-12 | 2004-09-16 | 526d | finish no earlier than 2004-09-16 | S5 | 4208h | 4208h |  | Motorola |  | Rel-6 | Mirko |  |  |
| 8455 | 44.2 | Performance Management | 591d | 2002-09-12 A | 2004-12-16 A | 100% | 2002-09-12 | 2004-12-16 | 591d | finish no earlier than 2004-12-16 | S5 | 4728h | 4728h |  | Nortel |  | Rel-6 | Mirko |  |  |
| 8456 | 44.4 | Network Infrastructure Management | 591d | 2002-09-12 A | 2004-12-16 A | 100% | 2002-09-12 | 2004-12-16 | 591d | finish no earlier than 2004-12-16 | S5 | 4728h | 4728h |  | Ericsson | thomas.tovinger@ericsson.com | Rel-6 | Mirko |  |  |

Notes:
- 8431: -
- 8432: -
- 8433: -
- 8434: -
- 8435: -
- 8436: -
- 8437: -
- 8438: -
- 8439: -
- 8440: -
- 8441: -
- 8442: -
- 8443: Completed at GERP#17
- 8444: -
- 8445: -
- 8446: -
- 8447: -
- 8448: Marked as stopped 10/2009
- 8449: Marked as stopped 10/2009
- 8450: SP#19 approved WID / Impacted TSs and TRs: 33.102
- 8451: - / Impacted TSs and TRs: 26.935
- 8452: - / Impacted TSs and TRs: 22.949
- 8453: SP#26: Updated WID SP-040766 was SP-020445. Completion delayed 12/04->03/05 due to OAM-Trace in CN1/4.
- 8454: SP#25 09/2004 completed / Impacted TSs and TRs: 32.101; 32.102
- 8455: SP#26 12/2004 completed / Impacted TSs and TRs: 32.401; 32.403; 52.402; 32.411; 32.412; 32.413; 32.432; 32.435; 32.436
- 8456: SP#26 12/2004 completed / Impacted TSs and TRs: 32.150/1/2; 32.805; 32.111-5; 32.313/4; 32.331/2/3/4/5; 32.341/2/3/4; 32.351/2/3/4; 32.361/2/3/4; 32.371/2/3/4; 32.804; 32.675; 32.690; 32.695; 32.71/2/3/4/5; 32.741/2/3/4/5

| ID | WBS | Task | Duration | Start | Finish | Complete | Baseline start | Baseline finish | Baseline duration | Constraint | Resources | Work | Actual work | Acronym | WI rapporteur name | WI rapporteur e-mail | Release | MCC resp | Acronym_3GU_Export | Impacted TSs and TRs | Created at | TSG stopped |
| --- | --- | --- | --- | --- | --- | --- | --- | --- | --- | --- | --- | --- | --- | --- | --- | --- | --- | --- | --- | --- | --- | --- |
| 8457 | 44.5 | **Rel-6 Trace Management** | 936.25d? | 2002-09-20 A | 2005-03-11 A | 100% | 2002-09-20 | 2005-03-11 | 646d? |  | S5; N4; R3 | 23877.9h | 23877.9h | OAM-Trace | Nokia | kari.t.ronka@nokia.com | Rel-6 | Mirko | OAM-Trace |  |  |  |
| 8458 | 2699.4.1 | Subscriber and UE trace management | 585d | 2002-09-20 A | 2004-12-16 A | 100% | 2002-09-20 | 2004-12-16 | 585d | finish no earlier than 2004-12-16 | S5 | 4680h | 4680h |  | Nokia | kari.t.ronka@nokia.com | Rel-6 | Mirko |  | 32.421; 32.422; 32.423; 52.008 |  |  |
| 8459 | 2699.4.2 | Subscriber and equipment trace in UTRAN | 268d? | 2003-06-06 A | 2004-06-15 A | 100% | 2003-06-06 | 2004-06-15 | 268d? | finish no earlier than 2004-06-15 | R3 | 2144h | 2144h | OAM-Trace-RAN | Nortel | Yann Sehedi (sehedic@nortelnetworks.com) | Rel-6 | Juha | OAM-Trace-RAN | 25.413; 25.420; 25.423 |  |  |
| 8460 | 2699.4.3 | Trace Management, Stage3 | 193.74d? | 2004-06-09 A | 2005-03-11 A | 100% | 2004-06-09 | 2005-03-11 | 193.74d? | finish no earlier than 2005-03-11 | N4 | 1549.92h | 1549.92h |  | Nokia | seppo.kauntola@nokia.com | Rel-6 | Kimmo |  | 23.205; 29.232; 29.060; 29.002; 29.228 |  |  |
| 8461 | 2700 | **Rel-6 Charging Management** | 965.25d? | 2002-11-21 A | 2005-06-09 A | 100% | 2002-11-21 | 2005-06-09 | 666d? |  | S5; S2; N3 | 67152h | 67152h | CH | T-Mobile | karl-heinz.nenner@t-mobile.de | Rel-6 | Mirko | CH |  |  |  |
| 8462 | 2700.1 | Charging architecture and principles | 390d? | 2003-03-21 A | 2004-09-16 A | 100% | 2003-03-21 | 2004-09-16 | 390d? | start no earlier than 2003-03-21 | S5 | 3120h | 3120h |  |  |  | Rel-6 | Mirko |  | 32.240 |  |  |
| 8463 | 2700.2 | Charging Data Record (CDR) file format and transfer | 260d? | 2003-03-21 A | 2004-03-18 A | 100% | 2003-03-21 | 2004-03-18 | 260d? | start no earlier than 2003-03-21 | S5 | 2080h | 2080h |  |  |  | Rel-6 | Mirko |  | 32.297 |  |  |
| 8464 | 2700.3 | CDR parameter description | 580d? | 2003-03-21 A | 2005-06-09 A | 100% | 2003-03-21 | 2005-06-09 | 580d? | finish no earlier than 2005-06-09 | S5 | 4640h | 4640h |  |  |  | Rel-6 | Mirko |  | 32.298 |  |  |
| 8465 | 2700.4 | Diameter charging applications | 390d? | 2003-03-21 A | 2004-09-16 A | 100% | 2003-03-21 | 2004-09-16 | 390d? | start no earlier than 2003-03-21 | S5 | 3120h | 3120h |  |  |  | Rel-6 | Mirko |  | 32.299 |  |  |
| 8466 | 2700.5 | Online Charging System (OCS) architecture study | 130d? | 2003-03-21 A | 2003-09-18 A | 100% | 2003-03-21 | 2003-09-18 | 130d? | start no earlier than 2003-03-21 | S5 | 1040h | 1040h |  |  |  | Rel-6 | Mirko |  | 32.815 |  |  |
| 8467 | 2700.6 | OCS: Applications and interfaces | 455d? | 2003-03-21 A | 2004-12-16 A | 100% | 2003-03-21 | 2004-12-16 | 455d? | start no earlier than 2003-03-21 | S5 | 3640h | 3640h |  |  |  | Rel-6 | Mirko |  | 32.296 |  |  |
| 8468 | 2700.7 | **Charging Management for Bearer level** | 565.5d? | 2003-03-21 A | 2004-09-16 A | 100% | 2003-03-21 | 2004-09-16 | 390d? |  | S5 | 11440h | 11440h | CH-BC | Nokia | Benni ALEXANDER | Rel-6 | Mirko | CH-BC |  |  |  |
| 8469 | 2700.7.1 | CS domain charging | 260d? | 2003-03-21 A | 2004-03-18 A | 100% | 2003-03-21 | 2004-03-18 | 260d? | start no earlier than 2003-03-21 | S5 | 2080h | 2080h |  |  |  | Rel-6 | Mirko |  | 32.250 |  |  |
| 8470 | 2700.7.2 | PS domain charging | 390d? | 2003-03-21 A | 2004-09-16 A | 100% | 2003-03-21 | 2004-09-16 | 390d? | start no earlier than 2003-03-21 | S5 | 3120h | 3120h |  |  |  | Rel-6 | Mirko |  | 32.251 |  |  |
| 8471 | 2700.7.3 | CDR transfer | 390d? | 2003-03-21 A | 2004-09-16 A | 100% | 2003-03-21 | 2004-09-16 | 390d? | start no earlier than 2003-03-21 | S5 | 3120h | 3120h |  |  |  | Rel-6 | Mirko |  | 32.295 |  |  |
| 8472 | 2700.8 | Charging Management for the Service domain | 580d? | 2003-03-21 A | 2005-06-09 A | 100% | 2003-03-21 | 2005-06-09 | 580d? | finish no earlier than 2005-06-09 | S5 | 4640h | 4640h |  | Siemens | Gerald.Goermer@nsn.com | Rel-6 | Mirko |  | 32.252; 32.270; 32.271; 32.272 |  |  |
| 8473 | 2700.9 | **Overall architectural aspects of IP flow based bearer level charging** | 872d? | 2002-11-21 A | 2005-03-11 A | 100% | 2002-11-21 | 2005-03-11 | 602d? |  | S2; N3 | 17448h | 17448h | CH-FBC |  |  | Rel-6 | Maurice | CH-FBC | 23.125 |  |  |
| 8474 | 2700.9.1 | Overall definition of FBC architecture | 334d? | 2002-11-21 A | 2004-03-02 A | 100% | 2002-11-21 | 2004-03-02 | 334d? | start no earlier than 2002-11-21 | S2 | 2672h | 2672h |  |  |  | Rel-6 | Maurice |  |  | SP-24 |  |
| 8475 | 2700.9.2 | Study on providing policy control with FBC | 130d? | 2004-02-02 A | 2004-07-30 A | 100% | 2004-02-02 | 2004-07-30 | 130d? | start no earlier than 2004-02-01 | S2 | 1040h | 1040h |  |  |  | Rel-6 | Maurice |  |  | SP-24 |  |
| 8476 | 2700.9.3 | Gx interface for flow based charging | 223d? | 2004-02-02 A | 2004-12-08 A | 100% | 2004-02-02 | 2004-12-08 | 223d? | start no earlier than 2004-02-01 | N3 | 1784h | 1784h |  | Nokia | juha.a.rasanen@nokia.com | Rel-6 | Gwiho |  | 29.210 | SP-25 |  |
| 8477 | 2700.9.4 | Rx interface for flow based charging | 290d? | 2004-02-02 A | 2005-03-11 A | 100% | 2004-02-02 | 2005-03-11 | 290d? | finish no earlier than 2005-03-11 | N3 | 2320h | 2320h |  | Nortel | Javier Gonzalez Gallego | Rel-6 | Gwiho |  | 29.209 | SP-25 |  |
| 8478 | 13 | **Rel-6 UICC/USIM enhancements and interworking** | 1686d? | 2000-09-25 A | 2005-03-10 A | 100% | 2000-09-25 | 2005-03-10 | 1164d? |  | T3 | 43088h | 43088h | USAT1 |  |  | Rel-6 | Xavier | USAT1 |  |  |  |
| 8479 | 13.1 | **UICC API** | 1125.75d | 2002-03-20 A | 2005-03-10 A | 100% | 2002-03-20 | 2005-03-10 | 777d |  | T3 | 15024h | 15024h | USAT1-API |  |  | Rel-6 | Xavier | USAT1-API |  |  |  |
| 8480 | 13.1.1 | Rel-6 Java API Test specification | 59d | 2002-03-20 A | 2002-06-10 A | 100% | 2002-03-20 | 2002-06-10 | 59d | finish no earlier than 2002-09-20 | T3 | 472h | 472h |  | Microelectrónica Española | Mario Pérez | Rel-6 | Xavier |  |  |  |  |
| 8481 | 2701.1.2 | 2G/3G Java Card™ API based applet interworking | 255d | 2003-03-17 A | 2004-03-05 A | 100% | 2003-03-17 | 2004-03-05 | 255d | finish no earlier than 2004-02-19 | T3 | 2040h | 2040h |  | Oberthur Card Systems | Stéphane Andrau | Rel-6 | Xavier |  |  |  |  |
| 8482 | 2701.1.3 | (U)SIM API for Java Card Testing | 519d | 2003-03-17 A | 2005-03-10 A | 100% | 2003-03-17 | 2005-03-10 | 519d | finish no earlier than 2005-03-10 | T3 | 4152h | 4152h |  | Axalto | Christophe Begassat (cbegassat@axalto.com) | Rel-6 | Xavier |  | 31.213 |  |  |
| 8483 | 13.1.2 | Deleted - Java API Test specification (TS 43.019 Rel-5) | 268d | 2002-05-30 A | 2003-06-09 A | 100% | 2002-05-30 | 2003-06-09 | 268d | finish no earlier than 2003-09-17 | T3 | 2144h | 2144h |  | Microelectrónica Española | Mario Pérez | Rel-6 | Xavier |  |  |  | TP-20 |

Notes:
- 8457: SP#26 12/2004 SA5 completed 12/04. Signalling Based Trace Activation for IMS (SIP) moved to Rel-7. Reason: CN1 cannot complete 24.229 trace without IETF dependency => estimate 05/2005.
- 8458: SP#26 12/2004 completed
- 8459: -
- 8460: -
- 8461: SP#28 Target 09/2005 for WLAN Charging 32.252
- 8462: SP#25 09/2004 completed
- 8463: SP#23 03/2004 completed
- 8464: SP#28 06/2005 completed
- 8465: SP#25 09/2004 completed
- 8466: SP#21 09/2003 completed
- 8467: SP#26 12/2004 completed
- 8468: SP#28 Target 09/2005 for WLAN Charging 32.252
- 8469: SP#23 03/2004 completed
- 8470: SP#25 09/2004 completed
- 8471: SP#25 09/2004 completed
- 8472: SP#26: Updated WID SP-040778 was SP-030050. Target completion 06/2005. Consisting of MMS-CH, LCS-CH, WLAN-CH, POC-CH, MBMS-CH
- 8473: -
- 8474: -
- 8475: -
- 8476: -
- 8477: -
- 8478: -
- 8479: 8/3/2001: test spec is based on R99 core spec, so deleted from Workplan
- 8480: -
- 8481: -
- 8482: -
- 8483: MOVED to Rel-5 WP

| ID | WBS | Task | Type | Duration | Start | Finish | Complete | Remaining | Baseline start | Baseline finish | Baseline duration | Total slack | Constraint | Resources | Work | Actual work | Acronym | WI rapporteur name | WI rapporteur e-mail | Release | MCC resp | Acronym_3GU_Export | TSG stopped |
| --- | --- | --- | --- | --- | --- | --- | --- | --- | --- | --- | --- | --- | --- | --- | --- | --- | --- | --- | --- | --- | --- | --- | --- |
| 8484 | 2701.2 | **Rel-6 USIM toolkit enhancements** |  | 1679.75d? | 2000-09-25 A | 2005-03-04 A | 100% |  | 2000-09-25 | 2005-03-04 | 1160d? |  |  | T3 | 21848h | 21848h | USAT1-API-MULTOS | Aspects Software | Neil Livingston | Rel-6 | Xavier | USAT1-API-MULTOS |  |
| 8485 | 2701.2.1 | **C SIM API** |  | 759d | 2000-09-25 A | 2002-09-27 A | 100% |  | 2000-09-25 | 2002-09-27 | 525d |  |  | T3 | 9960h | 9960h |  | Aspects Software | Neil Livingston | Rel-6 | Xavier |  |  |
| 8486 | 2701.2.1.1 | Specification of C SIM API |  | 525d | 2000-09-25 A | 2002-09-27 A | 100% |  | 2000-09-25 | 2002-09-27 | 525d |  | finish no earlier than 2002-09-27 | T3 | 4200h | 4200h |  | Aspects Software | Neil Livingston | Rel-6 | Xavier |  |  |
| 8487 | 2701.2.1.2 | Test specification for C SIM API |  | 195d | 2001-01-01 A | 2001-09-28 A | 100% |  | 2001-01-01 | 2001-09-28 | 195d |  | finish no earlier than 2001-09-28 | T3 | 1560h | 1560h |  | Aspects Software | Neil Livingston | Rel-6 | Xavier |  |  |
| 8488 | 2701.2.2 | USIM application toolkit Conformance Test Specification for Mobile Equipments |  | 326d? | 2003-12-05 A | 2005-03-04 A | 100% |  | 2003-12-05 | 2005-03-04 | 326d? |  | start no earlier than 2003-12-05 | T3 | 2608h | 2608h |  | Gemplus | Eric.laffont@gemplus.com | Rel-6 | Xavier |  |  |
| 8489 | 2702 | **Packet Switched Streaming Services Rel-6** |  | 1155.75d? | 2002-11-18 A | 2005-12-07 A | 100% |  | 2002-11-18 | 2005-12-07 | 798d? |  |  | S4; S1 | 19688h | 19688h | PSSrel6 | Ericsson | olle.franceschi@ericsson.com | Rel-6 | Paolo | PSSrel6 |  |
| 8490 | 2702.1 | Stage 1 for Packet Switched Streaming Services Rel-6 |  | 86d? | 2002-11-18 A | 2003-03-17 A | 100% |  | 2002-11-18 | 2003-03-17 | 86d? |  | finish no earlier than 2003-03-17 | S1 | 688h | 688h |  | Ericsson |  | Rel-6 | Alain |  |  |
| 8491 | 2702.2 | Stage 3 for Packet Switched Streaming Services Rel-6 |  | 779d? | 2002-12-13 A | 2005-12-07 A | 100% |  | 2002-12-13 | 2005-12-07 | 779d? |  | finish no earlier than 2005-12-07 | S4 | 6232h | 6232h | PSSrel6-Stage3 | Ericsson | olle.franceschi@ericsson.com | Rel-6 | Paolo | PSSrel6-Stage3 |  |
| 8492 | 2703 | AMR-WB extension for high audio quality |  | 779d | 2002-12-13 A | 2005-12-07 A | 100% |  | 2002-12-13 | 2005-12-07 | 779d |  | finish no earlier than 2005-12-07 | S4 | 6232h | 6232h | AMRWB+ | Nokia | janne.m.vainio@nokia.com | Rel-6 | Paolo | AMRWB+ |  |
| 8493 | 2704 | Codec Enhancements for Packet Switched Conversational Multimedia Applications |  | 198d? | 2004-03-16 A | 2004-12-16 A | 100% |  | 2004-03-16 | 2004-12-16 | 198d? |  | finish no earlier than 2004-12-16 | S4 | 1584h | 1584h | CEPSCM | Nokia | miska.hannuksela@nokia.com | Rel-6 | Paolo | CEPSCM |  |
| 8494 | 2705 | 3G-324M Improvements |  | 198d? | 2004-03-16 A | 2004-12-16 A | 100% |  | 2004-03-16 | 2004-12-16 | 198d? |  | finish no earlier than 2004-12-16 | S4 | 1584h | 1584h | 3G-324MI | Ericsson | bo.burman@ericsson.com | Rel-6 | Paolo | 3G-324MI |  |
| 8495 | 2706 | Single Antenna Receiver Interference Cancellation (SAIC) |  | 420.92d? | 2002-11-15 A | 2004-06-25 A | 100% |  | 2002-11-15 | 2004-06-25 | 420.92d? |  | finish no earlier than 2004-08-27 | GP; G1 | 6734.72h | 6734.72h | SAIC | Cingular | Marc Grant | Rel-6 | Paolo | SAIC |  |
| 8496 | 2707 | **Enhancement of dialled service for CAMEL** |  | 289d | 2003-03-28 A | 2003-12-31 A | 100% |  | 2003-03-28 | 2003-12-31 | 199d |  |  | S1; N2; N4 | 7960h | 7960h | EDCAMEL | Samsung | craig.bishop@samsung.com | Rel-6 | Alain | EDCAMEL |  |
| 8497 | 2707.1 | Stages 2 and 3 for Enhancement of dialled service for CAMEL |  | 199d | 2003-03-28 A | 2003-12-31 A | 100% |  | 2003-03-28 | 2003-12-31 | 199d |  | finish no earlier than 2003-09-19 | N2; N4 | 3184h | 3184h |  | Samsung | Richard Brook | Rel-6 | Kimmo |  |  |
| 8498 | 2708 | Study on Bandwidth and resource savings in CS networks |  | 273d? | 2003-06-01 A | 2004-06-16 A | 100% |  | 2003-06-01 | 2004-06-16 | 273d? |  | finish no earlier than 2004-06-16 | S2 | 2184h | 2184h | BARS |  |  | Rel-6 | Maurice | BARS |  |
| 8499 | 2709 | **Multiple TBF in A/Gb mode** |  | 1066.75d? | 2002-04-05 A | 2005-01-28 A | 100% |  | 2002-04-05 | 2005-01-28 | 736d? |  |  | GP; G2 | 35200h | 35200h | MULTBF | Ericsson | gunnar.mildh@era.ericsson.se | Rel-6 | Paolo | MULTBF |  |
| 8500 | 2709.1 | **Multiple TBF in A/Gb mode - Core** |  | 530.25d? | 2002-04-05 A | 2003-08-29 A | 100% |  | 2002-04-05 | 2003-08-29 | 366d? |  |  | GP; G2 | 23424h | 23424h | MULTBF-Agbmode | Ericsson | gunnar.mildh@era.ericsson.se | Rel-6 | Paolo | MULTBF-Agbmode |  |
| 8501 | 2709.1.1 | Multiple TBF Concept paper |  | 366d? | 2002-04-05 A | 2003-08-29 A | 100% |  | 2002-04-05 | 2003-08-29 | 366d? |  | finish no earlier than 2003-08-29 | GP; G2 | 5856h | 5856h |  |  |  | Rel-6 | Paolo |  |  |
| 8502 | 2709.1.2 | Multiple TBF Stage 2 (43.064) CRs |  | 366d? | 2002-04-05 A | 2003-08-29 A | 100% |  | 2002-04-05 | 2003-08-29 | 366d? |  | finish no earlier than 2003-08-29 | GP; G2 | 5856h | 5856h |  |  |  | Rel-6 | Paolo |  |  |
| 8503 | 2709.1.3 | Multiple TBF Stage 3 (44.060) CRs |  | 366d? | 2002-04-05 A | 2003-08-29 A | 100% |  | 2002-04-05 | 2003-08-29 | 366d? |  | finish no earlier than 2003-08-29 | GP; G2 | 5856h | 5856h |  |  |  | Rel-6 | Paolo |  |  |
| 8504 | 2709.2 | Deleted - Multiple TBF in A/Gb mode – MS testing | milestone | 0d? | 2005-01-28 A | 2005-01-28 A | 100% |  | 2005-01-28 | 2005-01-28 | 0d? |  | start no earlier than 2005-01-28 | G3new |  |  | MULTBF-Testing | Ericsson | gunnar.mildh@era.ericsson.se | Rel-6 | Paolo | MULTBF-Testing | GP-27 |
| 8505 | 2710 | **Alignment between the test-regimes for GERAN capable MS** |  | 762.25d? | 2003-08-29 A | 2005-09-02 | 99% | 0d? | 2003-08-29 | 2005-09-02 | 526d? | 0d |  | G3new | 4208h | 4208h | ALTERE | Ericsson | anthony.toubassi@sonyericsson.com | Rel-6 | Ingbert | ALTERE |  |
| 8506 | 2710.1 | Determine the controversial test cases in the different test regimes and align them with 3GPP GERAN test specifications. Such test cases to be added to TS 51.010. |  | 526d? | 2003-08-29 A | 2005-09-02 A | 100% |  | 2003-08-29 | 2005-09-02 | 526d? |  | finish no earlier than 2005-09-02 | G3new | 4208h | 4208h | ALTERE-TC |  |  | Rel-6 | Ingbert | ALTERE-TC |  |
| 8507 | 2711 | Addition of U-TDOA in the CS domain |  | 111d? | 2003-11-21 A | 2004-04-23 A | 100% |  | 2003-11-21 | 2004-04-23 | 111d? |  | finish no earlier than 2004-04-23 | GP | 888h | 888h | UTDOACS | TruePosition | Bob Gross, Rhys Robinson (rlgross@trueposition.com) | Rel-6 | Paolo | UTDOACS |  |
| 8508 | 2712 | Addition of U-TDOA in the PS domain |  | 361d? | 2003-06-27 A | 2004-11-12 A | 100% |  | 2003-06-27 | 2004-11-12 | 361d? |  | finish no earlier than 2004-11-12 | GP | 2888h | 2888h | UTDOAPS | TruePosition | Bob Gross, Rhys Robinson (rlgross@trueposition.com) | Rel-6 | Paolo | UTDOAPS |  |

Notes:
- 8484: -
- 8485: - / Impacted TSs and TRs: 31.101; 31.102; 31.103; 31.111; 31.113; new 31.115; 31.116
- 8486: -
- 8487: -
- 8488: - / Impacted TSs and TRs: 31.124
- 8489: -
- 8490: 2nd resp SA4 / Impacted TSs and TRs: 22.233
- 8491: TR tbc by Sept. 05 / Impacted TSs and TRs: 26.233; 26.234; 26.244; 26.245; 26.246; 26.401; 26.402; 26.403; 26.404; 26.405; 26.406; 26.410; 26.411; 26.412; 26.273; 26.290; 26.304; 26.412; 26.274; 26.936
- 8492: TR tbc by Sept. 05 / Impacted TSs and TRs: 26.290; 26.304; 26.273; 26.274; 26.412; 26.936
- 8493: - / Impacted TSs and TRs: 26.235; 26.236
- 8494: - / Impacted TSs and TRs: 26.111; 26.911
- 8495: - / Impacted TSs and TRs: 45.903
- 8496: - / Impacted TSs and TRs: 22.078
- 8497: - / Impacted TSs and TRs: 23.008; 23.016; 23.018; 23.078; 29.002; 29.078
- 8498: - / Impacted TSs and TRs: 23.977
- 8499: GP#17 Nov 2003 Moved from Rel-5 UID_50058 MULTBF (Only Multiple TBF Concept paper produced in Rel-5)
- 8500: -
- 8501: -
- 8502: -
- 8503: -
- 8504: -
- 8505: -
- 8506: -
- 8507: Completed, except for potential LMU performance specs
- 8508: -

| ID | WBS | Task | Type | Duration | Start | Finish | Complete | Baseline start | Baseline finish | Baseline duration | Constraint | Resources | Work | Actual work | Acronym | WI rapporteur name | WI rapporteur e-mail | Release | MCC resp | Acronym_3GU_Export | TSG stopped | Impacted TSs and TRs | Created at |
| --- | --- | --- | --- | --- | --- | --- | --- | --- | --- | --- | --- | --- | --- | --- | --- | --- | --- | --- | --- | --- | --- | --- | --- |
| 8509 | 2713 | **Downlink Advanced Receiver Performance** |  | 675.25d? | 2003-11-21 A | 2005-09-02 A | 100% | 2003-11-21 | 2005-09-02 | 466d? |  | GP | 19160h | 19160h | DARP | Nokia | tommy.bysted@nokia.com | Rel-6 | Paolo | DARP |  |  |  |
| 8510 | 2713.1 | DARP test scenarios |  | 201d? | 2003-11-21 A | 2004-08-27 A | 100% | 2003-11-21 | 2004-08-27 | 201d? | finish no earlier than 2004-08-27 | GP | 1608h | 1608h | DARP-TS | Nokia | tommy.bysted@nokia.com | Rel-6 | Paolo | DARP-TS |  |  |  |
| 8511 | 2713.2 | **DARP for GMSK modulated voice services** |  | 291d? | 2004-02-06 A | 2004-11-12 A | 100% | 2004-02-06 | 2004-11-12 | 201d? |  | GP | 4824h | 4824h | DARP-GMSK | Nokia | tommy.bysted@nokia.com | Rel-6 | Paolo | DARP-GMSK |  |  |  |
| 8512 | 2713.2.1 | Performance requirements in 45.005 for DARP for GMSK modulated voice services |  | 201d? | 2004-02-06 A | 2004-11-12 A | 100% | 2004-02-06 | 2004-11-12 | 201d? | finish no earlier than 2004-11-12 | GP | 1608h | 1608h | DARP-GMSK-Perf |  |  | Rel-6 | Paolo | DARP-GMSK-Perf |  |  |  |
| 8513 | 2713.2.2 | Radio subsystem link control in 45.008 for DARP for GMSK modulated voice services |  | 201d? | 2004-02-06 A | 2004-11-12 A | 100% | 2004-02-06 | 2004-11-12 | 201d? | finish no earlier than 2004-11-12 | GP | 1608h | 1608h | DARP-GMSK-LC |  |  | Rel-6 | Paolo | DARP-GMSK-LC |  |  |  |
| 8514 | 2713.3 | **DARP for GPRS and EGPRS MCS1-MCS4** |  | 291d? | 2004-02-06 A | 2004-11-12 A | 100% | 2004-02-06 | 2004-11-12 | 201d? |  | GP | 4824h | 4824h | DARP-GPRSE | Nokia | tommy.bysted@nokia.com | Rel-6 | Paolo | DARP-GPRSE |  |  |  |
| 8515 | 2713.3.1 | Performance requirements in 45.005 for DARP for GPRS and EGPRS MCS1-MCS4 |  | 201d? | 2004-02-06 A | 2004-11-12 A | 100% | 2004-02-06 | 2004-11-12 | 201d? | finish no earlier than 2004-11-12 | GP | 1608h | 1608h | DARP-GPRSE-Perf |  |  | Rel-6 | Paolo | DARP-GPRSE-Perf |  |  |  |
| 8516 | 2713.3.2 | Radio subsystem link control in 45.008 for DARP for GPRS and EGPRS MCS1-MCS4 |  | 201d? | 2004-02-06 A | 2004-11-12 A | 100% | 2004-02-06 | 2004-11-12 | 201d? | finish no earlier than 2004-11-12 | GP | 1608h | 1608h | DARP-GPRSE-LC |  |  | Rel-6 | Paolo | DARP-GPRSE-LC |  |  |  |
| 8517 | 2713.4 | DARP Capability signalling |  | 256d? | 2003-11-21 A | 2004-11-12 A | 100% | 2003-11-21 | 2004-11-12 | 256d? | finish no earlier than 2004-11-12 | GP | 2048h | 2048h | DARP-CAPSIG | Nokia | tommy.bysted@nokia.com | Rel-6 | Paolo | DARP-CAPSIG |  |  |  |
| 8518 | 2713.5 | GERAN MS Conformance test for DARP |  | 266d? | 2004-08-27 A | 2005-09-02 A | 100% | 2004-08-27 | 2005-09-02 | 266d? | finish no earlier than 2005-06-24 | G3new | 2128h | 2128h | ARP-ConfTest | Nokia | tommy.bysted@nokia.com | Rel-6 | Ingbert | ARP-ConfTest |  |  |  |
| 8519 | 2714 | **Reduction of PS service interruption in Dual Transfer Mode** |  | 602.75d? | 2003-11-21 A | 2005-06-24 A | 100% | 2003-11-21 | 2005-06-24 | 416d? |  | G2 | 8360h | 8360h | PSintDTM | Siemens | toby.proctor@roke.co.uk | Rel-6 | Gert | PSintDTM |  |  |  |
| 8520 | 2714.1 | Use case and requirement definition |  | 111d? | 2003-11-21 A | 2004-04-23 A | 100% | 2003-11-21 | 2004-04-23 | 111d? | finish no earlier than 2004-04-23 | G2 | 888h | 888h | PSintDTM-Req | Siemens | toby.proctor@roke.co.uk | Rel-6 | Gert | PSintDTM-Req |  |  |  |
| 8521 | 2714.2 | Performance Study of Current Procedures |  | 111d? | 2003-11-21 A | 2004-04-23 A | 100% | 2003-11-21 | 2004-04-23 | 111d? | start no earlier than 2003-11-21 | G2 | 888h | 888h | PSintDTM-Perf | Siemens | toby.proctor@roke.co.uk | Rel-6 | Gert | PSintDTM-Perf |  |  |  |
| 8522 | 2714.3 | Reduction of service interruption times and packet loss during Dual Transfer Mode and mobility procedures |  | 146d? | 2004-04-23 A | 2004-11-12 A | 100% | 2004-04-23 | 2004-11-12 | 146d? | finish no earlier than 2004-11-12 | G2 | 1168h | 1168h | PSintDTM-Reduct | Siemens | toby.proctor@roke.co.uk | Rel-6 | Gert | PSintDTM-Reduct |  |  |  |
| 8523 | 2714.4 | Deleted - MS Conformance testing - Reduction of PS service interruption in DTM |  | 261d? | 2004-06-25 A | 2005-06-24 A | 100% | 2004-06-25 | 2005-06-24 | 261d? | finish no earlier than 2005-06-24 | G3new | 2088h | 2088h | PSintDTM-ConfMS |  |  | Rel-6 | Ingbert | PSintDTM-ConfMS | GP-25 |  |  |
| 8524 | 2714.5 | Deleted - BTS Conformance testing - Reduction of PS service interruption in DTM | milestone | 0d? | 2005-06-24 A | 2005-06-24 A | 100% | 2005-06-24 | 2005-06-24 | 0d? | finish no earlier than 2005-06-24 | G3new |  |  | PSintDTM-ConfBTS |  |  | Rel-6 | Ingbert | PSintDTM-ConfBTS | GP-25 |  |  |
| 8525 | 2715 | CAMEL prepay interworking with SCUDIF |  | 216.3d | 2003-12-08 A | 2004-10-05 A | 100% | 2003-12-08 | 2004-10-05 | 216.3d |  | N4; N3; S1 | 5191.2h | 5191.2h | SCCAMEL | Nokia | Keijo.Palviainen@Nokia.Com | Rel-6 | Kimmo | SCCAMEL |  | 22.078; 23.078; 29.078; 29.002; 23.172 |  |
| 8526 | 2716 | **Circuit Switched Video and Voice Service Improvements** |  | 621.25d? | 2004-01-12 A | 2005-09-02 A | 100% | 2004-01-12 | 2005-09-02 | 430d? |  | S2; N1 | 12696h | 12696h | CS_VSS | Vodafone | John Watson | Rel-6 | Alain | CS_VSS |  |  |  |
| 8527 | 2716.1 | Deleted - Stage 1 - Requirements |  | 199d | 2004-01-12 A | 2004-10-14 A | 100% | 2004-01-12 | 2004-10-14 | 199d | finish no earlier than 2004-10-14 | S1 | 1592h | 1592h |  | Vodafone | John Watson | Rel-6 | Alain |  | SP-26 | 22.101 |  |
| 8528 | 2716.2 | Stage 2 Study on architecture alternatives |  | 244d? | 2004-01-12 A | 2004-12-16 A | 100% | 2004-01-12 | 2004-12-16 | 244d? | finish no earlier than 2004-08-13 | S2 | 1952h | 1952h |  | Vodafone | chris.pudney@vodafone.com | Rel-6 | Maurice |  |  | 23.903 | SP-24 |
| 8529 | 2716.3 | Deleted - Stage 2 description on Redial |  | 164d? | 2004-05-03 A | 2004-12-16 A | 100% | 2004-05-03 | 2004-12-16 | 164d? | finish no earlier than 2004-12-16 | S2 | 1312h | 1312h |  | Vodafone | chris.pudney@vodafone.com | Rel-6 | Maurice |  | SP-26 |  | SP-24 |
| 8530 | 2716.4 | Switching between voice and video call - Redial solution |  | 120d? | 2005-01-03 A | 2005-06-17 A | 100% | 2005-01-03 | 2005-06-17 | 120d? | start no earlier than 2005-01-03 | N1 | 960h | 960h |  | Vodafone |  | Rel-6 | Frederic |  |  | 23.009; 24.008 |  |
| 8531 | 2716.5 | Deleted - CS_VSS - GERAN2 Part | milestone | 0d | 2005-09-02 A | 2005-09-02 A | 100% | 2005-09-02 | 2005-09-02 | 0d | start no earlier than 2005-09-02 | G2 |  |  |  | Vodafone |  | Rel-6 | Gert |  | GP-26 |  |  |
| 8532 | 2716.6 | Deleted - CS_VSS - CN3 Part | milestone | 0d? | 2004-10-14 A | 2004-10-14 A | 100% | 2004-10-14 | 2004-10-14 | 0d? | start no earlier than 2004-10-14 | N3 |  |  |  | Vodafone |  | Rel-6 | Gwiho |  | TP-26 |  |  |
| 8533 | 2717 | Reorganisation of CS Data Specifications |  | 14d? | 2004-11-19 A | 2004-12-08 A | 100% | 2004-11-19 | 2004-12-08 | 14d? | finish no earlier than 2004-12-24 | N3 | 112h | 112h | CSData | Siemens | Thomas.Belling@nsn.com | Rel-6 | Gwiho | CS Data |  | 23.910; 29.007; New 23.202 |  |

Notes:
- 8509: -
- 8510: -
- 8511: -
- 8512: -
- 8513: -
- 8514: -
- 8515: -
- 8516: -
- 8517: -
- 8518: -
- 8519: -
- 8520: -
- 8521: -
- 8522: -
- 8523: -
- 8524: -
- 8525: -
- 8526: -
- 8527: -
- 8528: -
- 8529: -
- 8530: -
- 8531: -
- 8532: -
- 8533: Created at TSG#27 as 100 % complete

| ID | WBS | Task | Type | Duration | Start | Finish | Complete | Baseline start | Baseline finish | Baseline duration | Constraint | Resources | Work | Actual work | Acronym | WI rapporteur name | Release | MCC resp | Acronym_3GU_Export | Impacted TSs and TRs | WI rapporteur e-mail | TSG stopped |
| --- | --- | --- | --- | --- | --- | --- | --- | --- | --- | --- | --- | --- | --- | --- | --- | --- | --- | --- | --- | --- | --- | --- |
| 8534 | 2718 | **Generic Access to A/Gb Interface (GAAI)** |  | 595.5d? | 2004-06-25 A | 2006-01-20 A | 100% | 2004-06-25 | 2006-01-20 | 411d? |  | GP | 9160h | 9160h | GAAI | Motorola | Rel-6 | Paolo | GAAI |  |  |  |
| 8535 | 2718.1 | FS on GAAI |  | 46d? | 2004-06-25 A | 2004-08-27 A | 100% | 2004-06-25 | 2004-08-27 | 46d? | finish no earlier than 2004-08-27 | GP | 368h | 368h | GAAG | Motorola | Rel-6 | Paolo | GAAG | 43.901 |  |  |
| 8536 | 2718.2 | GAAI – Stage 2 |  | 161d? | 2004-08-27 A | 2005-04-08 A | 100% | 2004-08-27 | 2005-04-08 | 161d? | finish no earlier than 2005-04-08 | GP | 1288h | 1288h | GAAI-Stage2 | Ericsson | Rel-6 | Paolo | GAAI-Stage2 | 43.318 | jari.vikberg@ericsson.com |  |
| 8537 | 2718.3 | GAAI – Stage 3 |  | 161d? | 2004-08-27 A | 2005-04-08 A | 100% | 2004-08-27 | 2005-04-08 | 161d? | finish no earlier than 2005-04-08 | GP | 1288h | 1288h | GAAI-Stage3 |  | Rel-6 | Paolo | GAAI-Stage3 | 44.318 |  |  |
| 8538 | 2718.4 | MS Conformance Test for GAAI |  | 366d? | 2004-08-27 A | 2006-01-20 A | 100% | 2004-08-27 | 2006-01-20 | 366d? | finish no earlier than 2006-01-20 | GP | 2928h | 2928h | GAAI-CT |  | Rel-6 | Ingbert | GAAI-CT |  |  |  |
| 8539 | 2719 | **Support of PS Handover for GERAN A/Gb mode** |  | 684.5d? | 2003-11-03 A | 2005-08-24 A | 100% | 2003-11-03 | 2005-08-24 | 473d? |  | GP; G2 | 30272h | 30272h | SPSHAGB | Ericsson | Rel-6 | Paolo | SPSHAGB |  | gunnar.hedby@ericsson.com |  |
| 8540 | 2719.1 | Stage 2 for Support of PS Handover for GERAN A/Gb mode |  | 473d? | 2003-11-03 A | 2005-08-24 A | 100% | 2003-11-03 | 2005-08-24 | 473d? | finish no earlier than 2005-09-02 | GP; G2 | 7568h | 7568h | SPSHAGB-Stage2 | Ericsson | Rel-6 | Paolo | SPSHAGB-Stage2 | 43.129 | gunnar.hedby@ericsson.com |  |
| 8541 | 2719.2 | PS handover for Support of PS Handover for GERAN A/Gb mode |  | 473d? | 2003-11-03 A | 2005-08-24 A | 100% | 2003-11-03 | 2005-08-24 | 473d? | finish no earlier than 2005-09-02 | GP; G2 | 7568h | 7568h | SPSHAGB-PSHO | Ericsson | Rel-6 | Paolo | SPSHAGB-PSHO |  | gunnar.hedby@ericsson.com |  |
| 8542 | 2719.3 | Definition of radio resource management functionality for Support of PS Handover for GERAN A/Gb mode |  | 473d? | 2003-11-03 A | 2005-08-24 A | 100% | 2003-11-03 | 2005-08-24 | 473d? | finish no earlier than 2005-09-02 | GP; G2 | 7568h | 7568h | SPSHAGB-RRM | Ericsson | Rel-6 | Paolo | SPSHAGB-RRM |  | gunnar.hedby@ericsson.com |  |
| 8543 | 2720 | Study on (U)SIM Security Reuse by Peripheral Devices on Local Interfaces |  | 127d? | 2003-07-03 A | 2003-12-26 A | 100% | 2003-07-03 | 2003-12-26 | 127d? | finish no earlier than 2003-12-26 | S3 | 1016h | 1016h |  | Toshiba | Rel-6 | Mirko |  | 33.817 | Raziq Yaqub (ryaqub@tari.toshiba.com) |  |
| 8544 | 2721 | Study on Security for early IMS |  | 127d? | 2004-10-01 A | 2005-03-28 A | 100% | 2004-10-01 | 2005-03-28 | 127d? | finish no earlier than 2003-12-26 | S3 | 1016h | 1016h | SEC-IMS | Vodafone | Rel-6 | Mirko | SEC-IMS | 33.978 | Peter.Howard@vodafone.com |  |
| 8545 | 2722 | (Small) Technical Enhancements and Improvements for Rel-6 | milestone | 0d? | 2006-06-02 A | 2006-06-02 A | 100% | 2006-06-02 | 2006-06-02 | 0d? |  | SP; CP; RP; GP |  |  | TEI6 |  | Rel-6 | all | TEI6 |  |  |  |
| 8546 | 2723 | Test - (Small) Technical Enhancements and Improvements for Rel-6 |  | 503d? | 2006-06-02 A | 2008-05-06 A | 100% | 2006-06-02 | 2008-05-06 | 503d? | start no earlier than 2006-06-02 | R5; T1 | 8048h | 8048h | TEI6_Test |  | Rel-6 | Ingbert | TEI6_Test | 34.108.34.121-1/2.34.122.34.123-1/2/3 |  |  |
| 8547 | 2724 | Deleted - Study of Feature Interactions Requirements | milestone | 0d? | 2004-09-16 A | 2004-09-16 A | 100% | 2004-09-16 | 2004-09-16 | 0d? | finish no earlier than 2004-10-01 | S1 |  |  | FINTER |  | Rel-6 | Alain | FINTER |  |  | SP-25 |
| 8548 | 2725 | Deleted EVGCS - Enhancements of VGCS in public networks for communication of public authority officials |  | 7d? | 2005-08-25 A | 2005-09-02 A | 100% | 2005-08-25 | 2005-09-02 | 7d? | start no earlier than 2005-08-24 | GP; G2 | 112h | 112h |  | Siemens | Rel-6 | Paolo |  | 44.018; 44.068; 48.008 | kenneth.isaacs@roke.co.uk | GP-26 |
| 8549 | 2726 | **Deleted SCSAGB - Support of Conversational Services in A/Gb mode via the PS domain** |  | 93.25d? | 2003-11-21 A | 2004-02-19 A | 100% | 2003-11-21 | 2004-02-19 | 64d? |  | GP; N1 | 2048h | 2048h |  | Ericsson | Rel-6 | Paolo |  |  | David Bladsjö (david.bladsjo@ericsson.com) | GP-18 |
| 8550 | 2726.1 | Deleted - Creation of a TR | milestone | 0d? | 2003-11-21 A | 2003-11-21 A | 100% | 2003-11-21 | 2003-11-21 | 0d? | start no earlier than 2003-11-21 | GP |  |  | SCSAGB-TR | Ericsson | Rel-6 | Paolo | SCSAGB-TR |  | David Bladsjö (david.bladsjo@ericsson.com) | GP-17 |
| 8551 | 2726.2 | Deleted - Stage 2 | milestone | 0d? | 2003-11-21 A | 2003-11-21 A | 100% | 2003-11-21 | 2003-11-21 | 0d? | finish no earlier than 2003-11-21 | GP |  |  | SCSAGB-Stage2 | Ericsson | Rel-6 | Paolo | SCSAGB-Stage2 |  | David Bladsjö (david.bladsjo@ericsson.com) | GP-17 |
| 8552 | 2726.3 | Deleted - Radio Channel Support | milestone | 0d? | 2003-11-21 A | 2003-11-21 A | 100% | 2003-11-21 | 2003-11-21 | 0d? | finish no earlier than 2003-11-21 | GP |  |  | SCSAGB-RCS | Ericsson | Rel-6 | Paolo | SCSAGB-RCS |  | David Bladsjö (david.bladsjo@ericsson.com) | GP-17 |
| 8553 | 2726.4 | Deleted SCSAGB-RRM - Definition of radio resource management functionality | milestone | 0d? | 2003-11-21 A | 2003-11-21 A | 100% | 2003-11-21 | 2003-11-21 | 0d? | finish no earlier than 2003-11-21 | GP |  |  |  | Ericsson | Rel-6 | Paolo |  |  | David Bladsjö (david.bladsjo@ericsson.com) | GP-17 |
| 8554 | 2726.5 | Deleted - replaced by 50561 - PS Handover |  | 64d | 2003-11-24 A | 2004-02-19 A | 100% | 2003-11-24 | 2004-02-19 | 64d | start no earlier than 2003-11-21 | GP; N1 | 1024h | 1024h | SCSAGB-PSH | Ericsson | Rel-6 | Paolo | SCSAGB-PSH |  | David Bladsjö (david.bladsjo@ericsson.com) | GP-18 |
| 8555 | 2726.6 | Deleted SCSAGB-FLO - Modifications to FLO | milestone | 0d? | 2003-11-21 A | 2003-11-21 A | 100% | 2003-11-21 | 2003-11-21 | 0d? | finish no earlier than 2003-11-21 | GP |  |  |  | Ericsson | Rel-6 | Paolo |  |  | David Bladsjö (david.bladsjo@ericsson.com) | RP-29 |
| 8556 | 2727 | Deleted - Rel-6 Evolutions of the transport in the UTRAN (ETRAN) | milestone | 0d | 2003-12-31 A | 2003-12-31 A | 100% | 2003-12-31 | 2003-12-31 | 0d | start no earlier than 2003-12-31 | RP |  |  |  | Alcatel | Rel-6 | Issam |  |  | Francois Courau | RP-22 |
| 8557 | 2728 | --- RELEASE 5 --- |  | 325d? | 2000-01-03 A | 2001-03-29 A | 100% | 2000-01-03 | 2001-03-29 | 325d? |  | NP; GP; RP; SP; TP | 13000h | 13000h |  |  | Rel-5 | All |  |  |  |  |
| 8558 | 75 | IP transport in the UTRAN |  | 445d | 2000-07-17 A | 2002-03-29 A | 100% | 2000-07-17 | 2002-03-29 | 445d | finish no earlier than 2002-03-29 | R3 | 3560h | 3560h | ETRAN-IPtrans | Alcatel | Rel-5 | Juha | ETRAN-IPtrans |  | Nicolas Drevon |  |
| 8559 | 76 | Feasibility study on SS7 signalling transportation in the core network with SCCP-User Adaptation (SUA) |  | 205d | 2001-03-12 A | 2001-12-21 A | 100% | 2001-03-12 | 2001-12-21 | 205d | finish no earlier than 2001-12-21 | N4 | 1640h | 1640h | FS_SS7IP |  | Rel-5 | Kimmo | FS_SS7IP | 29.903 |  |  |

Notes:
- 8534: -
- 8535: Feasibility Study
- 8536: -
- 8537: -
- 8538: Marked as closed 12/2008 (was marked 90% complete)
- 8539: Replaces SCSAGB- Originally Started Nov 2003 as GP-030443
- 8540: Replaces SCSAGB-Stage2
- 8541: Replaces SCSAGB-PSH
- 8542: Replaces SCSAGB-RRM
- 8543: SP#20 approved WID
- 8544: SP#24 approved WID. SP#46 withdrawn TR 33.978 from Rel-8 onwards
- 8545: "Joker" WI, to be used for a Rel 6 CR not related to any feature and with very limited impact on the system. Moved in from Stoyan/Testing WP
- 8546: "Joker" WI, to be used for small modifications applicable to Rel 4 conformance testing
- 8547: SP#25 stopped
- 8548: GP#26 moved to Rel-7 as UID_11045 Enhancements of VGCS in public networks for communication of public authority officials
- 8549: -
- 8550: -
- 8551: Started
- 8552: Not started
- 8553: Not started
- 8554: Started
- 8555: Not started
- 8556: Generic feature ETRAN
- 8557: -
- 8558: -
- 8559: -

| ID | WBS | Task | Duration | Start | Finish | Complete | Baseline start | Baseline finish | Baseline duration | Constraint | Deadline | Resources | Work | Actual work | Acronym | WI rapporteur name | WI rapporteur e-mail | Release | MCC resp | Acronym_3GU_Export | Impacted TSs and TRs | Created at | TSG stopped |
| --- | --- | --- | --- | --- | --- | --- | --- | --- | --- | --- | --- | --- | --- | --- | --- | --- | --- | --- | --- | --- | --- | --- | --- |
| 8560 | 77 | **High Speed Downlink Packet Access** | 2245.25d? | 2001-04-02 A | 2007-03-09 A | 100% | 2001-04-02 | 2007-03-09 | 1550d? |  |  | R2; R5 | 43888h | 43888h | HSDPA | Motorola | Ravi Kuchibhotla | Rel-5 | Yong-Jun | HSDPA |  |  |  |
| 8561 | 77.1 | Physical Layer for High Speed Downlink Packet Access | 257d | 2001-04-05 A | 2002-03-29 A | 100% | 2001-04-05 | 2002-03-29 | 257d | finish no earlier than 2002-03-29 |  | R1 | 2056h | 2056h | HSDPA-Phys | Motorola | Amitabha Ghosh (qa0047@email.mot.com) | Rel-5 | Patrick | HSDPA-Phys |  |  |  |
| 8562 | 77.2 | Layer 2 and 3 aspects | 257d | 2001-04-05 A | 2002-03-29 A | 100% | 2001-04-05 | 2002-03-29 | 257d | finish no earlier than 2002-03-29 |  | R2 | 2056h | 2056h | HSDPA-L23 | Motorola | Ravi Kuchibhotla | Rel-5 | Yong-Jun | HSDPA-L23 |  |  |  |
| 8563 | 77.3 | Iub/Iur protocol aspects - for High Speed Downlink Packet Access | 260d | 2001-04-02 A | 2002-03-29 A | 100% | 2001-04-02 | 2002-03-29 | 260d | finish no earlier than 2002-03-29 |  | R3 | 2080h | 2080h | HSDPA-IubIur | Motorola | Mike Diesen | Rel-5 | Juha | HSDPA-IubIur |  |  |  |
| 8564 | 77.4 | RF Radio Transmission/ Reception, System Performance Requirements and Conformance Testing | 565d | 2001-04-09 A | 2003-06-06 A | 100% | 2001-04-09 | 2003-06-06 | 565d | finish no earlier than 2003-06-06 |  | R4 | 4520h | 4520h | HSDPA-RF | Motorola | Howard Benn | Rel-5 | Issam | HSDPA-RF |  |  |  |
| 8565 | 2731.5 | Conformance Testing of HSDPA | 786d | 2003-09-19 A | 2006-09-22 A | 100% | 2003-09-19 | 2006-09-22 | 786d | finish no earlier than 2006-09-22 |  | R5 | 6288h | 6288h | HSDPA_Test | Motorola | carolyn.taylor@motorola.com | Rel-5 | Ingbert | HSDPA_Test | 34.108; 34.121; 34.122; 34.123-1; 34.123-2; 34.123-3 | 19/9/2003 |  |
| 8566 | 2731.6 | Conformance Testing of HCR TDD HSDPA | 261d? | 2006-03-10 A | 2007-03-09 A | 100% | 2006-03-10 | 2007-03-09 | 261d? | finish no earlier than 2007-03-09 |  | R5 | 2088h | 2088h | HSDPA_HCRTDD_Test | IPWireless | drichards@ipwireless.com | Rel-5 | Ingbert | HSDPA_HCRTDD_Test | 34.108; 34.122; 34.123-1; 34.123-2; 34.123-3 |  |  |
| 8567 | 78 | **Rel-5 Improvements of Radio Interface** | 773.5d | 2000-08-14 A | 2002-08-30 A | 100% | 2000-08-14 | 2002-08-30 | 535d |  |  | RP | 30376h | 30376h |  |  |  | Rel-5 |  |  |  |  |  |
| 8568 | 78.1 | **Base station classification for TDD** | 693.75d | 2000-08-14 A | 2002-06-14 A | 100% | 2000-08-14 | 2002-06-14 | 480d |  |  | R4 | 9208h | 9208h | RInImp-BSClass | Nokia | antti.toskala@nokia.com | Rel-5 | Issam | RInImp-BSClass |  |  |  |
| 8569 | 78.1.1 | TDD Base station classification | 410d | 2000-08-14 A | 2002-03-08 A | 100% | 2000-08-14 | 2002-03-08 | 410d | finish no earlier than 2002-03-08 |  | R4 | 3280h | 3280h | RInImp-BSClass-TDD | Nokia | antti.toskala@nokia.com | Rel-5 | Issam | RInImp-BSClass-TDD |  |  |  |
| 8570 | 78.1.2 | Base Station Classification for 1.28 Mcps TDD option | 261d | 2001-06-15 A | 2002-06-14 A | 100% | 2001-06-15 | 2002-06-14 | 261d | finish no earlier than 2002-06-14 |  | R4 | 2088h | 2088h | RInImp-BSClass-LCRTDD | Siemens | Meik.Kottkamp@siemens.com | Rel-5 | Issam | RInImp-BSClass-LCRTDD |  |  |  |
| 8571 | 78.2 | Enhancement on the DSCH hard split mode | 271d | 2001-03-16 A | 2002-03-29 A | 100% | 2001-03-16 | 2002-03-29 | 271d | finish no earlier than 2002-03-29 |  | R1 | 2168h | 2168h | RInImp-DSCHhsp | Samsung | Jaeyoel KIM | Rel-5 | Patrick | RInImp-DSCHhsp |  |  |  |
| 8572 | 78.3 | Hybrid ARQ II/III | 355d | 2000-08-21 A | 2001-12-28 A | 100% | 2000-08-21 | 2001-12-28 | 355d | finish no earlier than 2001-12-28 |  | R2 | 2840h | 2840h | RInImp-HARQ | Siemens | armin.sitte@siemens.com | Rel-5 | Yong-Jun | RInImp-HARQ |  |  | RP-14 |
| 8573 | 78.4 | FS on USTS | 355d | 2000-08-14 A | 2001-12-21 A | 100% | 2000-08-14 | 2001-12-21 | 355d | finish no earlier than 2001-12-21 |  | R1 | 2840h | 2840h | RInImp-USTS | SK Telecom | D. Kim | Rel-5 | Patrick | RInImp-USTS |  |  |  |
| 8574 | 78.5 | FS on UE antenna efficiency test method performance requirements | 255d | 2000-09-25 A | 2001-09-14 A | 100% | 2000-09-25 | 2001-09-14 | 255d | finish no earlier than 2001-09-14 |  | R4 | 2040h | 2040h | RInImp-UEAnTM | Allgon | O. Edvardsson | Rel-5 | Issam | RInImp-UEAnTM |  |  |  |
| 8575 | 78.6 | FS on the re-introduction of the downlink SIR measurement | 200d | 2001-03-12 A | 2001-12-14 A | 100% | 2001-03-12 | 2001-12-14 | 200d | finish no earlier than 2001-12-14 |  | R4 | 1600h | 1600h | RInImp-SIR | Ericsson | Torgny.Palenius@ericsson.com | Rel-5 | Issam | RInImp-SIR |  |  |  |
| 8576 | 78.7 | FS on mitigating the effect of CPICH interference at the UE | 255d | 2001-03-19 A | 2002-03-08 A | 100% | 2001-03-19 | 2002-03-08 | 255d | finish no earlier than 2002-03-08 |  | R4 | 2040h | 2040h | RInImp-CPICH_Intf | Intel | shimon.moshavi@INTEL.COM | Rel-5 | Issam | RInImp-CPICH_Intf |  |  |  |
| 8577 | 78.8 | **Deleted - Conformance Test Spec. improvements in Radio Interface** | 200.75d | 2002-02-18 A | 2002-08-30 A | 100% | 2002-02-18 | 2002-08-30 | 140d |  |  | T1 | 3360h | 3360h |  |  |  | Rel-5 | Ingbert |  |  |  | TP-17 |
| 8578 | 78.8.1 | Deleted - Testing improvement of inter-frequency and inter-system measurement | 140d | 2002-02-18 A | 2002-08-30 A | 100% | 2002-02-18 | 2002-08-30 | 140d | finish no earlier than 2002-08-30 |  | T1 | 1120h | 1120h |  |  |  | Rel-5 | Ingbert |  |  |  | TP-17 |
| 8579 | 78.8.2 | Deleted - Testing Hybrid ARQ II/III | 140d | 2002-02-18 A | 2002-08-30 A | 100% | 2002-02-18 | 2002-08-30 | 140d | finish no earlier than 2002-08-30 |  | T1 | 1120h | 1120h |  |  |  | Rel-5 | Ingbert |  |  |  | TP-17 |
| 8580 | 79 | **Rel-5 RAN improvements** | 2263d? | 2001-03-16 A | 2007-03-09 A | 100% | 2001-03-16 | 2007-03-09 | 1561d? |  |  | RP | 49424h | 49424h |  |  |  | Rel-5 |  |  |  |  |  |
| 8581 | 79.1 | **RRM optimization for Iur and Iub** | 462d | 2001-03-16 A | 2002-06-04 A | 100% | 2001-03-16 | 2002-06-04 | 318d |  |  | R3 | 8904h | 8904h | RANimp-RRMopt | Ericsson | Gert-Jan.van.Lieshout@eln.ericsson.se | Rel-5 | Juha | RANimp-RRMopt |  |  |  |
| 8582 | 79.1.1 | Iur common transport channel efficiency optimization | 271d | 2001-03-16 A | 2002-03-29 A | 100% | 2001-03-16 | 2002-03-29 | 271d | finish no earlier than 2002-03-29 |  | R3 | 2168h | 2168h | RANimp-RRMopt-ctc | Ericsson | Shahrokh Amirijoo | Rel-5 | Juha | RANimp-RRMopt-ctc |  |  |  |
| 8583 | 79.1.2 | Iur neighbouring cell reporting efficiency optimization | 271d | 2001-03-16 A | 2002-03-29 A | 100% | 2001-03-16 | 2002-03-29 | 271d | finish no earlier than 2002-03-29 |  | R3 | 2168h | 2168h | RANimp-RRMopt-ncr | Ericsson | Shahrokh Amirijoo | Rel-5 | Juha | RANimp-RRMopt-ncr |  |  |  |
| 8584 | 79.1.3 | FS Introduction of direct transport bearers between SRNC and Node-B | 253d | 2001-06-15 A | 2002-06-04 A | 100% | 2001-06-15 | 2002-06-04 | 253d | finish no earlier than 2002-06-28 |  | R3 | 2024h | 2024h | RAN-imp-RRMopt-DTB | Ericsson | Risto Sepponen | Rel-5 | Juha | RAN-imp-RRMopt-DTB |  |  |  |
| 8585 | 79.2 | RL Timing Adjustment | 271d | 2001-03-16 A | 2002-03-29 A | 100% | 2001-03-16 | 2002-03-29 | 271d | finish no earlier than 2002-03-29 |  | R3 | 2168h | 2168h | RANimp-RLTA | Ericsson | Elena Voltolina | Rel-5 | Juha | RANimp-RLTA |  |  |  |
| 8586 | 79.3 | Separation of resource reservation and radio link activation | 271d | 2001-03-16 A | 2002-03-29 A | 100% | 2001-03-16 | 2002-03-29 | 271d | finish no earlier than 2002-03-29 |  | R3 | 2168h | 2168h | RANimp-SepRR | Ericsson | Gert-Jan.van.Lieshout@eln.ericsson.se | Rel-5 | Juha | RANimp-SepRR |  |  |  |
| 8587 | 79.4 | FS SRNS Relocation Procedure Enhancement | 318d | 2001-06-15 A | 2002-09-03 A | 100% | 2001-06-15 | 2002-09-03 | 318d | finish no earlier than 2002-09-06 |  | R3 | 2544h | 2544h | RANimp-SRNS | Nokia | Olivier Guyot | Rel-5 | Juha | RANimp-SRNS |  |  |  |
| 8588 | 79.5 | FS Improvement of Radio Resource Management across RNS and RNS/PSS | 201d | 2001-03-16 A | 2001-12-21 A | 100% | 2001-03-16 | 2001-12-21 | 201d | finish no earlier than 2001-12-21 |  | R3 | 1608h | 1608h | RANimp-ImpRRM | Nokia | antti.toskala@nokia.com | Rel-5 | Juha | RANimp-ImpRRM |  |  |  |
| 8589 | 79.6 | Re-arrangements of Iub transport bearers | 271d | 2001-03-16 A | 2002-03-29 A | 100% | 2001-03-16 | 2002-03-29 | 271d | finish no earlier than 2002-03-29 |  | R3 | 2168h | 2168h | RANimp-TTPS | Nokia | antti.toskala@nokia.com | Rel-5 | Juha | RANimp-TTPS |  |  |  |
| 8590 | 79.7 | RAB support enhancement for Rel-5 | 469d | 2001-04-02 A | 2002-06-28 A | 100% | 2001-04-02 | 2002-06-28 | 325d |  |  | R2 | 2600h | 2600h | RANimp-RABSE5 | Nokia | Juha Mikola | Rel-5 | Yong-Jun | RANimp-RABSE5 |  |  |  |
| 8591 | 16.5.1 | Testing of ROHC performance | 391d | 2005-09-09 A | 2007-03-09 A | 100% | 2005-09-09 | 2007-03-09 | 391d | finish no earlier than 2007-03-09 | 2006-06-02 | R5 | 3128h | 3128h | RANimp-RABSE5_Test | Nokia | jarkko.hellsten@nokia.com | Rel-5 | Ingbert | RANimp-RABSE5_Test | 34.108; 34.123-1; 34.123-2; 34.123-3 | Fri 11/03/05 |  |
| 8592 | 79.8 | Beamforming requirements for UE | 61d | 2001-09-21 A | 2001-12-14 A | 100% | 2001-09-21 | 2001-12-14 | 61d | finish no earlier than 2001-12-14 |  | R1 | 488h | 488h | RANimp-BFR-UE | Nokia | Jussi Kähtävä (juha.mikola@nokia.com) | Rel-5 | Patrick | RANimp-BFR-UE |  |  |  |
| 8593 | 79.9 | Support of Site Selection Diversity Transmission in UTRAN | 123d | 2001-12-14 A | 2002-06-04 A | 100% | 2001-12-14 | 2002-06-04 | 123d | finish no earlier than 2002-06-04 |  | R1 | 984h | 984h | RANimp-SSDT | NEC |  | Rel-5 | Patrick | RANimp-SSDT |  |  |  |
| 8594 | 79.10 | Node B Synchronisation for 1.28 Mcps TDD | 271d | 2001-03-16 A | 2002-03-29 A | 100% | 2001-03-16 | 2002-03-29 | 271d | finish no earlier than 2002-03-29 |  | R1 | 2168h | 2168h | RANimp-NBSLCR | CATT | Jinling HU | Rel-5 | Patrick | RANimp-NBSLCR |  |  |  |

Notes:
- 8560: -
- 8561: -
- 8562: -
- 8563: -
- 8564: -
- 8565: -
- 8566: -
- 8567: -
- 8568: -
- 8569: -
- 8570: -
- 8571: -
- 8572: Stopped at RP#14¦work on this task was performed as part of High Speed Downlink Packet Access feature
- 8573: -
- 8574: -
- 8575: -
- 8576: -
- 8577: Marked as stopped 12/2008
- 8578: Marked as stopped 12/2008
- 8579: Marked as stopped 12/2008
- 8580: -
- 8581: -
- 8582: -
- 8583: -
- 8584: FS was closed and introduction of WI not agreed at RAN #16
- 8585: -
- 8586: -
- 8587: -
- 8588: FS was closed and WI was introduced at RAN #14
- 8589: -
- 8590: RFC 3095 context relocation
- 8591: -
- 8592: -
- 8593: RP-020356
- 8594: -

| ID | WBS | Task | Duration | Start | Finish | Complete | Baseline start | Baseline finish | Baseline duration | Constraint | Deadline | Resources | Work | Actual work | Release | MCC resp | TSG stopped | Acronym | Impacted TSs and TRs | Acronym_3GU_Export | WI rapporteur name | WI rapporteur e-mail | Created at |
| --- | --- | --- | --- | --- | --- | --- | --- | --- | --- | --- | --- | --- | --- | --- | --- | --- | --- | --- | --- | --- | --- | --- | --- |
| 8595 | 79.12 | **Deleted - Conformance Test Aspects - RAN Improvements** | 819.25d? | 2002-01-01 A | 2004-03-01 A | 100% | 2002-01-01 | 2004-03-01 | 565d? |  |  | T1 | 8008h | 8008h | Rel-5 | Ingbert | TP-23 |  |  |  |  |  |  |
| 8596 | 79.12.1 | Deleted - Testing Radio access bearer support enhancements | 175d | 2002-01-01 A | 2002-09-02 A | 100% | 2002-01-01 | 2002-09-02 | 175d | finish no earlier than 2002-09-02 |  | T1 | 1400h | 1400h | Rel-5 | Ingbert | TP-17 |  |  |  |  |  |  |
| 8597 | 2733.12.2 | Deleted - General changes to TS34.121 and TS34.122 corresponding to release 5 | 261d? | 2003-03-03 A | 2004-03-01 A | 100% | 2003-03-03 | 2004-03-01 | 261d? | finish no earlier than 2004-03-01 |  | T1 | 2088h | 2088h | Rel-5 | Ingbert | TP-23 | RANimp-test,TEI5 | 34.108; 34.121; 34.122 | RANimp-test, TEI5 |  |  |  |
| 8598 | 80 | UTRAN Sharing in Connected Mode | 197d | 2001-12-03 A | 2002-09-03 A | 100% | 2001-12-03 | 2002-09-03 | 197d | finish no earlier than 2002-09-06 |  | R3 | 1576h | 1576h | Rel-5 | Juha |  | NETSHARE |  | NETSHARE | Ericsson | Martin Israelsson |  |
| 8599 | 81 | **Provisioning of IP-based multimedia services** | 2614.88d | 2000-01-03 A | 2006-12-01 A | 100% | 2000-01-03 | 2006-12-01 | 1806d |  |  | S1; S2; S3; S5; NP; T3; T1; R5 | 325092h | 325092h | Rel-5 | Alain |  | IMS |  | IMS | Openwave | Mark Cataldo |  |
| 8600 | 81.1 | **Call control and roaming to support IMS in UMTS** | 2614.88d | 2000-01-03 A | 2006-12-01 A | 100% | 2000-01-03 | 2006-12-01 | 1806d |  |  | S2; R5 | 109760h | 109760h | Rel-5 | Maurice |  | IMS-CCR |  | IMS-CCR | Lucent | Liz Daniel |  |
| 8601 | 81.1.1 | Stage 1 for Call control and roaming to support IMS in UMTS | 215d | 2000-02-21 A | 2000-12-15 A | 100% | 2000-02-21 | 2000-12-15 | 215d | finish no earlier than 2000-09-21 |  | S1 | 1720h | 1720h | Rel-5 | Alain |  |  | 22.228 |  | Motorola | Mark Cataldo |  |
| 8602 | 81.1.2 | Stage 2 (Architecture and Main flows) | 246d | 2000-04-14 A | 2001-03-23 A | 100% | 2000-04-14 | 2001-03-23 | 246d | finish no earlier than 2001-03-23 |  | S2 | 1968h | 1968h | Rel-5 | Maurice |  |  | 23.228 |  | Lucent | Liz Daniel |  |
| 8603 | 81.1.3 | Impact on MM/CC/SM | 400d | 2000-08-28 A | 2002-03-08 A | 100% | 2000-08-28 | 2002-03-08 | 400d | finish no earlier than 2002-03-08 |  | N1 | 3200h | 3200h | Rel-5 | Frederic |  | IMS-CCR-IWMM |  | IMS-CCR-IWMM | Lucent | Keith Drage (drage@alcatel-lucent.com) |  |
| 8604 | 81.1.4 | **SIP Call Control protocol for the IMS** | 556d | 2000-10-02 A | 2002-03-22 A | 100% | 2000-10-02 | 2002-03-22 | 385d |  |  | N1 | 12320h | 12320h | Rel-5 | Frederic |  |  | 24.228; 24.229; 23.218 |  | Lucent | Keith Drage (drage@alcatel-lucent.com) |  |
| 8605 | 81.1.4.1 | IMS signalling flows | 385d | 2000-10-02 A | 2002-03-22 A | 100% | 2000-10-02 | 2002-03-22 | 385d | finish no earlier than 2002-03-22 |  | N1 | 3080h | 3080h | Rel-5 | Frederic |  |  | 24.228 |  |  |  |  |
| 8606 | 81.1.4.2 | IMS stage 3 | 385d | 2000-10-02 A | 2002-03-22 A | 100% | 2000-10-02 | 2002-03-22 | 385d | finish no earlier than 2002-03-22 |  | N1 | 3080h | 3080h | Rel-5 | Frederic |  |  | 24.229 |  |  |  |  |
| 8607 | 81.1.4.3 | IMS Session Handling; stage 2 | 385d | 2000-10-02 A | 2002-03-22 A | 100% | 2000-10-02 | 2002-03-22 | 385d | finish no earlier than 2002-03-22 |  | N1 | 3080h | 3080h | Rel-5 | Frederic |  |  | 23.218 |  |  |  |  |
| 8608 | 16.5.1 | Conformance Test Aspects – IMS Call Control | 451d | 2005-03-11 A | 2006-12-01 A | 100% | 2005-03-11 | 2006-12-01 | 451d |  | 2006-06-02 | R5 | 3608h | 3608h | Rel-5 | Ingbert |  | IMS-CCR_Test | 34.108; 34.229-1; 34.229-2; 34.229-3 | IMS-CCR_Test | Motorola | Jacob.John@motorola.com | Fri 11/03/05 |
| 8609 | 81.1.4.4 | **Main IETF dependencies** | 925.62d | 2000-01-03 A | 2002-06-14 A | 100% | 2000-01-03 | 2002-06-14 | 641d |  |  | NP | 58048h | 58048h | Rel-5 | Kimmo |  |  |  |  | Lucent |  |  |
| 8610 | 81.1.4.4.1 | IETF: RFC 3261 (Session Initiation Protocol) | 346d | 2000-11-24 A | 2002-03-22 A | 100% | 2000-11-24 | 2002-03-22 | 346d | finish no earlier than 2002-03-22 |  | N1 | 2768h | 2768h | Rel-5 | Frederic |  |  |  |  | Lucent |  |  |
| 8611 | 81.1.4.4.2 | IETF: RFC 3262 (Reliability of provisional responses) | 346d | 2000-11-24 A | 2002-03-22 A | 100% | 2000-11-24 | 2002-03-22 | 346d | finish no earlier than 2002-03-22 |  | N1 | 2768h | 2768h | Rel-5 | Frederic |  |  |  |  | Lucent |  |  |
| 8612 | 81.1.4.4.3 | IETF: RFC 3312 (Without COMET)(Integration of resource management and SIP) | 382d | 2000-11-24 A | 2002-05-13 A | 100% | 2000-11-24 | 2002-05-13 | 382d | finish no earlier than 2002-05-13 |  | N1 | 3056h | 3056h | Rel-5 | Frederic |  |  |  |  | Lucent |  |  |
| 8613 | 81.1.4.4.4 | IETF: RFC 3323 (SIP extensions for caller identity and privacy) | 382d | 2000-11-24 A | 2002-05-13 A | 100% | 2000-11-24 | 2002-05-13 | 382d | finish no earlier than 2002-05-13 |  | N1 | 3056h | 3056h | Rel-5 | Frederic |  |  |  |  | Lucent |  |  |
| 8614 | 81.1.4.4.5 | IETF: RFC 3313 (SIP extensions for media authorization) | 382d | 2000-11-24 A | 2002-05-13 A | 100% | 2000-11-24 | 2002-05-13 | 382d | finish no earlier than 2002-05-13 |  | N1 | 3056h | 3056h | Rel-5 | Frederic |  |  |  |  | Lucent |  |  |
| 8615 | 81.1.4.4.6 | IETF: RFC 3265 (specific event notification) | 346d | 2000-11-24 A | 2002-03-22 A | 100% | 2000-11-24 | 2002-03-22 | 346d | finish no earlier than 2002-03-22 |  | N1 | 2768h | 2768h | Rel-5 | Frederic |  |  |  |  | Lucent |  |  |
| 8616 | 81.1.4.4.7 | IETF: RFC editor Queue (refer method) | 401d | 2000-11-24 A | 2002-06-07 A | 100% | 2000-11-24 | 2002-06-07 | 401d | finish no earlier than 2002-06-07 |  | N1 | 3208h | 3208h | Rel-5 | Frederic |  |  |  |  | Lucent |  |  |
| 8617 | 81.1.4.4.8 | IETF: RFC editor Queue (DHCP options for SIP servers) | 382d | 2000-11-24 A | 2002-05-13 A | 100% | 2000-11-24 | 2002-05-13 | 382d | finish no earlier than 2002-05-13 |  | N1 | 3056h | 3056h | Rel-5 | Frederic |  |  |  |  | Lucent |  |  |
| 8618 | 81.1.4.4.10 | IETF: RFC 3267 (AMR and AMR WB RTP and SDP) | 346d | 2000-11-24 A | 2002-03-22 A | 100% | 2000-11-24 | 2002-03-22 | 346d | finish no earlier than 2002-03-22 |  | N1 | 2768h | 2768h | Rel-5 | Frederic |  |  |  |  | Lucent |  |  |
| 8619 | 81.1.4.4.11 | IETF: RFC 3266 (IPv6 support within SDP) | 581d | 2000-01-03 A | 2002-03-22 A | 100% | 2000-01-03 | 2002-03-22 | 581d | finish no earlier than 2002-03-22 |  | N1 | 4640h | 4640h | Rel-5 | Frederic |  |  |  |  | Lucent |  |  |
| 8620 | 81.1.4.4.12 | IETF: RFC 3311 (The Update method) | 382d | 2000-11-24 A | 2002-05-13 A | 100% | 2000-11-24 | 2002-05-13 | 382d | finish no earlier than 2002-05-13 |  | N1 | 3056h | 3056h | Rel-5 | Frederic |  |  |  |  | Lucent |  |  |
| 8621 | 81.1.4.4.13 | IETF: RFC 3324 (Network Asserted Identity) | 382d | 2000-11-24 A | 2002-05-13 A | 100% | 2000-11-24 | 2002-05-13 | 382d | finish no earlier than 2002-05-13 |  | N1 | 3056h | 3056h | Rel-5 | Frederic |  |  |  |  | Lucent |  |  |
| 8622 | 81.1.4.4.14 | IETF: RFC editor Queue (Various 3GPP Private Extensions) | 382d | 2000-11-24 A | 2002-05-13 A | 100% | 2000-11-24 | 2002-05-13 | 382d | finish no earlier than 2002-05-13 |  | N1 | 3056h | 3056h | Rel-5 | Frederic |  |  |  |  | Lucent |  |  |

Notes:
- 8595: Marked as stopped 12/2008
- 8596: Marked as stopped 12/2008
- 8597: Marked as stopped 12/2008
- 8598: Formerly 'Shared Network support in connected mode', renamed at RAN #16.
- 8599: -
- 8600: -
- 8601: Issues include e.g.: Roaming requirements, Requirements on supplementary services, Interworking requirements
- 8602: Issues include e.g.: Mobile IP, RAB selection principles, Optimized VoIP bearer mechanisms, SIP multimedia protocol
- 8603: Per 26/2-02: This is understood to be the PCO & TFT CRs which CN1 provides to TSGN #15 for approval. If this is correct understanding, then the task is 100 % complete.
- 8604: TSGN_10 approved the change:CN1 - SA2 SIP joint meeting spotted one more place for improvement: work tasks with ID 1998 and 1278 are actually subtasks under of single CN1 WT. One WI has been approved for the CN1 WT with title "SIP Call Control protocol
- 8605: 24.228
- 8606: 24.229
- 8607: 23.218
- 8608: -
- 8609: -
- 8610: -
- 8611: -
- 8612: -
- 8613: -
- 8614: -
- 8615: -
- 8616: -
- 8617: -
- 8618: -
- 8619: -
- 8620: -
- 8621: -
- 8622: -

| ID | WBS | Task | Duration | Start | Finish | Complete | Baseline start | Baseline finish | Baseline duration | Constraint | Resources | Work | Actual work | Release | MCC resp | Acronym | Impacted TSs and TRs | WI rapporteur name | WI rapporteur e-mail | Acronym_3GU_Export | TSG stopped |
| --- | --- | --- | --- | --- | --- | --- | --- | --- | --- | --- | --- | --- | --- | --- | --- | --- | --- | --- | --- | --- | --- |
| 8623 | 81.1.4.5 | **Addressing** | 548.75d | 2000-10-09 A | 2002-03-22 A | 100% | 2000-10-09 | 2002-03-22 | 380d |  | S2 | 7744h | 7744h | Rel-5 | Maurice |  |  |  |  |  |  |
| 8624 | 81.1.4.5.1 | Architectural issues | 235d | 2000-10-09 A | 2001-08-31 A | 100% | 2000-10-09 | 2001-08-31 | 235d | finish no earlier than 2001-03-16 | S2 | 1880h | 1880h | Rel-5 | Maurice |  |  |  |  |  |  |
| 8625 | 81.1.4.5.2 | Impact on HSS | 353d | 2000-11-15 A | 2002-03-22 A | 100% | 2000-11-15 | 2002-03-22 | 353d | finish no earlier than 2002-03-22 | N4 | 2824h | 2824h | Rel-5 | Kimmo |  |  |  |  |  |  |
| 8626 | 81.1.4.6 | **Service Examples (Work stopped)** | 439d | 2001-04-17 A | 2002-06-14 A | 100% | 2001-04-17 | 2002-06-14 | 304d |  | S1 | 4864h | 4864h | Rel-5 | Alain | IMS-Sex | 22.928 | Motorola | Mark Cataldo | IMS-Sex |  |
| 8627 | 81.1.4.6.1 | IMS Framework Report (work stopped) | 304d | 2001-04-17 A | 2002-06-14 A | 100% | 2001-04-17 | 2002-06-14 | 304d | finish no earlier than 2002-06-14 | S1 | 2432h | 2432h | Rel-5 | Alain | IMS-FrWk | 22.941 | SBC | Randolph Wohlert (rwohlert@tri.sbc.com) | IMS-FrWk |  |
| 8628 | 81.2 | **Access Security for IMS** | 273.25d | 2001-10-08 A | 2002-06-28 A | 100% | 2001-10-08 | 2002-06-28 | 190d |  | S3; T3 | 5640h | 5640h | Rel-5 | Mirko | IMS-ASEC |  | Ericsson | krister.boman@emw.ericsson.se | IMS-ASEC |  |
| 8629 | 81.2.2 | IMS impacts on UICC (ISIM application) | 185d | 2001-10-08 A | 2002-06-21 A | 100% | 2001-10-08 | 2002-06-21 | 185d | finish no earlier than 2002-06-21 | T3 | 1480h | 1480h | Rel-5 | Xavier |  | 33.102; New 31.103 | Vodafone | Jeremy Norris |  |  |
| 8630 | 81.2.3 | Deleted - SIP extensions for Integrity protection | 140d | 2001-12-17 A | 2002-06-28 A | 100% | 2001-12-17 | 2002-06-28 | 140d | finish no earlier than 2002-06-28 | N1 | 1120h | 1120h | Rel-5 | Frederic |  |  |  |  |  | SP-69 |
| 8631 | 81.3 | Security Aspects of Requirement for Network Configuration Independence | 130d | 2001-07-02 A | 2001-12-28 A | 100% | 2001-07-02 | 2001-12-28 | 130d | finish no earlier than 2001-12-28 | S3 | 1040h | 1040h | Rel-5 | Mirko | SEC1-NCI | 33.203 | AT&T Wireless | hugh.shieh@attws.com | SEC1-NCI |  |
| 8632 | 81.4 | IMS Lawful Interception | 410d | 2000-09-04 A | 2002-03-29 A | 100% | 2000-09-04 | 2002-03-29 | 410d | finish no earlier than 2002-03-29 | S3 | 3280h | 3280h | Rel-5 | Mirko | IMS-LI | 33.106; 33.107; New 33.108 | Reg TP | berthold.wilhelm@regtp.de | IMS-LI |  |
| 8633 | 81.5 | Charging and OAM&P for IMS | 554d | 2000-12-25 A | 2002-06-12 A | 100% | 2000-12-25 | 2002-06-12 | 383d | finish no earlier than 2002-06-12 | S5 | 3064h | 3064h | Rel-5 | Mirko | IMS-OAM | 32-series |  |  | IMS-OAM |  |
| 8634 | 81.6 | **Multimedia codecs and protocols for conversational PS services** | 822.25d | 2000-07-26 A | 2002-09-27 A | 100% | 2000-07-26 | 2002-09-27 | 568d |  | S4 | 15640h | 15640h | Rel-5 | Paolo | IMS-CODEC | 26.235; 26.236 | Toshiba, Nokia | B. Aronson (Toshiba), pasi.s.ojala@nokia.com | IMS-CODEC |  |
| 8635 | 81.6.1 | Codecs | 427d | 2000-07-26 A | 2002-03-14 A | 100% | 2000-07-26 | 2002-03-14 | 427d | finish no earlier than 2001-03-21 | S4 | 3416h | 3416h | Rel-5 | Paolo |  | 26.235; 26.236 |  |  |  |  |
| 8636 | 81.6.2 | Transport protocols | 1d | 2002-03-12 A | 2002-03-12 A | 100% | 2002-03-12 | 2002-03-12 | 1d | finish no earlier than 2002-03-12 | S4 | 8h | 8h | Rel-5 | Paolo |  | 26.236 | Nokia | P. Ojala |  |  |
| 8637 | 81.6.4 | recommendation for QoS parameter values for various media types | 195d | 2001-12-31 A | 2002-09-27 A | 100% | 2001-12-31 | 2002-09-27 | 195d | finish no earlier than 2002-09-27 | S4 | 1560h | 1560h | Rel-5 | Paolo |  |  |  |  |  |  |
| 8638 | 81.6.5 | IETF: RFC 3310 (HTTP Digest Authentication using AKA) | 382d | 2000-11-24 A | 2002-05-13 A | 100% | 2000-11-24 | 2002-05-13 | 382d | finish no earlier than 2002-05-13 | N1 | 3056h | 3056h | Rel-5 | Frederic |  |  |  |  |  |  |
| 8639 | 81.6.6 | IETF: RFC 3329 (Security mechanism agreement for SIP connections) | 382d | 2000-11-24 A | 2002-05-13 A | 100% | 2000-11-24 | 2002-05-13 | 382d | finish no earlier than 2002-05-13 | N1 | 3056h | 3056h | Rel-5 | Frederic |  |  |  |  |  |  |
| 8640 | 81.7 | **SIP message compression** | 266d | 2001-09-24 A | 2002-06-07 A | 100% | 2001-09-24 | 2002-06-07 | 185d |  | S2 | 3128h | 3128h | Rel-5 | Maurice |  |  |  |  |  |  |
| 8641 | 81.7.1 | Stage 2 for SIP message compression | 25d | 2001-09-24 A | 2001-10-26 A | 100% | 2001-09-24 | 2001-10-26 | 25d | finish no earlier than 2001-10-26 | S2 | 200h | 200h | Rel-5 | Maurice |  |  |  |  |  |  |
| 8642 | 81.7.2 | Compression signalling | 181d | 2001-09-28 A | 2002-06-07 A | 100% | 2001-09-28 | 2002-06-07 | 181d | finish no earlier than 2002-06-07 | N1 | 1448h | 1448h | Rel-5 | Frederic |  |  |  |  |  |  |
| 8643 | 81.8 | **Stage 3 description of IMS interfaces** | 554d | 2001-03-14 A | 2002-08-30 A | 100% | 2001-03-14 | 2002-08-30 | 383d |  | NP | 29531.6h | 29531.6h | Rel-5 | Kimmo |  |  |  |  |  |  |
| 8644 | 81.8.1 | Cx interface (HSS to CSCF) | 135.95d | 2001-03-14 A | 2002-06-07 A | 100% | 2001-03-14 | 2002-06-07 | 135.95d | finish no earlier than 2002-06-07 | N4 | 1087.58h | 1087.58h | Rel-5 | Kimmo |  |  |  |  |  |  |
| 8645 | 81.8.2 | Mp interface (MRFC - MRFP) enhancements | 258d | 2001-03-14 A | 2002-03-08 A | 100% | 2001-03-14 | 2002-03-08 | 258d | finish no earlier than 2002-06-07 | N4 | 2064h | 2064h | Rel-5 | Kimmo |  |  |  |  |  |  |
| 8646 | 81.8.3 | Mw interface (CSCF to P-CSCF) | 323d | 2001-03-14 A | 2002-06-07 A | 100% | 2001-03-14 | 2002-06-07 | 323d | finish no earlier than 2002-06-07 | N1 | 2584h | 2584h | Rel-5 | Frederic |  |  |  |  |  |  |
| 8647 | 81.8.4 | Mr interface (CSCF to MRF) | 273d | 2001-03-14 A | 2002-03-29 A | 100% | 2001-03-14 | 2002-03-29 | 273d | finish no earlier than 2002-03-29 | N1 | 2184h | 2184h | Rel-5 | Frederic |  |  |  |  |  |  |
| 8648 | 81.8.5 | Dx interface (I-CSCF to SLF) | 323d | 2001-03-14 A | 2002-06-07 A | 100% | 2001-03-14 | 2002-06-07 | 323d | finish no earlier than 2002-06-07 | N4 | 2584h | 2584h | Rel-5 | Kimmo |  |  |  |  |  |  |
| 8649 | 81.8.6 | Go interface (GGSN to PCF) | 323d | 2001-03-14 A | 2002-06-07 A | 100% | 2001-03-14 | 2002-06-07 | 323d | finish no earlier than 2002-06-07 | N3 | 2584h | 2584h | Rel-5 | Gwiho |  |  |  |  |  |  |
| 8650 | 81.8.7 | ISC (IMS Service Control) Interface | 323d | 2001-03-14 A | 2002-06-07 A | 100% | 2001-03-14 | 2002-06-07 | 323d | finish no earlier than 2002-06-07 | N1 | 2584h | 2584h | Rel-5 | Frederic |  |  |  |  |  |  |
| 8651 | 81.8.8 | Sh interface (HSS to AS) | 82d | 2002-02-14 A | 2002-06-07 A | 100% | 2002-02-14 | 2002-06-07 | 82d | finish no earlier than 2002-06-07 | N4 | 656h | 656h | Rel-5 | Kimmo |  |  |  |  |  |  |
| 8652 | 81.8.9 | Si interface (HSS to IM-SSF) | 162.5d | 2002-01-16 A | 2002-08-30 A | 100% | 2002-01-16 | 2002-08-30 | 162.5d | finish no earlier than 2002-06-07 | N4 | 1300h | 1300h | Rel-5 | Kimmo |  |  |  |  |  |  |
| 8653 | 81.8.10 | Gm interface (UE to CSCF) | 323d | 2001-03-14 A | 2002-06-07 A | 100% | 2001-03-14 | 2002-06-07 | 323d | finish no earlier than 2002-06-07 | N1 | 2584h | 2584h | Rel-5 | Frederic |  |  |  |  |  |  |
| 8654 | 81.8.11 | Mi interface (CSCF to BGCF) | 323d | 2001-03-14 A | 2002-06-07 A | 100% | 2001-03-14 | 2002-06-07 | 323d | finish no earlier than 2002-06-07 | N1 | 2584h | 2584h | Rel-5 | Frederic |  |  |  |  |  |  |
| 8655 | 81.8.12 | Mj interface (BGCF to MGCF) | 323d | 2001-03-14 A | 2002-06-07 A | 100% | 2001-03-14 | 2002-06-07 | 323d | finish no earlier than 2002-06-07 | N1 | 2584h | 2584h | Rel-5 | Frederic |  |  |  |  |  |  |
| 8656 | 81.8.13 | Mk interface (BGCF to BGCF) | 323d | 2001-03-14 A | 2002-06-07 A | 100% | 2001-03-14 | 2002-06-07 | 323d | finish no earlier than 2002-06-07 | N1 | 2584h | 2584h | Rel-5 | Frederic |  |  |  |  |  |  |
| 8657 | 81.9 | Support of VHE/OSA by entities and protocols of the IMS (e.g. CSCF) | 186d | 2001-09-21 A | 2002-06-07 A | 100% | 2001-09-21 | 2002-06-07 | 186d | finish no earlier than 2002-06-07 | N5 | 1488h | 1488h | Rel-5 | Kimmo | IMS-ONOSA | 29.198; 29.998 | Ericsson | Ard.Jan.Moerdijk@eln.ericsson.se | IMS-ONOSA |  |

Notes:
- 8623: -
- 8624: -
- 8625: Covered by 29.228 & 29228
- 8626: -
- 8627: -
- 8628: -
- 8629: -
- 8630: CN1 is not aware of any requirements and is not doing anything on this task
- 8631: Consider security aspects in SA2 TS 23.228 clause 4.4 & annex C
- 8632: SP#17 completed
- 8633: -
- 8634: -
- 8635: -
- 8636: -
- 8637: -
- 8638: -
- 8639: -
- 8640: -
- 8641: -
- 8642: -
- 8643: -
- 8644: -
- 8645: [DAB 08-03-02] - No work required in CN4
- 8646: -
- 8647: -
- 8648: CN4#11 30/11/01: No inputs received in CN4
- 8649: [DAB - 23/05/03] - 100 % complete
- 8650: -
- 8651: CN4#11 30/11/01: No inputs received in CN4
- 8652: SA16: Part of Rel5 only if completed in September 02. Marked as closed 12/2008 (was marked 72% complete)
- 8653: -
- 8654: -
- 8655: -
- 8656: -
- 8657: -

| ID | WBS | Task | Duration | Start | Finish | Predecessors | Complete | Baseline start | Baseline finish | Baseline duration | Constraint | Resources | Work | Actual work | Acronym | WI rapporteur name | WI rapporteur e-mail | Release | MCC resp | Acronym_3GU_Export | TSG stopped | Impacted TSs and TRs | PCG approved | TSG approved |
| --- | --- | --- | --- | --- | --- | --- | --- | --- | --- | --- | --- | --- | --- | --- | --- | --- | --- | --- | --- | --- | --- | --- | --- | --- |
| 8658 | 81.10 | **CAMEL control of IMS services** | 527d | 2001-04-16 A | 2002-09-06 A |  | 100% | 2001-04-16 | 2002-09-06 | 365d |  | N2 | 9952h | 9952h | IMS-CAMEL | Lucent | Angelica Remoquillo | Rel-5 | Kimmo | IMS-CAMEL |  |  |  |  |
| 8659 | 81.10.1 | Stage2 work 'general' | 365d | 2001-04-16 A | 2002-09-06 A |  | 100% | 2001-04-16 | 2002-09-06 | 365d | finish no earlier than 2002-09-06 | N2 | 2920h | 2920h |  |  |  | Rel-5 | Kimmo |  |  |  |  |  |
| 8660 | 81.10.2 | Stage3 work 'CAP' | 175d | 2002-01-07 A | 2002-09-06 A |  | 100% | 2002-01-07 | 2002-09-06 | 175d | finish no earlier than 2002-09-06 | N2 | 1400h | 1400h |  |  |  | Rel-5 | Kimmo |  |  |  |  |  |
| 8661 | 81.10.3 | Stage2 work 'Si interface' | 175d | 2002-01-07 A | 2002-09-06 A |  | 100% | 2002-01-07 | 2002-09-06 | 175d | finish no earlier than 2002-09-06 | N2 | 1400h | 1400h |  |  |  | Rel-5 | Kimmo |  |  |  |  |  |
| 8662 | 81.10.4 | Stage3 work 'Si interface' | 82d | 2002-02-14 A | 2002-06-07 A |  | 100% | 2002-02-14 | 2002-06-07 | 82d | finish no earlier than 2002-06-07 | N4 | 656h | 656h |  |  |  | Rel-5 | Kimmo |  |  |  |  |  |
| 8663 | 81.10.5 | Deleted - SDM issues for CAMEL control of IMS | 82d | 2002-02-14 A | 2002-06-07 A |  | 100% | 2002-02-14 | 2002-06-07 | 82d | finish no earlier than 2002-06-07 | N4 | 656h | 656h |  |  |  | Rel-5 | Kimmo |  | NP-17 |  |  |  |
| 8664 | 81.11 | Pre-pay/real-time charging in IMS | 196d | 2001-06-15 A | 2002-03-15 A |  | 100% | 2001-06-15 | 2002-03-15 | 196d | finish no earlier than 2002-03-15 | S1 | 1568h | 1568h |  |  |  | Rel-5 | Alain |  |  |  |  |  |
| 8665 | 81.12 | **IMS Charging** | 417.25d | 2001-08-06 A | 2002-09-12 A |  | 100% | 2001-08-06 | 2002-09-12 | 289d |  | S2; S5 | 8944h | 8944h | OAM-CH | T-Mobile | karl-heinz.nenner@t-mobile.de | Rel-5 | Mirko | OAM-CH |  | 32.225 |  |  |
| 8666 | 81.12.1 | Charging Implications of IMS architecture | 75d | 2001-08-06 A | 2001-11-16 A |  | 100% | 2001-08-06 | 2001-11-16 | 75d | finish no earlier than 2001-11-16 | S2 | 600h | 600h |  |  |  | Rel-5 | Maurice |  |  |  |  |  |
| 8667 | 81.12.2 | Charging management for IMS (off-line & on-line) | 214d | 2001-11-19 A | 2002-09-12 A | 8666 | 100% | 2001-11-19 | 2002-09-12 | 214d | finish no earlier than 2002-09-12 | S5 | 1712h | 1712h |  |  |  | Rel-5 | Mirko |  |  | 32.225 |  |  |
| 8668 | 86.1.6.10 | Billing, accounting and call detail record aspects | 251d | 2001-09-27 A | 2002-09-12 A |  | 100% | 2001-09-27 | 2002-09-12 | 251d | finish no earlier than 2002-09-12 | S5 | 2008h | 2008h |  | T-Mobile | Karl-Heinz.Nenner@T-MOBILE.DE | Rel-5 | Mirko |  |  | 32.225 |  |  |
| 8669 | 81.13 | **Other IETF dependencies** | 581d | 2000-11-24 A | 2002-06-07 A |  | 100% | 2000-11-24 | 2002-06-07 | 401d |  | NP | 9624h | 9624h |  |  |  | Rel-5 |  |  |  |  |  |  |
| 8670 | 81.13.1 | IETF: draft-ietf-aaa-diameter - should be CN4 | 401d | 2000-11-24 A | 2002-06-07 A |  | 100% | 2000-11-24 | 2002-06-07 | 401d | finish no earlier than 2002-06-07 | NP | 3208h | 3208h |  |  |  | Rel-5 |  |  |  |  |  |  |
| 8671 | 81.13.2 | IETF: draft-johansson-aaa-diameter-mm-app - should be CN4 | 401d | 2000-11-24 A | 2002-06-07 A |  | 100% | 2000-11-24 | 2002-06-07 | 401d | finish no earlier than 2002-06-07 | NP | 3208h | 3208h |  |  |  | Rel-5 |  |  |  |  |  |  |
| 8672 | 81.15 | Conformance Test Aspects - Provisioning of IMS | 205d | 2002-03-18 A | 2002-12-27 A |  | 100% | 2002-03-18 | 2002-12-27 | 205d | finish no earlier than 2002-12-27 | T1 | 1640h | 1640h | IMS-TEST |  |  | Rel-5 | Ingbert | IMS-TEST |  |  |  |  |
| 8673 | 81.16 | Testing of support for IMS - prose | 270d | 2002-09-18 A | 2003-09-30 A |  | 100% | 2002-09-18 | 2003-09-30 | 270d | finish no earlier than 2003-09-30 | T1 | 2160h | 2160h |  | Anritsu | dan.fox@eu.anritsu.com | Rel-5 | Ingbert |  |  | 34.108; 34.123 |  |  |
| 8674 | 81.17 | Testing of support for IMS - TTCN | 381d | 2002-09-18 A | 2004-03-03 A |  | 100% | 2002-09-18 | 2004-03-03 | 381d | finish no earlier than 2004-03-03 | T1 | 3048h | 3048h |  | Anritsu | dan.fox@eu.anritsu.com | Rel-5 | Ingbert |  |  | 34.108; 34.123 |  |  |
| 8675 | 2736 | UE Conformance Test Aspects – IMS for Converged IP Communications | 263d? | 2016-12-14 A | 2017-12-15 A |  | 100% |  |  |  | finish no earlier than 2017-12-15 | R5 | 2104h | 2104h | IMS_CONV_IP_COM-UEConTest | Rohnert, Hans | Hans.Rohnert.ext@rohde-schwarz.com | Rel-5 |  |  |  | 34.229-1; 34.229-2; 34.229-3 | 38 | 74 |
| 8676 | 82 | **Extended Transparent End-to-End PS Streaming Service** | 454.75d? | 2002-01-03 A | 2003-03-17 A |  | 100% | 2002-01-03 | 2003-03-17 | 313d? |  | S4 | 6224h | 6224h | PSS-E | Ericsson | olle.franceschi@ericsson.com | Rel-5 | Paolo | PSS-E |  | 26.233; 26.234 |  |  |
| 8677 | 82.1 | **Stage 1 for Extended Transparent End-to-End PS Streaming Service** | 124.25d? | 2002-11-18 A | 2003-03-17 A |  | 100% | 2002-11-18 | 2003-03-17 | 86d? |  | S1 | 1376h | 1376h |  | Vodafone | stephen.wolak@vodafone.com | Rel-5 | Alain |  |  | 22.233 |  |  |
| 8678 | 2737.1.1 | Interaction with other services | 86d? | 2002-11-18 A | 2003-03-17 A |  | 100% | 2002-11-18 | 2003-03-17 | 86d? | finish no earlier than 2003-03-17 | S1 | 688h | 688h |  | Vodafone | stephen.wolak@vodafone.com | Rel-5 | Alain |  |  | 22.233 |  |  |
| 8679 | 82.2 | Stage 2 (version Rel-5 of TS 26.234) | 51d | 2002-01-03 A | 2002-03-14 A |  | 100% | 2002-01-03 | 2002-03-14 | 51d | finish no earlier than 2002-03-26 | S4 | 408h | 408h |  |  |  | Rel-5 | Paolo |  |  | 26.234 |  |  |
| 8680 | 82.3 | RTP usage model | 242d | 2002-01-03 A | 2002-12-06 A |  | 100% | 2002-01-03 | 2002-12-06 | 242d | finish no earlier than 2002-12-06 | S4 | 1936h | 1936h |  |  |  | Rel-5 | Paolo |  |  | 26.937 |  |  |
| 8681 | 83 | **Rel-5 Open Service Access (OSA) enhancements** | 1381.38d | 1999-04-27 A | 2002-12-20 A |  | 100% | 1999-04-27 | 2002-12-20 | 955d |  | S1; S3 | 72648h | 72648h | OSA1 | Siemens | joerg.swetina@neclab.eu | Rel-5 | Alain | OSA1 |  | 22.127; 23.127; 29.198-x; 29.998-x |  |  |
| 8682 | 83.1 | General Stage 2 for Rel-5 | 279.5d | 2001-09-11 A | 2002-06-07 A |  | 100% | 2001-09-11 | 2002-06-07 | 194d |  | S2 | 1232h | 1232h |  |  |  | Rel-5 | Maurice |  |  |  |  |  |

Notes:
- 8658: -
- 8659: DAB 12.12.01 split into cn4 and cn2 parts
- 8660: DAB 12.12.01 split into cn4 and cn2 parts
- 8661: DAB 12.12.01 split into cn4 and cn2 parts
- 8662: [DAB 08-03-02] - UID 12004 is MASTER of UID 14998
- 8663: Marked as stopped 12/2008
- 8664: Marked as closed 12/2008 (was marked 60% complete)
- 8665: -
- 8666: -
- 8667: -
- 8668: -
- 8669: Was introduced at SP#13 by Ileana Leuca (exact position in the WP and related WG have to be defined)
- 8670: Marked as closed 12/2008 (was marked 90% complete)
- 8671: Marked as closed 12/2008 (was marked 50% complete)
- 8672: The task is a BB, individual work items were considered but are constrained by lack of supporting companies. Marked as stopped 12/2008
- 8673: Marked as stopped 12/2008
- 8674: Marked as stopped 12/2008
- 8675: UID: 740999->740068¦Rel-14->Rel-519/9/17: Compl:0%->75%¦ 8/1/18: Compl:75%->100%
- 8676: -
- 8677: 2nd resp SA4
- 8678: 2nd resp SA4. Marked as closed 12/2008 (was marked 65% complete)
- 8679: 2nd resp SA2
- 8680: Marked as closed 12/2008 (was marked 90% complete)
- 8681: -
- 8682: Marked as closed 12/2008 (was marked 47% complete)

| ID | WBS | Task | Duration | Start | Finish | Predecessors | Complete | Baseline start | Baseline finish | Baseline duration | Constraint | Resources | Work | Actual work | Acronym | Release | MCC resp | Acronym_3GU_Export | Impacted TSs and TRs | WI rapporteur name | WI rapporteur e-mail |
| --- | --- | --- | --- | --- | --- | --- | --- | --- | --- | --- | --- | --- | --- | --- | --- | --- | --- | --- | --- | --- | --- |
| 8683 | 83.2 | **OSA APIs for Multimedia Call Control** | 721.75d | 2000-07-11 A | 2002-06-07 A |  | 100% | 2000-07-11 | 2002-06-07 | 499d |  | S2 | 5960h | 5960h | OSA1-CSCF | Rel-5 | Maurice | OSA1-CSCF |  |  |  |
| 8684 | 83.2.1 | Stage 1 for OSA APIs for Multimedia Call Control | 438d | 2000-07-11 A | 2002-03-14 A |  | 100% | 2000-07-11 | 2002-03-14 | 438d | finish no earlier than 2002-03-14 | S1 | 3504h | 3504h |  | Rel-5 | Alain |  | 22.127 | Siemens | Manfred.leitgeb@siemens.at |
| 8685 | 83.2.2 | Stages 2 and 3 for Multimedia Call Control | 194d | 2001-09-11 A | 2002-06-07 A |  | 100% | 2001-09-11 | 2002-06-07 | 194d | finish no earlier than 2002-06-07 | N5 | 1552h | 1552h |  | Rel-5 | Kimmo |  | 29.198-04 |  |  |
| 8686 | 83.3 | Generic user interaction - Stage 3 | 194d | 2001-09-11 A | 2002-06-07 A |  | 100% | 2001-09-11 | 2002-06-07 | 194d | finish no earlier than 2002-06-07 | N5 | 1552h | 1552h |  | Rel-5 | Kimmo |  | 29.198-05 |  |  |
| 8687 | 83.4 | OSA Charging - Stage 3 | 194d | 2001-09-11 A | 2002-06-07 A |  | 100% | 2001-09-11 | 2002-06-07 | 194d | finish no earlier than 2002-06-07 | N5 | 1552h | 1552h |  | Rel-5 | Kimmo |  | 29.198-12 |  |  |
| 8688 | 83.5 | Call Control Service Mapping; Multiparty Call Control SIP - Stage 3 | 194d | 2001-09-11 A | 2002-06-07 A |  | 100% | 2001-09-11 | 2002-06-07 | 194d | finish no earlier than 2002-06-07 | N5 | 1552h | 1552h |  | Rel-5 | Kimmo |  | 29.998-04-4 |  |  |
| 8689 | 83.6 | WSDL APIs for SOAP/HTTP - Stage 3 | 455d | 2000-09-11 A | 2002-06-07 A |  | 100% | 2000-09-11 | 2002-06-07 | 455d | finish no earlier than 2002-06-07 | N5 | 3640h | 3640h |  | Rel-5 | Kimmo |  | 29.198; 29.998 |  |  |
| 8690 | 83.7 | **OSA Security** | 924.75d | 2000-07-11 A | 2002-12-20 A |  | 100% | 2000-07-11 | 2002-12-20 | 639d |  | S3 | 15000h | 15000h | OSA1-SEC | Rel-5 | Mirko | OSA1-SEC | 33.102 | Ericsson | colin.blanchard@bt.com |
| 8691 | 83.7.1 | Stage 1 for OSA Security | 349d | 2000-07-11 A | 2001-11-09 A |  | 100% | 2000-07-11 | 2001-11-09 | 349d | finish no earlier than 2001-11-09 | S1 | 2792h | 2792h |  | Rel-5 | Alain |  | 22.127 | Siemens | Manfred.leitgeb@siemens.at |
| 8692 | 83.7.2 | OSA Stage 3 | 430d | 2000-10-23 A | 2002-06-14 A |  | 100% | 2000-10-23 | 2002-06-14 | 430d | finish no earlier than 2002-06-14 | S3 | 3440h | 3440h |  | Rel-5 | Mirko |  | 33.102 | BT, Ericsson | colin.blanchard@bt.com |
| 8693 | 83.7.3 | security related SCF(s) definition | 186d | 2001-09-21 A | 2002-06-07 A |  | 100% | 2001-09-21 | 2002-06-07 | 186d | finish no earlier than 2002-06-07 | N5 | 1488h | 1488h |  | Rel-5 | Kimmo |  | 29.198; 29.998 | Ericsson | Ard.Jan.Moerdijk@eln.ericsson.se |
| 8694 | 83.7.4 | OSA changes required from supporting platforms, e.g. gsmSCF, HLR | 69d | 2000-09-11 A | 2000-12-14 A |  | 100% | 2000-09-11 | 2000-12-14 | 69d | finish no earlier than 2000-12-14 | S3 | 552h | 552h |  | Rel-5 | Mirko |  | 33.102 | BT, Ericsson | colin.blanchard@bt.com |
| 8695 | 2738.7.5 | OSA Security (moved from Rel-6) | 202d | 2002-03-14 A | 2002-12-20 A |  | 100% | 2002-03-14 | 2002-12-20 | 202d | finish no earlier than 2002-12-20 | S3 | 1616h | 1616h |  | Rel-5 | Mirko |  | 33.102 | BT, Ericsson | colin.blanchard@bt.com |
| 8696 | 83.8 | **Interactions OSA - e-commerce** | 1178.38d | 1999-04-27 A | 2002-06-07 A |  | 100% | 1999-04-27 | 2002-06-07 | 815d |  | S2 | 6152h | 6152h | OSA1-ECOM | Rel-5 | Maurice | OSA1-ECOM |  |  |  |
| 8697 | 83.8.1 | Stage 1 for Interactions OSA - e-commerce | 439d | 1999-04-27 A | 2000-12-28 A |  | 100% | 1999-04-27 | 2000-12-28 | 439d | finish no earlier than 2000-12-28 | S1 | 3504h | 3504h |  | Rel-5 | Alain |  | 22.127 | Siemens | joerg.swetina@neclab.eu |
| 8698 | 83.8.2 | Stages 2 and 3 for Interactions OSA - e-commerce | 186d | 2001-09-21 A | 2002-06-07 A |  | 100% | 2001-09-21 | 2002-06-07 | 186d | finish no earlier than 2002-06-07 | N5 | 1488h | 1488h |  | Rel-5 | Kimmo |  | 29.198; 29.998 | Ericsson | Ard.Jan.Moerdijk@eln.ericsson.se |
| 8699 | 83.9 | Policy Management - Stage 3 | 194d | 2001-09-11 A | 2002-06-07 A |  | 100% | 2001-09-11 | 2002-06-07 | 194d | finish no earlier than 2002-06-07 | N5 | 1552h | 1552h |  | Rel-5 | Kimmo |  | 29.198-13 |  |  |
| 8700 | 83.10 | Presence and Availability Management (PAM) - Stage 3 | 194d | 2001-09-11 A | 2002-06-07 A |  | 100% | 2001-09-11 | 2002-06-07 | 194d | finish no earlier than 2002-06-07 | N5 | 1552h | 1552h |  | Rel-5 | Kimmo |  | 29.198-14 |  |  |
| 8701 | 83.11 | **LCS - OSA interfaces** | 657.5d | 2000-09-11 A | 2002-06-07 A |  | 100% | 2000-09-11 | 2002-06-07 | 455d |  | S1 | 5656h | 5656h | OSA1-LCSI | Rel-5 | Alain | OSA1-LCSI |  | Siemens | joerg.swetina@neclab.eu |
| 8702 | 83.11.1 | Stage 1 for LCS - OSA interfaces | 65d | 2000-09-11 A | 2000-12-08 A |  | 100% | 2000-09-11 | 2000-12-08 | 65d | finish no earlier than 2000-12-08 | S1 | 520h | 520h |  | Rel-5 | Alain |  | 22.127 | Siemens | joerg.swetina@neclab.eu |
| 8703 | 83.11.2 | Stage 2 for LCS - OSA interfaces | 1d | 2000-12-11 A | 2000-12-11 A | 8702 | 100% | 2000-12-11 | 2000-12-11 | 1d | finish no earlier than 2000-12-11 | S2 | 8h | 8h |  | Rel-5 | Maurice |  | 23.127 | Ericsson | Christophe GOURRAUD |
| 8704 | 83.11.3 | Stage 3 for LCS - OSA interfaces | 186d | 2001-09-21 A | 2002-06-07 A | 8703 | 100% | 2001-09-21 | 2002-06-07 | 186d | finish no earlier than 2002-06-07 | N5 | 1488h | 1488h |  | Rel-5 | Kimmo |  | 29.198; 29.998 | Ericsson | Ard.Jan.Moerdijk@eln.ericsson.se |
| 8705 | 2738.12 | Access to User Profile | 145d | 2001-06-01 A | 2001-12-20 A |  | 100% | 2001-06-01 | 2001-12-20 | 145d | finish no earlier than 2001-12-20 | S1 | 1160h | 1160h | OSA2-UP | Rel-5 | Alain | OSA2-UP |  |  |  |
| 8706 | 2738.13 | **Retrieval of Terminal capabilities** | 917.5d | 2000-07-11 A | 2002-12-13 A |  | 100% | 2000-07-11 | 2002-12-13 | 634d |  | S2 | 10808h | 10808h | OSA2-TC | Rel-5 | Maurice | OSA2-TC |  |  |  |
| 8707 | 2738.13.1 | Stage 1 for Retrieval of Terminal capabilities | 132d | 2000-07-11 A | 2001-01-10 A |  | 100% | 2000-07-11 | 2001-01-10 | 132d | finish no earlier than 2001-01-10 | S1 | 1056h | 1056h |  | Rel-5 | Alain |  | 22.127 | Siemens | joerg.swetina@neclab.eu |
| 8708 | 2738.13.2 | Stages 2 and 3 for Retrieval of Terminal capabilities | 321d | 2001-09-21 A | 2002-12-13 A | 8707 | 100% | 2001-09-21 | 2002-12-13 | 321d | finish no earlier than 2002-12-13 | N5 | 2568h | 2568h |  | Rel-5 | Kimmo |  | 29.198; 29.998 | Ericsson | Ard.Jan.Moerdijk@eln.ericsson.se |
| 8709 | 2738.13.3 | Provisioning of the terminal capabilities | 445d | 2001-04-02 A | 2002-12-13 A |  | 100% | 2001-04-02 | 2002-12-13 | 445d | finish no earlier than 2002-12-13 | T2 | 3560h | 3560h |  | Rel-5 |  |  | 23.057 |  |  |

Notes:
- 8683: For Rel5 even if completed by March
- 8684: -
- 8685: -
- 8686: -
- 8687: -
- 8688: -
- 8689: -
- 8690: SP#8 approved WID
- 8691: -
- 8692: SP#8 approved WID
- 8693: -
- 8694: SP#8 approved WID
- 8695: SP#8 approved WID
- 8696: -
- 8697: Marked as closed 12/2008 (was marked 95% complete)
- 8698: -
- 8699: -
- 8700: -
- 8701: az: CN#13 - changed to Rel5
- 8702: -
- 8703: az 24/05/01: Rel4 completion 90->100%.
- 8704: -
- 8705: -
- 8706: -
- 8707: -
- 8708: -
- 8709: According to T2 SWG1 M. Cataldo this is automatically supported by the MExE support of UAProf therefore 100% complete

| ID | WBS | Task | Duration | Start | Finish | Predecessors | Complete | Baseline start | Baseline finish | Baseline duration | Constraint | Resources | Work | Actual work | Acronym | WI rapporteur name | WI rapporteur e-mail | Release | MCC resp | Acronym_3GU_Export | Impacted TSs and TRs |
| --- | --- | --- | --- | --- | --- | --- | --- | --- | --- | --- | --- | --- | --- | --- | --- | --- | --- | --- | --- | --- | --- |
| 8710 | 84 | **CAMEL phase 4** | 904d | 2000-04-17 A | 2002-09-06 A |  | 100% | 2000-04-17 | 2002-09-06 | 625d |  | S1 | 41104h | 41104h | CAMEL4 | Nokia | keijo.palviainen@nokia.com | Rel-5 | Alain | CAMEL4 |  |
| 8711 | 84.1 | Service requirements | 565d | 2000-04-17 A | 2002-06-14 A |  | 100% | 2000-04-17 | 2002-06-14 | 565d | finish no earlier than 2002-06-14 | S1 | 4520h | 4520h |  |  |  | Rel-5 | Alain |  |  |
| 8712 | 84.2 | Call Party Handling | 500d | 2000-07-10 A | 2002-06-07 A |  | 100% | 2000-07-10 | 2002-06-07 | 500d | finish no earlier than 2002-06-07 | N2 | 4000h | 4000h | CAMEL4-CPH |  |  | Rel-5 | Kimmo | CAMEL4-CPH |  |
| 8713 | 84.3 | Mid call procedure for MO and MT calls | 495d | 2000-07-17 A | 2002-06-07 A |  | 100% | 2000-07-17 | 2002-06-07 | 495d | finish no earlier than 2002-06-07 | N2 | 3960h | 3960h | CAMEL4-MCP |  |  | Rel-5 | Kimmo | CAMEL4-MCP |  |
| 8714 | 84.4 | Interactions with Optimal Routing | 430d | 2000-07-17 A | 2002-03-08 A |  | 100% | 2000-07-17 | 2002-03-08 | 430d | finish no earlier than 2002-03-08 | N2 | 3440h | 3440h | CAMEL4-IOR |  |  | Rel-5 | Kimmo | CAMEL4-IOR |  |
| 8715 | 84.5 | Inclusion of flexible tone injection | 430d | 2000-07-17 A | 2002-03-08 A |  | 100% | 2000-07-17 | 2002-03-08 | 430d | finish no earlier than 2002-03-08 | N2 | 3440h | 3440h | CAMEL4-IFTI |  |  | Rel-5 | Kimmo | CAMEL4-IFTI |  |
| 8716 | 84.6 | CSE control over MT SMS | 430d | 2000-07-17 A | 2002-03-08 A |  | 100% | 2000-07-17 | 2002-03-08 | 430d | finish no earlier than 2002-03-08 | N2 | 3440h | 3440h | CAMEL4-CCSMS |  |  | Rel-5 | Kimmo | CAMEL4-CCSMS |  |
| 8717 | 84.7 | Notification of GPRS mobility management to CSE | 331d | 2001-03-02 A | 2002-06-07 A |  | 100% | 2001-03-02 | 2002-06-07 | 331d | finish no earlier than 2002-06-07 | N2 | 2648h | 2648h | CAMEL4-NMM |  |  | Rel-5 | Kimmo | CAMEL4-NMM |  |
| 8718 | 84.8 | Provision of location information of called subscriber | 266d | 2001-03-02 A | 2002-03-08 A |  | 100% | 2001-03-02 | 2002-03-08 | 266d | finish no earlier than 2002-03-08 | N2 | 2128h | 2128h | CAMEL4-LOCB |  |  | Rel-5 | Kimmo | CAMEL4-LOCB |  |
| 8719 | 84.9 | Inclusion of ODB data in the CSE_HLR interface | 175d | 2001-07-09 A | 2002-03-08 A |  | 100% | 2001-07-09 | 2002-03-08 | 175d | finish no earlier than 2002-03-08 | N2 | 1400h | 1400h | CAMEL4-ODB |  |  | Rel-5 | Kimmo | CAMEL4-ODB |  |
| 8720 | 84.10 | Location information during an ongoing call (Handover DP) | 280d | 2001-05-14 A | 2002-06-07 A |  | 100% | 2001-05-14 | 2002-06-07 | 280d | finish no earlier than 2002-06-07 | N2 | 2240h | 2240h | CAMEL4-HODP |  |  | Rel-5 | Kimmo | CAMEL4-HODP |  |
| 8721 | 84.11 | GPRS Any Time Interrogation | 240d | 2001-07-09 A | 2002-06-07 A |  | 100% | 2001-07-09 | 2002-06-07 | 240d | finish no earlier than 2002-06-07 | N2 | 1920h | 1920h | CAMEL4-ATI |  |  | Rel-5 | Kimmo | CAMEL4-ATI |  |
| 8722 | 84.12 | Transfer of IMEI (with SW version) to CSE (CAMEL4-ATI) | 240d | 2001-07-09 A | 2002-06-07 A |  | 100% | 2001-07-09 | 2002-06-07 | 240d | finish no earlier than 2002-06-07 | N2 | 1920h | 1920h |  |  |  | Rel-5 | Kimmo |  |  |
| 8723 | 84.13 | Handling of partial implementations of CAMEL4 | 131d | 2002-03-08 A | 2002-09-06 A |  | 100% | 2002-03-08 | 2002-09-06 | 131d | finish no earlier than 2002-06-07 | N2 | 1048h | 1048h | CAMEL4-SUB |  |  | Rel-5 | Kimmo | CAMEL4-SUB |  |
| 8724 | 85 | **Rel-5 MExE enhancements** | 360.25d | 2001-03-26 A | 2002-03-08 A |  | 100% | 2001-03-26 | 2002-03-08 | 250d |  | T2 | 2880h | 2880h | MEXE5 |  |  | Rel-5 | Kimmo | MEXE5 |  |
| 8725 | 85.1 | MExE Rel-5 Improvements and Investigations | 110d | 2001-03-26 A | 2002-03-08 A |  | 100% | 2001-03-26 | 2002-03-08 | 110d | finish no earlier than 2001-12-17 | T2 | 880h | 880h | MEXE5-ENHANC | Motorola | Mark Cataldo | Rel-5 | Kimmo | MEXE5-ENHANC | 22.057; 23.057 |
| 8726 | 86 | **Wideband Telephony Service - AMR** | 1500.62d | 2000-01-01 A | 2003-12-19 A |  | 100% | 2000-01-01 | 2003-12-19 | 1036d |  | S4 | 75408h | 75408h | AMRWB | Siemens | Imre.Varga@mch.siemens.de | Rel-5 | Paolo | AMRWB |  |
| 8727 | 86.1 | **Specification** | 920.62d | 2000-01-01 A | 2002-06-07 A |  | 100% | 2000-01-01 | 2002-06-07 | 636d |  | S4 | 19984h | 19984h |  |  |  | Rel-5 | Paolo |  |  |
| 8728 | 86.1.1 | Stage 1 for Wideband Telephony Service - AMR | 125d | 2001-10-01 A | 2002-03-22 A |  | 100% | 2001-10-01 | 2002-03-22 | 125d | finish no earlier than 2002-03-22 | S1 | 1000h | 1000h |  |  |  | Rel-5 | Alain |  |  |
| 8729 | 86.1.2 | **Stage 2 for Wideband Telephony Service - AMR** | 109.62d | 2000-01-03 A | 2000-04-17 A |  | 100% | 2000-01-03 | 2000-04-17 | 77d |  | S4 | 1232h | 1232h |  |  |  | Rel-5 | Paolo |  |  |
| 8730 | 86.1.2.1 | Design Constraints for Wideband Telephony Service - AMR | 27d | 2000-01-03 A | 2000-02-07 A |  | 100% | 2000-01-03 | 2000-02-07 | 27d |  | S4 | 208h | 208h |  |  |  | Rel-5 | Paolo |  |  |
| 8731 | 86.1.2.2 | General Description for Wideband Telephony Service - AMR | 51d | 2000-02-07 A | 2000-04-17 A | 8730 | 100% | 2000-02-07 | 2000-04-17 | 51d | start no earlier than 2000-09-25 | S4 | 408h | 408h |  |  |  | Rel-5 | Paolo |  |  |
| 8732 | 86.1.3 | Feasibility Study for Wideband Telephony Service - AMR | 26d | 2000-04-28 A | 2000-06-02 A | 8731 | 100% | 2000-04-28 | 2000-06-02 | 26d | finish no earlier than 2000-06-02 | S4 | 208h | 208h |  |  |  | Rel-5 | Paolo |  | 26.901 |
| 8733 | 86.1.4 | N1 Aspects for Wideband Telephony Service - AMR | 66d | 2001-09-21 A | 2001-12-21 A |  | 100% | 2001-09-21 | 2001-12-21 | 66d | finish no earlier than 2001-12-21 | N1 | 528h | 528h |  |  |  | Rel-5 | Frederic |  |  |
| 8734 | 86.1.5 | N4 work for Wideband Telephony Service - AMR | 83d | 2002-02-13 A | 2002-06-07 A |  | 100% | 2002-02-13 | 2002-06-07 | 83d | finish no earlier than 2002-06-07 | N4 | 664h | 664h |  |  |  | Rel-5 | Kimmo |  |  |

Notes:
- 8710: -
- 8711: -
- 8712: -
- 8713: -
- 8714: -
- 8715: -
- 8716: -
- 8717: -
- 8718: -
- 8719: Added on May 29, 2001
- 8720: -
- 8721: -
- 8722: -
- 8723: stage2 and stage3 CRs for approval at CN#17
- 8724: -
- 8725: -
- 8726: -
- 8727: -
- 8728: -
- 8729: -
- 8730: -
- 8731: -
- 8732: S4,TD SP-000024: TR 26.901 v.4.0.0
- 8733: Some of N1 tasks: Indication of supported codecs by the MS, Bearer cap negociation, codec indication to MS
- 8734: CN4#11 30/11/01: No inputs to CN4 at this meeting

| ID | WBS | Task | Duration | Start | Finish | Predecessors | Complete | Baseline start | Baseline finish | Baseline duration | Constraint | Resources | Work | Actual work | Release | MCC resp | Acronym | Acronym_3GU_Export | Impacted TSs and TRs | TSG stopped | WI rapporteur name | WI rapporteur e-mail |
| --- | --- | --- | --- | --- | --- | --- | --- | --- | --- | --- | --- | --- | --- | --- | --- | --- | --- | --- | --- | --- | --- | --- |
| 8735 | 86.1.6 | **Codec issues** | 918.38d | 2000-01-03 A | 2002-06-07 A |  | 100% | 2000-01-03 | 2002-06-07 | 636d |  | S4 | 9496h | 9496h | Rel-5 | Paolo |  |  |  |  |  |  |
| 8736 | 86.1.6.1 | Codec qualification | 86d | 2000-02-02 A | 2000-05-31 A |  | 100% | 2000-02-02 | 2000-05-31 | 86d | finish no earlier than 2000-05-31 | S4 | 688h | 688h | Rel-5 | Paolo |  |  |  |  |  |  |
| 8737 | 86.1.6.2 | Codec selection tests | 102d | 2000-06-01 A | 2000-10-20 A | 8736 | 100% | 2000-06-01 | 2000-10-20 | 102d | finish no earlier than 2000-10-20 | S4 | 816h | 816h | Rel-5 | Paolo |  |  |  |  |  |  |
| 8738 | 86.1.6.3 | Codec selection | 5d | 2000-10-23 A | 2000-10-27 A | 8737 | 100% | 2000-10-23 | 2000-10-27 | 5d | finish no earlier than 2000-10-27 | S4 | 40h | 40h | Rel-5 | Paolo |  |  |  |  |  |  |
| 8739 | 86.1.6.4 | TFO AMR-WB | 63d | 2001-12-18 A | 2002-03-14 A |  | 100% | 2001-12-18 | 2002-03-14 | 63d | finish no earlier than 2002-03-14 | S4 | 504h | 504h | Rel-5 | Paolo | AMRWB-TFO | AMRWB-TFO |  |  |  |  |
| 8740 | 86.1.6.5 | Other codec issues (verif., characterization) | 441d | 2000-09-29 A | 2002-06-07 A |  | 100% | 2000-09-29 | 2002-06-07 | 441d | finish no earlier than 2002-06-07 | S4 | 3528h | 3528h | Rel-5 | Paolo |  |  | 26.976 |  |  |  |
| 8741 | 86.1.6.6 | AMR-WB and narrrowband interworking | 121d | 2001-09-27 A | 2002-03-14 A |  | 100% | 2001-09-27 | 2002-03-14 | 121d | finish no earlier than 2002-03-14 | S4 | 968h | 968h | Rel-5 | Paolo | AMRWB-IWG | AMRWB-IWG |  |  |  |  |
| 8742 | 86.1.6.7 | Interworking with fixed broadband networks | 121d | 2001-09-27 A | 2002-03-14 A |  | 100% | 2001-09-27 | 2002-03-14 | 121d | finish no earlier than 2002-03-14 | S4 | 968h | 968h | Rel-5 | Paolo |  |  |  |  |  |  |
| 8743 | 86.1.6.8 | Tones and announcements | 121d | 2001-09-27 A | 2002-03-14 A |  | 100% | 2001-09-27 | 2002-03-14 | 121d | finish no earlier than 2002-03-14 | S4 | 968h | 968h | Rel-5 | Paolo |  |  |  |  |  |  |
| 8744 | 86.1.6.9 | Deleted - WB Conferencing and WB Voice Group calls | 1d | 2000-01-03 A | 2000-01-03 A |  | 100% | 2000-01-03 | 2000-01-03 | 1d | finish no earlier than 2000-01-03 | S1 | 8h | 8h | Rel-5 | Alain |  |  |  | SP-07 |  |  |
| 8745 | 86.1.8 | **Conformance tests (CRs to 34 series)** | 106.62d | 2000-01-01 A | 2000-04-12 A |  | 100% | 2000-01-01 | 2000-04-12 | 74d |  | T1 | 1768h | 1768h | Rel-5 | Ingbert |  |  |  |  |  |  |
| 8746 | 86.1.8.1 | **Terminal Acoustic Characteristics** | 106.62d | 2000-01-01 A | 2000-04-12 A |  | 100% | 2000-01-01 | 2000-04-12 | 74d |  | S4 | 1176h | 1176h | Rel-5 | Paolo |  |  |  |  |  |  |
| 8747 | 86.1.8.1.1 | Definition for Terminal Acoustic Characteristics | 22d | 2000-01-01 A | 2000-01-31 A |  | 100% | 2000-01-01 | 2000-01-31 | 22d | finish no earlier than 2000-01-28 | S4 | 168h | 168h | Rel-5 | Paolo |  |  | 26.131 |  |  |  |
| 8748 | 86.1.8.1.2 | Test specification for Terminal Acoustic Characteristics | 52d | 2000-02-01 A | 2000-04-12 A | 8747 | 100% | 2000-02-01 | 2000-04-12 | 52d | finish no earlier than 2000-03-13 | S4 | 416h | 416h | Rel-5 | Paolo |  |  | 26.132 |  |  |  |
| 8749 | 86.2 | Floating-point ANSI-C code for the AMR-WB speech codec | 123d | 2001-09-25 A | 2002-03-14 A |  | 100% | 2001-09-25 | 2002-03-14 | 123d | finish no earlier than 2002-03-14 | S4 | 984h | 984h | Rel-5 | Paolo | AMRWB-FP | AMRWB-FP | 26.204 |  | Nokia | janne.m.vainio@nokia.com |
| 8750 | 86.3 | **Support of AMR-WB in GERAN: GMSK and 8PSK WB FR / HR** | 940.12d | 2000-01-03 A | 2002-06-28 A |  | 100% | 2000-01-03 | 2002-06-28 | 651d |  | GP | 23488h | 23488h | Rel-5 | Paolo | GAMRWB | GAMRWB |  |  |  |  |
| 8751 | 86.3.1 | Channel coding in 45.003 for Support of AMR-WB in GERAN: GMSK and 8PSK WB FR / HR | 591d | 2000-01-03 A | 2002-04-05 A |  | 100% | 2000-01-03 | 2002-04-05 | 591d |  | GP | 4720h | 4720h | Rel-5 | Paolo |  |  |  |  |  |  |
| 8752 | 86.3.2 | Signalling for the A interface | 391d | 2000-01-03 A | 2001-06-29 A |  | 100% | 2000-01-03 | 2001-06-29 | 391d | finish no earlier than 2001-06-29 | GP | 3120h | 3120h | Rel-5 | Paolo |  |  |  |  |  |  |
| 8753 | 86.3.3 | Signalling for Iu | 651d | 2000-01-03 A | 2002-06-28 A |  | 100% | 2000-01-03 | 2002-06-28 | 651d | finish no earlier than 2002-06-28 | GP | 5200h | 5200h | Rel-5 | Paolo |  |  |  |  |  |  |
| 8754 | 86.3.4 | Receiver performance in TS 45.005 | 325d | 2001-04-02 A | 2002-06-28 A |  | 100% | 2001-04-02 | 2002-06-28 | 325d | finish no earlier than 2002-06-28 | GP | 2600h | 2600h | Rel-5 | Paolo |  |  |  |  |  |  |
| 8755 | 86.3.5 | Link Adaptation in 45.009 | 330d | 2001-03-26 A | 2002-06-28 A |  | 100% | 2001-03-26 | 2002-06-28 | 330d | finish no earlier than 2002-06-28 | GP | 2640h | 2640h | Rel-5 | Paolo |  |  |  |  |  |  |
| 8756 | 86.4 | **Deleted - GERAN MS conformance test for AMR-WB** | 1498.38d | 2000-01-03 A | 2003-12-19 A |  | 100% | 2000-01-03 | 2003-12-19 | 1036d |  | GP | 16568h | 16568h | Rel-5 | Paolo |  |  |  | SP-69 |  |  |
| 8757 | 86.4.1 | Deleted - MS test for AMR-WB | 1036d | 2000-01-03 A | 2003-12-19 A |  | 100% | 2000-01-03 | 2003-12-19 | 1036d | finish no earlier than 2003-12-19 | GP | 8280h | 8280h | Rel-5 | Paolo |  |  |  | GP-17 |  |  |
| 8758 | 86.5 | GERAN BTS conformance test for AMR-WB | 1102.88d | 2000-01-03 A | 2002-12-02 A |  | 100% | 2000-01-03 | 2002-12-02 | 762d |  | GP | 6096h | 6096h | Rel-5 | Paolo |  |  |  |  |  |  |

Notes:
- 8735: -
- 8736: -
- 8737: -
- 8738: -
- 8739: -
- 8740: ANSI C-Code , Test Sequences, Speech Transcoding Functions, Error Concealment of lost frames, Source Controlled Bit-Rate Operation, Voice Activity Detector, Frame Structure
- 8741: -
- 8742: -
- 8743: -
- 8744: -
- 8745: -
- 8746: -
- 8747: -
- 8748: -
- 8749: -
- 8750: -
- 8751: 50098 -> 50298
- 8752: -
- 8753: -
- 8754: -
- 8755: -
- 8756: Not started 02/2003. Marked as stopped 12/2008
- 8757: Marked as stopped 12/2008
- 8758: -

| ID | WBS | Task | Duration | Start | Finish | Complete | Baseline start | Baseline finish | Baseline duration | Constraint | Resources | Work | Actual work | Acronym | Release | MCC resp | Acronym_3GU_Export | WI rapporteur name | WI rapporteur e-mail |
| --- | --- | --- | --- | --- | --- | --- | --- | --- | --- | --- | --- | --- | --- | --- | --- | --- | --- | --- | --- |
| 8759 | 11 | **Rel-5 Terminal interfaces** | 322d | 2001-05-14 A | 2002-03-20 A | 100% | 2001-05-14 | 2002-03-20 | 223d |  | T2 | 3568h | 3568h | TLM5 | Rel-5 | Kimmo | TI, TLM5 |  |  |
| 8760 | 87 | Terminal local model enhancements | 223d | 2001-05-14 A | 2002-03-20 A | 100% | 2001-05-14 | 2002-03-20 | 223d | finish no earlier than 2002-03-20 | T2 | 1784h | 1784h | TLM5 | Rel-5 |  | TLM5 |  |  |
| 8761 | 88 | **Rel-5 Location Services enhancements** | 1223d | 2000-04-03 A | 2003-06-27 A | 100% | 2000-04-03 | 2003-06-27 | 845d |  | S2; S1; S3; S5; N4; R2; R3; GP | 237560h | 237560h | LCS1 | Rel-5 | Maurice | LCS1, Rel-5 | Nokia | Jan Kall |
| 8762 | 88.1 | **UE positioning for Rel-5 Location Services enhancements** | 454.5d | 2001-01-15 A | 2002-03-29 A | 100% | 2001-01-15 | 2002-03-29 | 315d |  | R2 | 6120h | 6120h | LCS1-Uepos | Rel-5 | Issam | LCS1-Uepos, Rel-5 |  |  |
| 8763 | 88.1.1 | UE positioning enhancements for 1.28 Mcps TDD | 255d | 2001-04-09 A | 2002-03-29 A | 100% | 2001-04-09 | 2002-03-29 | 255d | finish no earlier than 2002-03-29 | R2 | 2040h | 2040h | LCS-128Pos | Rel-5 | Yong-Jun | LCS-128Pos | CATT | Xiaohua Mei |
| 8764 | 88.1.2 | Open SMLC-SRNC Interface within the UTRAN to support A-GPS Positioning | 195d | 2001-01-15 A | 2001-10-12 A | 100% | 2001-01-15 | 2001-10-12 | 195d |  | R2 | 1560h | 1560h | LCS-INTF | Rel-5 | Yong-Jun | LCS-INTF | Qualcomm | Kirk Burroughs |
| 8765 | 88.2 | **Event Based and Periodic LCS** | 773.5d | 2000-05-22 A | 2002-06-07 A | 100% | 2000-05-22 | 2002-06-07 | 535d |  | S1; S2; N4 | 14848h | 14848h | LCS1-EBP | Rel-5 | Alain | LCS1-EBP | Pacific Bell Wireless | Randolph Wohlert (rwohlert@tri.sbc.com) |
| 8766 | 88.2.1 | Stage 1 for Event based and Periodic LCS | 130d | 2000-05-22 A | 2000-11-17 A | 100% | 2000-05-22 | 2000-11-17 | 130d | finish no earlier than 2000-07-21 | S1 | 1040h | 1040h |  | Rel-5 | Alain |  | Pacific Bell Wireless | Randolph Wohlert (rwohlert@tri.sbc.com) |
| 8767 | 88.2.2 | Stage 2 for Event based and Periodic LCS | 60d | 2000-11-06 A | 2001-01-26 A | 100% | 2000-11-06 | 2001-01-26 | 60d | finish no earlier than 2001-01-26 | S2 | 480h | 480h |  | Rel-5 | Maurice |  |  |  |
| 8768 | 88.2.3 | Impact on MAP | 61d | 2002-03-15 A | 2002-06-07 A | 100% | 2002-03-15 | 2002-06-07 | 61d | finish no earlier than 2002-06-07 | N4 | 488h | 488h |  | Rel-5 | Kimmo |  |  |  |
| 8769 | 88.3 | **Location Services for GERAN in A/Gb Mode** | 701d | 2000-04-03 A | 2002-02-08 A | 100% | 2000-04-03 | 2002-02-08 | 485d |  | GP | 26400h | 26400h | LCS-GERAN | Rel-5 | Paolo | LCS-GERAN | Nokia | Margaret Livingston |
| 8770 | 88.3.1 | GERAN LCS Stage 2 (first release) | 485d | 2000-04-03 A | 2002-02-08 A | 100% | 2000-04-03 | 2002-02-08 | 485d | finish no earlier than 2002-02-08 | GP; S2; G1; G2 | 15520h | 15520h |  | Rel-5 | Paolo |  | Nokia | Margaret Livingston |
| 8771 | 88.3.2 | Gb interface support for LCS | 370d | 2000-04-03 A | 2001-08-31 A | 100% | 2000-04-03 | 2001-08-31 | 370d | finish no earlier than 2001-08-31 | GP | 2960h | 2960h |  | Rel-5 | Paolo |  | Nokia | Margaret Livingston |
| 8772 | 88.3.3 | L3 protocol support for LCS | 305d | 2000-04-03 A | 2001-06-01 A | 100% | 2000-04-03 | 2001-06-01 | 305d | finish no earlier than 2001-06-01 | GP | 2440h | 2440h |  | Rel-5 | Paolo |  | Nokia | Margaret Livingston |
| 8773 | 88.3.4 | Stage 3 for Location Services for GERAN in A/Gb Mode | 305d | 2000-04-03 A | 2001-06-01 A | 100% | 2000-04-03 | 2001-06-01 | 305d | finish no earlier than 2001-06-01 | GP | 2440h | 2440h |  | Rel-5 | Paolo |  | Nokia | Margaret Livingston |
| 8774 | 88.4 | **Location Services for GERAN in Iu Mode** | 846d | 2000-04-03 A | 2002-06-28 A | 100% | 2000-04-03 | 2002-06-28 | 585d |  | S2; G1; G2; R2; R3 | 64264h | 64264h |  | Rel-5 | Paolo |  | Nokia | Margaret Livingston |
| 8775 | 88.4.1 | GERAN LCS Stage 2 | 585d | 2000-04-03 A | 2002-06-28 A | 100% | 2000-04-03 | 2002-06-28 | 585d | finish no earlier than 2002-06-28 | S2; G1; G2 | 14040h | 14040h |  | Rel-5 | Paolo |  | Nokia | Margaret Livingston |
| 8776 | 88.4.2 | Iu-ps interface support for LCS | 585d | 2000-04-03 A | 2002-06-28 A | 100% | 2000-04-03 | 2002-06-28 | 585d | finish no earlier than 2002-06-28 | R2; R3 | 9360h | 9360h |  | Rel-5 | Paolo |  | Nokia | Margaret Livingston |
| 8777 | 88.4.3 | Iu-cs interface support for LCS | 585d | 2000-04-03 A | 2002-06-28 A | 100% | 2000-04-03 | 2002-06-28 | 585d | finish no earlier than 2002-06-28 | R2; R3 | 9360h | 9360h |  | Rel-5 | Paolo |  | Nokia | Margaret Livingston |
| 8778 | 88.4.4 | Iur-g interface support for LCS | 62.5d | 2002-01-23 A | 2002-04-19 A | 100% | 2002-01-23 | 2002-04-19 | 62.5d | finish no earlier than 2002-04-19 | G1; G2 | 1000h | 1000h |  | Rel-5 | Paolo |  | Nokia | Margaret Livingston |
| 8779 | 88.4.5 | RRC protocol support for LCS | 75d | 2001-08-20 A | 2001-11-30 A | 100% | 2001-08-20 | 2001-11-30 | 75d | finish no earlier than 2001-11-30 | G1; G2; R2; R3 | 2400h | 2400h |  | Rel-5 | Paolo |  | Nokia | Margaret Livingston |
| 8780 | 88.4.6 | Additional impacts on Broadcast of LCS data on packet channels | 77.5d | 2001-08-20 A | 2001-12-05 A | 100% | 2001-08-20 | 2001-12-05 | 77.5d | finish no earlier than 2001-12-05 | G1; G2; R2; R3 | 2480h | 2480h |  | Rel-5 | Paolo |  | Nokia | Margaret Livingston |
| 8781 | 88.4.7 | Stage 3 for Location Services for GERAN in Iu Mode | 69.5d | 2002-03-25 A | 2002-06-28 A | 100% | 2002-03-25 | 2002-06-28 | 69.5d | finish no earlier than 2002-06-28 | G1; G2; R2; R3 | 2224h | 2224h |  | Rel-5 | Paolo |  | Nokia | Margaret Livingston |
| 8782 | 88.5 | **GERAN MS Conformance test for LCS** | 403.75d | 2002-06-03 A | 2003-06-27 A | 100% | 2002-06-03 | 2003-06-27 | 280d |  | GP | 11200h | 11200h | LCS-GERAN-MSconf | Rel-5 | Paolo | LCS-GERAN-MSconf |  |  |
| 8783 | 88.5.1 | LCS MS test case work plan (Release 98/99/4) | 280d | 2002-06-03 A | 2003-06-27 A | 100% | 2002-06-03 | 2003-06-27 | 280d | finish no earlier than 2003-06-27 | G4; G5 | 4480h | 4480h |  | Rel-5 | Paolo |  |  |  |
| 8784 | 88.5.2 | LCS MS test cases | 280d | 2002-06-03 A | 2003-06-27 A | 100% | 2002-06-03 | 2003-06-27 | 280d | finish no earlier than 2003-06-27 | G4; G5 | 4480h | 4480h |  | Rel-5 | Paolo |  |  |  |

Notes:
- 8759: Acronym changed from "TI, TLMN5"
- 8760: - / Impacted TSs and TRs: 23.227
- 8761: . Acronym changed from "LCS1, Rel-5"
- 8762: Acronym changed from "LCS1-Uepos, Rel-5"
- 8763: - / Impacted TSs and TRs: 25.123; 25.224; 25.225; 25.302; 25.303; 25.304; 25.305; 25.331; 25.420; 25.423; 25.430; 25.433; New 25.859
- 8764: RP#13 completed
- 8765: -
- 8766: Evaluate Event based and Periodic LCS to be included in R00, corresponding Stage 1 description / Impacted TSs and TRs: 22.071
- 8767: Marked as closed 12/2008 (was marked 51% complete)
- 8768: Possible impact on UTRAN of LCS quality level request
- 8769: -
- 8770: -
- 8771: -
- 8772: -
- 8773: -
- 8774: -
- 8775: -
- 8776: -
- 8777: -
- 8778: FFS
- 8779: -
- 8780: -
- 8781: -
- 8782: -
- 8783: Marked as closed 12/2008 (was marked 60% complete)
- 8784: Marked as closed 12/2008 (was marked 60% complete)

| ID | WBS | Task | Duration | Start | Finish | Predecessors | Complete | Baseline start | Baseline finish | Baseline duration | Constraint | Resources | Work | Actual work | Acronym | Release | MCC resp | TSG stopped | Acronym_3GU_Export | Impacted TSs and TRs | WI rapporteur name | WI rapporteur e-mail |
| --- | --- | --- | --- | --- | --- | --- | --- | --- | --- | --- | --- | --- | --- | --- | --- | --- | --- | --- | --- | --- | --- | --- |
| 8785 | 88.6 | **Deleted - GERAN BTS Conformance test for LCS** | 403.75d | 2002-06-03 A | 2003-06-27 A |  | 100% | 2002-06-03 | 2003-06-27 | 280d |  | GP | 11200h | 11200h | LCS-GERAN-BTSconf | Rel-5 | Paolo | GP-15 | LCS-GERAN-BTSconf |  |  |  |
| 8786 | 88.6.1 | Deleted - LCS BTS test case work plan (Release 98/99/4) | 280d | 2002-06-03 A | 2003-06-27 A |  | 100% | 2002-06-03 | 2003-06-27 | 280d | finish no earlier than 2003-06-27 | G4; G5 | 4480h | 4480h |  | Rel-5 | Paolo | GP-15 |  |  |  |  |
| 8787 | 88.6.2 | Deleted - LCS BTS test cases | 280d | 2002-06-03 A | 2003-06-27 A |  | 100% | 2002-06-03 | 2003-06-27 | 280d | finish no earlier than 2003-06-27 | G4; G5 | 4480h | 4480h |  | Rel-5 | Paolo | GP-15 |  |  |  |  |
| 8788 | 88.7 | LCS interoperation stage 2 aspects | 480d | 2000-08-28 A | 2002-06-28 A |  | 100% | 2000-08-28 | 2002-06-28 | 480d |  | S2 | 3840h | 3840h |  | Rel-5 | Maurice |  |  |  |  |  |
| 8789 | 88.8 | **LCS interoperability aspects to GERAN (LCS-GERAN)** | 693.75d | 2000-08-28 A | 2002-06-28 A |  | 100% | 2000-08-28 | 2002-06-28 | 480d |  | GP; S5 | 34560h | 34560h |  | Rel-5 | Paolo |  |  |  |  |  |
| 8790 | 88.8.1 | Co-ordinated development of GSM LCS Phase 2 and UMTS LCS, S2 and GERAN | 480d | 2000-08-28 A | 2002-06-28 A |  | 100% | 2000-08-28 | 2002-06-28 | 480d | finish no earlier than 2002-06-28 | GP; S2; S5; R2; R3; G2; G1 | 26880h | 26880h |  | Rel-5 | Paolo |  |  |  |  |  |
| 8791 | 88.9 | FS on LCS support in the IMS | 90d | 2001-02-12 A | 2002-01-18 A |  | 100% | 2001-02-12 | 2002-01-18 | 90d | start no earlier than 2001-02-12 | S1 | 720h | 720h |  | Rel-5 | Alain |  |  |  |  |  |
| 8792 | 88.10 | Charging and OAM&P for LCS enhancements | 201d | 2001-09-21 A | 2002-06-28 A |  | 100% | 2001-09-21 | 2002-06-28 | 201d | finish no earlier than 2002-06-28 | S5 | 1608h | 1608h | LCS1-OAM | Rel-5 | Mirko |  | LCS1-OAM | 32.200-series |  |  |
| 8793 | 88.11 | New security aspects of LCS | 446d | 2000-04-14 A | 2001-12-28 A |  | 100% | 2000-04-14 | 2001-12-28 | 446d | finish no earlier than 2001-12-28 | S3; S2 | 7136h | 7136h | LCS1-SEC | Rel-5 | Mirko |  | LCS1-SEC | 23.271; 43.059 | Nokia | valtteri.niemi@nokia.com |
| 8794 | 88.12 | Specification for the Le interface | 45d | 2002-01-14 A | 2002-03-15 A |  | 100% | 2002-01-14 | 2002-03-15 | 45d | start no earlier than 2002-01-14 | S2 | 360h | 360h | LCS1-Le | Rel-5 | Maurice |  | LCS1-Le |  |  |  |
| 8795 | 88.13 | Deleted - CHECK STATUS - Inter-GMLC interface | 153d | 2002-05-30 A | 2002-12-30 A |  | 100% | 2002-05-30 | 2002-12-30 | 153d | finish no earlier than 2002-12-30 | S2 | 1224h | 1224h |  | Rel-5 | Maurice | SP-10 |  |  |  |  |
| 8796 | 89 | **Rel-5 Security enhancements (SEC1)** | 889.5d | 2000-02-21 A | 2002-06-28 A |  | 100% | 2000-02-21 | 2002-06-28 | 615d |  | S3 | 29974.9h | 29974.9h |  | Rel-5 | Mirko |  |  |  | Vodafone | Peter.Howard@vodafone.com |
| 8797 | 89.1 | **Rel-5 Network Domain Security (SEC1-NDS)** | 889.5d | 2000-02-21 A | 2002-06-28 A |  | 100% | 2000-02-21 | 2002-06-28 | 615d |  | S3 | 25054.9h | 25054.9h |  | Rel-5 | Mirko |  |  | New 33.200 (exisalso for Rel-4) | Telenor | Geir-myrdahl.koien@telenor.com |
| 8798 | 89.1.3 | Rel-5 IP network layer security (NDS/IP) (SEC1-NDS-IP) | 457d | 2000-06-15 A | 2002-03-15 A |  | 100% | 2000-06-15 | 2002-03-15 | 457d | finish no earlier than 2002-03-15 | S3 | 3656h | 3656h |  | Rel-5 | Mirko |  |  | New 33.210 | Telenor | Geir-myrdahl.koien@telenor.com |
| 8799 | 89.1.1 | **Deleted - Control plane protection in core network (e.g., GTP, CAP, MAP/IP, provided by IPsec)** | 784d | 2000-05-12 A | 2002-06-07 A |  | 100% | 2000-05-12 | 2002-06-07 | 541d |  | S3 | 7118.9h | 7118.9h |  | Rel-5 | Mirko | SP-16 |  |  |  |  |
| 8800 | 89.1.1.1 | Deleted - Main aspects of User plane protection in core network (e.g., provided by IPsec) | 290d | 2000-05-12 A | 2001-06-21 A |  | 100% | 2000-05-12 | 2001-06-21 | 290d | finish no earlier than 2001-06-21 | S3 | 2320h | 2320h |  | Rel-5 | Mirko | SP-12 |  |  |  |  |
| 8801 | 89.1.1.2 | Deleted - Integration of GTP signalling security architecture - for User plane protection in core network (e.g., provided by IPsec) | 191d | 2001-09-14 A | 2002-06-07 A |  | 100% | 2001-09-14 | 2002-06-07 | 191d | finish no earlier than 2002-06-07 | N4 | 1528h | 1528h |  | Rel-5 | Kimmo | NP-16 |  |  |  |  |
| 8802 | 89.1.2 | **Deleted - User plane protection in core network (e.g., provided by IPsec)** | 889.5d | 2000-02-21 A | 2002-06-28 A |  | 100% | 2000-02-21 | 2002-06-28 | 615d |  | S3 | 9360h | 9360h |  | Rel-5 | Mirko | SP-16 |  |  |  |  |
| 8803 | 89.1.2.1 | Deleted -Main aspects of User plane protection in core network (e.g., provided by IPsec) | 349d | 2000-02-21 A | 2001-06-21 A |  | 100% | 2000-02-21 | 2001-06-21 | 349d | finish no earlier than 2001-06-21 | S3 | 2792h | 2792h |  | Rel-5 | Mirko | SP-12 |  |  |  |  |
| 8804 | 89.1.2.2 | Deleted - Integration of GTP signalling security architecture - for User plane protection in core network (e.g., provided by IPsec) | 206d | 2001-09-14 A | 2002-06-28 A |  | 100% | 2001-09-14 | 2002-06-28 | 206d | finish no earlier than 2002-06-28 | N4 | 1648h | 1648h |  | Rel-5 | Kimmo | NP-16 |  |  |  |  |
| 8805 | 90 | **Intra Domain Connection of RAN Nodes to Multiple CN Nodes** | 657.5d | 2000-10-02 A | 2002-06-28 A |  | 100% | 2000-10-02 | 2002-06-28 | 455d |  | S2; N1; N4; R3; GP | 30232h | 30232h | IUFLEX | Rel-5 | Alain |  | IUFLEX | 23.236 | Ericsson | stephen.terrill@ericsson.com |
| 8806 | 90.1 | Overall System Architecture for Intra Domain Connection of RAN Nodes to Multiple CN Nodes | 188d | 2001-01-03 A | 2001-09-21 A |  | 100% | 2001-01-03 | 2001-09-21 | 188d | finish no earlier than 2001-06-01 | S2 | 1504h | 1504h |  | Rel-5 | Maurice |  |  |  |  |  |
| 8807 | 90.2 | Stage 3: RAN node selecting CN node | 130d | 2001-09-24 A | 2002-03-22 A | 8806 | 100% | 2001-09-24 | 2002-03-22 | 130d | finish no earlier than 2002-03-22 | R3 | 1040h | 1040h |  | Rel-5 | Juha |  |  |  | Vodafone | Brendan.McWilliams@gb.vodafone.co.uk |
| 8808 | 90.3 | N1 work for Intra Domain Connection of RAN Nodes to Multiple CN Nodes | 205d | 2001-09-17 A | 2002-06-28 A |  | 100% | 2001-09-17 | 2002-06-28 | 205d | start no earlier than 2001-09-17 | N1 | 1640h | 1640h |  | Rel-5 | Frederic |  |  | 24.008 and check 29.018 |  |  |
| 8809 | 90.4 | N4 work for Intra Domain Connection of RAN Nodes to Multiple CN Nodes | 375d | 2000-10-02 A | 2002-03-08 A |  | 100% | 2000-10-02 | 2002-03-08 | 375d | finish no earlier than 2002-03-15 | N4 | 3000h | 3000h |  | Rel-5 | Kimmo |  |  |  |  |  |

Notes:
- 8785: Not started 02/3003. Marked as stopped 12/2008
- 8786: Marked as stopped 12/2008
- 8787: Marked as stopped 12/2008
- 8788: Marked as closed 12/2008 (was marked 17% complete)
- 8789: -
- 8790: -
- 8791: Marked as closed 12/2008 (was marked 75% complete)
- 8792: -
- 8793: SP#9 updated WID S3-000609 (Location services security)
- 8794: -
- 8795: Marked as stopped 12/2008
- 8796: Added BB UE authentication and rapporteur added. TO BE DELETED
- 8797: SP#9 approved WID SP-000420 (S3-000606 Network domain security). S3#17: All due in Rel5. (WI Update at S3#18). Replaced by NDS-IP and NDS-MAP. TO BE DELETED OR MOVED TO HISTORY FILE
- 8798: SP#12 WID updated SP-000420 (S3-000606) =>SP-010326 (S3-010286)
- 8799: Marked as stopped 12/2008
- 8800: TO BE DELETED. Marked as stopped 12/2008
- 8801: Waiting for input from SA3!. Marked as stopped 12/2008
- 8802: TO BE DELETED. Marked as stopped 12/2008
- 8803: -
- 8804: 14/02/2002 requirements are not clear/not receivedMarked as closed 12/2008 (was marked 95 complete)
- 8805: No clear indication on the end date. Put to Rel5 by AS.
- 8806: -
- 8807: Not identified
- 8808: -
- 8809: DAB 12.12.01 - % complete to 66%

| ID | WBS | Task | Duration | Start | Finish | Complete | Baseline start | Baseline finish | Baseline duration | Constraint | Resources | Work | Actual work | Acronym | WI rapporteur name | WI rapporteur e-mail | Release | MCC resp | Acronym_3GU_Export | TSG stopped | Impacted TSs and TRs |
| --- | --- | --- | --- | --- | --- | --- | --- | --- | --- | --- | --- | --- | --- | --- | --- | --- | --- | --- | --- | --- | --- |
| 8810 | 90.5 | **GERAN work for Intra Domain Connection of RAN Nodes to Multiple CN Nodes** | 146d | 2002-02-08 A | 2002-06-28 A | 100% | 2002-02-08 | 2002-06-28 | 101d |  | GP | 4848h | 4848h | IDCRAN-GERAN | Ericsson | ingemar.backlund@era.ericsson.se | Rel-5 | Paolo | IDCRAN-GERAN |  |  |
| 8811 | 90.5.1 | Stage 2 (changes to ) | 101d | 2002-02-08 A | 2002-06-28 A | 100% | 2002-02-08 | 2002-06-28 | 101d | finish no earlier than 2002-06-28 | G1 | 808h | 808h |  |  |  | Rel-5 | Paolo |  |  |  |
| 8812 | 90.5.2 | 43.051 Introduction of support for IDNNS in GERAN Iu mode | 101d | 2002-02-08 A | 2002-06-28 A | 100% | 2002-02-08 | 2002-06-28 | 101d | finish no earlier than 2002-06-28 | G1 | 808h | 808h |  |  |  | Rel-5 | Paolo |  |  |  |
| 8813 | 90.5.3 | Stage 3 (changes to ) | 101d | 2002-02-08 A | 2002-06-28 A | 100% | 2002-02-08 | 2002-06-28 | 101d | finish no earlier than 2002-06-28 | G2 | 808h | 808h |  |  |  | Rel-5 | Gert |  |  |  |
| 8814 | 90.5.4 | 48.016 Use of Gb interface concepts when a network applies IDNNS | 101d | 2002-02-08 A | 2002-06-28 A | 100% | 2002-02-08 | 2002-06-28 | 101d | finish no earlier than 2002-06-28 | G2 | 808h | 808h |  |  |  | Rel-5 | Gert |  |  |  |
| 8815 | 90.5.5 | 48.018 Include MSC/VLR identity in CS IMSI paging | 101d | 2002-02-08 A | 2002-06-28 A | 100% | 2002-02-08 | 2002-06-28 | 101d | finish no earlier than 2002-06-28 | G2 | 808h | 808h |  |  |  | Rel-5 | Gert |  |  |  |
| 8816 | 91 | **Deleted - GERAN improvements 3 (new transport layer on interface A)** | 646.25d | 2001-04-06 A | 2002-12-20 A | 100% | 2001-04-06 | 2002-12-20 | 446d |  | GP | 14272h | 14272h | GEIMP3 |  |  | Rel-5 | Paolo | GEIMP3 | SP-69 |  |
| 8817 | 91.1 | **Deleted - Evolution of the transport for A** | 646.25d | 2001-04-06 A | 2002-12-20 A | 100% | 2001-04-06 | 2002-12-20 | 446d |  | GP | 10704h | 10704h | GEIMP3-EtA |  |  | Rel-5 | Paolo | GEIMP3-EtA | GP-12 |  |
| 8818 | 91.1.1 | Deleted - Definition of a new A/Ater interface Transport Layer option based on the Iu Interface Transport Layer | 446d | 2001-04-06 A | 2002-12-20 A | 100% | 2001-04-06 | 2002-12-20 | 446d | finish no earlier than 2002-12-20 | GP | 3568h | 3568h |  |  |  | Rel-5 | Paolo |  | GP-12 |  |
| 8819 | 91.1.2 | Deleted - Adaptation of the Layer 3 BSSMAP procedures as required | 446d | 2001-04-06 A | 2002-12-20 A | 100% | 2001-04-06 | 2002-12-20 | 446d | finish no earlier than 2002-12-20 | GP | 3568h | 3568h |  |  |  | Rel-5 | Paolo |  | GP-12 |  |
| 8820 | 92 | **Rel-5 Charging Management & Operations, Administration, Maintenance and Provisioning (OAM&P)** | 381d | 2001-09-10 A | 2002-09-12 A | 100% | 2001-09-10 | 2002-09-12 | 264d |  | S5 | 9976h | 9976h | OAM5 |  |  | Rel-5 | Mirko | OAM5 |  |  |
| 8821 | 92.1 | Rel-5 Principles, high level Requirements and Architecture | 205d | 2001-09-17 A | 2002-06-28 A | 100% | 2001-09-17 | 2002-06-28 | 205d | finish no earlier than 2002-06-28 | S5 | 1640h | 1640h |  | Motorola |  | Rel-5 | Mirko |  |  | 32.101; 32.102 |
| 8822 | 92.2 | Rel-5 Performance Management | 259d | 2001-09-17 A | 2002-09-12 A | 100% | 2001-09-17 | 2002-09-12 | 259d | finish no earlier than 2002-09-12 | S5 | 2072h | 2072h |  | Nortel |  | Rel-5 | Mirko |  |  | 32.4xy; 52.402 |
| 8823 | 92.3 | Rel-5 Charging Management | 264d | 2001-09-10 A | 2002-09-12 A | 100% | 2001-09-10 | 2002-09-12 | 264d | finish no earlier than 2002-09-12 | S5 | 2112h | 2112h |  | T-Mobile | Karl-Heinz.Nenner@T-MOBILE.DE | Rel-5 | Mirko |  |  | 32.200; 32.205; 32.215; 32.225; 32.235 |
| 8824 | 92.4 | Rel-5 Network Infrastructure Management | 255d | 2001-09-21 A | 2002-09-12 A | 100% | 2001-09-21 | 2002-09-12 | 255d | finish no earlier than 2002-09-12 | S5 | 2040h | 2040h |  | Ericsson | thomas.tovinger@ericsson.com | Rel-5 | Mirko |  |  | 32.6xy; 32.3xy |
| 8825 | 93 | **GERAN enhancements for streaming services 1 (RLC enhancements)** | 621.25d | 2000-11-06 A | 2002-06-28 A | 100% | 2000-11-06 | 2002-06-28 | 430d |  | GP | 8944h | 8944h |  |  |  | Rel-5 | Paolo |  |  |  |
| 8826 | 93.1 | Concept for GERAN enhancements for streaming services 1 (RLC enhancements) | 258d | 2000-11-06 A | 2001-10-31 A | 100% | 2000-11-06 | 2001-10-31 | 258d | finish no earlier than 2001-10-31 | GP | 2064h | 2064h |  |  |  | Rel-5 | Paolo |  |  |  |
| 8827 | 93.2 | RLC protocol enhancement (SDU Discard) | 430d | 2000-11-06 A | 2002-06-28 A | 100% | 2000-11-06 | 2002-06-28 | 430d | finish no earlier than 2002-06-28 | GP | 3440h | 3440h |  |  |  | Rel-5 | Paolo |  |  |  |
| 8828 | 94 | **GERAN enhancements for streaming services 2 (usage of ECSD)** | 621.25d | 2000-11-06 A | 2002-06-28 A | 100% | 2000-11-06 | 2002-06-28 | 430d |  | GP | 19840h | 19840h |  | Ericsson | Frank Muller | Rel-5 | Paolo |  |  |  |
| 8829 | 94.1 | Usage of ECSD Concept | 380d | 2000-11-06 A | 2002-04-19 A | 100% | 2000-11-06 | 2002-04-19 | 380d | finish no earlier than 2002-04-19 | GP | 3040h | 3040h |  |  |  | Rel-5 | Paolo |  |  |  |
| 8830 | 94.2 | Stage 2 for GERAN enhancements for streaming services 2 (usage of ECSD) | 380d | 2000-11-06 A | 2002-04-19 A | 100% | 2000-11-06 | 2002-04-19 | 380d | finish no earlier than 2002-04-19 | GP | 3040h | 3040h |  |  |  | Rel-5 | Paolo |  |  |  |
| 8831 | 94.3 | Stage 3 for GERAN enhancements for streaming services 2 (usage of ECSD) | 430d | 2000-11-06 A | 2002-06-28 A | 100% | 2000-11-06 | 2002-06-28 | 430d | finish no earlier than 2002-06-28 | GP | 3440h | 3440h |  |  |  | Rel-5 | Paolo |  |  |  |
| 8832 | 94.4 | RLC PDU formats | 430d | 2000-11-06 A | 2002-06-28 A | 100% | 2000-11-06 | 2002-06-28 | 430d | finish no earlier than 2002-06-28 | GP | 3440h | 3440h |  |  |  | Rel-5 | Paolo |  |  |  |
| 8833 | 94.5 | MAC header | 430d | 2000-11-06 A | 2002-06-28 A | 100% | 2000-11-06 | 2002-06-28 | 430d | finish no earlier than 2002-06-28 | GP | 3440h | 3440h |  |  |  | Rel-5 | Paolo |  |  |  |

Notes:
- 8810: Accept changes Gb over IP
- 8811: -
- 8812: -
- 8813: -
- 8814: Closed, accept changes for Gb over IP
- 8815: -
- 8816: Terminated - not standardized. Marked as stopped 12/2008
- 8817: TERMINATED - NOT STANDARDIZED. Marked as stopped 12/2008
- 8818: TERMINATED - NOT STANDARDIZED. Marked as stopped 12/2008
- 8819: TERMINATED - NOT STANDARDIZED. Marked as stopped 12/2008
- 8820: -
- 8821: -
- 8822: -
- 8823: -
- 8824: -
- 8825: -
- 8826: -
- 8827: -
- 8828: AWS, Nokia, Ericsson, Nortel, Siemens, Motorola, Vodafone
- 8829: -
- 8830: -
- 8831: -
- 8832: -
- 8833: -

| ID | WBS | Task | Duration | Start | Finish | Predecessors | Complete | Baseline start | Baseline finish | Baseline duration | Constraint | Resources | Work | Actual work | Acronym | WI rapporteur name | WI rapporteur e-mail | Release | MCC resp | Acronym_3GU_Export |
| --- | --- | --- | --- | --- | --- | --- | --- | --- | --- | --- | --- | --- | --- | --- | --- | --- | --- | --- | --- | --- |
| 8834 | 95 | **GERAN/UTRAN interface evolution 1 (evolution of Iu PS)** | 689.75d | 2000-09-01 A | 2002-06-28 A |  | 100% | 2000-09-01 | 2002-06-28 | 476d |  | GP; R3 | 22848h | 22848h | GERUEV1 | SBC | Marc Grant | Rel-5 | Paolo | GERUEV1 |
| 8835 | 95.1 | **Evolution of Iu ps** | 689.75d | 2000-09-01 A | 2002-06-28 A |  | 100% | 2000-09-01 | 2002-06-28 | 476d |  | GP; R3 | 15232h | 15232h | GERUEV1-IuPS |  |  | Rel-5 | Paolo | GERUEV1-IuPS |
| 8836 | 95.1.1 | Identification of GERAN requirements on Iu ps | 326d | 2000-09-01 A | 2001-11-30 A |  | 100% | 2000-09-01 | 2001-11-30 | 326d | finish no earlier than 2001-11-30 | GP; R3 | 5216h | 5216h |  |  |  | Rel-5 | Paolo |  |
| 8837 | 95.1.2 | Update of Evolution of Iu ps specifications | 150d | 2001-12-03 A | 2002-06-28 A | 8836 | 100% | 2001-12-03 | 2002-06-28 | 150d | finish no earlier than 2002-06-28 | GP; R3 | 2400h | 2400h |  |  |  | Rel-5 | Paolo |  |
| 8838 | 96 | **GERAN/UTRAN interface evolution 2 (evolution of Iu CS)** | 756d | 2000-06-29 A | 2002-06-28 A |  | 100% | 2000-06-29 | 2002-06-28 | 522d |  | GP; R3 | 31872h | 31872h | GERUEV2 |  |  | Rel-5 | Paolo | GERUEV2 |
| 8839 | 96.1 | **Evolution of Iu cs** | 756d | 2000-06-29 A | 2002-06-28 A |  | 100% | 2000-06-29 | 2002-06-28 | 522d |  | GP; R3 | 23520h | 23520h | GERUEV2-IuCS | Lucent | Krishna Balachandran | Rel-5 | Paolo | GERUEV2-IuCS |
| 8840 | 96.1.1 | Identification of GERAN requirements on Iu cs | 472d | 2000-06-29 A | 2002-04-19 A |  | 100% | 2000-06-29 | 2002-04-19 | 472d | finish no earlier than 2002-04-19 | GP; R3 | 7552h | 7552h |  |  |  | Rel-5 | Paolo |  |
| 8841 | 96.1.2 | Update of Evolution of Iu cs specifications | 476d | 2000-09-01 A | 2002-06-28 A |  | 100% | 2000-09-01 | 2002-06-28 | 476d | finish no earlier than 2002-06-28 | GP; R3 | 7616h | 7616h |  |  |  | Rel-5 | Paolo |  |
| 8842 | 97 | **End to End QoS for PS Domain including IMS** | 693.75d | 2000-08-28 A | 2002-06-28 A |  | 100% | 2000-08-28 | 2002-06-28 | 480d |  | S2; S5; N3 | 18272h | 18272h | E2EQoS | Ericsson | Johnson.oyama@era.ericcson.se | Rel-5 | Maurice | E2EQoS, Rel-5 |
| 8843 | 97.1 | E2E QoSConcept and Architecture | 178d | 2001-01-03 A | 2001-09-07 A |  | 100% | 2001-01-03 | 2001-09-07 | 178d | finish no earlier than 2001-09-07 | S2 | 1424h | 1424h |  |  |  | Rel-5 | Maurice |  |
| 8844 | 97.2 | E2E QoS interworking | 672d | 2000-08-28 A | 2002-06-07 A |  | 100% | 2000-08-28 | 2002-06-07 | 465d | finish no earlier than 2002-06-07 | N3 | 3720h | 3720h | E2EQoS-IW | Lucent | Daisuke Yokota (yokota@lucent.com) | Rel-5 | Gwiho | E2EQoS-IW |
| 8845 | 97.3 | QoS Management (Provisioning and Monitoring) | 201d | 2001-09-21 A | 2002-06-28 A |  | 100% | 2001-09-21 | 2002-06-28 | 201d | finish no earlier than 2002-06-28 | S5 | 1608h | 1608h | E2EQoS-OAM |  |  | Rel-5 | Mirko | E2EQoS-OAM |
| 8846 | 98 | **Rel-5 Messaging enhancements** | 678.5d | 2001-06-15 A | 2003-03-31 A |  | 100% | 2001-06-15 | 2003-03-31 | 467d |  | T2 | 19000h | 19000h | MESS5 |  |  | Rel-5 | Kimmo | MESS5 |
| 8847 | 98.1 | **Rel-5 Multimedia Messaging (MMS) enhancements** | 678.5d | 2001-06-15 A | 2003-03-31 A |  | 100% | 2001-06-15 | 2003-03-31 | 467d |  | T2 | 11688h | 11688h | MESS5-MMS | Siemens | Josef.Laumen@SAL.SIEMENS.DE | Rel-5 | Alain | MESS5-MMS |
| 8848 | 98.1.1 | Definition of service requirements for MESS5-MMS | 196d | 2001-06-15 A | 2002-03-15 A |  | 100% | 2001-06-15 | 2002-03-15 | 196d | finish no earlier than 2002-03-15 | S1 | 1568h | 1568h | MESS5-SR | Siemens | Josef.Laumen@SAL.SIEMENS.DE | Rel-5 | Alain | MESS5-SR |
| 8849 | 98.1.2 | Technical realization of MESS5-MMS | 256d | 2001-06-15 A | 2002-06-07 A |  | 100% | 2001-06-15 | 2002-06-07 | 256d | finish no earlier than 2002-06-07 | T2 | 2048h | 2048h |  | Siemens | Josef.Laumen@SAL.SIEMENS.DE | Rel-5 |  |  |
| 8850 | 98.1.3 | WAP Forum dependency: MM1 stage 3 | 467d | 2001-06-15 A | 2003-03-31 A |  | 100% | 2001-06-15 | 2003-03-31 | 467d | finish no earlier than 2003-03-31 | T2 | 3736h | 3736h |  |  |  | Rel-5 |  |  |
| 8851 | 98.1.4 | MMS formats and codecs for MESS5-MMS | 75d | 2001-12-03 A | 2002-03-15 A |  | 100% | 2001-12-03 | 2002-03-15 | 75d | finish no earlier than 2002-03-15 | S4 | 600h | 600h |  |  |  | Rel-5 | Paolo |  |
| 8852 | 98.2 | **Enhanced Messaging Service (EMS) enhancements** | 276.5d | 2001-06-15 A | 2002-03-08 A |  | 100% | 2001-06-15 | 2002-03-08 | 191d |  | T2 | 3584h | 3584h | MESS5-EMS | Ericsson | Alan.Baldwin@EML.ERICSSON.SE | Rel-5 | Kimmo | MESS5-EMS |
| 8853 | 98.2.1 | Definition of service requirements for Enhanced Messaging Service (EMS) enhancements | 66d | 2001-06-15 A | 2001-09-14 A |  | 100% | 2001-06-15 | 2001-09-14 | 66d | finish no earlier than 2001-09-14 | S1 | 528h | 528h |  | Ericsson | Alan.Baldwin@EML.ERICSSON.SE | Rel-5 | Alain |  |
| 8854 | 98.2.2 | Technical realization of Enhanced Messaging Service (EMS) enhancements | 191d | 2001-06-15 A | 2002-03-08 A |  | 100% | 2001-06-15 | 2002-03-08 | 191d | finish no earlier than 2002-03-08 | T2 | 1528h | 1528h |  | Ericsson | Alan.Baldwin@EML.ERICSSON.SE | Rel-5 | Kimmo |  |
| 8855 | 99 | **GERAN Inter BSC NACC improvements over the Gb Interface** | 309.5d | 2001-09-03 A | 2002-06-28 A |  | 100% | 2001-09-03 | 2002-06-28 | 215d |  | GP | 11184h | 11184h | GERNACC |  |  | Rel-5 | Paolo | GERNACC |
| 8856 | 99.1 | **Modification of core network protocols for GERAN Inter BSC NACC over Gb Interface** | 237d | 2001-09-03 A | 2002-04-19 A |  | 100% | 2001-09-03 | 2002-04-19 | 165d |  | N4; S2 | 7048h | 7048h | GERNACC-Cnmod |  |  | Rel-5 | Kimmo | GERNACC-Cnmod |
| 8857 | 99.1.1 | Stage 2 - Concept | 43d | 2001-09-03 A | 2001-10-31 A |  | 100% | 2001-09-03 | 2001-10-31 | 43d | finish no earlier than 2001-10-31 | N4; S2 | 688h | 688h |  |  |  | Rel-5 | Kimmo |  |
| 8858 | 99.1.2 | Stage 2 - 23.060 change - Definition of Inter BSC NACC | 165d | 2001-09-03 A | 2002-04-19 A |  | 100% | 2001-09-03 | 2002-04-19 | 165d | finish no earlier than 2002-04-19 | N4; S2 | 2640h | 2640h |  |  |  | Rel-5 | Kimmo |  |
| 8859 | 99.1.3 | Stage 3 (changes to TS 29.060) | 135d | 2001-09-03 A | 2002-03-08 A |  | 100% | 2001-09-03 | 2002-03-08 | 135d | finish no earlier than 2002-03-08 | N4 | 1080h | 1080h |  |  |  | Rel-5 | Kimmo |  |

Notes:
- 8834: SBC, Motorola, Nokia, Ericsson, Nortel
- 8835: -
- 8836: -
- 8837: -
- 8838: -
- 8839: Lucent, Ericsson, AWS, Nortel
- 8840: -
- 8841: -
- 8842: Acronym changed from "E2EQoS, Rel-5"
- 8843: - / Impacted TSs and TRs: 23.207
- 8844: [DAB - 30/07/02] - % complete to 95% (if we exclude Diffserv). Marked as closed 12/2008 (was marked 95% complete) / Impacted TSs and TRs: 29.208; 29.207; 27.060; 29.061; 24.008; 24.228; ; 24.229; 29.060; 29.163
- 8845: - / Impacted TSs and TRs: 32-series
- 8846: support of UAProf, so this in my opinion is 100% complete
- 8847: -
- 8848: - / Impacted TSs and TRs: 22.140
- 8849: stage 3 MM7 is missing / Impacted TSs and TRs: 23.140
- 8850: Marked as closed 12/2008 (was marked 80% complete)
- 8851: - / Impacted TSs and TRs: 26.140
- 8852: - / Impacted TSs and TRs: 23.040
- 8853: -
- 8854: - / Impacted TSs and TRs: 23.040
- 8855: -
- 8856: -
- 8857: -
- 8858: -
- 8859: IP 30/11/01: Input awaited from GERAN2 to CN4

| ID | WBS | Task | Duration | Start | Finish | Complete | Baseline start | Baseline finish | Baseline duration | Constraint | Resources | Work | Actual work | Acronym | Release | MCC resp | Acronym_3GU_Export | TSG stopped | WI rapporteur name | WI rapporteur e-mail |
| --- | --- | --- | --- | --- | --- | --- | --- | --- | --- | --- | --- | --- | --- | --- | --- | --- | --- | --- | --- | --- |
| 8860 | 99.2 | **Modification of Gb protocols for GERAN Inter BSC NACC over Gb Interface** | 218.5d | 2001-11-30 A | 2002-06-28 A | 100% | 2001-11-30 | 2002-06-28 | 151d |  | GP | 2416h | 2416h | GERNACC-Gbmod | Rel-5 | Paolo | GERNACC-Gbmod |  |  |  |
| 8861 | 99.2.1 | Stage 3 (changes to TS 48.018) | 151d | 2001-11-30 A | 2002-06-28 A | 100% | 2001-11-30 | 2002-06-28 | 151d | finish no earlier than 2002-06-28 | GP | 1208h | 1208h |  | Rel-5 | Paolo |  |  |  |  |
| 8862 | 100 | **Enhanced Power Control** | 780.75d | 2001-11-26 A | 2003-12-19 A | 100% | 2001-11-26 | 2003-12-19 | 540d |  | GP | 12840h | 12840h | EPC | Rel-5 | Paolo | EPC |  |  |  |
| 8863 | 100.1 | Realization of Enhanced power control and signalling support | 5d | 2001-11-26 A | 2001-11-30 A | 100% | 2001-11-26 | 2001-11-30 | 5d | finish no earlier than 2001-11-30 | GP | 40h | 40h |  | Rel-5 | Paolo |  |  |  |  |
| 8864 | 100.2 | Deleted - GERAN MS Conformance test for Enhanced Power Control | 530d | 2001-12-10 A | 2003-12-19 A | 100% | 2001-12-10 | 2003-12-19 | 530d | finish no earlier than 2003-12-19 | GP | 4240h | 4240h |  | Rel-5 | Paolo |  | GP-17 |  |  |
| 8865 | 100.3 | Deleted - GERAN BTS Conformance test for Enhanced Power Control | 530d | 2001-12-10 A | 2003-12-19 A | 100% | 2001-12-10 | 2003-12-19 | 530d | finish no earlier than 2003-12-19 | GP | 4240h | 4240h |  | Rel-5 | Paolo |  | GP-17 |  |  |
| 8866 | 101 | **8PSK AMR HR** | 766.25d | 2001-12-10 A | 2003-12-19 A | 100% | 2001-12-10 | 2003-12-19 | 530d |  | GP | 21080h | 21080h | 8PSK-AH | Rel-5 | Paolo | 8PSK-AH |  |  |  |
| 8867 | 101.1 | **Definition of channel coding, performance requirements and signalling support** | 208d | 2001-12-10 A | 2002-06-28 A | 100% | 2001-12-10 | 2002-06-28 | 145d |  | GP | 10440h | 10440h |  | Rel-5 | Paolo |  |  |  |  |
| 8868 | 101.1.1 | Concept | 145d | 2001-12-10 A | 2002-06-28 A | 100% | 2001-12-10 | 2002-06-28 | 145d | finish no earlier than 2002-06-28 | GP | 1160h | 1160h |  | Rel-5 | Paolo |  |  |  |  |
| 8869 | 101.1.2 | Changes to 44.018 | 145d | 2001-12-10 A | 2002-06-28 A | 100% | 2001-12-10 | 2002-06-28 | 145d | finish no earlier than 2002-06-28 | G2 | 1160h | 1160h |  | Rel-5 | Gert |  |  |  |  |
| 8870 | 101.1.3 | Changes to 45.001 | 145d | 2001-12-10 A | 2002-06-28 A | 100% | 2001-12-10 | 2002-06-28 | 145d | finish no earlier than 2002-06-28 | G1 | 1160h | 1160h |  | Rel-5 | Paolo |  |  |  |  |
| 8871 | 101.1.4 | Changes to 45.002 | 145d | 2001-12-10 A | 2002-06-28 A | 100% | 2001-12-10 | 2002-06-28 | 145d | finish no earlier than 2002-06-28 | G1 | 1160h | 1160h |  | Rel-5 | Paolo |  |  |  |  |
| 8872 | 101.1.5 | Changes to 45.003 | 145d | 2001-12-10 A | 2002-06-28 A | 100% | 2001-12-10 | 2002-06-28 | 145d | finish no earlier than 2002-06-28 | G1 | 1160h | 1160h |  | Rel-5 | Paolo |  |  |  |  |
| 8873 | 101.1.6 | Changes to 45.005 | 145d | 2001-12-10 A | 2002-06-28 A | 100% | 2001-12-10 | 2002-06-28 | 145d | finish no earlier than 2002-06-28 | G1 | 1160h | 1160h |  | Rel-5 | Paolo |  |  |  |  |
| 8874 | 101.1.7 | Changes to 24.008 | 145d | 2001-12-10 A | 2002-06-28 A | 100% | 2001-12-10 | 2002-06-28 | 145d | finish no earlier than 2002-06-28 | G2 | 1160h | 1160h |  | Rel-5 | Gert |  |  |  |  |
| 8875 | 101.1.8 | Changes to 48.058 | 145d | 2001-12-10 A | 2002-06-28 A | 100% | 2001-12-10 | 2002-06-28 | 145d | finish no earlier than 2002-06-28 | G2 | 1160h | 1160h |  | Rel-5 | Gert |  |  |  |  |
| 8876 | 101.2 | Deleted - GERAN MS Conformance test for 8PSK HR | 530d | 2001-12-10 A | 2003-12-19 A | 100% | 2001-12-10 | 2003-12-19 | 530d | finish no earlier than 2003-12-19 | GP | 4240h | 4240h |  | Rel-5 | Paolo |  | GP-17 |  |  |
| 8877 | 101.3 | GERAN BTS Conformance test for 8PSK HR | 270d | 2001-12-10 A | 2002-12-20 A | 100% | 2001-12-10 | 2002-12-20 | 270d | finish no earlier than 2002-12-20 | GP | 2160h | 2160h |  | Rel-5 | Paolo |  |  |  |  |
| 8878 | 102 | Service Change and UDI Fallback | 175d | 2001-10-08 A | 2002-06-07 A | 100% | 2001-10-08 | 2002-06-07 | 175d | finish no earlier than 2002-06-07 | N3 | 1400h | 1400h | SCUDIF | Rel-5 | Gwiho | SCUDIF |  | Ericsson | Rune.Werner.Wiik@ericsson.no |
| 8879 | 103 | **Rel-5 USIM toolkit enhancements** | 1252d | 2000-06-05 A | 2003-09-26 A | 100% | 2000-06-05 | 2003-09-26 | 865d |  | T3; S1 | 36776h | 36776h | USAT5 | Rel-5 | Xavier | USAT1, USAT1-Interpr, USAT1LocLnk |  | G & D | Michael Meyer |
| 8880 | 103.1 | Deleted - Test specification for USIM toolkit security mechanisms | 349d | 2002-05-28 A | 2003-09-26 A | 100% | 2002-05-28 | 2003-09-26 | 349d | finish no earlier than 2003-09-26 | T3 | 2792h | 2792h |  | Rel-5 | Xavier |  | TP-21 | Gemplus | Sophie Viallet |
| 8881 | 103.2 | **Protocol Standardisation of a SIM Toolkit Interpreter** | 996.25d | 2000-06-05 A | 2003-01-22 A | 100% | 2000-06-05 | 2003-01-22 | 688d |  | T3; T2 | 18016h | 18016h |  | Rel-5 | Xavier |  |  | G & D | Michael Meyer |
| 8882 | 103.2.1 | Stage 1 for Protocol Standardisation of a SIM Toolkit Interpreter | 205d | 2000-06-05 A | 2001-03-16 A | 100% | 2000-06-05 | 2001-03-16 | 205d | finish no earlier than 2001-03-16 | T3 | 1640h | 1640h |  | Rel-5 | Xavier |  |  |  |  |
| 8883 | 103.2.2 | Stage 2 and 3 | 308d | 2001-01-03 A | 2002-03-08 A | 100% | 2001-01-03 | 2002-03-08 | 308d | finish no earlier than 2002-03-08 | T3 | 2464h | 2464h |  | Rel-5 | Xavier |  |  |  |  |
| 8884 | 103.2.3 | Test specification for Protocol Standardisation of a SIM Toolkit Interpreter | 363d | 2001-09-03 A | 2003-01-22 A | 100% | 2001-09-03 | 2003-01-22 | 363d | finish no earlier than 2003-01-22 | T3 | 2904h | 2904h |  | Rel-5 | Xavier |  |  | Gemplus | Gérald MAUNIER |

Notes:
- 8860: -
- 8861: -
- 8862: -
- 8863: Completed 11/2001
- 8864: Not started. Marked as stopped 12/2008
- 8865: Not started. Marked as stopped 12/2008
- 8866: Completed for Rel-5
- 8867: -
- 8868: -
- 8869: -
- 8870: -
- 8871: -
- 8872: -
- 8873: -
- 8874: -
- 8875: -
- 8876: Marked as stopped 12/2008
- 8877: -
- 8878: - / Impacted TSs and TRs: 29.007; 27.001; 24.008
- 8879: Acronym changed from USAT1, USAT1-Interpr, USAT1LocLnk / Impacted TSs and TRs: 22.038; 31.111 (USAT1); 22.038; 03.19; 03.48 (USAT1LocLnk); 23.048 (USAT1SM); 43.019 (USAT1APIJAVA)
- 8880: Marked as stopped 12/2008
- 8881: 28/5/2001: T3-19 proposed that since the stage 2 and 3 will not be presented to TP-12 for approval as expected, the WI will be moved to rel-5, with completion expected at TP-13. / Impacted TSs and TRs: T2 27.103
- 8882: 5/10/2001: Stage one comepeted at TP-12. / Impacted TSs and TRs: 31.112; 31.113; 31.114
- 8883: 5/10/2001: TS 31.112 and 31.113 approved at TP-13. TS 31.114 to be presented to TP-14. / Impacted TSs and TRs: 31.112; 31.113; 31.114
- 8884: 5/10/2001: Work started on test specification. Marked as closed 12/2008 (was marked 12% complete)

| ID | WBS | Task | Type | Duration | Start | Finish | Complete | Baseline start | Baseline finish | Baseline duration | Constraint | Resources | Work | Actual work | Acronym | WI rapporteur name | WI rapporteur e-mail | Release | MCC resp | Acronym_3GU_Export | TSG stopped |
| --- | --- | --- | --- | --- | --- | --- | --- | --- | --- | --- | --- | --- | --- | --- | --- | --- | --- | --- | --- | --- | --- |
| 8885 | 103.4 | **(U)SIM API** |  | 191.5d | 2002-03-20 A | 2002-09-20 A | 100% | 2002-03-20 | 2002-09-20 | 133d |  | T3 | 2128h | 2128h | USAT5-API | Microelectrónica Española | Mario Pérez | Rel-5 | Xavier | USAT1-API, TEI4 |  |
| 8886 | 103.4.1 | Rel-5 Java API Test specification |  | 133d | 2002-03-20 A | 2002-09-20 A | 100% | 2002-03-20 | 2002-09-20 | 133d | finish no earlier than 2002-09-20 | T3 | 1064h | 1064h |  | Microelectrónica Española | Mario Pérez | Rel-5 | Xavier |  |  |
| 8887 | 104 | (Small) Technical Enhancements and Improvements for Rel-5 | milestone | 0d? | 2000-01-03 A | 2000-01-03 A | 100% | 2000-01-03 | 2000-01-03 | 0d? |  | SP; CP; RP; GP |  |  | TEI5 |  |  | Rel-5 | all | TEI5 |  |
| 8888 | 2760 | Test - (Small) Technical Enhancements and Improvements for Rel-5 |  | 2349d? | 2000-01-03 A | 2008-12-31 A | 100% | 2000-01-03 | 2008-12-31 | 2349d? | finish no earlier than 2008-12-31 | R5; T1 | 37584h | 37584h | TEI5_Test |  |  | Rel-5 | Ingbert | TEI5_Test |  |
| 8889 | 105 | Technical Report on UE Functionality Split |  | 124.12d | 2000-01-03 A | 2000-05-01 A | 100% | 2000-01-03 | 2000-05-01 | 87d |  | S1 | 688h | 688h | UESPLIT | Motorola | jian.j.wu@motorola.com | Rel-5 | Alain | UESPLIT |  |
| 8890 | 106 | **User Equipment Management** |  | 386.25d | 2001-06-21 A | 2002-06-28 A | 100% | 2001-06-21 | 2002-06-28 | 267d |  | S5 | 3752h | 3752h | UEM | Vodafone | john.mudge@vf.vodafone.co.uk | Rel-5 | Mirko | UEM |  |
| 8891 | 106.1 | FS on User Equipment (UE) Management |  | 267d | 2001-06-21 A | 2002-06-28 A | 100% | 2001-06-21 | 2002-06-28 | 267d | finish no earlier than 2002-06-28 | S5 | 2136h | 2136h | OAM-UEM | Vodafone | john.mudge@vf.vodafone.co.uk | Rel-5 | Mirko | OAM-UEM |  |
| 8892 | 107 | **Flow control supporting an MS with multiple data flows with different QoS over the Gb interface** |  | 70.25d | 2002-06-24 A | 2002-08-30 A | 100% | 2002-06-24 | 2002-08-30 | 50d |  | GP | 1288h | 1288h | FlowCon | Ericsson | ingemar.backlund@era.ericsson.se | Rel-5 | Paolo | FlowCon |  |
| 8893 | 107.1 | **Update of stage 2 specifications** |  | 70.25d | 2002-06-24 A | 2002-08-30 A | 100% | 2002-06-24 | 2002-08-30 | 50d |  | GP | 808h | 808h |  |  |  | Rel-5 | Paolo |  |  |
| 8894 | 107.1.1 | Concept document 23.060 (changes to) |  | 46d | 2002-06-28 A | 2002-08-30 A | 100% | 2002-06-28 | 2002-08-30 | 46d | finish no earlier than 2002-08-30 | S2 | 368h | 368h |  |  |  | Rel-5 | Maurice |  |  |
| 8895 | 107.1.2 | Flow Control |  | 5d | 2002-06-24 A | 2002-06-28 A | 100% | 2002-06-24 | 2002-06-28 | 5d | finish no earlier than 2002-06-28 | GP | 40h | 40h |  |  |  | Rel-5 | Paolo |  |  |
| 8896 | 107.2 | **Modification of BSSGP protocol** |  | 5d | 2002-06-24 A | 2002-06-28 A | 100% | 2002-06-24 | 2002-06-28 | 5d |  | GP | 80h | 80h |  | Ericsson | ingemar.backlund@era.ericsson.se | Rel-5 | Paolo |  |  |
| 8897 | 107.2.1 | Stage 3 (changes to 48.018) |  | 5d | 2002-06-24 A | 2002-06-28 A | 100% | 2002-06-24 | 2002-06-28 | 5d | finish no earlier than 2002-06-28 | G2 | 40h | 40h |  |  |  | Rel-5 | Gert |  |  |
| 8898 | 108 | **Deleted - Multiple TBF in A/Gb mode - Phase 1 (MULTBF)** |  | 610d | 2002-04-19 A | 2003-11-28 A | 100% | 2002-04-19 | 2003-11-28 | 421d |  | GP | 17480h | 17480h |  | Ericsson | gunnar.mildh@era.ericsson.se | Rel-5 | Paolo |  | GP-17 |
| 8899 | 108.1 | **Deleted - Multiple TBF in A/Gb mode - Core (MULTBF-Agbmode)** |  | 508.5d | 2002-04-19 A | 2003-08-22 A | 100% | 2002-04-19 | 2003-08-22 | 351d |  | GP | 8112h | 8112h |  |  |  | Rel-5 | Paolo |  | GP-17 |
| 8900 | 108.1.1 | Deleted - Multiple TBF Concept paper |  | 351d | 2002-04-19 A | 2003-08-22 A | 100% | 2002-04-19 | 2003-08-22 | 351d | finish no earlier than 2003-08-22 | GP | 2808h | 2808h |  |  |  | Rel-5 | Paolo |  | GP-17 |
| 8901 | 108.1.2 | Deleted - Multiple TBF Stage 2 (43.064) CRs |  | 156d | 2002-04-19 A | 2002-11-22 A | 100% | 2002-04-19 | 2002-11-22 | 156d | finish no earlier than 2002-11-22 | G1 | 1248h | 1248h |  |  |  | Rel-5 | Paolo |  | GP-12 |
| 8902 | 108.1.3 | Deleted - Multiple TBF Stage 3 (44.060) CRs |  | 156d | 2002-04-19 A | 2002-11-22 A | 100% | 2002-04-19 | 2002-11-22 | 156d | finish no earlier than 2002-11-22 | G2 | 1248h | 1248h |  |  |  | Rel-5 | Gert |  | GP-12 |
| 8903 | 108.2 | **Deleted - Multiple TBF in A/Gb mode - Phase 1 – MS testing** |  | 541.5d | 2002-06-24 A | 2003-11-28 A | 100% | 2002-06-24 | 2003-11-28 | 375d |  | GP | 6000h | 6000h |  | Ericsson | ingemar.backlund@era.ericsson.se | Rel-5 | Paolo |  | GP-17 |
| 8904 | 108.2.1 | Deleted - MS conformance tests for Multiple TBF in A/Gb mode |  | 375d | 2002-06-24 A | 2003-11-28 A | 100% | 2002-06-24 | 2003-11-28 | 375d | finish no earlier than 2003-11-28 | G4 | 3000h | 3000h |  |  |  | Rel-5 | Paolo |  | GP-17 |
| 8905 | 109 | **Alignment of 3G functional split and Iu** |  | 1336d | 2000-06-08 A | 2003-12-19 A | 100% | 2000-06-08 | 2003-12-19 | 922d |  | GP | 165704h | 165704h | GER3GAL | Ericsson | Frank Muller | Rel-5 | Paolo | GER3GAL |  |
| 8906 | 109.1 | **GERAN user / control plane** |  | 780.75d | 2000-08-07 A | 2002-08-30 A | 100% | 2000-08-07 | 2002-08-30 | 540d |  | GP | 36232h | 36232h | GER3GAL-GUCOPL | Ericsson | Frank Muller | Rel-5 | Paolo | GER3GAL-GUCOPL |  |
| 8907 | 109.1.1 | **Alignment with UMTS bearer concept** |  | 780.75d | 2000-08-07 A | 2002-08-30 A | 100% | 2000-08-07 | 2002-08-30 | 540d |  | GP | 24952h | 24952h |  |  |  | Rel-5 | Paolo |  |  |
| 8908 | 109.1.1.1 | Enhanced power control - for Alignment with UMTS bearer concept |  | 1d | 2001-08-31 A | 2001-08-31 A | 100% | 2001-08-31 | 2001-08-31 | 1d | finish no earlier than 2001-08-31 | GP | 8h | 8h |  |  |  | Rel-5 | Paolo |  |  |
| 8909 | 109.1.1.2 | Stage 2 - for Alignment with UMTS bearer concept |  | 235d | 2000-08-07 A | 2001-06-29 A | 100% | 2000-08-07 | 2001-06-29 | 235d | finish no earlier than 2001-06-29 | GP | 1880h | 1880h |  |  |  | Rel-5 | Paolo |  |  |
| 8910 | 109.1.1.3 | Adoption of the UTRAN PDCP |  | 295d | 2000-11-06 A | 2001-12-21 A | 100% | 2000-11-06 | 2001-12-21 | 295d | finish no earlier than 2001-12-21 | GP | 2360h | 2360h |  |  |  | Rel-5 | Paolo |  |  |
| 8911 | 109.1.1.4 | Development of RLC / MAC |  | 261d | 2001-08-31 A | 2002-08-30 A | 100% | 2001-08-31 | 2002-08-30 | 261d | finish no earlier than 2002-08-30 | GP | 2088h | 2088h |  |  |  | Rel-5 | Paolo |  |  |
| 8912 | 109.1.1.5 | Development of GERAN RRC |  | 266d | 2001-06-22 A | 2002-06-28 A | 100% | 2001-06-22 | 2002-06-28 | 266d | finish no earlier than 2002-06-28 | GP | 2128h | 2128h |  |  |  | Rel-5 | Paolo |  |  |
| 8913 | 109.1.1.6 | Ciphering and integrity protection concept paper |  | 166d | 2001-08-31 A | 2002-04-19 A | 100% | 2001-08-31 | 2002-04-19 | 166d | finish no earlier than 2002-04-19 | GP | 1328h | 1328h |  |  |  | Rel-5 | Paolo |  |  |
| 8914 | 109.1.1.7 | Multiple TBF or equivalent Concept paper |  | 116d | 2001-08-31 A | 2002-02-08 A | 100% | 2001-08-31 | 2002-02-08 | 116d | finish no earlier than 2002-02-08 | GP | 928h | 928h |  |  |  | Rel-5 | Paolo |  |  |
| 8915 | 109.1.1.8 | Paging concept |  | 166d | 2001-08-31 A | 2002-04-19 A | 100% | 2001-08-31 | 2002-04-19 | 166d | finish no earlier than 2002-04-19 | GP | 1328h | 1328h |  |  |  | Rel-5 | Paolo |  |  |
| 8916 | 109.1.1.9 | Dedicated Physical subchannels, includes traffic and control channels |  | 66d | 2001-08-31 A | 2001-11-30 A | 100% | 2001-08-31 | 2001-11-30 | 66d | finish no earlier than 2001-11-30 | GP | 528h | 528h |  |  |  | Rel-5 | Paolo |  |  |
| 8917 | 109.1.1.10 | Iu support and broadcast concept |  | 166d | 2001-08-31 A | 2002-04-19 A | 100% | 2001-08-31 | 2002-04-19 | 166d | finish no earlier than 2002-04-19 | GP | 1328h | 1328h |  |  |  | Rel-5 | Paolo |  |  |
| 8918 | 109.1.1.11 | Impact of using RLC instead of LAPDm concept |  | 116d | 2001-08-31 A | 2002-02-08 A | 100% | 2001-08-31 | 2002-02-08 | 116d | finish no earlier than 2002-02-08 | GP | 928h | 928h |  |  |  | Rel-5 | Paolo |  |  |
| 8919 | 109.1.1.12 | Contention resolution, mobile station identity, and access concept |  | 66d | 2001-08-31 A | 2001-11-30 A | 100% | 2001-08-31 | 2001-11-30 | 66d | finish no earlier than 2001-11-30 | GP | 528h | 528h |  |  |  | Rel-5 | Paolo |  |  |
| 8920 | 109.1.1.13 | PDCP concept |  | 166d | 2001-08-31 A | 2002-04-19 A | 100% | 2001-08-31 | 2002-04-19 | 166d | finish no earlier than 2002-04-19 | GP | 1328h | 1328h |  |  |  | Rel-5 | Paolo |  |  |
| 8921 | 109.1.1.14 | Downlink delayed TBF release |  | 261d | 2001-08-31 A | 2002-08-30 A | 100% | 2001-08-31 | 2002-08-30 | 261d | finish no earlier than 2002-08-30 | GP | 2088h | 2088h |  |  |  | Rel-5 | Paolo |  |  |
| 8922 | 109.1.1.15 | Add transparent RLC Concept |  | 116d | 2001-08-31 A | 2002-02-08 A | 100% | 2001-08-31 | 2002-02-08 | 116d | finish no earlier than 2002-02-08 | GP | 928h | 928h |  |  |  | Rel-5 | Paolo |  |  |
| 8923 | 109.1.1.16 | Handover concept |  | 116d | 2001-08-31 A | 2002-02-08 A | 100% | 2001-08-31 | 2002-02-08 | 116d | finish no earlier than 2002-02-08 | GP | 928h | 928h |  |  |  | Rel-5 | Paolo |  |  |

Notes:
- 8885: 8/3/2001: test spec is based on R99 core spec, so deleted from Workplan. Acronym changed from USAT1-API, TEI4
- 8886: - / Impacted TSs and TRs: 51.013
- 8887: "Joker" WI, to be used for a Rel 5 CR not related to any feature and with very limited impact on the system
- 8888: "Joker" WI, to be used for small modifications applicable to Rel 5 conformance testing. Moved in from Stoyan/testing WP. / Impacted TSs and TRs: 34.108; 34.109; 34.121-1; 34.121-2; 34.122; 34.123-1; 34.123-2; 34.123-3; 34.171; 34.229-1; 34.229-2; 34.229-3
- 8889: - / Impacted TSs and TRs: New 22.944
- 8890: - / Impacted TSs and TRs: 32.802
- 8891: - / Impacted TSs and TRs: 32.802
- 8892: 50101 -> 50201
- 8893: 50102 -> 50202
- 8894: -
- 8895: 50103 -> 50203
- 8896: 50104 -> 50204
- 8897: -
- 8898: GP#17 Nov 2003 Moved to Rel-6 as UID_50600 MULTBF (Only Multiple TBF Concept paper produced in Rel-5)
- 8899: Marked as closed 12/2008 (was marked 26% complete)
- 8900: Marked as closed 12/2008 (was marked 50% complete)
- 8901: Marked as stopped 12/2008
- 8902: Marked as stopped 12/2008
- 8903: 08/08: duplicate UID_50106=-> 50206. Marked as stopped 12/2008
- 8904: Not started. Marked as stopped 12/2008
- 8905: AWS, Nokia, Ericsson, Nortel, Siemens, Vodafone
- 8906: AWS, Nokia, Ericsson, Nortel, Siemens, Vodafone
- 8907: -
- 8908: -
- 8909: -
- 8910: Responsible is GERAN¦RAN WG2 help may be needed.
- 8911: -
- 8912: -
- 8913: -
- 8914: -
- 8915: -
- 8916: -
- 8917: -
- 8918: -
- 8919: -
- 8920: -
- 8921: -
- 8922: -
- 8923: -

| ID | WBS | Task | Duration | Start | Finish | Complete | Baseline start | Baseline finish | Baseline duration | Constraint | Resources | Work | Actual work | Release | MCC resp | Acronym | WI rapporteur name | WI rapporteur e-mail | Acronym_3GU_Export |
| --- | --- | --- | --- | --- | --- | --- | --- | --- | --- | --- | --- | --- | --- | --- | --- | --- | --- | --- | --- |
| 8924 | 109.1.2 | **Physical layer alignment with UMTS bearer concept** | 403.75d | 2000-11-06 A | 2001-11-30 A | 100% | 2000-11-06 | 2001-11-30 | 280d |  | GP | 6960h | 6960h | Rel-5 | Paolo |  |  |  |  |
| 8925 | 109.1.2.1 | PDTCH/TCH in 45.003 | 155d | 2000-11-06 A | 2001-06-08 A | 100% | 2000-11-06 | 2001-06-08 | 155d | finish no earlier than 2001-06-08 | GP | 1240h | 1240h | Rel-5 | Paolo |  |  |  |  |
| 8926 | 109.1.2.2 | Control channels in 45.003 | 155d | 2000-11-06 A | 2001-06-08 A | 100% | 2000-11-06 | 2001-06-08 | 155d | finish no earlier than 2001-06-08 | GP | 1240h | 1240h | Rel-5 | Paolo |  |  |  |  |
| 8927 | 109.1.2.3 | Receiver performance in 45.005 for PDTCH/TCH and control channels | 280d | 2000-11-06 A | 2001-11-30 A | 100% | 2000-11-06 | 2001-11-30 | 280d | finish no earlier than 2001-11-30 | GP | 2240h | 2240h | Rel-5 | Paolo |  |  |  |  |
| 8928 | 109.2 | **Iu rg interface** | 621.25d | 2000-11-06 A | 2002-06-28 A | 100% | 2000-11-06 | 2002-06-28 | 430d |  | GP; RP | 61920h | 61920h | Rel-5 | Paolo | GER3GAL-Iurg | Ericsson | Frank Muller | GER3GAL-Iurg |
| 8929 | 109.2.1 | **Inter BSS interface** | 621.25d | 2000-11-06 A | 2002-06-28 A | 100% | 2000-11-06 | 2002-06-28 | 430d |  | GP; RP | 24080h | 24080h | Rel-5 | Paolo |  |  |  |  |
| 8930 | 109.2.1.1 | Identification of requirements for Inter BSS interface | 430d | 2000-11-06 A | 2002-06-28 A | 100% | 2000-11-06 | 2002-06-28 | 430d | finish no earlier than 2002-06-28 | GP | 3440h | 3440h | Rel-5 | Paolo |  |  |  |  |
| 8931 | 109.2.1.2 | Stage 2 for Inter BSS interface | 430d | 2000-11-06 A | 2002-06-28 A | 100% | 2000-11-06 | 2002-06-28 | 430d | finish no earlier than 2002-06-28 | GP | 3440h | 3440h | Rel-5 | Paolo |  |  |  |  |
| 8932 | 109.2.1.3 | Adoption of relevant parts from Iur - for Inter BSS interface | 430d | 2000-11-06 A | 2002-06-28 A | 100% | 2000-11-06 | 2002-06-28 | 430d | finish no earlier than 2002-06-28 | GP | 3440h | 3440h | Rel-5 | Paolo |  |  |  |  |
| 8933 | 109.2.1.4 | Complementation with GERAN specifics - for Inter BSS interface | 430d | 2000-11-06 A | 2002-06-28 A | 100% | 2000-11-06 | 2002-06-28 | 430d | finish no earlier than 2002-06-28 | GP | 3440h | 3440h | Rel-5 | Paolo |  |  |  |  |
| 8934 | 109.2.1.5 | Stage 3 for Inter BSS interface | 430d | 2000-11-06 A | 2002-06-28 A | 100% | 2000-11-06 | 2002-06-28 | 430d | finish no earlier than 2002-06-28 | GP | 3440h | 3440h | Rel-5 | Paolo |  |  |  |  |
| 8935 | 109.2.2 | **Inter BSS-RNS interface** | 621.25d | 2000-11-06 A | 2002-06-28 A | 100% | 2000-11-06 | 2002-06-28 | 430d |  | GP; RP | 30960h | 30960h | Rel-5 | Paolo |  |  |  |  |
| 8936 | 109.2.2.1 | Identification of requirements for Inter BSS-RNS interface | 430d | 2000-11-06 A | 2002-06-28 A | 100% | 2000-11-06 | 2002-06-28 | 430d | start no earlier than 2000-11-06 | GP; R3 | 6880h | 6880h | Rel-5 | Paolo |  |  |  |  |
| 8937 | 109.2.2.2 | Stage 2 for Inter BSS-RNS interface | 430d | 2000-11-06 A | 2002-06-28 A | 100% | 2000-11-06 | 2002-06-28 | 430d | finish no earlier than 2002-06-28 | GP; R3 | 6880h | 6880h | Rel-5 | Paolo |  |  |  |  |
| 8938 | 109.2.2.3 | Adoption of relevant parts from Iur - for Inter BSS-RNS interface | 430d | 2000-11-06 A | 2002-06-28 A | 100% | 2000-11-06 | 2002-06-28 | 430d | finish no earlier than 2002-06-28 | GP; R3 | 6880h | 6880h | Rel-5 | Paolo |  |  |  |  |
| 8939 | 109.2.2.4 | Complementation with GERAN specifics - for Inter BSS-RNS interface | 107.5d | 2002-01-30 A | 2002-06-28 A | 100% | 2002-01-30 | 2002-06-28 | 107.5d | finish no earlier than 2002-06-28 | GP; R3 | 1720h | 1720h | Rel-5 | Paolo |  |  |  |  |
| 8940 | 109.2.2.5 | Stage 3 for Inter BSS-RNS interface | 107.5d | 2002-01-30 A | 2002-06-28 A | 100% | 2002-01-30 | 2002-06-28 | 107.5d | finish no earlier than 2002-06-28 | GP; R3 | 1720h | 1720h | Rel-5 | Paolo |  |  |  |  |
| 8941 | 109.3 | **Voice over GERAN PS and CS concept** | 621.25d | 2000-11-06 A | 2002-06-28 A | 100% | 2000-11-06 | 2002-06-28 | 430d |  | GP; R3 | 35200h | 35200h | Rel-5 | Paolo |  |  |  |  |
| 8942 | 109.3.1 | Architecture for A, Iu cs and Iu ps | 430d | 2000-11-06 A | 2002-06-28 A | 100% | 2000-11-06 | 2002-06-28 | 430d | finish no earlier than 2002-06-28 | GP; R3 | 6880h | 6880h | Rel-5 | Paolo |  |  |  |  |
| 8943 | 109.3.2 | Transcoder position/operation | 115d | 2000-11-06 A | 2001-04-13 A | 100% | 2000-11-06 | 2001-04-13 | 115d | finish no earlier than 2001-04-13 | GP | 920h | 920h | Rel-5 | Paolo |  |  |  |  |
| 8944 | 109.3.3 | Handover for Voice over GERAN PS and CS | 430d | 2000-11-06 A | 2002-06-28 A | 100% | 2000-11-06 | 2002-06-28 | 430d | finish no earlier than 2002-06-28 | GP; R3 | 6880h | 6880h | Rel-5 | Paolo |  |  |  |  |
| 8945 | 109.3.4 | RTP payload | 430d | 2000-11-06 A | 2002-06-28 A | 100% | 2000-11-06 | 2002-06-28 | 430d | finish no earlier than 2002-06-28 | GP; R3 | 6880h | 6880h | Rel-5 | Paolo |  |  |  |  |
| 8946 | 109.3.5 | Codec renegotiation concept | 365d | 2000-11-06 A | 2002-03-29 A | 100% | 2000-11-06 | 2002-03-29 | 365d | finish no earlier than 2002-03-29 | GP; R3 | 5840h | 5840h | Rel-5 | Paolo |  |  |  |  |
| 8947 | 109.3.6 | LA | 115d | 2000-11-06 A | 2001-04-13 A | 100% | 2000-11-06 | 2001-04-13 | 115d | finish no earlier than 2001-04-13 | GP | 920h | 920h | Rel-5 | Paolo |  |  |  |  |

Notes:
- 8924: -
- 8925: -
- 8926: -
- 8927: -
- 8928: AWS, Nokia, Ericsson, Nortel, Siemens, Vodafone
- 8929: -
- 8930: -
- 8931: -
- 8932: -
- 8933: -
- 8934: -
- 8935: -
- 8936: -
- 8937: -
- 8938: -
- 8939: -
- 8940: -
- 8941: -
- 8942: -
- 8943: -
- 8944: -
- 8945: -
- 8946: -
- 8947: -

| ID | WBS | Task | Duration | Start | Finish | Complete | Baseline start | Baseline finish | Baseline duration | Constraint | Resources | Work | Actual work | Release | MCC resp | TSG stopped | Acronym | WI rapporteur name | WI rapporteur e-mail | Acronym_3GU_Export | Impacted TSs and TRs |
| --- | --- | --- | --- | --- | --- | --- | --- | --- | --- | --- | --- | --- | --- | --- | --- | --- | --- | --- | --- | --- | --- |
| 8948 | 109.4 | **Deleted - GERAN MS Conformance test for GERAN interface evolution** | 954.75d | 2001-06-11 A | 2003-12-19 A | 100% | 2001-06-11 | 2003-12-19 | 660d |  | GP | 10560h | 10560h | Rel-5 | Paolo | GP-17 |  |  |  |  |  |
| 8949 | 109.4.1 | Deleted - MS test for GERAN interface evolution | 660d | 2001-06-11 A | 2003-12-19 A | 100% | 2001-06-11 | 2003-12-19 | 660d | finish no earlier than 2003-12-19 | GP | 5280h | 5280h | Rel-5 | Paolo | GP-17 |  |  |  |  |  |
| 8950 | 109.5 | **GERAN BSS Conformance test for GERAN interface evolution** | 1336d | 2000-06-08 A | 2003-12-19 A | 100% | 2000-06-08 | 2003-12-19 | 922d |  | GP | 14752h | 14752h | Rel-5 | Paolo |  |  |  |  |  |  |
| 8951 | 109.5.1 | Deleted - BSS test | 922d | 2000-06-08 A | 2003-12-19 A | 100% | 2000-06-08 | 2003-12-19 | 922d | finish no earlier than 2003-12-19 | GP | 7376h | 7376h | Rel-5 | Paolo | GP-17 |  |  |  |  |  |
| 8952 | 110 | **GERAN support for IMS** | 998.25d | 2000-05-01 A | 2002-12-20 A | 100% | 2000-05-01 | 2002-12-20 | 690d |  | GP | 83939.6h | 83939.6h | Rel-5 | Paolo |  | GERIMS | Nokia | Shkumbin Hamiti | GERIMS |  |
| 8953 | 110.1 | **GERAN Header adaptation** | 998.25d | 2000-05-01 A | 2002-12-20 A | 100% | 2000-05-01 | 2002-12-20 | 690d |  | GP; S2; RP | 40011.6h | 40011.6h | Rel-5 | Paolo |  | GERIMS-HEADAPT | Nokia | Shkumbin Hamiti | GERIMS-HEADAPT |  |
| 8954 | 110.1.1 | Definition of compression and removal modes for PDCP protocol | 29.15d | 2000-07-24 A | 2000-09-01 A | 100% | 2000-07-24 | 2000-09-01 | 29.15d | finish no earlier than 2000-09-01 | GP; S2; RP | 699.6h | 699.6h | Rel-5 | Paolo |  |  |  |  |  |  |
| 8955 | 110.1.2 | Conceptual description in stage 2 | 393d | 2000-05-01 A | 2001-10-31 A | 100% | 2000-05-01 | 2001-10-31 | 393d | finish no earlier than 2001-10-31 | GP; S2; RP | 9432h | 9432h | Rel-5 | Paolo |  |  |  |  |  |  |
| 8956 | 110.1.3 | Necessary changes on stage 3 regarding header removal | 555d | 2000-11-06 A | 2002-12-20 A | 100% | 2000-11-06 | 2002-12-20 | 555d | finish no earlier than 2002-12-20 | GP; S2; RP | 13320h | 13320h | Rel-5 | Paolo |  |  |  |  |  |  |
| 8957 | 110.2 | **Deleted - GERAN Radio access bearer design for IMS** | 621.25d | 2000-11-06 A | 2002-06-28 A | 100% | 2000-11-06 | 2002-06-28 | 430d |  | GP; S2; RP | 29520h | 29520h | Rel-5 | Paolo | GP-10 | GERIMS-RABDES | Nokia | Shkumbin Hamiti | GERIMS-RABDES |  |
| 8958 | 110.2.1 | **Deleted - MuM control signalling for conversational multimedia services** | 621.25d | 2000-11-06 A | 2002-06-28 A | 100% | 2000-11-06 | 2002-06-28 | 430d |  | GP; S2; RP | 19200h | 19200h | Rel-5 | Paolo | GP-10 |  |  |  |  |  |
| 8959 | 110.2.1.1 | Deleted - Identification of requirements for MuM control signalling for conversational multimedia services | 330d | 2000-11-06 A | 2002-02-08 A | 100% | 2000-11-06 | 2002-02-08 | 330d | finish no earlier than 2002-02-08 | GP; S2; RP | 7920h | 7920h | Rel-5 | Paolo | GP-08 |  |  |  |  |  |
| 8960 | 110.2.1.2 | Deleted - Necessary modifications due to SIP | 40d | 2002-05-06 A | 2002-06-28 A | 100% | 2002-05-06 | 2002-06-28 | 40d | finish no earlier than 2002-06-28 | GP; S2; RP | 960h | 960h | Rel-5 | Paolo | GP-10 |  |  |  |  |  |
| 8961 | 110.3 | **Deleted - GERAN MS Conformance test for support of IMS** | 577.75d | 2001-06-11 A | 2002-12-20 A | 100% | 2001-06-11 | 2002-12-20 | 400d |  | GP | 6400h | 6400h | Rel-5 | Paolo | GP-12 | GERIMS-MSconf | Nokia | Shkumbin Hamiti | GERIMS-MSconf |  |
| 8962 | 110.3.1 | Deleted - MS test for support of IMS | 400d | 2001-06-11 A | 2002-12-20 A | 100% | 2001-06-11 | 2002-12-20 | 400d | finish no earlier than 2002-12-20 | G4 | 3200h | 3200h | Rel-5 | Paolo | GP-12 |  |  |  |  |  |
| 8963 | 110.4 | Deleted - GERAN BTS Conformance test for support of IMS | 577.75d | 2001-06-11 A | 2002-12-20 A | 100% | 2001-06-11 | 2002-12-20 | 400d |  | GP | 3200h | 3200h | Rel-5 | Paolo | GP-12 | GERIMS-BTSconf | Nokia | Shkumbin Hamiti | GERIMS-BTSconf |  |
| 8964 | 2767 | MS Conformance Testing of Dual Transfer Mode | 65d? | 2002-11-11 A | 2003-02-07 A | 100% | 2002-11-11 | 2003-02-07 | 65d? | finish no earlier than 2003-02-07 | G4; G5 | 1040h | 1040h | Rel-5 | Paolo |  | MSCTDTM | Vodafone | Dave Fox | MSCTDTM |  |
| 8965 | 2768 | **Handling of early Ues** | 1317.12d? | 2000-01-03 A | 2003-06-27 A | 100% | 2000-01-03 | 2003-06-27 | 911d? |  | S2 | 4488h | 4488h | Rel-5 | Maurice |  | LATE_UE |  |  | LATE_UE |  |
| 8966 | 2768.1 | Feasibility Study on Handling of early Ues | 50d? | 2002-10-07 A | 2002-12-13 A | 100% | 2002-10-07 | 2002-12-13 | 50d? | finish no earlier than 2002-12-13 | S2 | 400h | 400h | Rel-5 | Maurice |  |  |  |  |  |  |
| 8967 | 2768.2 | Stage 2 for Handling of early Ues | 125d? | 2003-01-06 A | 2003-06-27 A | 100% | 2003-01-06 | 2003-06-27 | 125d? | start no earlier than 2003-01-06 | S2 | 1000h | 1000h | Rel-5 | Maurice |  |  |  |  |  |  |
| 8968 | 2768.3 | FS for the Early Mobile Handling in UTRAN | 195d | 2002-09-09 A | 2003-06-06 A | 100% | 2002-09-09 | 2003-06-06 | 195d | finish no earlier than 2003-06-06 | R2 | 1560h | 1560h | Rel-5 | Yong-Jun |  | FSEarlyUE | Vodafone | alan.law@vodafone.com | FSEarlyUE |  |
| 8969 | 2768.4 | Note: Stage 3 RAN part not shown | 1d | 2000-01-03 A | 2000-01-03 A | 100% | 2000-01-03 | 2000-01-03 | 1d |  | RP | 8h | 8h | Rel-5 |  |  |  |  |  |  |  |
| 8970 | 2769 | --- RELEASE 4 --- | 326d? | 2000-01-03 A | 2001-03-30 A | 100% | 2000-01-03 | 2001-03-30 | 326d? |  | NP; GP; RP; SP; TP | 13040h | 13040h | Rel-4 | All |  |  |  |  |  |  |
| 8971 | 15 | **Miscellaneous UE Conformance Testing Activities** | 1387.75d | 2001-04-02 A | 2004-12-01 A | 100% | 2001-04-02 | 2004-12-01 | 958d |  | T1 | 36360h | 36360h | Rel-4 | Ingbert |  | MISTST1 |  |  | MISTST1 |  |
| 8972 | 15.1 | Optimization of Test Time, RF Aspects (FDD) | 508d | 2001-09-24 A | 2003-09-03 A | 100% | 2001-09-24 | 2003-09-03 | 508d | finish no earlier than 2003-09-03 | T1 | 4064h | 4064h | Rel-4 | Ingbert |  | MISTST1-OpFDD |  |  | MISTST1-OpFDD | 34.121 |
| 8973 | 15.2 | Optimization of Test Time, RF Aspects (TDD) | 508d | 2001-09-24 A | 2003-09-03 A | 100% | 2001-09-24 | 2003-09-03 | 508d | finish no earlier than 2003-09-03 | T1 | 4064h | 4064h | Rel-4 | Ingbert |  | MISTST1-OpTDD |  |  | MISTST1-OpTDD | 34.122 |
| 8974 | 15.3 | Extensions to R99 Test cases | 139.4w | 2001-04-02 A | 2003-12-02 A | 100% | 2001-04-02 | 2003-12-02 | 139.4w | finish no earlier than 2003-12-02 | T1 | 5576h | 5576h | Rel-4 | Ingbert |  | MISTST1-Ext |  |  | MISTST1-Ext | 34.123 p 1.2 |
| 8975 | 15.4 | Extension to R99 Test cases - TTCN | 439d | 2002-06-28 A | 2004-03-03 A | 100% | 2002-06-28 | 2004-03-03 | 439d | finish no earlier than 2004-03-03 | T1 | 3512h | 3512h | Rel-4 | Ingbert |  |  |  |  |  |  |
| 8976 | 15.5 | Creation of R99 TCs for TDD - prose | 719d | 2001-10-01 A | 2004-07-01 A | 100% | 2001-10-01 | 2004-07-01 | 719d | finish no earlier than 2004-07-01 | T1 | 5752h | 5752h | Rel-4 | Ingbert |  | MISTST1-TDD |  |  | MISTST1-TDD | 34.123-1 |
| 8977 | 15.6 | Deleted - Creation of R99 TCs for TDD - TTCN | 587d | 2002-09-03 A | 2004-12-01 A | 100% | 2002-09-03 | 2004-12-01 | 587d | finish no earlier than 2004-12-01 | T1 | 4696h | 4696h | Rel-4 | Ingbert | TP-26 |  |  |  |  |  |
| 8978 | 15.7 | Deleted - Review all other work items for impact on new or exiting 34 series specs. | 25.8w | 2002-07-02 A | 2002-12-27 A | 100% | 2002-07-02 | 2002-12-27 | 25.8w | finish no earlier than 2002-12-27 | T1 | 1032h | 1032h | Rel-4 | Ingbert | TP-18 |  |  |  |  | 34.121.122.123.125 |

Notes:
- 8948: Not started. Marked as stopped 12/2008
- 8949: Not started. Marked as stopped 12/2008
- 8950: Not started. Marked as stopped 12/2008
- 8951: Not started. Marked as stopped 12/2008
- 8952: AWS, Nokia, Ericsson, Nortel, Siemens, Motorola
- 8953: AWS, Nokia, Ericsson, Nortel, Siemens, Motorola
- 8954: -
- 8955: -
- 8956: -
- 8957: TERMINATED - NOT STANDARDIZED. Marked as stopped 12/2008
- 8958: TERMINATED - NOT STANDARDIZED. Marked as stopped 12/2008
- 8959: TERMINATED - NOT STANDARDIZED
- 8960: TERMINATED - NOT STANDARDIZED
- 8961: TERMINATED - NOT STANDARDIZED. Marked as stopped 12/2008
- 8962: TERMINATED - NOT STANDARDIZED. Marked as stopped 12/2008
- 8963: TERMINATED - NOT STANDARDIZED. Marked as stopped 12/2008
- 8964: Needed to complete DTM (R99)
- 8965: -
- 8966: -
- 8967: -
- 8968: -
- 8969: -
- 8970: -
- 8971: -
- 8972: It is believed that the current R99 test spec. can be optimised for faster overall test times. Marked as stopped 12/2008 (was 70% complete)
- 8973: It is believed that the current R99 test spec. can be optimised for faster overall test times
- 8974: Further test coverage of the R99 specification to cover supplementry services. Marked as stopped 12/2008 (was 70% complete)
- 8975: Marked as closed 12/2008 (was marked 50% complete)
- 8976: Marked as closed 12/2008 (was marked 50% complete)
- 8977: Marked as stopped 12/2008
- 8978: Marked as stopped 12/2008

| ID | WBS | Task | Duration | Start | Finish | Predecessors | Complete | Baseline start | Baseline finish | Baseline duration | Constraint | Resources | Work | Actual work | Acronym | Release | MCC resp | Acronym_3GU_Export | Impacted TSs and TRs | WI rapporteur name | WI rapporteur e-mail |
| --- | --- | --- | --- | --- | --- | --- | --- | --- | --- | --- | --- | --- | --- | --- | --- | --- | --- | --- | --- | --- | --- |
| 8979 | 46 | **Real Time Facsimile** | 127.25d | 2000-02-22 A | 2000-06-23 A |  | 100% | 2000-02-22 | 2000-06-23 | 89d |  | S1 | 4376h | 4376h | FAX-RT | Rel-4 | Alain | FAX-RT |  |  |  |
| 8980 | 46.1 | **Real Time Fax** | 127.25d | 2000-02-22 A | 2000-06-23 A |  | 100% | 2000-02-22 | 2000-06-23 | 89d |  | S2 | 3664h | 3664h |  | Rel-4 | Maurice |  |  |  |  |
| 8981 | 46.1.1 | Terminal capabilities, AT commands | 89d | 2000-02-22 A | 2000-06-23 A |  | 100% | 2000-02-22 | 2000-06-23 | 89d | finish no earlier than 2000-06-23 | T2 | 712h | 712h |  | Rel-4 |  |  | 21.904; 27.007 |  |  |
| 8982 | 46.1.2 | Signalling aspects (e.g. ICM) | 89d | 2000-02-22 A | 2000-06-23 A |  | 100% | 2000-02-22 | 2000-06-23 | 89d | start no earlier than 2000-02-22 | N1 | 712h | 712h |  | Rel-4 | Frederic |  |  |  |  |
| 8983 | 46.1.3 | Service provision | 89d | 2000-02-22 A | 2000-06-23 A |  | 100% | 2000-02-22 | 2000-06-23 | 89d | finish no earlier than 2000-06-23 | N3 | 712h | 712h |  | Rel-4 | Gwiho |  | 23.146 |  |  |
| 8984 | 46.1.4 | Review whether service/stage 1 aspects need to be aligned | 51d | 2000-04-14 A | 2000-06-23 A |  | 100% | 2000-04-14 | 2000-06-23 | 51d | finish no earlier than 2000-12-14 | S1 | 408h | 408h |  | Rel-4 | Alain |  |  |  |  |
| 8985 | 46.1.5 | Review whether architecture/stage 2 aspects need to be aligned | 51d | 2000-04-14 A | 2000-06-23 A |  | 100% | 2000-04-14 | 2000-06-23 | 51d | finish no earlier than 2000-12-14 | S2 | 408h | 408h |  | Rel-4 | Maurice |  |  |  |  |
| 8986 | 47 | Transparent End-to-End PS mobile streaming application | 365.5d | 2000-04-03 A | 2001-03-21 A |  | 100% | 2000-04-03 | 2001-03-21 | 253d | finish no earlier than 2000-12-29 | S4 | 2024h | 2024h | PSTREAM | Rel-4 | Paolo | PSTREAM | 26.233; 26.234 |  |  |
| 8987 | 48 | **Multimedia Messaging** | 400.75d | 2000-02-22 A | 2001-03-14 A |  | 100% | 2000-02-22 | 2001-03-14 | 277d |  | T2; S1 | 14424h | 14424h | MMS4 | Rel-4 | Kimmo | MMS, Rel-4 | 22.140; 23.140 | Siemens | Josef.Laumen@SAL.SIEMENS.DE |
| 8988 | 48.1 | Definition of service requirements for Multimedia Messaging | 72d | 2000-02-22 A | 2000-05-31 A |  | 100% | 2000-02-22 | 2000-05-31 | 72d | start no earlier than 2000-02-22 | S1 | 576h | 576h |  | Rel-4 | Alain |  |  |  |  |
| 8989 | 48.2 | Review of definition of service requirements | 205d | 2000-06-01 A | 2001-03-14 A | 8988 | 100% | 2000-06-01 | 2001-03-14 | 205d | finish no earlier than 2000-09-08 | T2 | 1640h | 1640h |  | Rel-4 | Kimmo |  | 22.140; 23.140 | Siemens |  |
| 8990 | 48.3 | **Technical Realisation** | 351d | 2000-04-10 A | 2001-03-14 A |  | 100% | 2000-04-10 | 2001-03-14 | 243d |  | T2 | 7776h | 7776h |  | Rel-4 | Kimmo |  | 22.140; 23.140 | Siemens | Josef.Laumen@SAL.SIEMENS.DE |
| 8991 | 48.3.1 | Review of definition of reference Achitecture model | 243d | 2000-04-10 A | 2001-03-14 A |  | 100% | 2000-04-10 | 2001-03-14 | 243d | finish no earlier than 2001-03-14 | T2 | 1944h | 1944h |  | Rel-4 | Kimmo |  | 22.140; 23.140 | Siemens | Josef.Laumen@SAL.SIEMENS.DE |
| 8992 | 48.3.2 | Fulfill Requirements of Stage 1 | 243d | 2000-04-10 A | 2001-03-14 A |  | 100% | 2000-04-10 | 2001-03-14 | 243d | finish no earlier than 2001-03-14 | T2 | 1944h | 1944h |  | Rel-4 | Kimmo |  | 22.140; 23.140 | Siemens | Josef.Laumen@SAL.SIEMENS.DE |
| 8993 | 48.3.3 | Definition of MMS primitives in Stage 2 | 243d | 2000-04-10 A | 2001-03-14 A |  | 100% | 2000-04-10 | 2001-03-14 | 243d | finish no earlier than 2001-03-14 | T2 | 1944h | 1944h |  | Rel-4 | Kimmo |  | 22.140; 23.140 | Siemens | Josef.Laumen@SAL.SIEMENS.DE |
| 8994 | 49 | **Transcoder-Free Operation** | 468.88d | 2000-01-03 A | 2001-03-30 A |  | 100% | 2000-01-03 | 2001-03-30 | 326d |  | N4; S2; N1 | 18272h | 18272h | TrFO | Rel-4 | Kimmo | TrFO |  |  |  |
| 8995 | 49.1 | **Out-of-Band Transcoder Control solution** | 468.88d | 2000-01-03 A | 2001-03-30 A |  | 100% | 2000-01-03 | 2001-03-30 | 326d |  | N4 | 8448h | 8448h | TrFO-OoBTC | Rel-4 | Kimmo | TrFO-OoBTC |  | NEC | Toshiyuki Tamura (tamurato@aj.jp.nec.com) |
| 8996 | 49.1.1 | implementation in UTRAN | 145d | 2000-09-11 A | 2001-03-30 A |  | 100% | 2000-09-11 | 2001-03-30 | 145d | finish no earlier than 2001-03-30 | R3 | 1160h | 1160h | TrFO-OoBTC-UTRAN | Rel-4 | Juha | TrFO-OoBTC-UTRAN | 25.401; 25.410; 25.413; 25.415; 23.153 | Siemens | Alexander Vesely |
| 8997 | 49.1.2 | Impact on architecture, Principles and Terminology | 211d | 2000-01-03 A | 2000-10-20 A |  | 100% | 2000-01-03 | 2000-10-20 | 211d | finish no earlier than 2000-10-20 | S2 | 1680h | 1680h |  | Rel-4 | Maurice |  |  |  |  |
| 8998 | 49.1.3 | Codec Negotiation between UE and MSC | 125d | 2000-08-14 A | 2001-02-02 A |  | 100% | 2000-08-14 | 2001-02-02 | 125d | finish no earlier than 2001-02-02 | N1 | 1000h | 1000h |  | Rel-4 | Frederic |  | 24.008; 23.009; 23.108; (29.002) | Motorola | Andrew Howell |
| 8999 | 49.1.4 | Codec Negotiation inter MSC | 125d | 2000-07-03 A | 2000-12-22 A |  | 100% | 2000-07-03 | 2000-12-22 | 125d | finish no earlier than 2000-12-22 | N4 | 1000h | 1000h |  | Rel-4 | Kimmo |  |  |  |  |
| 9000 | 49.1.5 | Bearer establishment inter MSC | 125d | 2000-07-03 A | 2000-12-22 A |  | 100% | 2000-07-03 | 2000-12-22 | 125d | finish no earlier than 2000-12-22 | N4 | 1000h | 1000h |  | Rel-4 | Kimmo |  | 23.153 |  |  |
| 9001 | 49.2 | **Speech Transcoder: Location and Control at the UMTS Core Network Border** | 179d | 2000-04-10 A | 2000-09-29 A |  | 100% | 2000-04-10 | 2000-09-29 | 125d |  | S2 | 2000h | 2000h | TrFO-STLC | Rel-4 | Maurice | TrFO-STLC |  |  |  |
| 9002 | 49.2.1 | Transcoder at Edge | 125d | 2000-04-10 A | 2000-09-29 A |  | 100% | 2000-04-10 | 2000-09-29 | 125d | finish no earlier than 2000-09-29 | NP | 1000h | 1000h |  | Rel-4 | Kimmo |  |  |  |  |

Notes:
- 8979: -
- 8980: postponed from R99 to R00, SP-000169
- 8981: -
- 8982: -
- 8983: -
- 8984: -
- 8985: -
- 8986: -
- 8987: Acronym changed from "MMS, Rel-4"
- 8988: -
- 8989: -
- 8990: -
- 8991: -
- 8992: e.g. minimum set of media formats, media format conversion, personalization of MMS.
- 8993: -
- 8994: Lead given to CN4 from CN
- 8995: -
- 8996: moved according to NP-000575
- 8997: e.g. study cascading TrFO/TFO/TrFO
- 8998: the link to NP-000085has been deleted because refering to a R99 status sheet
- 8999: Bearer establishment inter MSC. TS 23.153 R99 part complete. capabilities moved to annex + list of open issues
- 9000: Bearer establishment inter MSC. TS 23.153 R99 part complete. capabilities moved to annex.
- 9001: WI description and Tdoc S2-99352
- 9002: WI description and Tdoc S2-99352

| ID | WBS | Task | Duration | Start | Finish | Complete | Baseline start | Baseline finish | Baseline duration | Constraint | Resources | Work | Actual work | Acronym | Release | MCC resp | Acronym_3GU_Export | WI rapporteur name | WI rapporteur e-mail |
| --- | --- | --- | --- | --- | --- | --- | --- | --- | --- | --- | --- | --- | --- | --- | --- | --- | --- | --- | --- |
| 9003 | 50 | **GERAN improvements 1 (Gb over IP)** | 326.25d | 2000-05-09 A | 2001-03-19 A | 100% | 2000-05-09 | 2001-03-19 | 225d |  | GP | 6472h | 6472h | GEIMP1 | Rel-4 | Paolo | GEIMP1 |  |  |
| 9004 | 50.1 | **Gb over IP (Ip-fication of Gb)** | 326.25d | 2000-05-09 A | 2001-03-19 A | 100% | 2000-05-09 | 2001-03-19 | 225d |  | GP | 4672h | 4672h | GbIP | Rel-4 | Paolo | GbIP |  |  |
| 9005 | 50.1.1 | Concept of Gb over IP (Ip-fication of Gb) | 134d | 2000-05-09 A | 2000-11-10 A | 100% | 2000-05-09 | 2000-11-10 | 134d |  | GP | 1072h | 1072h |  | Rel-4 | Paolo |  |  |  |
| 9006 | 50.1.2 | Changes to 08.16, 08.18 | 225d | 2000-05-09 A | 2001-03-19 A | 100% | 2000-05-09 | 2001-03-19 | 225d |  | GP | 1800h | 1800h |  | Rel-4 | Paolo |  |  |  |
| 9007 | 51 | **GERAN improvements 2 (NACC)** | 980.75d | 2000-11-06 A | 2003-06-10 A | 100% | 2000-11-06 | 2003-06-10 | 677d |  | GP | 22408h | 22408h | GEIMP2 | Rel-4 | Paolo | GEIMP2 |  |  |
| 9008 | 51.1 | **Gb enhancements** | 222.5d | 2000-11-06 A | 2001-06-08 A | 100% | 2000-11-06 | 2001-06-08 | 155d |  | GP | 7440h | 7440h | Gben | Rel-4 | Paolo | Gben |  |  |
| 9009 | 51.1.1 | **Intra BSC NACC (Network Assisted Cell Change)** | 222.5d | 2000-11-06 A | 2001-06-08 A | 100% | 2000-11-06 | 2001-06-08 | 155d |  | GP | 6200h | 6200h |  | Rel-4 | Paolo |  |  |  |
| 9010 | 51.1.1.1 | Concept | 155d | 2000-11-06 A | 2001-06-08 A | 100% | 2000-11-06 | 2001-06-08 | 155d | finish no earlier than 2001-06-08 | GP | 1240h | 1240h |  | Rel-4 | Paolo |  |  |  |
| 9011 | 51.1.1.2 | Changes in 03.64 | 155d | 2000-11-06 A | 2001-06-08 A | 100% | 2000-11-06 | 2001-06-08 | 155d | finish no earlier than 2001-06-08 | GP | 1240h | 1240h |  | Rel-4 | Paolo |  |  |  |
| 9012 | 51.1.1.3 | Changes in 04.60 | 155d | 2000-11-06 A | 2001-06-08 A | 100% | 2000-11-06 | 2001-06-08 | 155d | finish no earlier than 2001-06-08 | GP | 1240h | 1240h |  | Rel-4 | Paolo |  |  |  |
| 9013 | 51.1.1.4 | Changes in 44.008 | 155d | 2000-11-06 A | 2001-06-08 A | 100% | 2000-11-06 | 2001-06-08 | 155d | finish no earlier than 2001-06-08 | GP | 1240h | 1240h |  | Rel-4 | Paolo |  |  |  |
| 9014 | 51.3 | **MS conformance test for Intra BSC NACC** | 578d | 2001-11-30 A | 2003-06-10 A | 100% | 2001-11-30 | 2003-06-10 | 398d |  | GP | 9552h | 9552h | GEIMP2-Msconf | Rel-4 | Paolo | GEIMP2-Msconf |  |  |
| 9015 | 51.3.1 | Changes in 51.010 | 398d | 2001-11-30 A | 2003-06-10 A | 100% | 2001-11-30 | 2003-06-10 | 398d | finish no earlier than 2003-12-19 | G5; G4 | 6368h | 6368h |  | Rel-4 | Paolo |  |  |  |
| 9016 | 52 | **GERAN improvements 4 (Delayed TBF)** | 150d | 2001-01-15 A | 2001-06-08 A | 100% | 2001-01-15 | 2001-06-08 | 105d |  | GP | 4158h | 4158h | GEIMP4 | Rel-4 | Paolo | GEIMP4 |  |  |
| 9017 | 52.1 | **Gb enhancements 2** | 150d | 2001-01-15 A | 2001-06-08 A | 100% | 2001-01-15 | 2001-06-08 | 105d |  | GP | 3318h | 3318h | GEIMP4-Gben2 | Rel-4 | Paolo | GEIMP4-Gben2 |  |  |
| 9018 | 52.1.1 | Stage 2 for Gb enhancements 2 | 105d | 2001-01-15 A | 2001-06-08 A | 100% | 2001-01-15 | 2001-06-08 | 105d | finish no earlier than 2001-06-08 | GP | 840h | 840h |  | Rel-4 | Paolo |  |  |  |
| 9019 | 52.1.2 | **Stage 3 (changes in 44.060)** | 84.75d | 2001-01-15 A | 2001-04-06 A | 100% | 2001-01-15 | 2001-04-06 | 60d |  | G2 | 1638h | 1638h |  | Rel-4 | Gert |  |  |  |
| 9020 | 52.1.2.1 | Definition of enhanced countdown procedure | 60d | 2001-01-15 A | 2001-04-06 A | 100% | 2001-01-15 | 2001-04-06 | 60d | finish no earlier than 2001-04-06 | G2 | 480h | 480h |  | Rel-4 | Gert |  |  |  |
| 9021 | 52.1.2.2 | Definition of enhanced TBF release procedure | 60d | 2001-01-15 A | 2001-04-06 A | 100% | 2001-01-15 | 2001-04-06 | 60d | finish no earlier than 2001-04-06 | G2 | 480h | 480h |  | Rel-4 | Gert |  |  |  |
| 9022 | 52.1.2.3 | Definition of USF=FREE type polling mechanism on PDCH | 60d | 2001-01-15 A | 2001-04-06 A | 100% | 2001-01-15 | 2001-04-06 | 60d | finish no earlier than 2001-04-06 | G2 | 480h | 480h |  | Rel-4 | Gert |  |  |  |
| 9023 | 53 | **Low Chip Rate TDD option** | 1276d | 2000-07-19 A | 2003-12-02 A | 100% | 2000-07-19 | 2003-12-02 | 880d |  | R1 | 27488h | 27488h | LCRTDD | Rel-4 | Patrick | LCRTDD | CWTS | G. Yang |
| 9024 | 53.1 | Physical layer for Low Chip Rate TDD option | 183d | 2000-07-19 A | 2001-03-30 A | 100% | 2000-07-19 | 2001-03-30 | 183d | finish no earlier than 2001-03-30 | R1 | 1464h | 1464h | LCRTDD-Phys | Rel-4 | Patrick | LCRTDD-Phys | CWTS | G. Yang |
| 9025 | 53.2 | Layer 2 and layer 3 protocol aspects | 183d | 2000-07-19 A | 2001-03-30 A | 100% | 2000-07-19 | 2001-03-30 | 183d | finish no earlier than 2001-03-30 | R2 | 1464h | 1464h | LCRTDD-L23 | Rel-4 | Yong-Jun | LCRTDD-L23 | CWTS | Y. Liu |
| 9026 | 53.3 | RF radio transmission/reception, system performance requirements and conformance testing | 165d | 2000-08-14 A | 2001-03-30 A | 100% | 2000-08-14 | 2001-03-30 | 165d | finish no earlier than 2001-03-30 | R4 | 1320h | 1320h | LCRTDD-RF | Rel-4 | Issam | LCRTDD-RF | CWTS | D. Zhang |
| 9027 | 53.4 | UE radio access capability | 165d | 2000-08-14 A | 2001-03-30 A | 100% | 2000-08-14 | 2001-03-30 | 165d | finish no earlier than 2001-03-30 | R2 | 1320h | 1320h | LCRTDD-UErac | Rel-4 | Yong-Jun | LCRTDD-UErac | CWTS | Y. Liu |
| 9028 | 53.5 | Iub/Iur protocol aspects - for Low Chip Rate TDD option | 165d | 2000-08-14 A | 2001-03-30 A | 100% | 2000-08-14 | 2001-03-30 | 165d | finish no earlier than 2001-03-30 | R3 | 1320h | 1320h | LCRTDD-IubIur | Rel-4 | Juha | LCRTDD-IubIur | CWTS | Y. Liu |

Notes:
- 9003: -
- 9004: -
- 9005: -
- 9006: -
- 9007: -
- 9008: -
- 9009: -
- 9010: -
- 9011: -
- 9012: -
- 9013: -
- 9014: -
- 9015: az 05/08: duplicated UID_50099 => 50299. Marked as closed 12/2008 (was marked 50% complete)
- 9016: -
- 9017: -
- 9018: -
- 9019: -
- 9020: -
- 9021: -
- 9022: -
- 9023: -
- 9024: -
- 9025: -
- 9026: -
- 9027: -
- 9028: -

| ID | WBS | Task | Duration | Start | Finish | Predecessors | Complete | Baseline start | Baseline finish | Baseline duration | Constraint | Resources | Work | Actual work | Release | MCC resp | Impacted TSs and TRs | TSG stopped | Acronym | WI rapporteur name | WI rapporteur e-mail | Acronym_3GU_Export |
| --- | --- | --- | --- | --- | --- | --- | --- | --- | --- | --- | --- | --- | --- | --- | --- | --- | --- | --- | --- | --- | --- | --- |
| 9029 | 53.6 | **Low chiprate TDD interworking with GERAN** | 146d | 2000-09-01 A | 2001-01-19 A | 9028 | 100% | 2000-09-01 | 2001-01-19 | 101d |  | GP | 1616h | 1616h | Rel-4 | Paolo |  |  |  |  |  |  |
| 9030 | 53.6.1 | Handover and Cell Selection / Reselection to UTRA 1.28 Mcps TDD | 101d | 2000-09-01 A | 2001-01-19 A |  | 100% | 2000-09-01 | 2001-01-19 | 101d | finish no earlier than 2001-01-19 | GP | 808h | 808h | Rel-4 | Paolo |  |  |  |  |  |  |
| 9031 | 53.8 | **Conformance Test Aspects - Low Chip Rate TDD** | 835.75d | 2001-09-17 A | 2003-12-02 A | 9029 | 100% | 2001-09-17 | 2003-12-02 | 577d |  | T1 | 12088h | 12088h | Rel-4 | Ingbert |  |  |  |  |  |  |
| 9032 | 53.8.1 | Testing Layer 2 and layer 3 protocol aspects | 468d | 2001-09-17 A | 2003-07-02 A |  | 100% | 2001-09-17 | 2003-07-02 | 468d | finish no earlier than 2003-07-02 | T1 | 3744h | 3744h | Rel-4 | Ingbert | 34.123-1; 34.123-2 |  |  |  |  |  |
| 9033 | 53.8.2 | Deleted - Testing Layer 2 and layer 3 protocol aspects - TTCN | 261d | 2002-12-03 A | 2003-12-02 A |  | 100% | 2002-12-03 | 2003-12-02 | 261d | finish no earlier than 2003-12-02 | T1 | 2088h | 2088h | Rel-4 | Ingbert | 34.123-3 | TP-22 |  |  |  |  |
| 9034 | 53.8.3 | Testing RF Radio Transmission and Reception | 205d | 2001-09-17 A | 2002-06-28 A |  | 100% | 2001-09-17 | 2002-06-28 | 205d | finish no earlier than 2002-06-28 | T1 | 1640h | 1640h | Rel-4 | Ingbert |  |  |  |  |  |  |
| 9035 | 54 | **Enable bearer independent CS architecture** | 816.88d | 2000-01-03 A | 2002-03-01 A |  | 100% | 2000-01-03 | 2002-03-01 | 566d |  | S2; N3; N4 | 28008h | 28008h | Rel-4 | Maurice |  |  | CSSPLIT | Siemens | Alexander Milinski | CSSPLIT |
| 9036 | 54.1 | **Enable bearer-independent call control** | 612.88d | 2000-01-03 A | 2001-08-16 A |  | 100% | 2000-01-03 | 2001-08-16 | 425d |  | N4 | 12344h | 12344h | Rel-4 | Kimmo |  |  |  | Ericsson | Heinz-Peter.Keutmann@eed.ericsson.se |  |
| 9037 | 54.1.1 | Architecture and Stage 2 description | 181d | 2000-01-03 A | 2000-09-08 A |  | 100% | 2000-01-03 | 2000-09-08 | 181d | finish no earlier than 2000-09-08 | S2 | 1440h | 1440h | Rel-4 | Maurice | 23.002 |  |  |  |  |  |
| 9038 | 54.1.2 | Standardisation of protocols (control & user planes) over Nb interface | 64d | 2001-01-02 A | 2001-03-30 A |  | 100% | 2001-01-02 | 2001-03-30 | 64d | finish no earlier than 2001-03-30 | N3 | 512h | 512h | Rel-4 | Gwiho |  |  |  |  |  |  |
| 9039 | 54.1.3 | Standardisation of protocols over reference points between MSC server and Gateway MSC server | 130d | 2000-09-25 A | 2001-03-23 A |  | 100% | 2000-09-25 | 2001-03-23 | 130d | finish no earlier than 2001-03-23 | N4 | 1040h | 1040h | Rel-4 | Kimmo |  |  |  |  |  |  |
| 9040 | 54.1.4 | Standardisation of detailed stage 2 description | 180d | 2000-07-17 A | 2001-03-23 A |  | 100% | 2000-07-17 | 2001-03-23 | 180d | finish no earlier than 2001-03-23 | N4 | 1440h | 1440h | Rel-4 | Kimmo |  |  |  |  |  |  |
| 9041 | 54.1.5 | **Bearer control between MSC server and MGW** | 362.5d | 2000-09-01 A | 2001-08-16 A |  | 100% | 2000-09-01 | 2001-08-16 | 250d |  | N4 | 4512h | 4512h | Rel-4 | Kimmo |  |  |  |  |  |  |
| 9042 | 54.1.5.1 | stage 3 - protocol issues | 250d | 2000-09-01 A | 2001-08-16 A |  | 100% | 2000-09-01 | 2001-08-16 | 250d | finish no earlier than 2001-08-16 | N4 | 2000h | 2000h | Rel-4 | Kimmo |  |  |  |  |  |  |
| 9043 | 54.1.5.2 | stage 3 - parameter value issues | 64d | 2001-01-02 A | 2001-03-30 A |  | 100% | 2001-01-02 | 2001-03-30 | 64d | finish no earlier than 2001-03-30 | N3 | 512h | 512h | Rel-4 | Gwiho |  |  |  |  |  |  |
| 9044 | 54.4 | Deleted - Conformance Test Aspects - Enable bearer independent CS architecture | 260d | 2001-03-05 A | 2002-03-01 A |  | 100% | 2001-03-05 | 2002-03-01 | 260d |  | T1 | 2080h | 2080h | Rel-4 | Ingbert |  | TP-15 | CSSPLIT-TEST |  |  | CSSPLIT-TEST |
| 9045 | 55 | **MExE enhancements Rel-4** | 737.12d | 2000-01-03 A | 2001-12-14 A |  | 100% | 2000-01-03 | 2001-12-14 | 511d |  | T2; S3 | 26912h | 26912h | Rel-4 | Kimmo |  |  | MEXE |  |  | MEXE |
| 9046 | 55.1 | **MExE Security Analysis Activity** | 685.5d | 2000-02-22 A | 2001-12-14 A |  | 100% | 2000-02-22 | 2001-12-14 | 474d |  | S3; T2 | 12256h | 12256h | Rel-4 | Mirko |  |  | MEXE-SEC | BT | Andrew.Myers@bt.com | MEXE-SEC |
| 9047 | 55.1.1 | Stage 3 for MExE Security | 370d | 2000-07-17 A | 2001-12-14 A |  | 100% | 2000-07-17 | 2001-12-14 | 370d | finish no earlier than 2001-12-14 | S3 | 2960h | 2960h | Rel-4 | Mirko | 21.133; 33.102 |  |  | BT | Andrew.Myers@bt.com |  |
| 9048 | 55.1.2 | Terminal aspects for MExE Security | 214d | 2000-02-22 A | 2000-12-15 A |  | 100% | 2000-02-22 | 2000-12-15 | 214d | finish no earlier than 2000-12-15 | T2 | 1712h | 1712h | Rel-4 |  | 23.057 |  |  | BT | Andrew.Myers@bt.com |  |
| 9049 | 55.2 | **MExE Rel-4 Improvements and Investigations** | 360.12d | 2000-01-03 A | 2000-12-15 A |  | 100% | 2000-01-03 | 2000-12-15 | 251d |  | T2 | 6480h | 6480h | Rel-4 | Kimmo | 22.057; 23.057 |  | MEXE-ENHANC | Motorola | Mark Cataldo | MEXE-ENHANC |
| 9050 | 55.2.1 | 3rd MExE classmark | 251d | 2000-01-03 A | 2000-12-15 A |  | 100% | 2000-01-03 | 2000-12-15 | 251d | finish no earlier than 2000-12-15 | T2 | 2000h | 2000h | Rel-4 | Kimmo | 22.057; 23.057 |  |  | Motorola | Mark Cataldo |  |
| 9051 | 55.2.2 | FS on Secure download mechanism and capabilities to support SDR concepts | 225d | 2000-02-07 A | 2000-12-15 A |  | 100% | 2000-02-07 | 2000-12-15 | 225d | finish no earlier than 2000-12-15 | T2 | 1800h | 1800h | Rel-4 | Kimmo | 22.057; 23.057 |  |  | Motorola | Mark Cataldo |  |
| 9052 | 55.2.3 | FS on Support of MP3/MPEG4 content | 225d | 2000-02-07 A | 2000-12-15 A |  | 100% | 2000-02-07 | 2000-12-15 | 225d | finish no earlier than 2000-12-15 | T2 | 1800h | 1800h | Rel-4 | Kimmo | 22.057; 23.057 |  |  | Motorola | Mark Cataldo |  |

Notes:
- 9029: -
- 9030: -
- 9031: -
- 9032: Marked as closed 12/2008 (was marked 60% complete)
- 9033: Marked as stopped 12/2008
- 9034: duration set to 6 months (was 0), finish date set
- 9035: -
- 9036: DAB 12.12.01 should be 100% hence closed
- 9037: R00 stage 2 at least 80 % complete in TSGS #8 21.-23.6.2000
- 9038: -
- 9039: -
- 9040: -
- 9041: -
- 9042: -
- 9043: -
- 9044: Marked as stopped 12/2008
- 9045: -
- 9046: SP#12 updated WID
- 9047: -
- 9048: -
- 9049: -
- 9050: Additional features for MExE R2000
- 9051: -
- 9052: -

| ID | WBS | Task | Duration | Start | Finish | Complete | Baseline start | Baseline finish | Baseline duration | Constraint | Resources | Work | Actual work | Acronym | Release | MCC resp | Acronym_3GU_Export | Impacted TSs and TRs | WI rapporteur name | WI rapporteur e-mail |
| --- | --- | --- | --- | --- | --- | --- | --- | --- | --- | --- | --- | --- | --- | --- | --- | --- | --- | --- | --- | --- |
| 9053 | 56 | **Tandem Free aspects for 3G and between 2G and 3G systems** | 497d | 2000-02-22 A | 2001-06-15 A | 100% | 2000-02-22 | 2001-06-15 | 344d |  | S4 | 9696h | 9696h | TFO | Rel-4 | Paolo | TFO |  |  |  |
| 9054 | 56.1 | **Tandem Free AMR** | 497d | 2000-02-22 A | 2001-06-15 A | 100% | 2000-02-22 | 2001-06-15 | 344d |  | S4 | 6944h | 6944h | TFO-AMR | Rel-4 | Paolo | TFO-AMR |  |  |  |
| 9055 | 56.1.1 | Specification of Tandem Free AMR | 284d | 2000-02-22 A | 2001-03-23 A | 100% | 2000-02-22 | 2001-03-23 | 284d | start no earlier than 2000-02-22 | S4 | 2272h | 2272h |  | Rel-4 | Paolo |  | 28.062 |  |  |
| 9056 | 56.1.2 | **Impact of Tandem Free AMR on:** | 164.5d | 2001-01-08 A | 2001-06-15 A | 100% | 2001-01-08 | 2001-06-15 | 115d |  | NP | 1920h | 1920h |  | Rel-4 | Kimmo |  |  |  |  |
| 9057 | 56.1.2.1 | CN | 60d | 2001-03-26 A | 2001-06-15 A | 100% | 2001-03-26 | 2001-06-15 | 60d | finish no earlier than 2001-06-15 | NP | 480h | 480h |  | Rel-4 | Kimmo |  |  |  |  |
| 9058 | 56.1.2.2 | GERAN | 65d | 2001-01-08 A | 2001-04-06 A | 100% | 2001-01-08 | 2001-04-06 | 65d | finish no earlier than 2001-04-06 | GP | 520h | 520h |  | Rel-4 | Paolo |  |  |  |  |
| 9059 | 57 | **Advanced Speech Call Items enhancements_Rel-4** | 483.62d | 2000-12-03 A | 2002-03-14 A | 100% | 2000-12-03 | 2002-03-14 | 334d |  | N1 | 5925.6h | 5925.6h | ASCI4 | Rel-4 | Frederic | ASCI, Rel-4 |  | Nortel | sonia.garapaty@nortelnetworks.com |
| 9060 | 57.1 | Stage 2 for Advanced Speech Call Items enhancements_Rel-4 (ASCI) | 326.7d | 2000-12-03 A | 2002-03-14 A | 100% | 2000-12-03 | 2002-03-14 | 326.7d | finish no earlier than 2002-03-14 | N4 | 2613.6h | 2613.6h |  | Rel-4 | Kimmo |  | 23.067; 24.067 | Sagem | Vivien Perlic |
| 9061 | 57.2 | Stages 2 and 3 on A interface | 80d | 2000-12-03 A | 2001-03-23 A | 100% | 2000-12-03 | 2001-03-23 | 80d | finish no earlier than 2001-03-23 | N1 | 640h | 640h |  | Rel-4 | Frederic |  | 44.068; 44.069; 24.008 | Nortel | sonia.garapaty@nortelnetworks.com |
| 9062 | 58 | **700 MHz spectrum support** | 1121.38d | 2000-01-03 A | 2002-12-20 A | 100% | 2000-01-03 | 2002-12-20 | 776d |  | GP | 20016h | 20016h | 700SS | Rel-4 | Paolo | 700SS |  |  |  |
| 9063 | 58.1 | **GERAN support for the 700 MHz band** | 396.38d | 2000-01-03 A | 2001-01-19 A | 100% | 2000-01-03 | 2001-01-19 | 276d |  | GP | 8808h | 8808h |  | Rel-4 | Paolo |  |  |  |  |
| 9064 | 58.1.1 | Signalling support | 276d | 2000-01-03 A | 2001-01-19 A | 100% | 2000-01-03 | 2001-01-19 | 276d | finish no earlier than 2001-01-19 | GP | 2200h | 2200h |  | Rel-4 | Paolo |  |  |  |  |
| 9065 | 58.1.2 | Physical layer definitions - for GERAN support for the 700 MHz band | 276d | 2000-01-03 A | 2001-01-19 A | 100% | 2000-01-03 | 2001-01-19 | 276d | finish no earlier than 2001-01-19 | GP | 2200h | 2200h |  | Rel-4 | Paolo |  |  |  |  |
| 9066 | 58.1.3 | Receiver performance and RF budget | 276d | 2000-01-03 A | 2001-01-19 A | 100% | 2000-01-03 | 2001-01-19 | 276d | finish no earlier than 2001-01-19 | GP | 2200h | 2200h |  | Rel-4 | Paolo |  |  |  |  |
| 9067 | 58.2 | GERAN MS Conformance test for 700 MHz band | 251.5d | 2001-04-02 A | 2001-11-30 A | 100% | 2001-04-02 | 2001-11-30 | 175d |  | GP | 1400h | 1400h |  | Rel-4 | Paolo |  |  |  |  |
| 9068 | 58.3 | GERAN BTS Conformance test for 700 MHz band | 650.25d | 2001-04-02 A | 2002-12-20 A | 100% | 2001-04-02 | 2002-12-20 | 450d |  | GP | 3600h | 3600h |  | Rel-4 | Paolo |  |  |  |  |
| 9069 | 59 | Operator Determined Barring for Packet Oriented Services | 208d | 2000-06-01 A | 2001-03-19 A | 100% | 2000-06-01 | 2001-03-19 | 208d | finish no earlier than 2001-03-19 | NP | 1664h | 1664h | ODB | Rel-4 | Kimmo | ODB |  | NEC | Toshiyuki Tamura (tamurato@aj.jp.nec.com) |
| 9070 | 60 | **UMTS QoS Architecture for PS Domain** | 1097.62d | 2000-01-03 A | 2002-11-27 A | 100% | 2000-01-03 | 2002-11-27 | 759d |  | S2; S5; R3; GP | 72848h | 72848h | QoSPS | Rel-4 | Maurice | QoSPS |  | Ericsson | Ina.widegren@era.ericsson.se |
| 9071 | 60.1 | Architecture | 153d | 2000-06-05 A | 2001-01-03 A | 100% | 2000-06-05 | 2001-01-03 | 153d | finish no earlier than 2001-01-03 | S2 | 1224h | 1224h |  | Rel-4 | Maurice |  | 23.107 |  |  |
| 9072 | 60.2 | Charging and OAM&P for QoS Management | 201d | 2001-09-21 A | 2002-06-28 A | 100% | 2001-09-21 | 2002-06-28 | 201d | finish no earlier than 2002-06-28 | S5 | 1608h | 1608h | QoSPS-OAM | Rel-4 | Mirko | QoSPS-OAM | 32-series |  |  |
| 9073 | 60.3 | **RAB Quality of Service (re)Negotiation over Iu** | 222.5d | 2000-08-21 A | 2001-03-23 A | 100% | 2000-08-21 | 2001-03-23 | 155d |  | R3 | 3648h | 3648h | QoSPS-MAPEND-RABQoS | Rel-4 | Juha | QoSPS-MAPEND-RABQoS | 25.413 | Ericsson | anders.molander@ericsson.com |
| 9074 | 60.3.1 | RAB Quality of Service Negotiation over Iu | 155d | 2000-08-21 A | 2001-03-23 A | 100% | 2000-08-21 | 2001-03-23 | 155d | finish no earlier than 2001-03-23 | R3 | 1240h | 1240h | QoSPS-MAPEND-RABQoS-Negot | Rel-4 | Juha | QoSPS-MAPEND-RABQoS-Negot |  | Ericsson | anders.molander@ericsson.com |
| 9075 | 60.3.2 | RAB Quality of Service Negotiation over Iu during relocation | 16d | 2001-03-02 A | 2001-03-23 A | 100% | 2001-03-02 | 2001-03-23 | 16d | start no earlier than 2001-03-02 | R3 | 128h | 128h | QoSPS-MAPEND-RABQoS-NegotReloc | Rel-4 | Juha | QoSPS-MAPEND-RABQoS-NegotReloc |  |  |  |
| 9076 | 60.3.3 | RAB Quality of Service Re-Negotiation over Iu | 130d | 2000-09-25 A | 2001-03-23 A | 100% | 2000-09-25 | 2001-03-23 | 130d | finish no earlier than 2001-03-23 | R3 | 1040h | 1040h | QoSPS-MAPEND-RABQoS-ReNegot | Rel-4 | Juha | QoSPS-MAPEND-RABQoS-ReNegot |  | Motorola | S. Irwin |

Notes:
- 9053: RAN and CN to verify no problems for GSM terminals roaming in 3G R99
- 9054: RAN and CN to verify UMTS_AMR_2 support
- 9055: -
- 9056: "Implementation" changed to "Impact on:" by A. Sultan (for better wording)
- 9057: RAN and CN to verify UMTS_AMR_2 support
- 9058: End date Modified from June to March to have it in Rel4
- 9059: Approved at CN#10. Acronym changed from ASCI, Rel-4
- 9060: CN4#11 30/11/02: no inputs received in CN4
- 9061: -
- 9062: -
- 9063: -
- 9064: -
- 9065: -
- 9066: -
- 9067: -
- 9068: -
- 9069: Completed WI missing from the P-plan Added for tracking
- 9070: -
- 9071: -
- 9072: -
- 9073: -
- 9074: -
- 9075: -
- 9076: -

| ID | WBS | Task | Type | Duration | Start | Finish | Complete | Baseline start | Baseline finish | Baseline duration | Constraint | Resources | Work | Actual work | Acronym | Release | MCC resp | Acronym_3GU_Export | TSG stopped | WI rapporteur name | WI rapporteur e-mail | Impacted TSs and TRs |
| --- | --- | --- | --- | --- | --- | --- | --- | --- | --- | --- | --- | --- | --- | --- | --- | --- | --- | --- | --- | --- | --- | --- |
| 9077 | 60.4 | **GERAN QoS Aspects - Handovers: maintenance of real-time QoS while moving between cells in the PLMN including inter-SGSN and SRNS relocation or possibly other mechanisms** |  | 722.62d | 2000-01-03 A | 2001-11-30 A | 100% | 2000-01-03 | 2001-11-30 | 501d |  | GP | 14456h | 14456h | GERQoS | Rel-4 | Paolo | GERQoS |  |  |  |  |
| 9078 | 60.4.1 | **Handover Concept for the PS domain** |  | 722.62d | 2000-01-03 A | 2001-11-30 A | 100% | 2000-01-03 | 2001-11-30 | 501d |  | GP | 10448h | 10448h |  | Rel-4 | Paolo |  |  |  |  |  |
| 9079 | 60.4.1.1 | Stable RT handover report 25.936 including header removal |  | 14d | 2000-01-03 A | 2000-01-19 A | 100% | 2000-01-03 | 2000-01-19 | 14d | start no earlier than 2000-01-03 | GP | 104h | 104h |  | Rel-4 | Paolo |  |  |  |  |  |
| 9080 | 60.4.1.2 | Update of stage 2 |  | 293d | 2000-01-03 A | 2001-02-13 A | 100% | 2000-01-03 | 2001-02-13 | 293d | finish no earlier than 2001-02-13 | GP | 2336h | 2336h |  | Rel-4 | Paolo |  |  |  |  |  |
| 9081 | 60.4.1.3 | Update of relevant stage 3 specs -> RRC |  | 501d | 2000-01-03 A | 2001-11-30 A | 100% | 2000-01-03 | 2001-11-30 | 501d | finish no earlier than 2001-11-30 | G2 | 4000h | 4000h |  | Rel-4 | Gert |  |  |  |  |  |
| 9082 | 60.5 | **Deleted - GERAN MS Conformance test for inter-system and intra-system Packet data real-time Handover** |  | 470.25d | 2001-08-31 A | 2002-11-27 A | 100% | 2001-08-31 | 2002-11-27 | 324d |  | G4; R3 | 25920h | 25920h | GERQoS-Mstest | Rel-4 | Paolo | GERQoS-Mstest | GP-12 |  |  |  |
| 9083 | 60.5.1 | **Deleted - Handover for the PS domain** |  | 470.25d | 2001-08-31 A | 2002-11-27 A | 100% | 2001-08-31 | 2002-11-27 | 324d |  | G4; R3 | 20736h | 20736h |  | Rel-4 | Paolo |  | GP-12 |  |  |  |
| 9084 | 60.5.1.1 | Deleted - Stable RT handover report 25.936 including header removal |  | 324d | 2001-08-31 A | 2002-11-27 A | 100% | 2001-08-31 | 2002-11-27 | 324d | finish no earlier than 2002-11-27 | G4; R3 | 5184h | 5184h |  | Rel-4 | Paolo |  | GP-12 |  |  |  |
| 9085 | 60.5.1.2 | Deleted - Update of stage 2 |  | 324d | 2001-08-31 A | 2002-11-27 A | 100% | 2001-08-31 | 2002-11-27 | 324d | finish no earlier than 2002-11-27 | G4; R3 | 5184h | 5184h |  | Rel-4 | Paolo |  | GP-12 |  |  |  |
| 9086 | 60.5.1.3 | Deleted - Update of relevant stage 3 specs |  | 324d | 2001-08-31 A | 2002-11-27 A | 100% | 2001-08-31 | 2002-11-27 | 324d | finish no earlier than 2002-11-27 | G4; R3 | 5184h | 5184h |  | Rel-4 | Paolo |  | GP-12 |  |  |  |
| 9087 | 60.6 | PS-domain handover for real-time services |  | 155d | 2000-08-28 A | 2001-03-30 A | 100% | 2000-08-28 | 2001-03-30 | 155d | finish no earlier than 2001-03-30 | R3 | 1240h | 1240h | QoSPS-PSdoRTS | Rel-4 | Juha | QoSPS-PSdoRTS |  | Nokia | atte.lansisalmi@nokia.com |  |
| 9088 | 60.7 | Deleted - RAB QoS Renegotiation at Relocation |  | 58d | 2001-01-03 A | 2001-03-23 A | 100% | 2001-01-03 | 2001-03-23 | 58d | finish no earlier than 2001-03-23 | R3 | 464h | 464h |  | Rel-4 | Juha |  | RP-11 |  |  | 25.851; 25.946 |
| 9089 | 61 | (Small) Technical Enhancements and Improvements for Rel-4 | milestone | 0d? | 2000-01-03 A | 2000-01-03 A | 100% | 2000-01-03 | 2001-03-30 | 326d? |  | SP; CP; RP; GP |  |  | TEI4 | Rel-4 | all | TEI4 |  |  |  |  |
| 9090 | 2787 | Test - (Small) Technical Enhancements and Improvements for Rel-4 |  | 326d? | 2000-01-03 A | 2001-03-30 A | 100% | 2000-01-03 | 2001-03-30 | 326d? | finish no earlier than 2008-12-31 | R5; T1 | 5216h | 5216h | TEI4_Test | Rel-4 | Ingbert | TEI4_Test |  |  |  |  |
| 9091 | 62 | **Rel-4 Evolutions of the transport in the UTRAN** |  | 759d | 2000-08-21 A | 2002-08-23 A | 100% | 2000-08-21 | 2002-08-23 | 525d |  | RP | 8600h | 8600h | ETRAN | Rel-4 | Issam | ETRAN |  | Alcatel | Francois Courau |  |
| 9092 | 62.1 | QoS optimization for AAL2 connections over Iub and Iur interfaces |  | 160d | 2000-08-21 A | 2001-03-30 A | 100% | 2000-08-21 | 2001-03-30 | 160d | finish no earlier than 2001-03-30 | R3 | 1280h | 1280h | ETRAN-QoSAAL2 | Rel-4 | Juha | ETRAN-QoSAAL2 |  | Japan Telecom | T. Yoshimura |  |
| 9093 | 62.2 | Transport bearer modification procedure on Iub, Iur, and Iu |  | 130d | 2000-10-02 A | 2001-03-30 A | 100% | 2000-10-02 | 2001-03-30 | 130d | finish no earlier than 2001-03-30 | R3 | 1040h | 1040h | ETRAN-MigrMod | Rel-4 | Juha | ETRAN-MigrMod |  | Japan Telecom | T. Yoshimura |  |
| 9094 | 62.3 | **Deleted - Conformance Test Aspects of Rel-4 evolutions of the transport in UTRAN** |  | 186.25d | 2002-02-25 A | 2002-08-23 A | 100% | 2002-02-25 | 2002-08-23 | 130d |  | T1 | 2080h | 2080h |  | Rel-4 | Ingbert |  | TP-17 |  |  |  |
| 9095 | 62.3.1 | Deleted - Testing RAB support enhancements |  | 130d | 2002-02-25 A | 2002-08-23 A | 100% | 2002-02-25 | 2002-08-23 | 130d | finish no earlier than 2002-08-23 | T1 | 1040h | 1040h | CT-RABS? | Rel-4 | Ingbert | CT-RABS? | TP-17 |  |  | 34.108; 34; 121; 34.122; 34.123 p 1.2; 34.123 pt 3 |
| 9096 | 63 | **Rel-4 Evolutions of the transport in the CN** |  | 309.5d | 2000-05-29 A | 2001-03-23 A | 100% | 2000-05-29 | 2001-03-23 | 215d |  | N4; N1; N2; S2 | 13128h | 13128h | CNTRSP | Rel-4 | Kimmo | CNTRSP |  |  |  |  |
| 9097 | 63.1 | **IP Transport of CN protocols (e.g. CAP, MAP)** |  | 110.75d | 2000-12-07 A | 2001-03-23 A | 100% | 2000-12-07 | 2001-03-23 | 77d |  | N4 | 2808h | 2808h | SS7IP | Rel-4 | Kimmo | SS7IP |  |  |  |  |
| 9098 | 63.1.1 | **Stage 3 for IP Transport of CN protocols (e.g. CAP, MAP)** |  | 110.75d | 2000-12-07 A | 2001-03-23 A | 100% | 2000-12-07 | 2001-03-23 | 77d |  | N4 | 2192h | 2192h |  | Rel-4 | Kimmo |  |  |  |  |  |
| 9099 | 63.1.1.1 | CAP |  | 77d | 2000-12-07 A | 2001-03-23 A | 100% | 2000-12-07 | 2001-03-23 | 77d | finish no earlier than 2001-03-23 | N2 | 616h | 616h |  | Rel-4 | Kimmo |  |  |  |  |  |
| 9100 | 63.1.1.2 | MAP |  | 77d | 2000-12-07 A | 2001-03-23 A | 100% | 2000-12-07 | 2001-03-23 | 77d | finish no earlier than 2001-03-23 | N4 | 616h | 616h |  | Rel-4 | Kimmo |  |  |  |  | 29.202 |
| 9101 | 63.1.1.3 | BSSAP+ |  | 43d | 2001-01-15 A | 2001-03-14 A | 100% | 2001-01-15 | 2001-03-14 | 43d | finish no earlier than 2001-03-14 | N1 | 344h | 344h | SS7IP-BSSAP+ | Rel-4 | Frederic | SS7IP-BSSAP+ |  |  |  |  |

Notes:
- 9077: -
- 9078: -
- 9079: -
- 9080: -
- 9081: -
- 9082: Still exist? To be clarified by GERAN4/5. Marked as stopped 12/2008
- 9083: Marked as stopped 12/2008
- 9084: Marked as stopped 12/2008
- 9085: Marked as stopped 12/2008
- 9086: Marked as stopped 12/2008
- 9087: -
- 9088: Marked as stopped 12/2008
- 9089: "Joker" WI, to be used for a Rel 4 CR not related to any feature and with very limited impact on the system
- 9090: "Joker" WI, to be used for small modifications applicable to Rel 4 conformance testing. Moved in from the Stoyan/Testing WP
- 9091: -
- 9092: -
- 9093: -
- 9094: Marked as stopped 12/2008
- 9095: Marked as stopped 12/2008
- 9096: -
- 9097: -
- 9098: -
- 9099: -
- 9100: -
- 9101: -

| ID | WBS | Task | Duration | Start | Finish | Complete | Baseline start | Baseline finish | Baseline duration | Constraint | Resources | Work | Actual work | WI rapporteur name | WI rapporteur e-mail | Release | MCC resp | Acronym | Acronym_3GU_Export | Impacted TSs and TRs | TSG stopped |
| --- | --- | --- | --- | --- | --- | --- | --- | --- | --- | --- | --- | --- | --- | --- | --- | --- | --- | --- | --- | --- | --- |
| 9102 | 63.2 | **FS on Transport and control separation in the PS CN domain** | 309.5d | 2000-05-29 A | 2001-03-23 A | 100% | 2000-05-29 | 2001-03-23 | 215d |  | S2 | 3440h | 3440h | Ericsson | Juan-Antonio.Ibanez@eed.ericsson.se | Rel-4 | Maurice |  |  |  |  |
| 9103 | 63.2.1 | Architectural impacts | 215d | 2000-05-29 A | 2001-03-23 A | 100% | 2000-05-29 | 2001-03-23 | 215d | finish no earlier than 2001-03-23 | S2 | 1720h | 1720h |  |  | Rel-4 | Maurice |  |  |  |  |
| 9104 | 64 | **Rel-4 Improvements of Radio Interface** | 1012.75d | 2000-07-10 A | 2003-03-14 A | 100% | 2000-07-10 | 2003-03-14 | 700d |  | RP | 28624h | 28624h |  |  | Rel-4 |  |  |  |  |  |
| 9105 | 64.1 | UTRA repeater specification (master) | 183d | 2000-07-10 A | 2001-03-21 A | 100% | 2000-07-10 | 2001-03-21 | 183d | finish no earlier than 2001-03-21 | R4 | 1464h | 1464h | Mikom, Allgon | T. Kummetz, Mikom; Alf Ahlström, Allgon | Rel-4 | Issam | RInImp-REP | RInImp-REP |  |  |
| 9106 | 64.2 | DSCH power control improvement in soft handover | 140d | 2000-09-11 A | 2001-03-23 A | 100% | 2000-09-11 | 2001-03-23 | 140d | finish no earlier than 2001-03-23 | R1 | 1120h | 1120h | Nokia | antti.toskala@nokia.com | Rel-4 | Patrick | RInImp-DSCHsho | RInImp-DSCHsho |  |  |
| 9107 | 64.3 | UMTS 1800 | 320d | 2000-09-25 A | 2001-12-14 A | 100% | 2000-09-25 | 2001-12-14 | 320d | finish no earlier than 2001-12-14 | R4 | 2560h | 2560h | Motorola | Howard Benn | Rel-4 | Issam | RInImp-UMTS18 | RInImp-UMTS18 |  |  |
| 9108 | 64.4 | UMTS 1900 | 195d | 2001-03-19 A | 2001-12-14 A | 100% | 2001-03-19 | 2001-12-14 | 195d | finish no earlier than 2001-12-14 | R4 | 1560h | 1560h | Motorola | Howard Benn | Rel-4 | Issam | RInImp-UMTS19 | RInImp-UMTS19 | 25.101 |  |
| 9109 | 64.5 | FS on High Speed downlink packet access | 155d | 2000-08-21 A | 2001-03-23 A | 100% | 2000-08-21 | 2001-03-23 | 155d | finish no earlier than 2001-03-23 | R2 | 1240h | 1240h | Motorola | Amitabha Ghosh (qa0047@email.mot.com) | Rel-4 | Yong-Jun | RInImp-HSDPA | RInImp-HSDPA |  |  |
| 9110 | 64.6 | Deleted - FS on improved common DL channel for Cell-FACH state | 340d | 2000-09-11 A | 2001-12-28 A | 100% | 2000-09-11 | 2001-12-28 | 340d | finish no earlier than 2001-12-28 | R2 | 2720h | 2720h | GBT | J. Kwak | Rel-4 | Yong-Jun | RInImp-DLCFACH | RInImp-DLCFACH |  | RP-14 |
| 9111 | 64.7 | **Conformance Test Spec. Rel-4 improvements in Radio Interface** | 541.5d | 2001-10-08 A | 2003-03-14 A | 100% | 2001-10-08 | 2003-03-14 | 375d |  | T1 | 12360h | 12360h |  |  | Rel-4 | Ingbert |  |  |  |  |
| 9112 | 64.7.1 | Deleted - Testing Improved usage of downlink resource in FDD for CCTrCHs of dedicated type | 140d | 2002-02-18 A | 2002-08-30 A | 100% | 2002-02-18 | 2002-08-30 | 140d | finish no earlier than 2002-08-30 | T1 | 1120h | 1120h |  |  | Rel-4 | Ingbert |  |  |  | TP-17 |
| 9113 | 64.7.2 | Deleted - Testing Terminal Power saving features | 140d | 2002-02-18 A | 2002-08-30 A | 100% | 2002-02-18 | 2002-08-30 | 140d | finish no earlier than 2002-08-30 | T1 | 1120h | 1120h |  |  | Rel-4 | Ingbert |  |  |  | TP-17 |
| 9114 | 64.7.3 | Deleted - Testing DSCH power control improvement in soft handover | 140d | 2002-02-18 A | 2002-08-30 A | 100% | 2002-02-18 | 2002-08-30 | 140d | finish no earlier than 2002-08-30 | T1 | 1120h | 1120h |  |  | Rel-4 | Ingbert |  |  |  | TP-17 |
| 9115 | 64.7.4 | Testing UMTS 1800 | 180d | 2001-10-08 A | 2002-06-14 A | 100% | 2001-10-08 | 2002-06-14 | 180d | finish no earlier than 2002-06-14 | T1 | 1440h | 1440h |  |  | Rel-4 | Ingbert |  |  | 34.108; 34.121; 34.122; 34.123-1 |  |
| 9116 | 64.7.5 | Testing UMTS 1900 | 180d | 2001-10-08 A | 2002-06-14 A | 100% | 2001-10-08 | 2002-06-14 | 180d | finish no earlier than 2002-06-14 | T1 | 1440h | 1440h |  |  | Rel-4 | Ingbert |  |  | 34.108; 34.121; 34.122; 34.123-1 |  |
| 9117 | 64.7.6 | Testing UMTS 1800 - TTCN | 195d | 2002-06-17 A | 2003-03-14 A | 100% | 2002-06-17 | 2003-03-14 | 195d | finish no earlier than 2003-03-14 | T1 | 1560h | 1560h |  |  | Rel-4 | Ingbert |  |  | 34.123-3 |  |
| 9118 | 64.7.7 | Testing UMTS 1900 - TTCN | 195d | 2002-06-17 A | 2003-03-14 A | 100% | 2002-06-17 | 2003-03-14 | 195d | finish no earlier than 2003-03-14 | T1 | 1560h | 1560h |  |  | Rel-4 | Ingbert |  |  | 34.123-3 |  |
| 9119 | 65 | **Rel-4 RAN improvements** | 1358.75d? | 2000-08-14 A | 2004-03-17 A | 100% | 2000-08-14 | 2004-03-17 | 938d? |  | RP | 29336h | 29336h |  |  | Rel-4 |  |  |  |  |  |
| 9120 | 65.1 | Node B synchronization for TDD | 160d | 2000-08-14 A | 2001-03-23 A | 100% | 2000-08-14 | 2001-03-23 | 160d | finish no earlier than 2001-03-23 | R1 | 1280h | 1280h | Siemens | S. Oestreich | Rel-4 | Patrick | RANimp-NBsync | RANimp-NBsync |  |  |
| 9121 | 65.2 | RAB support enhancement for Rel-4 | 155d | 2000-08-21 A | 2001-03-23 A | 100% | 2000-08-21 | 2001-03-23 | 155d | finish no earlier than 2001-03-23 | R2 | 1240h | 1240h | Ericsson | M. Israelsson, A. Krishnarajah | Rel-4 | Yong-Jun | RANimp-RABSE | RANimp-RABSE |  |  |
| 9122 | 65.4 | **Deleted - Conformance Test Aspects - Rel-4 RAN Improvements** | 835.75d? | 2002-01-01 A | 2004-03-17 A | 100% | 2002-01-01 | 2004-03-17 | 577d? |  | T1 | 19312h | 19312h |  |  | Rel-4 | Ingbert |  |  |  | TP-23 |
| 9123 | 65.4.1 | Deleted - Testing Radio access bearer support enhancments | 175d | 2002-01-01 A | 2002-09-02 A | 100% | 2002-01-01 | 2002-09-02 | 175d | finish no earlier than 2002-09-02 | T1 | 1400h | 1400h |  |  | Rel-4 | Ingbert |  |  |  | TP-17 |
| 9124 | 65.4.2 | Deleted - Testing RAB support enhancements-Robust Header Compression | 332d | 2002-05-28 A | 2003-09-03 A | 100% | 2002-05-28 | 2003-09-03 | 332d | finish no earlier than 2003-09-03 | T1 | 2656h | 2656h |  |  | Rel-4 | Ingbert | RABimp-RoCH | RABimp-RoCH | 34.123-1; -2 | TP-21 |
| 9125 | 65.4.3 | Deleted - Testing RAB support enhancements-Robust Header Compression - TTCN | 472d | 2002-05-28 A | 2004-03-17 A | 100% | 2002-05-28 | 2004-03-17 | 472d | finish no earlier than 2004-03-17 | T1 | 3776h | 3776h |  |  | Rel-4 | Ingbert |  |  | 34.123-3 | TP-23 |
| 9126 | 65.4.4 | Testing of Extended Robut Header Compression | 270d | 2002-09-18 A | 2003-09-30 A | 100% | 2002-09-18 | 2003-09-30 | 270d | finish no earlier than 2003-09-30 | T1 | 2160h | 2160h |  |  | Rel-4 | Ingbert | Ext-RoHC | Ext-RoHC | 34.123-1; -2 |  |
| 9127 | 65.4.5 | Deleted - Testing of Extended Robut Header Compression - TTCN | 325d | 2002-09-18 A | 2003-12-16 A | 100% | 2002-09-18 | 2003-12-16 | 325d | finish no earlier than 2003-12-16 | T1 | 2600h | 2600h |  |  | Rel-4 | Ingbert |  |  | 34.123-3 | TP-22 |
| 9128 | 2791.3.6 | Deleted - General changes to TS34.121 corresponding to release 4 | 263d? | 2003-03-03 A | 2004-03-03 A | 100% | 2003-03-03 | 2004-03-03 | 263d? | finish no earlier than 2004-03-03 | T1 | 2104h | 2104h |  |  | Rel-4 | Ingbert | RANimp-test,TEI4 | RANimp-test, TEI4 | 34.108; 34.121 | TP-23 |

Notes:
- 9102: -
- 9103: -
- 9104: -
- 9105: -
- 9106: -
- 9107: -
- 9108: -
- 9109: -
- 9110: Stopped at RP#14
- 9111: -
- 9112: Marked as stopped 12/2008
- 9113: Marked as stopped 12/2008
- 9114: Marked as stopped 12/2008
- 9115: -
- 9116: -
- 9117: -
- 9118: -
- 9119: -
- 9120: -
- 9121: 29 Nov 2000: split into ROHC and non-ROHC part¦5 Mar 2001: splitting off of ROHC for Rel-4 agreed by R2
- 9122: Marked as stopped 12/2008
- 9123: Marked as stopped 12/2008
- 9124: UID changed. Marked as stopped 12/2008
- 9125: UID changed. Marked as stopped 12/2008
- 9126: Marked as closed 12/2008 (was marked 15% complete)
- 9127: Marked as stopped 12/2008
- 9128: Marked as stopped 12/2008

| ID | WBS | Task | Duration | Start | Finish | Complete | Baseline start | Baseline finish | Baseline duration | Constraint | Resources | Work | Actual work | Acronym | WI rapporteur name | Release | MCC resp | Special Focus Doc | Acronym_3GU_Export | TSG stopped | WI rapporteur e-mail | Status Report |
| --- | --- | --- | --- | --- | --- | --- | --- | --- | --- | --- | --- | --- | --- | --- | --- | --- | --- | --- | --- | --- | --- | --- |
| 9129 | 66 | **Rel-4 Emergency call enhancements** | 908.12d | 2000-01-03 A | 2002-05-28 A | 100% | 2000-01-03 | 2002-05-28 | 628d |  | N1; S1; T1 | 18672h | 18672h | EMC1-CS | Ericsson | Rel-4 | Frederic | Public Safety (I-A) | EMC1, EMC1-CS |  |  |  |
| 9130 | 66.1 | **For CS based calls** | 908.12d | 2000-01-03 A | 2002-05-28 A | 100% | 2000-01-03 | 2002-05-28 | 628d |  | N1 | 3600h | 3600h | EMC1-CS | Ericsson | Rel-4 | Frederic | Public Safety (I-A) | EMC1-CS |  |  |  |
| 9131 | 66.1.1 | Distinction in CS domain of emergency call types to different emergency services | 40d | 2000-05-01 A | 2000-06-23 A | 100% | 2000-05-01 | 2000-06-23 | 40d | finish no earlier than 2000-06-23 | S1 | 320h | 320h |  |  | Rel-4 | Alain | Public Safety (I-A) |  |  |  |  |
| 9132 | 66.1.2 | Distinction in CS domain of emergency calls to different emergency types | 22d | 2000-08-24 A | 2000-09-22 A | 100% | 2000-08-24 | 2000-09-22 | 22d | finish no earlier than 2000-09-22 | N1 | 176h | 176h |  |  | Rel-4 | Frederic | Public Safety (I-A) |  |  |  |  |
| 9133 | 66.1.3 | Deleted - Conformance Test Aspects - Emergency call enhancements | 151d | 2000-01-03 A | 2000-07-28 A | 100% | 2000-01-03 | 2000-07-28 | 151d |  | T1 | 1200h | 1200h |  |  | Rel-4 | Ingbert | Public Safety (I-A) |  | TP-08 |  |  |
| 9134 | 66.1.4 | Testing CS based emergency calls | 96.25d | 2002-02-25 A | 2002-05-28 A | 100% | 2002-02-25 | 2002-05-28 | 67d | finish no earlier than 2002-05-28 | T1 | 536h | 536h |  |  | Rel-4 | Ingbert | Public Safety (I-A) |  |  |  |  |
| 9135 | 66.1.5 | Testing CS based emergency calls - TTCN | 134d | 2001-11-22 A | 2002-05-28 A | 100% | 2001-11-22 | 2002-05-28 | 134d | finish no earlier than 2002-05-28 | T1 | 1072h | 1072h |  |  | Rel-4 | Ingbert | Public Safety (I-A) |  |  |  |  |
| 9136 | 67 | **Rel-4 Terminal interfaces** | 453.38d | 2000-01-03 A | 2001-03-15 A | 100% | 2000-01-03 | 2001-03-15 | 315d |  | T2 | 14296h | 14296h | TI |  | Rel-4 | Kimmo |  | TI |  |  |  |
| 9137 | 67.1 | **AT commands enhancements** | 452.38d | 2000-01-03 A | 2001-03-14 A | 100% | 2000-01-03 | 2001-03-14 | 314d |  | T2 | 5016h | 5016h | TI-ATC |  | Rel-4 | Kimmo |  | TI-ATC |  |  |  |
| 9138 | 67.1.1 | Specification of AT commands for new services | 314d | 2000-01-03 A | 2001-03-14 A | 100% | 2000-01-03 | 2001-03-14 | 314d | finish no earlier than 2001-03-14 | T2 | 2504h | 2504h |  |  | Rel-4 | Kimmo |  |  |  |  |  |
| 9139 | 67.2 | **Wide Area Data Synchronization** | 452.38d | 2000-01-03 A | 2001-03-14 A | 100% | 2000-01-03 | 2001-03-14 | 314d |  | T2 | 5016h | 5016h | TI-WADS |  | Rel-4 | Kimmo |  | TI-WADS |  |  |  |
| 9140 | 67.2.1 | Continues evolution of Synchronization protocol | 314d | 2000-01-03 A | 2001-03-14 A | 100% | 2000-01-03 | 2001-03-14 | 314d | finish no earlier than 2001-03-14 | T2 | 2504h | 2504h | TI-SYNC-EVOL |  | Rel-4 | Kimmo |  | TI-SYNC-EVOL |  |  |  |
| 9141 | 67.3 | Terminal local model | 218d | 2000-05-16 A | 2001-03-15 A | 100% | 2000-05-16 | 2001-03-15 | 218d | finish no earlier than 2001-03-15 | T2 | 1744h | 1744h | TLM | Ericsson | Rel-4 | Kimmo |  | TLM |  | Olga.Tome@ECS.ERICSSON.SE |  |
| 9142 | 68 | **Rel-4 Location Services enhancements** | 657.5d | 2000-04-03 A | 2001-12-28 A | 100% | 2000-04-03 | 2001-12-28 | 455d |  | S2; S1; T2; N1; N4; R3; R2 | 67671.2h | 67671.2h | LCS4 | Nokia | Rel-4 | Maurice |  | LCS1 |  | Jan Kall |  |
| 9143 | 68.1 | CBS interactions | 455d | 2000-04-03 A | 2001-12-28 A | 100% | 2000-04-03 | 2001-12-28 | 455d | finish no earlier than 2001-12-28 | T2 | 3640h | 3640h | LCS4-CBS |  | Rel-4 |  |  | LCS1-CBS |  |  |  |
| 9144 | 68.2 | LCS support in the CS domain | 180d | 2000-05-15 A | 2001-01-19 A | 100% | 2000-05-15 | 2001-01-19 | 180d | finish no earlier than 2001-01-19 | S2 | 1440h | 1440h | LCS4-CS |  | Rel-4 | Maurice |  | LCS1-CS |  |  |  |
| 9145 | 68.3 | **LCS support in the PS domain** | 628.5d | 2000-05-01 A | 2001-12-28 A | 100% | 2000-05-01 | 2001-12-28 | 435d |  | S2; S1; N1; N4 | 29880h | 29880h | LCS4-PS |  | Rel-4 | Maurice |  | LCS1-PS |  |  |  |
| 9146 | 68.3.1 | Stage 1 for LCS support in the PS domain | 40d | 2000-07-03 A | 2000-08-25 A | 100% | 2000-07-03 | 2000-08-25 | 40d | start no earlier than 2000-07-03 | S1 | 320h | 320h |  | Pacific Bell Wireless | Rel-4 | Alain |  |  |  | Randolph Wohlert (rwohlert@tri.sbc.com) |  |
| 9147 | 68.3.2 | Stage 2 for LCS support in the PS domain | 190d | 2000-05-01 A | 2001-01-19 A | 100% | 2000-05-01 | 2001-01-19 | 190d | finish no earlier than 2001-01-19 | S2; R2; G1 | 4560h | 4560h |  |  | Rel-4 | Maurice |  |  |  |  |  |
| 9148 | 68.3.3 | **Stage 3 for LCS support in the PS domain** | 512.5d | 2000-08-21 A | 2001-12-28 A | 100% | 2000-08-21 | 2001-12-28 | 355d |  | N1; N4 | 11080h | 11080h |  |  | Rel-4 | Frederic |  |  |  |  |  |
| 9149 | 68.3.3.1 | Layer 3 LCS signalling UE (MS) -SGSN (UMTS PS and and GSM-GPRS) | 355d | 2000-08-21 A | 2001-12-28 A | 100% | 2000-08-21 | 2001-12-28 | 355d | finish no earlier than 2001-12-28 | N1 | 2840h | 2840h |  | Nokia | Rel-4 | Frederic |  |  |  | Janne Muhonen |  |
| 9150 | 68.3.3.2 | MAP impacts of LCS | 160d | 2000-08-21 A | 2001-03-30 A | 100% | 2000-08-21 | 2001-03-30 | 160d | finish no earlier than 2001-03-30 | N4 | 1280h | 1280h |  |  | Rel-4 | Kimmo |  |  |  |  |  |
| 9151 | 68.3.3.3 | GTP signalling for LCS | 160d | 2000-08-21 A | 2001-03-30 A | 100% | 2000-08-21 | 2001-03-30 | 160d | finish no earlier than 2001-03-30 | N4 | 1280h | 1280h |  |  | Rel-4 | Kimmo |  |  |  |  |  |
| 9152 | 68.4 | **UE positioning Rel-4** | 374.75d | 2000-04-03 A | 2001-03-30 A | 100% | 2000-04-03 | 2001-03-30 | 260d |  | R3; R2 | 7231.2h | 7231.2h | LCS1-UEpos |  | Rel-4 | Issam |  | LCS1-UEpos |  |  | RP-010045 |
| 9153 | 68.4.1 | Iub/Iur interfaces for methods Rel 99 | 233.9d | 2000-04-03 A | 2001-03-30 A | 100% | 2000-04-03 | 2001-03-30 | 233.9d | finish no earlier than 2001-03-30 | R3 | 1871.2h | 1871.2h | LCS1-UEpos-IubIur | Ericsson | Rel-4 | Juha |  | LCS1-UEpos-IubIur |  | Yun-Chao Hu | RP-010045 |
| 9154 | 68.4.2 | UE positioning enhancements - IPDL for TDD | 150d | 2000-08-28 A | 2001-03-23 A | 100% | 2000-08-28 | 2001-03-23 | 150d | finish no earlier than 2001-03-23 | R2 | 1200h | 1200h | LCS1-UEpos-enh | Siemens | Rel-4 | Yong-Jun |  | LCS1-UEpos-enh |  | Armin Sitte | RP-010045 |

Notes:
- 9129: Acronym changed from EMC1, EMC1-CS
- 9130: WI approved in TSG_10
- 9131: -
- 9132: Calls to different emergency services such as ambulance, fire brigade, police, etc. can be routed to respective different emergency centres. / Impacted TSs and TRs: 24.008
- 9133: UID changed. Marked as stopped 12/2008
- 9134: - / Impacted TSs and TRs: 34.123-1
- 9135: - / Impacted TSs and TRs: 34.123-3
- 9136: -
- 9137: - / Impacted TSs and TRs: 27.007
- 9138: goal not completely achieved because of missing input / Impacted TSs and TRs: 27.007
- 9139: AS: Rel5 changed to Rel4 according to SP#10 decision, milestone on testing added
- 9140: - / Impacted TSs and TRs: 27.903; 27.103
- 9141: - / Impacted TSs and TRs: 23.227
- 9142: Acronym changed form LCS1
- 9143: - / Impacted TSs and TRs: 23.041
- 9144: Only MAP impact foreseen so far. To be further split if needed.
- 9145: -
- 9146: To be also considered: External LCS client identity, and Privacy options when PDP-context and when no PDP-context is established / Impacted TSs and TRs: 22.071
- 9147: SP#10 completed / Impacted TSs and TRs: 25.305 (UTRAN part); new 23.271 (CN part by S2; 43.059 (GERAN part)
- 9148: -
- 9149: -
- 9150: -
- 9151: -
- 9152: -
- 9153: - / Impacted TSs and TRs: 25.401; 25.420; 25.423; 25.430; 25.433; new 25.850
- 9154: 5 Mar 2001: split of IPDL for TDD agreed by R2 / Impacted TSs and TRs: new 25.847

| ID | WBS | Task | Duration | Start | Finish | Complete | Baseline start | Baseline finish | Baseline duration | Constraint | Resources | Work | Actual work | Acronym | Release | MCC resp | Acronym_3GU_Export | Impacted TSs and TRs | WI rapporteur name | WI rapporteur e-mail | TSG stopped |
| --- | --- | --- | --- | --- | --- | --- | --- | --- | --- | --- | --- | --- | --- | --- | --- | --- | --- | --- | --- | --- | --- |
| 9155 | 69 | **Rel-4 UICC/(U)SIM enhancements and interworking** | 251.5d | 2000-07-24 A | 2001-03-23 A | 100% | 2000-07-24 | 2001-03-23 | 175d |  | T3 | 2800h | 2800h | UICC1 | Rel-4 | Xavier | UICC1, Rel-4 |  |  |  |  |
| 9156 | 69.1 | Common PCN Handset Specification (CPHS) | 175d | 2000-07-24 A | 2001-03-23 A | 100% | 2000-07-24 | 2001-03-23 | 175d | finish no earlier than 2001-03-23 | T3 | 1400h | 1400h | UICC1-CPHS | Rel-4 | Xavier | UICC1-CPHS | 27.103 | One2One |  |  |
| 9157 | 70 | **Rel-4 (U)SIM toolkit enhancements** | 302.25d | 2000-06-05 A | 2001-03-23 A | 100% | 2000-06-05 | 2001-03-23 | 210d |  | T3; S1 | 6720h | 6720h | USAT4 | Rel-4 | Xavier | USAT1, USAT1-LocLnk, USAT1APIJAVA, USAT1SM | 23.048 (USAT1SM); 43.019 (USAT1APIJAVA) | Gemplus | Jean-Francois Rubon |  |
| 9158 | 70.1 | USAT local link | 210d | 2000-06-05 A | 2001-03-23 A | 100% | 2000-06-05 | 2001-03-23 | 210d | finish no earlier than 2001-03-23 | T3; S1 | 3360h | 3360h | USAT1-LocLnk | Rel-4 | Xavier | USAT1-LocLnk | 22.038; 31.111 | Gemplus | Jean-Francois Rubon |  |
| 9159 | 71 | **Rel-4 Security enhancements** | 831.38d | 2000-01-03 A | 2002-03-15 A | 100% | 2000-01-03 | 2002-03-15 | 576d |  | S3; N4; N1 | 38112h | 38112h | SEC4 | Rel-4 | Mirko | SEC1 |  | Vodafone | Peter.Howard@vodafone.com |  |
| 9160 | 54.2 | Rel-4 Lawful Interception | 155d | 2000-08-21 A | 2001-03-23 A | 100% | 2000-08-21 | 2001-03-23 | 155d | finish no earlier than 2001-03-23 | S3 | 1240h | 1240h | SEC4-LI | Rel-4 | Mirko | SEC1-LI | 33.107 |  |  |  |
| 9161 | 71.1 | Evolution of GSM CS algorithms (e.g. A5/3 development and deployment) | 272d | 2000-01-03 A | 2001-01-15 A | 100% | 2000-01-03 | 2001-01-15 | 272d | finish no earlier than 2001-01-15 | S3 | 2168h | 2168h | SEC1-CSALGO1 | Rel-4 | Mirko | SEC1-CSALGO1 | 33.102; 33.103; 33.105 | DTI, BIS | cbrookson@iee.org |  |
| 9162 | 71.2 | **Evolution of GSM PS algorithms (e.g. GEA 2 deployment)** | 315.75d | 2000-02-22 A | 2000-12-22 A | 100% | 2000-02-22 | 2000-12-22 | 219d |  | S3; N4; N1 | 9528h | 9528h | SEC1-PSALGO1 | Rel-4 | Mirko | SEC1-PSALGO1 | 33.102; 33.103; 33.105 | DTI, BIS | cbrookson@iee.org |  |
| 9163 | 71.2.1 | Deleted - Main aspects of Evolution of GSM PS algorithms (e.g. GEA 2 deployment) | 199d | 2000-02-22 A | 2000-11-24 A | 100% | 2000-02-22 | 2000-11-24 | 199d | finish no earlier than 2000-11-24 | S3 | 1592h | 1592h |  | Rel-4 | Mirko |  |  | DTI, BIS | cbrookson@iee.org | SP-69 |
| 9164 | 71.2.2 | Impact on GTP | 200d | 2000-03-20 A | 2000-12-22 A | 100% | 2000-03-20 | 2000-12-22 | 200d | finish no earlier than 2000-12-22 | N4 | 1600h | 1600h |  | Rel-4 | Kimmo |  |  | DTI, BIS | cbrookson@iee.org |  |
| 9165 | 71.2.3 | GEA capability indication in MS CM | 135d | 2000-06-19 A | 2000-12-22 A | 100% | 2000-06-19 | 2000-12-22 | 135d | finish no earlier than 2000-12-22 | N1 | 1080h | 1080h | SEC1-PSALGO1-GEACAP | Rel-4 | Frederic | SEC1-PSALGO1-GEACAP |  | Vodafone Airtouch | Duncan Mills |  |
| 9166 | 71.3 | **Deleted - MAP application layer security** | 831.38d | 2000-01-03 A | 2002-03-15 A | 100% | 2000-01-03 | 2002-03-15 | 576d |  | S3 | 11352h | 11352h | SEC1-MAPAL | Rel-4 | Mirko | SEC1-MAPAL |  |  |  | SP-15 |
| 9167 | 71.3.1 | Deleted - Main aspects of MAP application layer security | 199d | 2000-02-21 A | 2001-03-29 A | 100% | 2000-02-21 | 2001-03-29 | 199d | start no earlier than 2000-02-21 | S3 | 1592h | 1592h |  | Rel-4 | Mirko |  |  |  |  | SP-11 |
| 9168 | 71.3.2 | Deleted - Other stage 3 aspects | 199d | 2000-02-22 A | 2000-11-24 A | 100% | 2000-02-22 | 2000-11-24 | 199d | finish no earlier than 2000-11-24 | N4 | 1592h | 1592h |  | Rel-4 | Kimmo |  |  |  |  | CP-10 |
| 9169 | 71.3.3 | Deleted - Visibility and Configurability of security | 576d | 2000-01-03 A | 2002-03-15 A | 100% | 2000-01-03 | 2002-03-15 | 576d | finish no earlier than 2002-03-15 | S3 | 4600h | 4600h | SEC1-VCS | Rel-4 | Mirko | SEC1-VCS |  | France Telecom | Sebastien.nguyenngoc@rd.francetelecom.com | SP-15 |
| 9170 | 72 | **Rel-4 Charging and OAM&P** | 320d | 2000-12-01 A | 2001-10-05 A | 100% | 2000-12-01 | 2001-10-05 | 221d |  | S5 | 10472h | 10472h | OAM4 | Rel-4 | Mirko | OAM4 |  |  |  |  |
| 9171 | 72.1 | Rel-4 Principles, high level Requirements and Architecture | 145d | 2000-12-01 A | 2001-06-21 A | 100% | 2000-12-01 | 2001-06-21 | 145d | finish no earlier than 2001-06-21 | S5 | 1160h | 1160h |  | Rel-4 | Mirko |  | 32.101; 32.102 | Motorola, Telia | Michael.Truss@motorola.com, Tommy.R.Berggren@TELIA.SE |  |
| 9172 | 72.2 | Rel-4 Performance Management | 216d | 2000-12-01 A | 2001-09-28 A | 100% | 2000-12-01 | 2001-09-28 | 216d | finish no earlier than 2001-06-21 | S5 | 1728h | 1728h |  | Rel-4 | Mirko |  | 32.4xy; 52.402 | T-Mobile | karl-heinz.nenner@t-mobile.de |  |
| 9173 | 72.3 | Fault Management | 221d | 2000-12-01 A | 2001-10-05 A | 100% | 2000-12-01 | 2001-10-05 | 221d | finish no earlier than 2001-06-21 | S5 | 1768h | 1768h |  | Rel-4 | Mirko |  | 32.111-1/4 | Lucent |  |  |
| 9174 | 72.4 | Configuration Management | 145d | 2000-12-01 A | 2001-06-21 A | 100% | 2000-12-01 | 2001-06-21 | 145d | finish no earlier than 2001-06-21 | S5 | 1160h | 1160h |  | Rel-4 | Mirko |  | 32.106-1/8 | Ericsson | thomas.tovinger@ericsson.com |  |
| 9175 | 72.5 | Rel-4 Charging Management | 216d | 2000-12-01 A | 2001-09-28 A | 100% | 2000-12-01 | 2001-09-28 | 216d | finish no earlier than 2001-06-21 | S5 | 1728h | 1728h |  | Rel-4 | Mirko |  | 32.200; 32.205; 32.215; 32.235 | T-Mobile | karl-heinz.nenner@t-mobile.de |  |
| 9176 | 72.6 | UTRAN Operations and Maintenance procedures | 145d | 2000-12-01 A | 2001-06-21 A | 100% | 2000-12-01 | 2001-06-21 | 145d | finish no earlier than 2001-06-21 | S5 | 1160h | 1160h | UOAM | Rel-4 | Mirko | UOAM | 32.800 | Mannesmann Mobilfunk | bert.boden@d2mannesmann.de |  |
| 9177 | 73 | **Global Text Telephony** | 457.62d? | 2000-01-03 A | 2001-03-19 A | 100% | 2000-01-03 | 2009-09-18 | 2537d? |  | S1; S2; S4; T1; R5 | 18528h | 18528h | GTT | Rel-4 | Maurice | GTT |  | Ericsson | gunnar.hellstrom@omnitor.se |  |
| 9178 | 73.1 | Stage 1 for Global Text Telephony | 188d | 2000-04-05 A | 2000-12-22 A | 100% | 2000-04-05 | 2000-12-22 | 188d | finish no earlier than 2000-12-22 | S1 | 1504h | 1504h |  | Rel-4 | Alain |  | 22.226 |  |  |  |
| 9179 | 73.2 | Stage 2 for Global Text Telephony | 206d | 2000-01-03 A | 2000-10-13 A | 100% | 2000-01-03 | 2000-10-13 | 206d |  | S2 | 1640h | 1640h |  | Rel-4 | Maurice |  | 23.226 |  |  |  |

Notes:
- 9155: Acronym changed from UICC1, Rel-4
- 9156: 28/5/2001: CRs approved at TP-11. WI complete.
- 9157: Acronym changed from USAT1, USAT1-LocLnk, USAT1APIJAVA, USAT1SM
- 9158: 25/5/2001:CR was approved at TP-11. WI is complete
- 9159: acronym changed from SEC1
- 9160: Requirements capture: S3#14 (Aug 00), Feature specification: S3#15 (Sep 00), Definition of architecture. Should be included in general LI work mentioned above.. Acronym changed from SEC1-LI
- 9161: SP#8 approved WID
- 9162: SP#8 approved WID
- 9163: Complete TSG#09 (09/2000). S3#17: Proposed for deletion. TO BE DELETED
- 9164: -
- 9165: -
- 9166: REPLACED BY NDS-MAP and NDS-IP. Completed Auto Key Management -> Rel-6. Marked as stopped 12/2008
- 9167: UID changed. Marked as stopped 12/2008
- 9168: UID changed. Marked as stopped 12/2008
- 9169: CR approved at SA3#21 awaiting comments from CN1. Marked as stopped 12/2008
- 9170: SP#13 approved WID
- 9171: -
- 9172: -
- 9173: -
- 9174: -
- 9175: -
- 9176: -
- 9177: SP#12 updated WID SP-000162=>SP-010340
- 9178: -
- 9179: -

| ID | WBS | Task | Type | Duration | Start | Finish | Complete | Baseline start | Baseline finish | Baseline duration | Constraint | Resources | Work | Actual work | Acronym | Release | MCC resp | Acronym_3GU_Export | PCG stopped | TSG stopped |
| --- | --- | --- | --- | --- | --- | --- | --- | --- | --- | --- | --- | --- | --- | --- | --- | --- | --- | --- | --- | --- |
| 9180 | 73.3 | **Specification of Cellular Text telephone Modem** |  | 196.75d | 2000-09-11 A | 2001-03-19 A | 100% | 2000-09-11 | 2001-03-19 | 136d |  | S4 | 2704h | 2704h | GTT-CTM | Rel-4 | Paolo | GTT-CTM |  |  |
| 9181 | 73.3.1 | General description and C-code |  | 66d | 2000-09-11 A | 2000-12-11 A | 100% | 2000-09-11 | 2000-12-11 | 66d | finish no earlier than 2000-12-11 | S4 | 528h | 528h |  | Rel-4 | Paolo |  |  |  |
| 9182 | 73.3.2 | Minimum Performance requirements |  | 136d | 2000-09-11 A | 2001-03-19 A | 100% | 2000-09-11 | 2001-03-19 | 136d | finish no earlier than 2001-03-19 | S4 | 1088h | 1088h |  | Rel-4 | Paolo |  |  |  |
| 9183 | 73.5 | Deleted - Conformance Test Aspects - Global Text Telephony | milestone | 0d? | 2000-09-21 A | 2000-09-21 A | 100% | 2000-09-21 | 2009-09-18 | 2348d? | finish no earlier than 2009-09-18 | R5; T1 |  |  | GTT_Test | Rel-4 | Ingbert | GTT_Test | PCG-23 | RP-45 |
| 9184 | 2800 | --- RELEASE 99 --- |  | 261d? | 2000-01-03 A | 2000-12-29 A | 100% | 2000-01-03 | 2000-12-29 | 261d? |  | NP; SP; TP; SMG | 8352h | 8352h |  | R99 | All |  |  |  |
| 9185 | 2801 | **UMTS Features** |  | 378d? | 1999-01-01 A | 1999-12-31 A | 100% | 1999-01-01 | 1999-12-31 | 261d? |  | S1; S2; S4; SMG; N3; N4; RP | 39672h | 39672h |  | R99 | Alain |  |  |  |
| 9186 | 2801.1 | UMTS_SERVICES |  | 261d? | 1999-01-01 A | 1999-12-31 A | 100% | 1999-01-01 | 1999-12-31 | 261d? | start no earlier than 1999-01-01 | S1 | 2088h | 2088h | UMTS_SERVICES | R99 | Alain | UMTS_SERVICES |  |  |
| 9187 | 2801.2 | UMTS phase 1 |  | 261d? | 1999-01-01 A | 1999-12-31 A | 100% | 1999-01-01 | 1999-12-31 | 261d? | start no earlier than 1999-01-01 | S1 | 2088h | 2088h | UMTS1 | R99 | Alain | UMTS1 |  |  |
| 9188 | 2801.3 | UMTS Capabilities |  | 261d? | 1999-01-01 A | 1999-12-31 A | 100% | 1999-01-01 | 1999-12-31 | 261d? | start no earlier than 1999-01-01 | S1 | 2088h | 2088h | UMTS_Capabil | R99 | Alain | UMTS_Capabil |  |  |
| 9189 | 2801.4 | Architecture of the GSM-UMTS platform |  | 261d? | 1999-01-01 A | 1999-12-31 A | 100% | 1999-01-01 | 1999-12-31 | 261d? | start no earlier than 1999-01-01 | S2; N4 | 4176h | 4176h |  | R99 | Maurice |  |  |  |
| 9190 | 2801.5 | UMTS Terrestrial Radio Access Network |  | 261d? | 1999-01-01 A | 1999-12-31 A | 100% | 1999-01-01 | 1999-12-31 | 261d? | start no earlier than 1999-01-01 | RP | 2088h | 2088h | UTRAN | R99 | Yong-Jun | UTRAN |  |  |
| 9191 | 2801.6 | UMTS 1800, UMTS 1900 |  | 261d? | 1999-01-01 A | 1999-12-31 A | 100% | 1999-01-01 | 1999-12-31 | 261d? | start no earlier than 1999-01-01 | R2 | 2088h | 2088h | Rlnlmp19,Rlnlmp18 | R99 | Yong-Jun | Rlnlmp19, Rlnlmp18 |  |  |
| 9192 | 2801.7 | Mandatory speech codec for narrowband telephony service |  | 261d? | 1999-01-01 A | 1999-12-31 A | 100% | 1999-01-01 | 1999-12-31 | 261d? | start no earlier than 1999-01-01 | S4 | 2088h | 2088h | Mandatory_Speech_Codec,AMR-NB,AMR | R99 | Paolo | Mandatory_Speech_Codec, AMR-NB, AMR |  |  |
| 9193 | 2801.8 | Codec for low bitrate multimedia telephony service |  | 261d? | 1999-01-01 A | 1999-12-31 A | 100% | 1999-01-01 | 1999-12-31 | 261d? | start no earlier than 1999-01-01 | S4 | 2088h | 2088h | Low_bit_rate_codec_for_MM_Tel.,H.324M | R99 | Paolo | Low_bit_rate_codec_for_MM_Tel., H.324M |  |  |
| 9194 | 2801.9 | 3G Audio-Visual Terminal characteristics |  | 261d? | 1999-01-01 A | 1999-12-31 A | 100% | 1999-01-01 | 1999-12-31 | 261d? | start no earlier than 1999-01-01 | S4 | 2088h | 2088h | WI5TAC,3G-AVT,Terminal_Acoustic_Characteristics | R99 | Paolo | WI5TAC, 3G-AVT, Terminal_Acoustic_Characteristics |  |  |
| 9195 | 2801.10 | Updates_for_UMTS |  | 261d? | 1999-01-01 A | 1999-12-31 A | 100% | 1999-01-01 | 1999-12-31 | 261d? | start no earlier than 1999-01-01 | N3 | 2088h | 2088h | Updates_for_UMTS | R99 | Gwiho | Updates_for_UMTS |  |  |
| 9196 | 2801.11 | UMTS |  | 261d? | 1999-01-01 A | 1999-12-31 A | 100% | 1999-01-01 | 1999-12-31 | 261d? | start no earlier than 1999-01-01 | N3 | 2088h | 2088h | UMTS | R99 | Gwiho | UMTS |  |  |
| 9197 | 2802 | **UMTS and GSM Features** |  | 378d? | 1999-01-01 A | 1999-12-31 A | 100% | 1999-01-01 | 1999-12-31 | 261d? |  | S1; S2; SMG; T2; N1; N2; N3; N4; R2; R3 | 219240h | 219240h |  | R99 | Alain |  |  |  |
| 9198 | 2802.1 | Multimedia Messaging Service |  | 261d? | 1999-01-01 A | 1999-12-31 A | 100% | 1999-01-01 | 1999-12-31 | 261d? | start no earlier than 1999-01-01 | T2 | 2088h | 2088h | MMS | R99 |  | MMS |  |  |
| 9199 | 2802.2 | Location Services |  | 261d? | 1999-01-01 A | 1999-12-31 A | 100% | 1999-01-01 | 1999-12-31 | 261d? | start no earlier than 1999-01-01 | S1; S2; S3; SMG1; SMG2; SMG12; N1; N2; N4; R2; R3 | 22968h | 22968h | LCS | R99 | Alain | LCS |  |  |
| 9200 | 2802.3 | **Customised Application for Mobile network Enhanced Logic Phase 3** |  | 378d? | 1999-01-01 A | 1999-12-31 A | 100% | 1999-01-01 | 1999-12-31 | 261d? |  | S1; S2; N2; N4 | 18792h | 18792h | CAMEL3 | R99 | Alain | CAMEL3 |  |  |
| 9201 | 2802.3.1 | Global view |  | 261d? | 1999-01-01 A | 1999-12-31 A | 100% | 1999-01-01 | 1999-12-31 | 261d? | start no earlier than 1999-01-01 | S1; S2; N2; N4 | 8352h | 8352h |  | R99 | Alain |  |  |  |
| 9202 | 2802.3.2 | Multiple Subscriber Profile (MSP) based on CAMEL phase 3 |  | 261d? | 1999-01-01 A | 1999-12-31 A | 100% | 1999-01-01 | 1999-12-31 | 261d? | start no earlier than 1999-01-01 | S1 | 2088h | 2088h |  | R99 | Alain |  |  |  |
| 9203 | 2802.4 | Short Message Service enhancements / Enhanced Messaging Service (EMS) |  | 261d? | 1999-01-01 A | 1999-12-31 A | 100% | 1999-01-01 | 1999-12-31 | 261d? | start no earlier than 1999-01-01 | T2 | 2088h | 2088h | EMS | R99 |  | EMS |  |  |
| 9204 | 2802.5 | Mobile Station Execution Environment |  | 261d? | 1999-01-01 A | 1999-12-31 A | 100% | 1999-01-01 | 1999-12-31 | 261d? | start no earlier than 1999-01-01 | S1; SMG1; T2 | 6264h | 6264h | MExE | R99 | Alain | MExE |  |  |
| 9205 | 2802.6 | MS_Classmark |  | 261d? | 1999-01-01 A | 1999-12-31 A | 100% | 1999-01-01 | 1999-12-31 | 261d? | start no earlier than 1999-01-01 | N1 | 2088h | 2088h | MS_Classmark | R99 | Frederic | MS_Classmark |  |  |

Notes:
- 9180: -
- 9181: - / Impacted TSs and TRs: 26.226; 26.230
- 9182: - / Impacted TSs and TRs: 26.231
- 9183: RP#45 work item abandoned/closed (it was never really started)
- 9184: -
- 9185: -
- 9186: - / Impacted TSs and TRs: 22.101
- 9187: - / Impacted TSs and TRs: 22.100
- 9188: Requirement for high quality speech in UMTS Phase 1 but not in R99 / Impacted TSs and TRs: 22.105
- 9189: wid Architecture overview of the GSM-UMTS System, Architecture the GSM-UMTS Platform and New Access Network to Core Network (BSS-NSS) interface / Impacted TSs and TRs: 23.002; 23.008; 23.060; 23.101; 23.110
- 9190: - / Impacted TSs and TRs: 22.011; 22.038; 22.060; 22.078; 22.100; 22.101; 22.105; 22.115; 22.129; 23.002; 23.060; 24.007; 24.008; 25.101; 25.102; 25.104; 25.105; 25.113; 25.123; 25.133; 25.141; 25.142; 25.201; 25.211; 25.212; 25.213; 25.214; 25.215; 25.221; 25.222; 25.223; 25.224.
- 9191: - / Impacted TSs and TRs: 25.307 CR#0002; 0003 Inclusion of release independent RF related information
- 9192: Define the default speech codec for UMTS (both for FDD and TDD). Definition limited to selection of one codec among several existing ones/proposed codecs: GSM AMR, IS127 EVRC, ITU G.729 and MPEG-4 speech codec. / Impacted TSs and TRs: 04.08; 05.01; 05.02; 05.03; 05.05; 05.08; 05.09; 05.09; 05.50; 08.60; 08.61; 11.21; 26.071; 26.073; 26.074; 26.090; 26.091; 26.092; 26.093; 26.094; 26.101; 26.102; 26.103; 26.104; 26.975
- 9193: - / Impacted TSs and TRs: 26.104; 26.110; 26.111; 26.911; 26.912; 26.915
- 9194: - / Impacted TSs and TRs: 26.131; 26.132
- 9195: - / Impacted TSs and TRs: 24.022; 27.001; 29.007
- 9196: - / Impacted TSs and TRs: 27.060; 29.061
- 9197: -
- 9198: MMS allows users to send/receive messages e.g. almost unlimited text length, images, audio and video clips and new content types. R99 only includes the concept. MMS stage 3 is not included in 23.140. Rel-4 adds detailed architecture and protocols. / Impacted TSs and TRs: 22.140; 23.040; 23.140
- 9199: LCS provide ability to localize a terminal / Impacted TSs and TRs: 02.07; 03.71; 04.31; 04.35; 04.71; 05.05; 08.08; 08.31; 08.71; 09.31; 22.071; 23.002; 23.003; 23.007; 23.008; 23.016; 23.018; 23.032; 23.171; 24.007; 24.008; 24.030; 24.080; 25.305; 25.306; 25.331; 25.413; 25.423; 29.002; 29.010
- 9200: CAMEL is a network feature providing mechanisms to support services of operators which are not covered by standardised services, even when roaming outside the HPLMN. / Impacted TSs and TRs: 22.101; 23.008; 23.012; 23.016; 23.018; 23.060; 23.072; 23.078; 23.079; 23.082; 23.093; 29.002; 29.078
- 9201: - / Impacted TSs and TRs: 22.078; 23.078; 29.078
- 9202: MSP is an optional service enabling mobile subscribers to have several profiles associated with a single IMSI, with each profile being a subscription option. Each profile may be used for mobile originated and mobile terminated calls. / Impacted TSs and TRs: 22.097 (Advanced Addressing)
- 9203: SMS for 3G terminals compatible with GSM SMS. Added Enhanced Messaging Service (EMS) allowing small pictures, sounds, animations to be transferred via SMS. / Impacted TSs and TRs: 23.038; 23.039; 23.040; 23.042
- 9204: MExE provides a standardized MS execution environment and ability to negotiate its supported capabilities with a MExE SP. R99 enhances SIM MExE certificate management, security clarifications, QoS and defines two MExE classmarks WAP/Personal-Java based. / Impacted TSs and TRs: 02.57; 22.057; 22.101; 23.057
- 9205: MExE classmark identifies a category of MExE UE supporting MExE functionality with a minimum level of processing, memory, display, and interactive capabilities. Several MExE classmarks may be defined. / Impacted TSs and TRs: 24.008

| ID | WBS | Task | Duration | Start | Finish | Complete | Baseline start | Baseline finish | Baseline duration | Constraint | Resources | Work | Actual work | Acronym | Release | MCC resp | Acronym_3GU_Export | TSG stopped |
| --- | --- | --- | --- | --- | --- | --- | --- | --- | --- | --- | --- | --- | --- | --- | --- | --- | --- | --- |
| 9206 | 2802.7 | **MultiCall** | 378d? | 1999-01-01 A | 1999-12-31 A | 100% | 1999-01-01 | 1999-12-31 | 261d? |  | S1; N1; N2; N4 | 10440h | 10440h | Multicall | R99 | Alain | Multicall |  |
| 9207 | 2802.7.1 | Stage 1 for Multicall | 261d? | 1999-01-01 A | 1999-12-31 A | 100% | 1999-01-01 | 1999-12-31 | 261d? | start no earlier than 1999-01-01 | S1 | 2088h | 2088h |  | R99 | Alain |  |  |
| 9208 | 2802.8 | Virtual Home Environment | 261d? | 1999-01-01 A | 1999-12-31 A | 100% | 1999-01-01 | 1999-12-31 | 261d? | start no earlier than 1999-01-01 | S1; SMG1; S2 | 6264h | 6264h | VHE | R99 | Alain | VHE |  |
| 9209 | 2802.9 | Open Service Access | 261d? | 1999-01-01 A | 1999-12-31 A | 100% | 1999-01-01 | 1999-12-31 | 261d? | start no earlier than 1999-01-01 | S1; S2; N5 | 6264h | 6264h | OSA | R99 | Alain | OSA |  |
| 9210 | 2802.10 | Super Charger mechanism for signalling traffic associated with mobility | 261d? | 1999-01-01 A | 1999-12-31 A | 100% | 1999-01-01 | 1999-12-31 | 261d? | start no earlier than 1999-01-01 | N2; N4 | 4176h | 4176h | Super_Charger | R99 | Kimmo | Super_Charger |  |
| 9211 | 2802.11 | Follow_Me service | 261d? | 1999-01-01 A | 1999-12-31 A | 100% | 1999-01-01 | 1999-12-31 | 261d? | start no earlier than 1999-01-01 | S1; N2; N4 | 6264h | 6264h | Follow_Me | R99 | Alain | Follow_Me |  |
| 9212 | 2802.12 | Wide area network Synchronization and object exchange | 261d? | 1999-01-01 A | 1999-12-31 A | 100% | 1999-01-01 | 1999-12-31 | 261d? | start no earlier than 1999-01-01 | T2 | 2088h | 2088h | SYNC | R99 |  | SYNC |  |
| 9213 | 2802.13 | **R99 Terminal Interfaces** | 378d? | 1999-01-01 A | 1999-12-31 A | 100% | 1999-01-01 | 1999-12-31 | 261d? |  | T2 | 8352h | 8352h |  | R99 |  |  |  |
| 9214 | 2802.13.1 | AT commands for 3GPP | 261d? | 1999-01-01 A | 1999-12-31 A | 100% | 1999-01-01 | 1999-12-31 | 261d? | start no earlier than 1999-01-01 | T2 | 2088h | 2088h |  | R99 |  |  |  |
| 9215 | 2802.13.2 | Physical interfaces | 261d? | 1999-01-01 A | 1999-12-31 A | 100% | 1999-01-01 | 1999-12-31 | 261d? | start no earlier than 1999-01-01 | T2 | 2088h | 2088h |  | R99 |  |  |  |
| 9216 | 2802.13.3 | Multiplexer | 261d? | 1999-01-01 A | 1999-12-31 A | 100% | 1999-01-01 | 1999-12-31 | 261d? | start no earlier than 1999-01-01 | T2 | 2088h | 2088h | MUXMS-TE | R99 |  | MUX MS-TE |  |
| 9217 | 2802.14 | **Bearer Services** | 378d? | 1999-01-01 A | 1999-12-31 A | 100% | 1999-01-01 | 1999-12-31 | 261d? |  | S1; T2; N1; N3 | 41760h | 41760h |  | R99 | Alain |  |  |
| 9218 | 2802.14.1 | **Circuit Switched Bearer Services** | 378d? | 1999-01-01 A | 1999-12-31 A | 100% | 1999-01-01 | 1999-12-31 | 261d? |  | S1; N3 | 16704h | 16704h | Circuit_switched_Bearer_Services | R99 | Alain | Circuit_switched_Bearer_Services |  |
| 9219 | 2802.14.1.1 | Stage 1 for Circuit Switched Bearer Services | 261d? | 1999-01-01 A | 1999-12-31 A | 100% | 1999-01-01 | 1999-12-31 | 261d? | start no earlier than 1999-01-01 | S1 | 2088h | 2088h | CS_Bearerss_in_UMTS | R99 | Alain | CS_Bearerss_in_UMTS |  |
| 9220 | 2802.14.1.2 | CS_Bearers | 261d? | 1999-01-01 A | 1999-12-31 A | 100% | 1999-01-01 | 1999-12-31 | 261d? | start no earlier than 1999-01-01 | N3 | 2088h | 2088h | CS_Bearers | R99 | Gwiho | CS_Bearers |  |
| 9221 | 2802.14.1.3 | CS_Bearerss | 261d? | 1999-01-01 A | 1999-12-31 A | 100% | 1999-01-01 | 1999-12-31 | 261d? | start no earlier than 1999-01-01 | N3 | 2088h | 2088h | CS_Bearerss | R99 | Gwiho | CS_Bearerss |  |
| 9222 | 2802.14.1.4 | CS_Data | 261d? | 1999-01-01 A | 1999-12-31 A | 100% | 1999-01-01 | 1999-12-31 | 261d? | start no earlier than 1999-01-01 | N3 | 2088h | 2088h | CS_Data | R99 | Gwiho | CS_Data |  |
| 9223 | 2802.14.1.5 | CS_Data_Bearers | 261d? | 1999-01-01 A | 1999-12-31 A | 100% | 1999-01-01 | 1999-12-31 | 261d? | start no earlier than 1999-01-01 | N3 | 2088h | 2088h | CS_Data_Bearers | R99 | Gwiho | CS_Data_Bearers |  |
| 9224 | 2802.14.1.6 | Deleted - CN3 poart of Circuit Switched Bearer Services | 261d? | 1999-01-01 A | 1999-12-31 A | 100% | 1999-01-01 | 1999-12-31 | 261d? | start no earlier than 1999-01-01 | N3 | 2088h | 2088h | CSBS | R99 | Gwiho | CSBS | NP-06 |
| 9225 | 2802.14.2 | Frame Tunnelling Mode | 261d? | 1999-01-01 A | 1999-12-31 A | 100% | 1999-01-01 | 1999-12-31 | 261d? | start no earlier than 1999-01-01 | T2; N1; N3 | 6264h | 6264h | FTM | R99 | Gwiho | FTM |  |
| 9226 | 2802.14.3 | Access to ISPs and Intranets – Wireless/Remote access to LANs | 261d? | 1999-01-01 A | 1999-12-31 A | 100% | 1999-01-01 | 1999-12-31 | 261d? | start no earlier than 1999-01-01 | N3 | 2088h | 2088h | InterworkingwithPDN(DHCP) | R99 | Gwiho | Interworking with PDN (DHCP) |  |
| 9227 | 2802.14.4 | **PHS Internet Access Forum Specification** | 378d? | 1999-01-01 A | 1999-12-31 A | 100% | 1999-01-01 | 1999-12-31 | 261d? |  | S1; N3 | 8352h | 8352h | PIAFS | R99 | Alain | PIAFS |  |
| 9228 | 2802.14.4.1 | Personal Handyphone System Internet Access Forum Standard (PIAFS) | 261d? | 1999-01-01 A | 1999-12-31 A | 100% | 1999-01-01 | 1999-12-31 | 261d? | start no earlier than 1999-01-01 | S1 | 2088h | 2088h |  | R99 | Alain |  |  |
| 9229 | 2802.14.4.2 | Support_of_PIAFS_in_UMTS | 261d? | 1999-01-01 A | 1999-12-31 A | 100% | 1999-01-01 | 1999-12-31 | 261d? | start no earlier than 1999-01-01 | N3 | 2088h | 2088h | Support_of_PIAFS_in_UMTS | R99 | Gwiho | Support_of_PIAFS_in_UMTS |  |

Notes:
- 9206: Multicall allows several simultaneous CS calls with dedicated bearers of independent traffic and performance characteristics. R99 Multicall was defined as a supplementary service limited to one CS bearer to be used for speech at any time. / Impacted TSs and TRs: 22.030; 22.083; 22.087; 23.008; 23.009; 23.016; 23.018; 23.108; 23.135; 24.008; 24.080; 24.135; 29.002; 29.010
- 9207: - / Impacted TSs and TRs: 22.030; 22.083; 22.087
- 9208: Information exists in SP#5-8 reports & in SP-99416,SP-000095,SP 000155. OSA allows service development by operators and 3rd parties by making use of network functionality through open, standardised, secure, extensible and scalable interfaces. / Impacted TSs and TRs: 02.01; 22.105; 22.121.23.127
- 9209: Open Service Architecture became in later Releases Open Service Access. Produced by Parlay, ETSI SPAN (TISPAN), 3GPP SA1 (Stage 1), SA2 (Stage 2) and CN5 (Stage 3), resulting in a single set of standard OSA APIs for the whole development community. / Impacted TSs and TRs: 22.121; 23.127; 29.198; 29.998
- 9210: Super Charger reduces mobility management cost by reducing the volume of location update signalling. It changes subscriber data management associated with inter-VLR and SGSN location updates. It also applies to packet services (SGSN replaces VLR and / Impacted TSs and TRs: 21.905; 23.007; 23.008; 23.012; 23.016; 23.018; 23.040; 23.060; 23.116; 23.912; 29.002
- 9211: Follow Me enables a mobile subscriber A to manipulate the Follow Me data of a party B in such a way that - under certain conditions - subsequent calls directed to party B will be forwarded to subscriber A. It is PLMN-specific and control based on USSD / Impacted TSs and TRs: 21.905; 22.004; 22.030; 22.082; 22.090; 22.094; 23.090; 24.090; 22.094; 23.011; 23.015; 23.082; 29.002
- 9212: Allows data stored in ME/USIM to be synchronized with the outside world. TS 27.103 defines protocols based upon IrMC level 4 and will evaluate new technologies (XML) for inclusion. From Rel-4 IrMC was replaced by SyncML in 27.103. / Impacted TSs and TRs: 27.103; 27.903
- 9213: -
- 9214: AT commands to control a 3G ME via an external Terminal Equipment (TE), fully compatible with GSM AT commands. R99 adds new AT commands e.g. to control Advanced Speech Call Items (ASCI) services. / Impacted TSs and TRs: 27.005; 27.007
- 9215: Conclusion: 3GPP should not produce any technical specification for terminal interfaces other than radio interface and USIM interface. SDOs could develop own optional physical connector specification based on market requirements / Impacted TSs and TRs: 27.901
- 9216: Multiplexing protocol allowing a number of simultaneous sessions between a MS and a terminal¦used to send any data (voice, SMS, USSD, fax etc.). 27.010 describes the protocol, but not the commands or data transported with it. / Impacted TSs and TRs: 27.010
- 9217: -
- 9218: CS and real-time data services provided for interworking with PSTN/ISDN so that user is unaware of access network used (UMTS, GSM or handover between ANs). Transparent(constant delay) & non-transparent(zero error with flow control) services are supported / Impacted TSs and TRs: 22.002; 23.910; 27.001; 29.007
- 9219: CS and real-time data services provided for interworking with PSTN/ISDN so that user is unaware of access network used (UMTS, GSM or handover between ANs). Transparent(constant delay) & non-transparent(zero error with flow control) services are supported / Impacted TSs and TRs: 22.002
- 9220: - / Impacted TSs and TRs: 29.007
- 9221: - / Impacted TSs and TRs: 04.21; 23.910; 27.001; 29.007
- 9222: - / Impacted TSs and TRs: 27.001; 27.002; 27.003; 29.007
- 9223: - / Impacted TSs and TRs: 23.910; 27.001; 29.007
- 9224: No CR or new TS/TR approved under this WI / Impacted TSs and TRs: 23.910; 27.001; 29.007
- 9225: FTM is a type of async non-transparent CS bearer service (22.002). Generic term for HDLC and HDLC-related transmission protocols. Converts async non-transp data stream towards mobile side & sync data stream using X.31 flag stuffing on fixed network side. / Impacted TSs and TRs: 22.002; 27.001; 27.007; 29.007
- 9226: Access to an Intranet or ISP by running DHCP between the TE and a server in the Intranet/ISP domain. / Impacted TSs and TRs: 29.061
- 9227: PIAFS is one type of CS bearer data service (22.002). It refers to async CS tx protocol over ISDN 64 kbit/s unrestricted digital line. Facilitates interworking between PHS-MS and UMTS-UE & UMTS-UE and existing PIAFS TA (Terminal Adapter). / Impacted TSs and TRs: 22.002; 27.001; 27.007; 29.007
- 9228: PIAFS was originally standardised by the PHS Internet Access Forum in Japan. More information can be found at: http://www.infopro.or.jp/piaf / Impacted TSs and TRs: 22.002
- 9229: - / Impacted TSs and TRs: 27.001; 27.007; 29.007

| ID | WBS | Task | Duration | Start | Finish | Complete | Baseline start | Baseline finish | Baseline duration | Constraint | Resources | Work | Actual work | Acronym | Release | MCC resp | Acronym_3GU_Export | TSG stopped |
| --- | --- | --- | --- | --- | --- | --- | --- | --- | --- | --- | --- | --- | --- | --- | --- | --- | --- | --- |
| 9230 | 2802.15 | **Universal Integrated Circuit Card (UICC) and Universal Subscriber Identity Module (USIM)** | 378d? | 1999-01-01 A | 1999-12-31 A | 100% | 1999-01-01 | 1999-12-31 | 261d? |  | T3 | 31320h | 31320h | UICC,USIM | R99 | Xavier | UICC, USIM |  |
| 9231 | 2802.15.1 | UICC / Terminal interface; Physical and logical characteristics | 261d? | 1999-01-01 A | 1999-12-31 A | 100% | 1999-01-01 | 1999-12-31 | 261d? | start no earlier than 1999-01-01 | T3 | 2088h | 2088h | UICC | R99 | Xavier | UICC |  |
| 9232 | 2802.15.2 | UICC/(U)SIM enhancements and interworking | 261d? | 1999-01-01 A | 1999-12-31 A | 100% | 1999-01-01 | 1999-12-31 | 261d? | start no earlier than 1999-01-01 | T3 | 2088h | 2088h | UICC99 | R99 | Xavier | UICC1 |  |
| 9233 | 2802.15.3 | Characteristics of the USIM application | 261d? | 1999-01-01 A | 1999-12-31 A | 100% | 1999-01-01 | 1999-12-31 | 261d? | start no earlier than 1999-01-01 | T3 | 2088h | 2088h | USIM | R99 | Xavier | USIM |  |
| 9234 | 2802.15.4 | UICC Application Identifiers | 261d? | 1999-01-01 A | 1999-12-31 A | 100% | 1999-01-01 | 1999-12-31 | 261d? | start no earlier than 1999-01-01 | T3 | 2088h | 2088h | AID,Application_Identifiers | R99 | Xavier | AID, Application_Identifiers |  |
| 9235 | 2802.15.5 | SIM Application Toolkit | 261d? | 1999-01-01 A | 1999-12-31 A | 100% | 1999-01-01 | 1999-12-31 | 261d? | start no earlier than 1999-01-01 | S1; T3 | 4176h | 4176h | SAT | R99 | Alain | SAT |  |
| 9236 | 2802.15.6 | USIM Application Toolkit | 261d? | 1999-01-01 A | 1999-12-31 A | 100% | 1999-01-01 | 1999-12-31 | 261d? | start no earlier than 1999-01-01 | T3 | 2088h | 2088h | USAT | R99 | Xavier | USAT |  |
| 9237 | 2802.15.7 | Bearer Independent Protocol for SAT applications to exchange data over the GSM network | 261d? | 1999-01-01 A | 1999-12-31 A | 100% | 1999-01-01 | 1999-12-31 | 261d? | start no earlier than 1999-01-01 | T3 | 2088h | 2088h | BIP | R99 | Xavier | BIP |  |
| 9238 | 2802.15.8 | Administrative commands and functions for IC cards | 261d? | 1999-01-01 A | 1999-12-31 A | 100% | 1999-01-01 | 1999-12-31 | 261d? | start no earlier than 1999-01-01 | T3 | 2088h | 2088h |  | R99 | Xavier |  |  |
| 9239 | 2802.15.9 | USIM and UICC requirements | 261d? | 1999-01-01 A | 1999-12-31 A | 100% | 1999-01-01 | 1999-12-31 | 261d? | start no earlier than 1999-01-01 | T3 | 2088h | 2088h |  | R99 | Xavier |  |  |
| 9240 | 2802.15.10 | SIM_API | 261d? | 1999-01-01 A | 1999-12-31 A | 100% | 1999-01-01 | 1999-12-31 | 261d? | start no earlier than 1999-01-01 | T3 | 2088h | 2088h | SIM_API | R99 | Xavier | SIM_API |  |
| 9241 | 2802.15.11 | SIM_toolkit_API | 261d? | 1999-01-01 A | 1999-12-31 A | 100% | 1999-01-01 | 1999-12-31 | 261d? | start no earlier than 1999-01-01 | SMG9; T3 | 4176h | 4176h | SIM_toolkit | R99 | Xavier | SIM_toolkit |  |
| 9242 | 2802.15.12 | Deleted - 1.8 Volt SIM ME interface | 261d? | 1999-01-01 A | 1999-12-31 A | 100% | 1999-01-01 | 1999-12-31 | 261d? | start no earlier than 1999-01-01 | SMG9 | 2088h | 2088h | SMIME_1.8V | R99 | Xavier | SMIME_1.8V | TP-06 |
| 9243 | 2802.16 | **USIM/UICC Testing** | 378d? | 1999-01-01 A | 1999-12-31 A | 100% | 1999-01-01 | 1999-12-31 | 261d? |  | T3 | 10440h | 10440h |  | R99 | Xavier |  |  |
| 9244 | 2802.16.1 | Terminal tests for the UICC Interface | 261d? | 1999-01-01 A | 1999-12-31 A | 100% | 1999-01-01 | 1999-12-31 | 261d? | start no earlier than 1999-01-01 | T3 | 2088h | 2088h |  | R99 | Xavier |  |  |
| 9245 | 2802.16.2 | USIM application test specification | 261d? | 1999-01-01 A | 1999-12-31 A | 100% | 1999-01-01 | 1999-12-31 | 261d? | start no earlier than 1999-01-01 | T3 | 2088h | 2088h |  | R99 | Xavier |  |  |
| 9246 | 2802.16.3 | USIM conformance test specification | 261d? | 1999-01-01 A | 1999-12-31 A | 100% | 1999-01-01 | 1999-12-31 | 261d? | start no earlier than 1999-01-01 | T3 | 2088h | 2088h |  | R99 | Xavier |  |  |
| 9247 | 2802.16.4 | SIM toolkit test specification | 261d? | 1999-01-01 A | 1999-12-31 A | 100% | 1999-01-01 | 1999-12-31 | 261d? | start no earlier than 1999-01-01 | T3 | 2088h | 2088h |  | R99 | Xavier |  |  |
| 9248 | 2802.17 | **Security for UMTS and GSM Features** | 378d? | 1999-01-01 A | 1999-12-31 A | 100% | 1999-01-01 | 1999-12-31 | 261d? |  | S3; N2; N4 | 16704h | 16704h | Security | R99 | Mirko | Security |  |
| 9249 | 2802.17.1 | Fraud Information Gathering Service (for connection-orientated services) | 261d? | 1999-01-01 A | 1999-12-31 A | 100% | 1999-01-01 | 1999-12-31 | 261d? | start no earlier than 1999-01-01 | S3 | 2088h | 2088h | FIGS | R99 | Mirko | FIGS |  |
| 9250 | 2802.17.2 | Immediate Service Termination / SECurity Immediate Service Termination | 261d? | 1999-01-01 A | 1999-12-31 A | 100% | 1999-01-01 | 1999-12-31 | 261d? | start no earlier than 1999-01-01 | S3; N2; N4 | 6264h | 6264h | IST,SECIST | R99 | Mirko | IST, SECIST |  |
| 9251 | 2802.17.3 | Core_Network_Security | 261d? | 1999-01-01 A | 1999-12-31 A | 100% | 1999-01-01 | 1999-12-31 | 261d? | start no earlier than 1999-01-01 | N4 | 2088h | 2088h | Core_Network_Security | R99 | Kimmo | Core_Network_Security |  |
| 9252 | 2803 | **GSM Features** | 378d? | 1999-01-01 A | 1999-12-31 A | 100% | 1999-01-01 | 1999-12-31 | 261d? |  | S1; S2; SMG; T2; N1; N2; N3; N4 | 164952h | 164952h |  | R99 | Alain |  |  |
| 9253 | 2803.1 | **Dual Transfer Mode within GSM and GPRS** | 378d? | 1999-01-01 A | 1999-12-31 A | 100% | 1999-01-01 | 1999-12-31 | 261d? |  | SMG; N1 | 10440h | 10440h | DTM | R99 | Frederic | DTM |  |
| 9254 | 2803.1.1 | Class A Dual Transfer Mode | 261d? | 1999-01-01 A | 1999-12-31 A | 100% | 1999-01-01 | 1999-12-31 | 261d? | start no earlier than 1999-01-01 | SMG | 2088h | 2088h | Class_A_Dual_Transfer_Mode_(DTM) | R99 | Frederic | Class_A_Dual_Transfer_Mode_(DTM) |  |
| 9255 | 2803.1.2 | Dual Transfer Mode | 261d? | 1999-01-01 A | 1999-12-31 A | 100% | 1999-01-01 | 1999-12-31 | 261d? | start no earlier than 1999-01-01 | SMG; N1 | 4176h | 4176h |  | R99 | Frederic |  |  |

Notes:
- 9230: For 3G, GSM 11.11 was divided into two parts: a platform comprised of basic physical, electrical and logical specification (31.101) and an application specification (31.102)
- 9231: Defines a generic Terminal/Integrated Circuit Card (ICC) interface. Is independent of 3G USIM application => platform for any IC card application. Ensures interoperability between ICC and terminal independently of manufacturer, card issuer or operator. / Impacted TSs and TRs: 31.101 (Since 10/2000; ETSI EP SCP is responsible for the generic Terminal/Integrated Circuit Card (ICC) interface 102 221)
- 9232: Acronym changed from UICC1 / Impacted TSs and TRs: 31.102; 31.900
- 9233: Defines Universal Subscriber Identity Module (USIM) application for 3G telecom network operation & resides on UICC, an IC card specified in 31.101. UICC can be used as a multi-application card: several USIMs and/or other applications can co-exist / Impacted TSs and TRs: 31.102
- 9234: Defines and administers Application IDentifiers (AID) for UICC. AID is used to address an application in the card. Consists of Registered application provider ID (RID) & Proprietary application ID exception (PIX - according to ISO/IEC 7816-5). / Impacted TSs and TRs: 21.111; 31.110
- 9235: - / Impacted TSs and TRs: 11.14; 22.030; 22.100; 22.101
- 9236: Defines UICC - ME interface, and mandatory ME procedures for USAT. Based on GSM 11.14 (SIM Application Toolkit). Commands and procedures defined in USIM and 3G Terminal for using USAT. Service and security requirements defined in 22.100 and 22.101. / Impacted TSs and TRs: 31.111
- 9237: Defines at SIM-ME interface a basic protocol allowing SIM Toolkit applications to determine available bearers and to exchange data by selecting using the most appropriate bearer available (CS data, GPRS, SMS, Unstructured Supplementary Service Data (USSD) / Impacted TSs and TRs: 03.48; 11.10; 11.14
- 9238: Defines function and syntax of administrative commands for telecommunication IC Card used during installation, activation and de-activation of applications. Compliant to ISO/IEC 7816 series. Handed over to ETSI Project Smart Card Platform (SCP) in 2000. / Impacted TSs and TRs: ETSI 102 222
- 9239: High level requirements for 3GPP IC card and its interface to 3GPP terminal (USIM&UICC reqs). Service&security reqs in 322.01,22.00. USIM is a 3GPP application on an IC card. Inter-operates with 3GPP terminals and provides access to 3GPP services / Impacted TSs and TRs: 21.111
- 9240: - / Impacted TSs and TRs: 03.19
- 9241: - / Impacted TSs and TRs: 03.48; 11.11; 11.14
- 9242: No CR or new TS/TR approved under this WI / Impacted TSs and TRs: 11.18
- 9243: -
- 9244: Test spec for the interface between UICC and terminal (originally based GSM 11.10-1 clause 27). Ensures UICC - terminal interoperability independently of manufacturer, card issuer or operator. Tests for applications residing on UICC are in 31.121 / Impacted TSs and TRs: 31.120
- 9245: Application test spec originally based on GSM 11.17. Aspects related to UICC administrative management phase are not defined. Any internal technical realisation of either UICC or terminal is only specified where these are reflected over the interface. / Impacted TSs and TRs: 31.121
- 9246: Conformance Test specification for UICC defined in 31.101 with USIM defined in 31.102. / Impacted TSs and TRs: 31.122
- 9247: SIM Application Toolkit (SAT) has major impact on ME design and enhances SIM/ME interface. Contains tests for SIM/ME interface optional features (no network related signalling issues involved). Doesn't form basis for any type approval or regulatory tests. / Impacted TSs and TRs: 11.10-4
- 9248: - / Impacted TSs and TRs: 02.09; 03.20; 21.133; 22.022; 23.003; 23.007; 23.008; 23.012; 23.018; 24.007; 24.008; 24.010; 24.011; 29.002; 29.060; New (33.102; 33.103; 33.105; 33.107; 35.201)
- 9249: HPLMN can monitor its subscribers in VPLMN, which collects info on a defined set of monitored subscribers activities & sends it to HPLMN, which can perform service limitation control eg Operator Determined Barring (ODB) and IST to limit financial exposure / Impacted TSs and TRs: New 22.031; 23.031
- 9250: HPLMN can terminate all activities of its subscriber in VPLMN, if decides (based on info via eg FIGS) that a roaming subscriber is behaving in fraudulent/suspicious way. HPLMN can terminate all subscriber activities including calls in progress. / Impacted TSs and TRs: 03.35; 22.032; 23.008; 23.016; 23.035; 29.002
- 9251: - / Impacted TSs and TRs: 29.002
- 9252: -
- 9253: 2-99-1780 (2-99-H80 from SMG2#32) WID on BSS co-ordination of Radio Resource allocation for class A GPRS services - GSM Radio Access (R99) / Impacted TSs and TRs: 03.55; 03.64; 04.18; 04.60; 05.01; 05.02; 05.08; 08.08; 23.060; 24.007; 24.008
- 9254: - / Impacted TSs and TRs: 05.10
- 9255: - / Impacted TSs and TRs: 03.55; 03.64; 04.18; 05.01; 05.02; 05.08; 24.008

| ID | WBS | Task | Duration | Start | Finish | Complete | Baseline start | Baseline finish | Baseline duration | Constraint | Resources | Work | Actual work | Acronym | Release | MCC resp | Acronym_3GU_Export | TSG stopped | WI rapporteur name | WI rapporteur e-mail |
| --- | --- | --- | --- | --- | --- | --- | --- | --- | --- | --- | --- | --- | --- | --- | --- | --- | --- | --- | --- | --- |
| 9256 | 2803.2 | **General Packet Radio Service enahancements** | 378d? | 1999-01-01 A | 1999-12-31 A | 100% | 1999-01-01 | 1999-12-31 | 261d? |  | S1; S2; SMG1; SMG2; SMG7; N1; N2; N3; N4; T2 | 50112h | 50112h | GPRSenhancements | R99 | Alain | GPRS enhancements |  |  |  |
| 9257 | 2803.2.1 | General Packet Radio Service | 261d? | 1999-01-01 A | 1999-12-31 A | 100% | 1999-01-01 | 1999-12-31 | 261d? | start no earlier than 1999-01-01 | S1; S2; SMG1; SMG2; SMG7; N1; N2; N3; N4; T2 | 20880h | 20880h | GPRS | R99 | Alain | GPRS |  |  |  |
| 9258 | 2803.2.2 | GPRS2 | 261d? | 1999-01-01 A | 1999-12-31 A | 100% | 1999-01-01 | 1999-12-31 | 261d? | start no earlier than 1999-01-01 | SMG1; N2 | 4176h | 4176h | GPRS2 | R99 |  | GPRS2 |  |  |  |
| 9259 | 2803.2.3 | GPRS Tunnelling Protocol enhancement | 261d? | 1999-01-01 A | 1999-12-31 A | 100% | 1999-01-01 | 1999-12-31 | 261d? | start no earlier than 1999-01-01 | N4; N2 | 4176h | 4176h | GTP_enhancement | R99 | Kimmo | GTP_enhancement |  |  |  |
| 9260 | 2803.3 | **Enhanced Data rates for GSM Evolution - Phase 1** | 378d? | 1999-01-01 A | 1999-12-31 A | 100% | 1999-01-01 | 1999-12-31 | 261d? |  | SMG2; SMG1; SMG3; SMG4; SMG7; SMG9; SMG10; N1; N3; T2 | 73080h | 73080h | EDGE-Phase1 | R99 | Maurice | EDGE - Phase 1 |  |  |  |
| 9261 | 2803.3.1 | Enhanced Data rates for GSM Evolution | 261d? | 1999-01-01 A | 1999-12-31 A | 100% | 1999-01-01 | 1999-12-31 | 261d? | start no earlier than 1999-01-01 | SMG2; SMG1; SMG3; SMG4; SMG7; SMG9; SMG10; N1; N3; T2 | 20880h | 20880h | EDGE | R99 | Maurice | EDGE |  |  |  |
| 9262 | 2803.3.2 | EDGE-Layer1 | 261d? | 1999-01-01 A | 1999-12-31 A | 100% | 1999-01-01 | 1999-12-31 | 261d? | start no earlier than 1999-01-01 | SMG2 | 2088h | 2088h | EDGE-Layer1 | R99 |  | EDGE-Layer1 |  |  |  |
| 9263 | 2803.3.3 | High Speed Circuit Switched Data | 261d? | 1999-01-01 A | 1999-12-31 A | 100% | 1999-01-01 | 1999-12-31 | 261d? | start no earlier than 1999-01-01 | SMG1; SMG2; SMG7 | 6264h | 6264h | HSCSD | R99 |  | HSCSD |  |  |  |
| 9264 | 2803.3.4 | Enhanced Circuit Switched Data - Phase 1 | 261d? | 1999-01-01 A | 1999-12-31 A | 100% | 1999-01-01 | 1999-12-31 | 261d? | start no earlier than 1999-01-01 | S1; SMG | 4176h | 4176h | ECSD | R99 | Alain | ECSD |  |  |  |
| 9265 | 2803.3.5 | EDGE-Enhanced Circuit Switched Data | 261d? | 1999-01-01 A | 1999-12-31 A | 100% | 1999-01-01 | 1999-12-31 | 261d? | start no earlier than 1999-01-01 | SMG2 | 2088h | 2088h | EDGE-ECSD | R99 |  | EDGE-ECSD |  |  |  |
| 9266 | 2803.3.6 | Enhanced GPRS - Phase 1 | 261d? | 1999-01-01 A | 1999-12-31 A | 100% | 1999-01-01 | 1999-12-31 | 261d? | start no earlier than 1999-01-01 | SMG; N1 | 4176h | 4176h | EGPRS | R99 |  | EGPRS |  |  |  |
| 9267 | 2803.3.7 | EDGE-EGPRS | 261d? | 1999-01-01 A | 1999-12-31 A | 100% | 1999-01-01 | 1999-12-31 | 261d? | start no earlier than 1999-01-01 | SMG2 | 2088h | 2088h | EDGE-EGPRS | R99 |  | EDGE-EGPRS |  |  |  |
| 9268 | 2803.3.8 | Packet Flow Context (PFC) | 261d? | 1999-01-01 A | 1999-12-31 A | 100% | 1999-01-01 | 1999-12-31 | 261d? | start no earlier than 1999-01-01 | SMG2 | 2088h | 2088h | PFC | R99 |  | PFC |  |  |  |
| 9269 | 2803.3.9 | Support for EGPRS in ANSI-136 networks and EDGE COMPACT | 261d? | 1999-01-01 A | 1999-12-31 A | 100% | 1999-01-01 | 1999-12-31 | 261d? | start no earlier than 1999-01-01 | SMG | 2088h | 2088h | EDGE-Compact | R99 |  | EDGE-Compact |  |  |  |
| 9270 | 2803.3.10 | EGPRS COMPACT | 261d? | 1999-01-01 A | 1999-12-31 A | 100% | 1999-01-01 | 1999-12-31 | 261d? | start no earlier than 1999-01-01 | SMG | 2088h | 2088h | EGPRS-Compact | R99 |  | EGPRS-Compact |  |  |  |
| 9271 | 2803.3.11 | COMPACT | 261d? | 1999-01-01 A | 1999-12-31 A | 100% | 1999-01-01 | 1999-12-31 | 261d? | start no earlier than 1999-01-01 | SMG; N1 | 4176h | 4176h | COMPACT | R99 |  | COMPACT |  |  |  |
| 9272 | 2803.4 | GSM_400 | 261d? | 1999-01-01 A | 1999-12-31 A | 100% | 1999-01-01 | 1999-12-31 | 261d? | start no earlier than 1999-01-01 | SMG2; SMG7; T2 | 6264h | 6264h | GSM_400 | R99 | Paolo | GSM_400 |  |  |  |
| 9273 | 2803.5 | GSM_450 | 261d? | 1999-01-01 A | 1999-12-31 A | 100% | 1999-01-01 | 1999-12-31 | 261d? | start no earlier than 1999-01-01 | SMG2 | 2088h | 2088h | GSM_450 | R99 |  | GSM_450 |  |  |  |
| 9274 | 2803.6 | GSM_700 | 261d? | 1999-01-01 A | 1999-12-31 A | 100% | 1999-01-01 | 1999-12-31 | 261d? | start no earlier than 1999-01-01 | SMG2 | 2088h | 2088h | GSM_700 | R99 |  | GSM_700 |  |  |  |
| 9275 | 2803.7 | Deleted - GERAN | 261d? | 1999-01-01 A | 1999-12-31 A | 100% | 1999-01-01 | 1999-12-31 | 261d? | start no earlier than 1999-01-01 | SMG2; S2 | 4176h | 4176h | GERAN | R99 | Maurice | GERAN | SP-06 |  |  |
| 9276 | 2804 | **GSM Features transposed to UMTS** | 378d? | 1999-01-01 A | 1999-12-31 A | 100% | 1999-01-01 | 1999-12-31 | 261d? |  | S1; S3; T2; N2; N4 | 31320h | 31320h |  | R99 | Alain |  |  |  |  |
| 9277 | 2804.1 | Cell Broadcast Service | 261d? | 1999-01-01 A | 1999-12-31 A | 100% | 1999-01-01 | 1999-12-31 | 261d? | start no earlier than 1999-01-01 | T2 | 2088h | 2088h | CBS | R99 |  | CBS |  |  |  |
| 9278 | 2804.2 | **GSM mobile number portability euro MNP / North American MNP** | 378d? | 1999-01-01 A | 1999-12-31 A | 100% | 1999-01-01 | 1999-12-31 | 261d? |  | S1; N2; N4 | 10440h | 10440h | MNP | R99 | Alain | MNP |  |  |  |
| 9279 | 2804.2.1 | Mobile Number Portability | 261d? | 1999-01-01 A | 1999-12-31 A | 100% | 1999-01-01 | 1999-12-31 | 261d? | start no earlier than 1999-01-01 | N2; N4 | 4176h | 4176h |  | R99 | Kimmo |  |  |  |  |
| 9280 | 2804.3 | Automatic establishment of roaming relations | 261d? | 1999-01-01 A | 1999-12-31 A | 100% | 1999-01-01 | 1999-12-31 | 261d? | start no earlier than 1999-01-01 | S1 | 2088h | 2088h |  | R99 | Alain |  |  | Telecom Italia | enrico.scarrone@telecomitalia.it |
| 9281 | 2804.4 | Advanced addressing | 261d? | 1999-01-01 A | 1999-12-31 A | 100% | 1999-01-01 | 1999-12-31 | 261d? | start no earlier than 1999-01-01 | S1 | 2088h | 2088h |  | R99 | Alain |  |  |  |  |
| 9282 | 2804.5 | UMTS numbering, addressing and identities | 261d? | 1999-01-01 A | 1999-12-31 A | 100% | 1999-01-01 | 1999-12-31 | 261d? | start no earlier than 1999-01-01 | S1 | 2088h | 2088h |  | R99 | Alain |  |  |  |  |
| 9283 | 2804.6 | Lawful Interception for GSM Features transposed to UMTS | 261d? | 1999-01-01 A | 1999-12-31 A | 100% | 1999-01-01 | 1999-12-31 | 261d? | start no earlier than 1999-01-01 | S3 | 2088h | 2088h | LI | R99 | Mirko | LI |  |  |  |

Notes:
- 9256: GPRS was introduced in Release 97. Release 99 brings a number of essential corrections e.g. on Downlink Power Control, Timing Advance procedure, Cell reselection delay time, PBCCH scheduling, PTCCH mapping, etc. / Impacted TSs and TRs: 05.02; 05.05; 05.08; 05.10; 05.50; 11.21; 23.064; 24.008; 24.060
- 9257: - / Impacted TSs and TRs: 02.60; 03.22; 03.64; 04.18; 04.60; 04.64; 04.65; 05.01; 05.02; 05.05; 05.08; 05.10; 08.08; 08.18; 11.10-1; 11.21; 22.041; 22.060; 23.003; 23.007; 23.060; 23.107; 23.122; 24.007; 24.008; 27.007; 27.060; 29.002; 29.016; 29.018; 29.060; 29.061
- 9258: Introduction of EGPRS (S1) + Introduction of Reserved Service Labels in the APN (N2) / Impacted TSs and TRs: 02.60; 23.003
- 9259: - / Impacted TSs and TRs: 23.003; 23.008; 29.060
- 9260: EDGE is independent of the frequency bands, so it can be deployed e.g. in 900 and 1900 MHz bands. The new physical layer based on 8-PSK modulation is introduced and EGPRS and ECSD facilitate the new modulation in single and multi slot constellation. / Impacted TSs and TRs: 10.59; 02.34; 02.60; 03.30; 05.10; 05.50; 11.26
- 9261: WID in SMG2 331/97, SMG 1147/97, SMG 1148/97 / Impacted TSs and TRs: 02.34; 03.10; 03.20; 03.64; 04.03; 04.04; 04.06; 04.08; 04.18; 04.21; 04.22; 04.60; 04.64; 05.01; 05.02; 05.03; 05.04; 05.05; 05.08; 05.10; 05.50; 07.01; 07.02; 07.03; 08.08; 08.20; 08.58; 08.60; 09.07; 09.18; 11.10-1; 11.11; 11.21; 11.26; 23.034; 24.008.
- 9262: WID in SMG2 331/97, SMG 1147/97, SMG 1148/97 / Impacted TSs and TRs: 05.05; 05.10; 05.50
- 9263: No additional features for R99. / Impacted TSs and TRs: 02.34; 04.18; 11.10-1
- 9264: ECSD supports both transparent and non-transparent services, up to 64 kbit/s and 57.6 kbit/s respectively. See Tdoc SMG2 670/99 ECSD Concept Evaluation for more info / Impacted TSs and TRs: 05.02; 08.58; 22.034
- 9265: - / Impacted TSs and TRs: 05.03
- 9266: - / Impacted TSs and TRs: 02.07; 03.64; 04.14; 04.18; 04.60; 05.05; 05.08; 24.008
- 9267: - / Impacted TSs and TRs: 05.03; 05.05; 05.08
- 9268: - / Impacted TSs and TRs: 04.18
- 9269: Support for EGPRS in ANSI-136 networks and EDGE Compact (for ANSI-136 networks only). COMPACT = Deployment of servicES in CP-150spectrum below 1 MHz / Impacted TSs and TRs: 03.22; 03.30; 03.64; 05.01; 05.02; 05.03; 05.05; 05.08; 05.10
- 9270: COMPACT = Deployment of servicES in CP-150spectrum below 1 MHz / Impacted TSs and TRs: 04.18; 05.02
- 9271: COMPACT = Deployment of servicES in CP-150spectrum below 1 MHz / Impacted TSs and TRs: 03.22; 04.18; 04.60; 05.08; 23.122; 24.008
- 9272: GSM in the 400 MHz bands allows to deploy GSM within frequency bands in the range 450 to 500 MHz, previously used for analogue cellular systems. See Tdoc SMG2 190/99 and 595/99 for further info. / Impacted TSs and TRs: 02.17; 03.22; 03.30; 04.04; 04.18; 04.60; 05.01; 05.02; 05.05; 05.08; 05.10; 05.50; 08.18; 08.58; 11.21; 24.008; 27.007
- 9273: - / Impacted TSs and TRs: 03.22; 03.30; 05.01; 05.05; 05.08
- 9274: - / Impacted TSs and TRs: 05.05
- 9275: No CR or new TS/TR approved under this WI / Impacted TSs and TRs: G2: 04.18 CR#A248 ; 04.60 CR#B090
- 9276: -
- 9277: Moved to CT1 at TSG-T closure. Applicability of the Cell Broadcast Service (as defined for GSM network) to 3G networks / Impacted TSs and TRs: 23.041
- 9278: R98 MNP: mobile subscriber ability to change PLMN operator within the same country whilst retaining its original MS ISDN number (MSISDN). IMSI is changed, only MSISDN is kept. R99 adds requirements for North American Service Provider Number Portability. / Impacted TSs and TRs: 22.066
- 9279: - / Impacted TSs and TRs: 23.018; 23.066; 29.002
- 9280: framework for commercial and technical interworking between UMTS Home Environments and Serving Networks who have no direct prior commercial agreements with each other. / Impacted TSs and TRs: 22.101; 22.971
- 9281: - / Impacted TSs and TRs: 22.101; 22.75U; 22.975
- 9282: Also new requirements for Single and Multiple Numbering scheme was added (CR#20 and 21). Deleted the term International Mobile User Identifier (IMUI) and changed IMSI (International Mobile Station Identifier=>International Mobile Subscriber Identity. / Impacted TSs and TRs: 22.101
- 9283: Defines an interception system in UMTS that supports a number of regional interception regulations. Regional interception requirements shall be met in using specific (regional) mediation functions allowing only required information to be transported. / Impacted TSs and TRs: New 33.106; 33.107

| ID | WBS | Task | Duration | Start | Finish | Complete | Baseline start | Baseline finish | Baseline duration | Constraint | Resources | Work | Actual work | Release | MCC resp | Acronym | Acronym_3GU_Export | TSG stopped |
| --- | --- | --- | --- | --- | --- | --- | --- | --- | --- | --- | --- | --- | --- | --- | --- | --- | --- | --- |
| 9284 | 2805 | **Charging** | 378d? | 1999-01-01 A | 1999-12-31 A | 100% | 1999-01-01 | 1999-12-31 | 261d? |  | S1; S5 | 8352h | 8352h | R99 | Alain |  |  |  |
| 9285 | 2805.1 | R99 Charging | 261d? | 1999-01-01 A | 1999-12-31 A | 100% | 1999-01-01 | 1999-12-31 | 261d? | start no earlier than 1999-01-01 | S1 | 2088h | 2088h | R99 | Alain | Charging | Charging |  |
| 9286 | 2805.2 | R99 OAM Charging Management | 261d? | 1999-01-01 A | 1999-12-31 A | 100% | 1999-01-01 | 1999-12-31 | 261d? | start no earlier than 1999-01-01 | S5 | 2088h | 2088h | R99 | Mirko | OAMCH,CH | OAMCH, CH |  |
| 9287 | 2806 | **Operations, Administration, Maintenance and Provisioning (OAM&P)** | 378d? | 1999-01-01 A | 1999-12-31 A | 100% | 1999-01-01 | 1999-12-31 | 261d? |  | S5 | 12528h | 12528h | R99 | Mirko | OAM1999 | OAM1999 |  |
| 9288 | 2806.1 | OAM Principles and High-level Requirements | 261d? | 1999-01-01 A | 1999-12-31 A | 100% | 1999-01-01 | 1999-12-31 | 261d? | start no earlier than 1999-01-01 | S5 | 2088h | 2088h | R99 | Mirko | PR,Princs_&_Reqs_(PR) | PR, Princs_&_Reqs_(PR) |  |
| 9289 | 2806.2 | OAM Architecture | 261d? | 1999-01-01 A | 1999-12-31 A | 100% | 1999-01-01 | 1999-12-31 | 261d? | start no earlier than 1999-01-01 | S5 | 2088h | 2088h | R99 | Mirko | OAMAR,AR,Telecom_Management_Arch_(AR) | OAMAR, AR, Telecom_Management_Arch_(AR) |  |
| 9290 | 2806.3 | OAM Configuration Management | 261d? | 1999-01-01 A | 1999-12-31 A | 100% | 1999-01-01 | 1999-12-31 | 261d? | start no earlier than 1999-01-01 | S5 | 2088h | 2088h | R99 | Mirko | OAMCM,CM | OAMCM, CM |  |
| 9291 | 2806.4 | OAM Fault Management | 261d? | 1999-01-01 A | 1999-12-31 A | 100% | 1999-01-01 | 1999-12-31 | 261d? | start no earlier than 1999-01-01 | S5 | 2088h | 2088h | R99 | Mirko | OAMFM | OAMFM |  |
| 9292 | 2806.5 | OAM Performance Management | 261d? | 1999-01-01 A | 1999-12-31 A | 100% | 1999-01-01 | 1999-12-31 | 261d? | start no earlier than 1999-01-01 | S5 | 2088h | 2088h | R99 | Mirko | OAMPM,PM | OAMPM, PM |  |
| 9293 | 2807 | Vocabulary | 261d? | 1999-01-01 A | 1999-12-31 A | 100% | 1999-01-01 | 1999-12-31 | 261d? | start no earlier than 1999-01-01 | S1 | 2088h | 2088h | R99 | Alain | Vocabulary | Vocabulary |  |
| 9294 | 2808 | Emergency | 261d? | 1999-01-01 A | 1999-12-31 A | 100% | 1999-01-01 | 1999-12-31 | 261d? | start no earlier than 1999-01-01 | S1 | 2088h | 2088h | R99 | Alain | Emergency | Emergency |  |
| 9295 | 2809 | GSM General Bearer Services (GBS) and interworking scenarios support in UMTS | 261d? | 1999-01-01 A | 1999-12-31 A | 100% | 1999-01-01 | 1999-12-31 | 261d? | start no earlier than 1999-01-01 | S1 | 2088h | 2088h | R99 | Alain | GSM_to_UMTS_Evol | GSM_to_UMTS_Evol |  |
| 9296 | 2810 | GPRS_Mobile_IP_interworking | 261d? | 1999-01-01 A | 1999-12-31 A | 100% | 1999-01-01 | 1999-12-31 | 261d? | start no earlier than 1999-01-01 | N3 | 2088h | 2088h | R99 |  | GPRS_Mobile_IP_interworking | GPRS_Mobile_IP_interworking |  |
| 9297 | 2811 | GSM/UMTS interworking | 261d? | 1999-01-01 A | 1999-12-31 A | 100% | 1999-01-01 | 1999-12-31 | 261d? | start no earlier than 1999-01-01 | N1; N2; N4; R3; S1; SMG | 12528h | 12528h | R99 | Frederic | 2G3Ginterworking | 2G3Ginterworking |  |
| 9298 | 2812 | Handover | 261d? | 1999-01-01 A | 1999-12-31 A | 100% | 1999-01-01 | 1999-12-31 | 261d? | start no earlier than 1999-01-01 | S1; SMG2; N1; N2; N4 | 10440h | 10440h | R99 | Alain | Handover | Handover |  |
| 9299 | 2813 | 2G3Ghandover | 261d? | 1999-01-01 A | 1999-12-31 A | 100% | 1999-01-01 | 1999-12-31 | 261d? | start no earlier than 1999-01-01 | SMG2 | 2088h | 2088h | R99 |  | 2G3Ghandover | 2G3Ghandover |  |
| 9300 | 2814 | Service Provider Name Indication | 261d? | 1999-01-01 A | 1999-12-31 A | 100% | 1999-01-01 | 1999-12-31 | 261d? | start no earlier than 1999-01-01 | S1 | 2088h | 2088h | R99 | Alain | SPANME | SPANME |  |
| 9301 | 2815 | Data & Data_CleanUp | 261d? | 1999-01-01 A | 1999-12-31 A | 100% | 1999-01-01 | 1999-12-31 | 261d? | start no earlier than 1999-01-01 | SMG1 | 2088h | 2088h | R99 |  | Data,Data_CleanUp | Data, Data_CleanUp |  |
| 9302 | 2816 | Unstructured Supplementary Service Data (USSD) | 261d? | 1999-01-01 A | 1999-12-31 A | 100% | 1999-01-01 | 1999-12-31 | 261d? | start no earlier than 1999-01-01 | SMG1; N4 | 4176h | 4176h | R99 | Kimmo | USSD | USSD |  |
| 9303 | 2817 | Man-Machine Interface (MMI) of the User Equipment (UE) | 261d? | 1999-01-01 A | 1999-12-31 A | 100% | 1999-01-01 | 1999-12-31 | 261d? | start no earlier than 1999-01-01 | S1 | 2088h | 2088h | R99 | Alain | MMI | MMI |  |
| 9304 | 2818 | Network Identity and Timezone (NITZ) | 261d? | 1999-01-01 A | 1999-12-31 A | 100% | 1999-01-01 | 1999-12-31 | 261d? | start no earlier than 1999-01-01 | SMG1; SMG3 | 4176h | 4176h | R99 | Alain | NITZ | NITZ |  |
| 9305 | 2819 | Deleted - Operator Determined Barring for Packet Oriented Services | 261d? | 1999-01-01 A | 1999-12-31 A | 100% | 1999-01-01 | 1999-12-31 | 261d? | start no earlier than 1999-01-01 | S1 | 2088h | 2088h | R99 | Alain | ODB_Enh. | ODB_Enh. | SP-69 |
| 9306 | 2820 | Packet Flow Management | 261d? | 1999-01-01 A | 1999-12-31 A | 100% | 1999-01-01 | 1999-12-31 | 261d? | start no earlier than 1999-01-01 | SMG2 | 2088h | 2088h | R99 |  | Packet_Flow_Management | Packet_Flow_Management |  |
| 9307 | 2821 | GPRS_Point-To-Multipoint Group call | 261d? | 1999-01-01 A | 1999-12-31 A | 100% | 1999-01-01 | 1999-12-31 | 261d? | start no earlier than 1999-01-01 | SMG1 | 2088h | 2088h | R99 |  | GPRS_PTMG | GPRS_PTMG |  |

Notes:
- 9284: -
- 9285: - / Impacted TSs and TRs: 22.115; 23.121
- 9286: - / Impacted TSs and TRs: 32.005; 32.015
- 9287: -
- 9288: - / Impacted TSs and TRs: 32.101
- 9289: - / Impacted TSs and TRs: 32.101; 32.102
- 9290: - / Impacted TSs and TRs: 32.106; 32.106-1; 32.106-2; 32.106-3; 32.106-4; 32.106-5; 32.106-6; 32.106-7; 32.106-8
- 9291: - / Impacted TSs and TRs: 32.111; 32.111-1; 32.111-2; 32.111-3; 32.111-4
- 9292: - / Impacted TSs and TRs: 12.04; 32.104
- 9293: - / Impacted TSs and TRs: 21.905
- 9294: - / Impacted TSs and TRs: 22.101
- 9295: UMTS shall support GSM General Bearer Services (GBS) and interworking scenarios as specified in 02.02 / Impacted TSs and TRs: 22.105
- 9296: - / Impacted TSs and TRs: 29.061
- 9297: - / Impacted TSs and TRs: 03.22; 04.18; 04.60; 05.02; 05.08; 05.10; 08.08; 08.18; 08.58; 09.08; 22.011; 23.003; 23.009; 23.014; 23.034; 23.122; 24.007; 24.008; 24.011; 24.080; 29.108
- 9298: - / Impacted TSs and TRs: 04.18; 08.08; 08.58; 22.129; 23.009; 29.002; 29.010
- 9299: - / Impacted TSs and TRs: 04.18; 04.60; 05.02; 05.08; 05.10; 08.08; 29.010
- 9300: Service Provider Name Indication included in R98 (02.07) was not carried into R99 (22.101), but is in the SIM/USIM specification for R99 / Impacted TSs and TRs: 22.101
- 9301: - / Impacted TSs and TRs: 02.01; 02.02; 02.04; 02.34
- 9302: No additional features for R99. / Impacted TSs and TRs: 02.04; 02.90; 23.090; 29.002
- 9303: Data services streamlining + Support for Anonymous Call Rejection / Impacted TSs and TRs: 22.030
- 9304: - / Impacted TSs and TRs: 02.42; 04.08
- 9305: Remove ODB for Packet Oriented Services from R99 / Impacted TSs and TRs: 22.041
- 9306: - / Impacted TSs and TRs: 08.18
- 9307: - / Impacted TSs and TRs: 02.60

| ID | WBS | Task | Duration | Start | Finish | Complete | Baseline start | Baseline finish | Baseline duration | Constraint | Resources | Work | Actual work | Release | MCC resp | Acronym | Acronym_3GU_Export |
| --- | --- | --- | --- | --- | --- | --- | --- | --- | --- | --- | --- | --- | --- | --- | --- | --- | --- |
| 9308 | 2822 | **Call Forwarding** | 378d? | 1999-01-01 A | 1999-12-31 A | 100% | 1999-01-01 | 1999-12-31 | 261d? |  | SMG1; N2; N4 | 16704h | 16704h | R99 | Kimmo |  |  |
| 9309 | 2822.1 | Call Forwarding enhancements | 261d? | 1999-01-01 A | 1999-12-31 A | 100% | 1999-01-01 | 1999-12-31 | 261d? | start no earlier than 1999-01-01 | N4; N2 | 4176h | 4176h | R99 | Kimmo | CF_enhancements | CF_enhancements |
| 9310 | 2822.2 | Call_Forwarding | 261d? | 1999-01-01 A | 1999-12-31 A | 100% | 1999-01-01 | 1999-12-31 | 261d? | start no earlier than 1999-01-01 | SMG1; N2 | 4176h | 4176h | R99 | Kimmo | Call_Forwarding | Call_Forwarding |
| 9311 | 2822.3 | Call_Forwarding_Enhancements | 261d? | 1999-01-01 A | 1999-12-31 A | 100% | 1999-01-01 | 1999-12-31 | 261d? | start no earlier than 1999-01-01 | N4 | 2088h | 2088h | R99 | Kimmo | Call_Forwarding_Enhancements | Call_Forwarding_Enhancements |
| 9312 | 2823 | **Quality of Service** | 378d? | 1999-01-01 A | 1999-12-31 A | 100% | 1999-01-01 | 1999-12-31 | 261d? |  | S2; T2; N1; N2; N4 | 31320h | 31320h | R99 | Maurice |  |  |
| 9313 | 2823.1 | End-to-end UMTS Quality of Service management | 261d? | 1999-01-01 A | 1999-12-31 A | 100% | 1999-01-01 | 1999-12-31 | 261d? | start no earlier than 1999-01-01 | S2; T2; N1; N2; N4 | 10440h | 10440h | R99 | Maurice | QoS | QoS |
| 9314 | 2823.2 | End-to-end QoS for PS Domain including IMS | 261d? | 1999-01-01 A | 1999-12-31 A | 100% | 1999-01-01 | 1999-12-31 | 261d? | start no earlier than 1999-01-01 | S2 | 2088h | 2088h | R99 | Maurice | E2EQoS99 | E2EQoS |
| 9315 | 2823.3 | GPRS-enhanced_QoS | 261d? | 1999-01-01 A | 1999-12-31 A | 100% | 1999-01-01 | 1999-12-31 | 261d? | start no earlier than 1999-01-01 | T2 | 2088h | 2088h | R99 |  | GPRS-enhanced_QoS | GPRS-enhanced_QoS |
| 9316 | 2823.4 | QoS_enhancements | 261d? | 1999-01-01 A | 1999-12-31 A | 100% | 1999-01-01 | 1999-12-31 | 261d? | start no earlier than 1999-01-01 | N2; N1; N4 | 6264h | 6264h | R99 | Kimmo | QoS_enhancements | QoS_enhancements |
| 9317 | 2824 | Support of Localised Service Area | 261d? | 1999-01-01 A | 1999-12-31 A | 100% | 1999-01-01 | 1999-12-31 | 261d? | start no earlier than 1999-01-01 | SMG2; SMG3; SMG7; N2 | 8352h | 8352h | R99 | Maurice | SoLSA | SoLSA |
| 9318 | 2825 | Transcoder_location | 261d? | 1999-01-01 A | 1999-12-31 A | 100% | 1999-01-01 | 1999-12-31 | 261d? | start no earlier than 1999-01-01 | S2 | 2088h | 2088h | R99 | Maurice | Transcoder_location | Transcoder_location |
| 9319 | 2826 | Antenna_test_methods | 261d? | 1999-01-01 A | 1999-12-31 A | 100% | 1999-01-01 | 1999-12-31 | 261d? | start no earlier than 1999-01-01 | SMG2 | 2088h | 2088h | R99 |  | Antenna_test_methods | Antenna_test_methods |
| 9320 | 2827 | WBAMR / high quality speech in UMTS Phase 1 but not in R99 | 261d? | 1999-01-01 A | 1999-12-31 A | 100% | 1999-01-01 | 1999-12-31 | 261d? | start no earlier than 1999-01-01 | S1 | 2088h | 2088h | R99 | Alain | WBAMR | WBAMR |
| 9321 | 2828 | **Codec** | 378d? | 1999-01-01 A | 1999-12-31 A | 100% | 1999-01-01 | 1999-12-31 | 261d? |  | S4 | 27144h | 27144h | R99 | Paolo |  |  |
| 9322 | 2828.1 | **Codecs for Multimedia Telephony Service** | 378d? | 1999-01-01 A | 1999-12-31 A | 100% | 1999-01-01 | 1999-12-31 | 261d? |  | S4 | 14616h | 14616h | R99 | Paolo | Codec_for_Multimedia_Telephony | Codec_for_Multimedia_Telephony |
| 9323 | 2828.1.1 | Codecs for Multimedia Telephony Service | 261d? | 1999-01-01 A | 1999-12-31 A | 100% | 1999-01-01 | 1999-12-31 | 261d? | start no earlier than 1999-01-01 | S4 | 2088h | 2088h | R99 | Paolo | Multimedia_Codec | Multimedia_Codec |
| 9324 | 2828.1.2 | Codecs for Multimedia Telephony Service | 261d? | 1999-01-01 A | 1999-12-31 A | 100% | 1999-01-01 | 1999-12-31 | 261d? | start no earlier than 1999-01-01 | S4 | 2088h | 2088h | R99 | Paolo | CSM | CSM |
| 9325 | 2828.1.3 | Codecs for Multimedia Telephony Service | 261d? | 1999-01-01 A | 1999-12-31 A | 100% | 1999-01-01 | 1999-12-31 | 261d? | start no earlier than 1999-01-01 | S4 | 2088h | 2088h | R99 | Paolo | WI2MMC | WI2MMC |
| 9326 | 2828.1.4 | Codecs for Multimedia Telephony Service | 261d? | 1999-01-01 A | 1999-12-31 A | 100% | 1999-01-01 | 1999-12-31 | 261d? | start no earlier than 1999-01-01 | S4 | 2088h | 2088h | R99 | Paolo | Codec(s)_for_CS_MM_Tel._Serv | Codec(s)_for_CS_MM_Tel._Serv |
| 9327 | 2828.1.5 | Codecs for Multimedia Telephony Service | 261d? | 1999-01-01 A | 1999-12-31 A | 100% | 1999-01-01 | 1999-12-31 | 261d? | start no earlier than 1999-01-01 | S4 | 2088h | 2088h | R99 | Paolo | Codec(s)_for_MM_Tel_Service | Codec(s)_for_MM_Tel_Service |
| 9328 | 2828.1.6 | Codecs for Multimedia Telephony Service | 261d? | 1999-01-01 A | 1999-12-31 A | 100% | 1999-01-01 | 1999-12-31 | 261d? | start no earlier than 1999-01-01 | S4 | 2088h | 2088h | R99 | Paolo |  |  |
| 9329 | 2828.2 | QoS for Speech and Multimedia Codec | 261d? | 1999-01-01 A | 1999-12-31 A | 100% | 1999-01-01 | 1999-12-31 | 261d? | start no earlier than 1999-01-01 | S4 | 2088h | 2088h | R99 | Paolo | QoS_for_Speech_&_MM_Codecs_/_AMR | QoS_for_Speech_&_MM_Codecs_/_AMR |
| 9330 | 2828.3 | Tandem Free Operation - Adaptive Multi-Rate codec types | 261d? | 1999-01-01 A | 1999-12-31 A | 100% | 1999-01-01 | 1999-12-31 | 261d? | start no earlier than 1999-01-01 | S4 | 2088h | 2088h | R99 | Paolo | TFOAMR | TFOAMR |
| 9331 | 2828.4 | Noise Suppression for AMR | 261d? | 1999-01-01 A | 1999-12-31 A | 100% | 1999-01-01 | 1999-12-31 | 261d? | start no earlier than 1999-01-01 | S4 | 2088h | 2088h | R99 | Paolo | AMRNS | AMRNS |
| 9332 | 2828.5 | Out-of-Band Transcoder | 261d? | 1999-01-01 A | 1999-12-31 A | 100% | 1999-01-01 | 1999-12-31 | 261d? | start no earlier than 1999-01-01 | N1 | 2088h | 2088h | R99 | Frederic | OoBT | OoBT |
| 9333 | 2828.6 | Out-of-Band Transcoder Control | 261d? | 1999-01-01 A | 1999-12-31 A | 100% | 1999-01-01 | 1999-12-31 | 261d? | start no earlier than 1999-01-01 | N1 | 2088h | 2088h | R99 | Frederic | OoBTC | OoBTC |
| 9334 | 2829 | Advanced Speech Call Items enhancements | 261d? | 1999-01-01 A | 1999-12-31 A | 100% | 1999-01-01 | 1999-12-31 | 261d? | start no earlier than 1999-01-01 | SMG1; SMG2; SMG3; SMG7; SMG9; N1; N4; S1; T2 | 18792h | 18792h | R99 | Alain | ASCI | ASCI |
| 9335 | 2830 | Call Control improvements | 261d? | 1999-01-01 A | 1999-12-31 A | 100% | 1999-01-01 | 1999-12-31 | 261d? | start no earlier than 1999-01-01 | N1 | 2088h | 2088h | R99 | Frederic | CC_Related_items | CC_Related_items |
| 9336 | 2831 | Multimedia | 261d? | 1999-01-01 A | 1999-12-31 A | 100% | 1999-01-01 | 1999-12-31 | 261d? | start no earlier than 1999-01-01 | N1; N3 | 4176h | 4176h | R99 | Frederic | Multimedia | Multimedia |
| 9337 | 2832 | Sub-System Number allocation for RANAP, RNSAP | 261d? | 1999-01-01 A | 1999-12-31 A | 100% | 1999-01-01 | 1999-12-31 | 261d? | start no earlier than 1999-01-01 | N2 | 2088h | 2088h | R99 | Frederic | SSN_allocation | SSN_allocation |
| 9338 | 2833 | Intranet / ISP access with DHCP end-to-end | 261d? | 1999-01-01 A | 1999-12-31 A | 100% | 1999-01-01 | 1999-12-31 | 261d? | start no earlier than 1999-01-01 | N3 | 2088h | 2088h | R99 | Gwiho | ISPaccess | ISPaccess |
| 9339 | 2834 | Point_to_Multipoint_Services | 261d? | 1999-01-01 A | 1999-12-31 A | 100% | 1999-01-01 | 1999-12-31 | 261d? | start no earlier than 1999-01-01 | N3 | 2088h | 2088h | R99 | Gwiho | Point_to_Multipoint_Services | Point_to_Multipoint_Services |
| 9340 | 2835 | Facsimile | 261d? | 1999-01-01 A | 1999-12-31 A | 100% | 1999-01-01 | 1999-12-31 | 261d? | start no earlier than 1999-01-01 | S1 | 2088h | 2088h | R99 | Alain | FAX | FAX |
| 9341 | 2836 | Realtime_NT_FAX_in_UMTS | 261d? | 1999-01-01 A | 1999-12-31 A | 100% | 1999-01-01 | 1999-12-31 | 261d? | start no earlier than 1999-01-01 | N3 | 2088h | 2088h | R99 | Gwiho | Realtime_NT_FAX_in_UMTS | Realtime_NT_FAX_in_UMTS |
| 9342 | 2837 | Gateway Location Register (GLR) - Mobile Application Part (MAP) specification | 261d? | 1999-01-01 A | 1999-12-31 A | 100% | 1999-01-01 | 1999-12-31 | 261d? | start no earlier than 1999-01-01 | N4 | 2088h | 2088h | R99 | Kimmo | GLR | GLR |
| 9343 | 2838 | Multiple Subscriber Profile phase 2 | 261d? | 1999-01-01 A | 1999-12-31 A | 100% | 1999-01-01 | 1999-12-31 | 261d? | start no earlier than 1999-01-01 | S1; N4 | 4176h | 4176h | R99 | Alain | MSP2 | MSP2 |
| 9344 | 2839 | Prepaging | 261d? | 1999-01-01 A | 1999-12-31 A | 100% | 1999-01-01 | 1999-12-31 | 261d? | start no earlier than 1999-01-01 | N2; N4 | 4176h | 4176h | R99 | Kimmo | Prepaging | Prepaging |
| 9345 | 2840 | Re-definition of channel quality measure used for AMR link adaptation for Downlink Advanced Receiver Performance (DARP) MS | 261d? | 1999-01-01 A | 1999-12-31 A | 100% | 1999-01-01 | 1999-12-31 | 261d? | start no earlier than 1999-01-01 | SMG | 2088h | 2088h | R99 |  |  |  |
| 9346 | 2841 | Harmonized Standard | 261d? | 1999-01-01 A | 1999-12-31 A | 100% | 1999-01-01 | 1999-12-31 | 261d? | start no earlier than 1999-01-01 | SMG2 | 2088h | 2088h | R99 |  | HS | HS |
| 9347 | 2842 | Streamlining of specifications | 261d? | 1999-01-01 A | 1999-12-31 A | 100% | 1999-01-01 | 1999-12-31 | 261d? | start no earlier than 1999-01-01 | N3 | 2088h | 2088h | R99 | Gwiho | Streamlining | Streamlining |
| 9348 | 2843 | R99_Service_Clean_up | 261d? | 1999-01-01 A | 1999-12-31 A | 100% | 1999-01-01 | 1999-12-31 | 261d? | start no earlier than 1999-01-01 | N3 | 2088h | 2088h | R99 | Gwiho | R99_Service_Clean_up | R99_Service_Clean_up |

Notes:
- 9308: -
- 9309: No additional features for R99. / Impacted TSs and TRs: 23.078; 23.079; 23.082; 29.002; 29.078
- 9310: - / Impacted TSs and TRs: 02.82; 29.002
- 9311: - / Impacted TSs and TRs: 23.082
- 9312: WID SMG 98-0781 End To End UMTS QoS Management
- 9313: WID SMG 98-0781 End To End UMTS QoS Management / Impacted TSs and TRs: 23.107; 23.907; 24.008
- 9314: Acronym changed from E2EQos / Impacted TSs and TRs: 23.060; 23.170
- 9315: AT-commands for Enhanced QoS Support management / Impacted TSs and TRs: 27.007
- 9316: - / Impacted TSs and TRs: 23.008; 23.016; 24.008; 29.002; 29.060
- 9317: Mechanism which can be used as a platform for providing special tariffs and/or special set of service features for certain subscribers within a regionally restricted area or areas. No additional features for R99. / Impacted TSs and TRs: 04.08; 04.18; 08.08; 11.10-1; 29.002
- 9318: UE location identification: background information and associated primitives 2. Transcoder location at the core network and source depending coding belonging to the non-access stratum. / Impacted TSs and TRs: 23.110
- 9319: - / Impacted TSs and TRs: 03.30
- 9320: Add requirement for high quality speech in UMTS Phase 1 but not in R99 / Impacted TSs and TRs: 22.105
- 9321: -
- 9322: -
- 9323: - / Impacted TSs and TRs: 26.911; 26.104; 26.111
- 9324: - / Impacted TSs and TRs: 26.911; 26.104; 26.111
- 9325: - / Impacted TSs and TRs: 26.911; 26.104; 26.111
- 9326: - / Impacted TSs and TRs: 26.911; 26.104; 26.111
- 9327: - / Impacted TSs and TRs: 26.911; 26.104; 26.111
- 9328: - / Impacted TSs and TRs: 26.911; 26.104; 26.111
- 9329: - / Impacted TSs and TRs: 26.102; 26.912
- 9330: UMTS_AMR2 is default Codec Type in R99 dual_mode terminals / Impacted TSs and TRs: 26.103
- 9331: Combination of the AMR speech codec and the Noise Suppression function. TS 06.77 and TR 06.78 only apply to GSM. They apply to UMTS from Rel-4 onwards, when they were converted to TS 26.077 and TR 26.078. / Impacted TSs and TRs: 06.77; 06.78
- 9332: Transcoder handling in the CN at inter-system handover and relocation + Introduction of UMTS AMR / Impacted TSs and TRs: 23.009; 24.008
- 9333: 24.008 CR#0572 in NP-020220 was approved under this WI / Impacted TSs and TRs: 24.008 CR#0572 in NP-020220
- 9334: - / Impacted TSs and TRs: 02.30; 02.68; 03.68; 03.69; 04.18; 08.08; 11.10-1; 11.11; 23.067; 23.094; 24.008; 24.067; 27.007; 29.002
- 9335: Minor improvements to 24.007 and 24.008 to increase the number of simultaneous calls/sessions from the present 7: the TI value is increased (NP-99441). / Impacted TSs and TRs: 24.007; 24.008
- 9336: - / Impacted TSs and TRs: 24.008; 27.001; 29.007
- 9337: Sub-System Number allocation for Radio Access Network Application Part, Radio Network Subsystem Application Part / Impacted TSs and TRs: 23.003
- 9338: Access to an Intranet/ISP with DHCP end to end / Impacted TSs and TRs: 29.061
- 9339: Support for the IP-Multicast protocol / Impacted TSs and TRs: 29.061
- 9340: - / Impacted TSs and TRs: 22.003; 22.100
- 9341: Asynchronous Interface for real-time NT Fax + Introduction of Asynchronous interface for Real-time non-transparent FAX / Impacted TSs and TRs: 27.001; 27.003
- 9342: - / Impacted TSs and TRs: 29.120
- 9343: -; 5/6/25: 100%->100 / Impacted TSs and TRs: 22.097; 23.072; 23.083; 23.084; 23.091; 23.093; 23.097
- 9344: - / Impacted TSs and TRs: 23.018; 23.082; 29.002
- 9345: Re-definition of channel quality measure used for AMR link adaptation for DARP MS / Impacted TSs and TRs: 05.09
- 9346: - / Impacted TSs and TRs: 13.21
- 9347: - / Impacted TSs and TRs: 27.060; 29.061
- 9348: - / Impacted TSs and TRs: 03.10; 27.001; 27.002; 27.003; 27.060; 29.007; 29.061

| ID | WBS | Task | Type | Duration | Start | Finish | Complete | Baseline start | Baseline finish | Baseline duration | Constraint | Resources | Work | Actual work | Acronym | Release | MCC resp | Acronym_3GU_Export | Impacted TSs and TRs | TSG stopped | WI rapporteur name | WI rapporteur e-mail |
| --- | --- | --- | --- | --- | --- | --- | --- | --- | --- | --- | --- | --- | --- | --- | --- | --- | --- | --- | --- | --- | --- | --- |
| 9349 | 2844 | **(Small) Technical Enhancements and Improvements for R99** |  | 378d? | 1999-01-01 A | 1999-12-31 A | 100% | 1999-01-01 | 1999-12-31 | 261d? |  | N3 | 6264h | 6264h | TEI | R99 | Gwiho | TEI |  |  |  |  |
| 9350 | 2844.1 | TEI_[CS_Data] |  | 261d? | 1999-01-01 A | 1999-12-31 A | 100% | 1999-01-01 | 1999-12-31 | 261d? | start no earlier than 1999-01-01 | N3 | 2088h | 2088h | TEI_[CS_Data] | R99 | Gwiho | TEI_[CS_Data] |  |  |  |  |
| 9351 | 2844.2 | TEI_[GPRS] |  | 261d? | 1999-01-01 A | 1999-12-31 A | 100% | 1999-01-01 | 1999-12-31 | 261d? | start no earlier than 1999-01-01 | N3 | 2088h | 2088h | TEI_[GPRS] | R99 | Gwiho | TEI_[GPRS] |  |  |  |  |
| 9352 | 2845 | **R99 UE Conformance Testing** |  | 378d? | 1999-01-01 A | 1999-12-31 A | 100% | 1999-01-01 | 1999-12-31 | 261d? |  | R5; T1 | 6264h | 6264h | TEI_Test | R99 | Ingbert | TEI_Test | 34.108; 34.121; 34.122; 34.123-1; 34.123-2; 34.123-3 |  |  |  |
| 9353 | 2845.1 | Deleted - RTEI |  | 261d? | 1999-01-01 A | 1999-12-31 A | 100% | 1999-01-01 | 1999-12-31 | 261d? | start no earlier than 1999-01-01 | T1 | 2088h | 2088h | RTEI | R99 | Ingbert | RTEI | 34.123-1 CR#0650; 0651; 34.123-3 CR#0148; 0149; 0150 | TP-06 |  |  |
| 9354 | 2845.2 | Common test environments for User Equipment (UE); Conformance testing | milestone | 0d? | 1999-01-01 A | 1999-01-01 A | 100% | 1999-01-01 | 1999-01-01 | 0d? | start no earlier than 1999-01-01 | R5; T1 |  |  |  | R99 | Ingbert |  | 34.108 |  |  |  |
| 9355 | 2845.3 | Terminal conformance specification, Radio transmission and reception (FDD) | milestone | 0d? | 1999-01-01 A | 1999-01-01 A | 100% | 1999-01-01 | 1999-01-01 | 0d? | start no earlier than 1999-01-01 | R5; T1 |  |  |  | R99 | Ingbert |  | 34.121 |  |  |  |
| 9356 | 2845.4 | Terminal conformance specification, Radio transmission and reception (TDD) | milestone | 0d? | 1999-01-01 A | 1999-01-01 A | 100% | 1999-01-01 | 1999-01-01 | 0d? | start no earlier than 1999-01-01 | R5; T1 |  |  |  | R99 | Ingbert |  | 34.122 |  |  |  |
| 9357 | 2845.5 | UE conformance specification; Part 1: Protocol conformance specification | milestone | 0d? | 1999-01-01 A | 1999-01-01 A | 100% | 1999-01-01 | 1999-01-01 | 0d? | start no earlier than 1999-01-01 | R5; T1 |  |  |  | R99 | Ingbert |  | 34.123-1 |  |  |  |
| 9358 | 2845.6 | UE conformance specification; Part 2: Implementation Conformance Statement (ICS) specification | milestone | 0d? | 1999-01-01 A | 1999-01-01 A | 100% | 1999-01-01 | 1999-01-01 | 0d? | start no earlier than 1999-01-01 | R5; T1 |  |  |  | R99 | Ingbert |  | 34.123-2 |  |  |  |
| 9359 | 2845.7 | UE conformance specification; Part 3: Abstract test suites (ATSs) | milestone | 0d? | 1999-01-01 A | 1999-01-01 A | 100% | 1999-01-01 | 1999-01-01 | 0d? | start no earlier than 1999-01-01 | R5; T1 |  |  |  | R99 | Ingbert |  | 34.123-3 |  |  |  |
| 9360 | 2846 | Deleted - Dual Tone Multi-Frequency signalling : Support in the whole 3GPP system |  | 261d? | 1999-01-01 A | 1999-12-31 A | 100% | 1999-01-01 | 1999-12-31 | 261d? | start no earlier than 1999-01-01 | N1 | 2088h | 2088h | DTMF | R99 | Frederic | DTMF | 23.014 CR#0004 | NP-06 |  |  |
| 9361 | 2847 | Deleted - Intersystem_Change |  | 261d? | 1999-01-01 A | 1999-12-31 A | 100% | 1999-01-01 | 1999-12-31 | 261d? | start no earlier than 1999-01-01 | SMG | 2088h | 2088h | Intersystem_Change | R99 |  | Intersystem_Change | 04.18 CR#A243 | SMG |  |  |
| 9362 | 2848 | Deleted - Long_Forwardedto_Numbers |  | 261d? | 1999-01-01 A | 1999-12-31 A | 100% | 1999-01-01 | 1999-12-31 | 261d? | start no earlier than 1999-01-01 | N2 | 2088h | 2088h | Long_Forwardedto_Numbers | R99 | Kimmo | Long_Forwardedto_Numbers | 29.002 | NP-06 |  |  |
| 9363 | 2849 | Deleted - RANimp-FSEarlyUE |  | 261d? | 1999-01-01 A | 1999-12-31 A | 100% | 1999-01-01 | 1999-12-31 | 261d? | start no earlier than 1999-01-01 | R3 | 2088h | 2088h | RANimp-FSEarlyUE | R99 | Juha | RANimp-FSEarlyUE | 25.413 CR#0520; 0538; 0565; 0563; 0541; 0540; 0539; 0547 | RP-06 |  |  |
| 9364 | 2850 | Release 1999 Studies |  | 261d? | 1999-01-01 A | 1999-12-31 A | 100% | 1999-01-01 | 1999-12-31 | 261d? |  | S1; T2 | 4176h | 4176h |  | R99 | Alain |  |  |  |  |  |
| 9365 | 2851 | Advanced Addressing/Numbering |  | 261d? | 1999-01-01 A | 1999-12-31 A | 100% | 1999-01-01 | 1999-12-31 | 261d? | start no earlier than 1999-01-01 | S1 | 2088h | 2088h | Numbering | R99 | Alain | Numbering | 22.975 |  | Vodafone | mona.mustapha@vodafone.com |
| 9366 | 2852 | Combined GSM and Mobile IP mobility handling in UMTS IP CN |  | 261d? | 1999-01-01 A | 1999-12-31 A | 100% | 1999-01-01 | 1999-12-31 | 261d? | start no earlier than 1999-01-01 | S2 | 2088h | 2088h |  | R99 | Maurice |  | 23.923 |  |  |  |
| 9367 | 2853 | UE Capabilities Requirements |  | 261d? | 1999-01-01 A | 1999-12-31 A | 100% | 1999-01-01 | 1999-12-31 | 261d? | start no earlier than 1999-01-01 | T2 | 2088h | 2088h | UCR | R99 |  | UCR | 21.904 |  |  |  |
| 9368 | 2854 | Electrical safety requirements and regulations |  | 261d? | 1999-01-01 A | 1999-12-31 A | 100% | 1999-01-01 | 1999-12-31 | 261d? | start no earlier than 1999-01-01 | T2 | 2088h | 2088h |  | R99 |  |  | 34.907 |  |  |  |
| 9369 | 2855 | Specific Absorbtion Rate (SAR) requirements and regulations in different regions |  | 261d? | 1999-01-01 A | 1999-12-31 A | 100% | 1999-01-01 | 1999-12-31 | 261d? | start no earlier than 1999-01-01 | T2 | 2088h | 2088h |  | R99 |  |  | 34.925 |  |  |  |
| 9370 | 2856 | Multi-mode UE issues |  | 261d? | 1999-01-01 A | 1999-12-31 A | 100% | 1999-01-01 | 1999-12-31 | 261d? | start no earlier than 1999-01-01 | T2 | 2088h | 2088h |  | R99 |  |  | 21.810; 21.910 |  |  |  |
| 9371 | 2857 | Provision of fax service in GSM and UMTS |  | 261d? | 1999-01-01 A | 1999-12-31 A | 100% | 1999-01-01 | 1999-12-31 | 261d? | start no earlier than 1999-01-01 | T2 | 2088h | 2088h |  | R99 |  |  | 22.945 |  | Ericsson | peter.bleckert@ericsson.com |
| 9372 | 2858 | Separating Radio Resources and Mobility Management specific parts of the MS Classmark |  | 378d | 1999-01-01 A | 1999-12-31 A | 100% | 1999-01-01 | 1999-12-31 | 261d |  | T2 | 2088h | 2088h |  | R99 |  |  | 23.814 |  |  |  |

Notes:
- 9349: -
- 9350: -
- 9351: -
- 9352: Specifies Conformance Tests for a 3G UE to be recognised as 3GPP-standard compliant. A 3GPP-external body, GCF (Global Certification Forum), delivers certificates to prove that a UE has correctly passed tests and is then conform to the 3GPP standard.
- 9353: No CR or new TS/TR approved under this WI
- 9354: -
- 9355: measurement procedures for the conformance test of the UE that contain transmitting characteristics, receiving characteristics and performance requirements in addition to requirements for support of RRM (Radio Resource Management) in FDD mode.
- 9356: measurement procedures for the conformance test of the UE that contain transmitting characteristics, receiving characteristics and performance requirements in addition to requirements for support of RRM (Radio Resource Management) in TDD mode.
- 9357: TS 34.123, composed of three parts, actually specifies the protocol conformance testing for the 3G UE. Part 1 describes the overall test structure.
- 9358: Part 2 contains the applicability of each test case defined as the Implementation Conformance Statement (ICS) proforma, in compliance with the relevant requirements, and in accordance with the relevant guidance given in ISO/IEC 9646-7 and ETS 300 406.
- 9359: Part 3 specifies the protocol conformance testing in TTCN for the 3G UE at the Uu interface. It defines the TTCN test specification and design considerations in Abstract Test Suites based on the test cases specified in prose in part 1.
- 9360: No CR or new TS/TR approved under this WI
- 9361: No CR or new TS/TR approved under this WI
- 9362: -
- 9363: No CR or new TS/TR approved under this WI
- 9364: -
- 9365: Study on requirements for numbering and addressing for UMTS
- 9366: -
- 9367: Moved to CT1 at TSG-T closure
- 9368: Moved to RAN4 at TSG-T closure. TR summarizes differences between international and national standards relevant to IEC60950 and refers to regulations for conformity assessment due to different regulatory environments in different countries / regions.
- 9369: Moved to RAN4 at TSG-T closure.
- 9370: Moved to CT1 at TSG-T closure. Consequences on roaming capabilities and service availability (e.g. handover) of multi-mode UEs while roaming in various regions with various network configurations. Case studies for each of the possible scenarios in specs
- 9371: CP#27: Moved to C1 on closure of T2¦see TP-050062. CP#28: C1->C3
- 9372: CP#27: change of WG as a result of closure of CN and T.
